# Outline ELEXON Plan_kc

Schedule from MS Project, 2022-10-31 to 2027-05-28, status date 2024-08-07, A marks actual dates.

## Calendars

- Standard: Mon-Fri 08:00-12:00, 13:00-17:00; Sat-Sun off.

## Resources

| Resource |
| --- |
| PMO |
| SI |
| PPC |
| Lead Workstream |
| CPT |
| PP |
| SI Design |
| SI Design |
| SI Design |
| Design |
| SI DevOps |
| SI Test |
| PSG |
| DAG |
| TMAG |
| CCAG |
| Code drafters (SRO Design Team |
| Code Bodies) |
| CCAG PM |
| Programme Participants |
| Code drafters |
| CDWG |
| SRO Design Team |
| Code Bodies |
| Ofgem |
| Elexon resources TBC |
| LDP Programme Manager |
| SRO Client Programme Director |
| IPA |
| LDP |
| SRO |
| )) |
| ? |
| TBC |
| OOC |
| MHHSP |
| Adrian Page |
| Amy Clayton |
| Anand Kaveripatna |
| Berlinda Kugara |
| Cesar Lopes |
| Charlie Blanks |
| Chetan Ubale |
| Daniel Callender |
| Daniel Gee |
| David Hollinshead |
| Dean Bailey |
| Dominic Mooney |
| Elayaraja Jeyaraman |
| Georgi Rabotov |
| Giles Clayden |
| Helen Richardson |
| Ishti Bhatti |
| Jafer Shah |
| Jason Brogden |
| John Edmonds Bell |
| John Wiggins |
| Karthikeyan Ganesan |
| Kasimali Hajiyani |
| Kate Goodman |
| Keegan Moodley |
| Keith Clark |
| Keith Lawlor |
| kevin Davis |
| Kishore Konduru |
| Kyle Abraham |
| Mahjabeen Newaz |
| Martin Freeman |
| Matt Hall |
| Matthew Breen |
| Michael Inije |
| Michael Walton |
| Ming Li |
| Nathalia Revlien |
| Nick Sewell |
| Nigel Hunt |
| Oskar Cahill |
| Paul Pettitt |
| Rakhee Shah |
| Rebecca Farooq |
| Renu Rathor |
| Robert Short |
| Robert Topley |
| Saadia Sajjad |
| Sean Tuffy |
| Shaid Hussain |
| Sharmeen Shaikh |
| Simon Berry |
| Steve Bradford |
| Steve Weston |
| Taaran Suri |
| Waseem Mohammed |
| Zak Hussain |
| berli |
| SI Migration |
| v |
| Andrew Margan |
| Lee Cox |
| DIP SP |
| DIPS SP |
| DIPSP |
| Ian Smith |
| N/A |
| SIT Component Integration Testing 2 Preparation Complete (incl. approval of SI SIT Component Integration Test Readiness Report) |
| Nich |
| Nicola Farley |
| Warren Fulton |
| Richard Puddephatt |
| Matthew Bray |
| Programme |
| LDSOs |
| Ben Wickins |
| paul |
| LDSO |
| Simon chidwick |
| Stuart Scott |
| MHHS Programme |
| Claire Silk |
| Laura Kennedy |
| Rowan B |
| FD |
| MB |
| AM |
| Roger Robar |
| Laura Kennedy. |

## Schedule

| ID | WBS | Task | Type | Duration | Start | Finish | Complete | Remaining | Baseline start | Baseline finish | Baseline duration | Baseline 1 start | Baseline 1 finish | Total slack | Constraint | Baseline cost | Responsible | Involved | Update Version | MHHS Resource Name | Sched Status | RAG | Task Status | Text3 |
| --- | --- | --- | --- | --- | --- | --- | --- | --- | --- | --- | --- | --- | --- | --- | --- | --- | --- | --- | --- | --- | --- | --- | --- | --- |
| 1 | 1 | **PROGRAMME PLAN** |  | 1195d | 2022-10-31 A | 2027-05-28 | 53% | 565.17d | 2022-10-31 | 2027-05-28 | 1195d |  |  | 0d |  | -0 | N/A | N/A | 5.0 | N/A |  |  |  |  |
| 2 | 1.1 | MHHS Programme Start | milestone | 0d | 2022-10-31 A | 2022-10-31 A | 100% |  | 2022-10-31 | 2022-10-31 | 0d |  |  |  |  |  | N/A | N/A | 5.7 | N/A | Complete | COMPLETE |  |  |
| 3 | 1.2 | **PROGRAMME MANAGEMENT** |  | 1089d | 2022-10-31 A | 2026-12-31 | 42% | 634d | 2022-10-31 | 2026-12-31 | 1089d | 2022-10-31 | 2026-12-31 | 106d |  |  | N/A | N/A | 5.0 | N/A |  |  |  |  |
| 4 | 1.2.1 | **Programme Management** |  | 1089d | 2022-10-31 A | 2026-12-31 | 41% | 641d | 2022-10-31 | 2026-12-31 | 1089d | 2022-10-31 | 2026-12-31 | 106d |  |  | N/A | N/A | 5.0 | N/A |  |  | M10 |  |
| 5 | 1.2.1.1 | Sprint-based prioritisation planning and execution |  | 1089d | 2022-10-31 A | 2026-12-31 | 41% | 641d | 2022-10-31 | 2026-12-31 | 1089d | 2022-10-31 | 2026-12-31 | 106d | finish no earlier than 2026-12-31 |  | PMO | CPT | 5.0 | N/A | Green | GREEN |  |  |
| 6 | 1.2.1.2 | Programme governance secretariat |  | 1089d | 2022-10-31 A | 2026-12-31 | 41% | 641d | 2022-10-31 | 2026-12-31 | 1089d | 2022-10-31 | 2026-12-31 | 106d |  |  | PMO | CPT | 5.0 | N/A | Green | GREEN |  |  |
| 7 | 1.2.1.3 | RAID management and reporting |  | 1089d | 2022-10-31 A | 2026-12-31 | 41% | 641d | 2022-10-31 | 2026-12-31 | 1089d | 2022-10-31 | 2026-12-31 | 106d |  |  | PMO | CPT | 5.0 | N/A | Green | GREEN |  |  |
| 8 | 1.2.1.4 | Tracking against Programme outcomes and KPIs |  | 1089d | 2022-10-31 A | 2026-12-31 | 41% | 641d | 2022-10-31 | 2026-12-31 | 1089d | 2022-10-31 | 2026-12-31 | 106d |  |  | PMO | CPT | 5.0 | N/A | Green | GREEN |  |  |
| 9 | 1.2.1.5 | Change control and reporting |  | 1089d | 2022-10-31 A | 2026-12-31 | 41% | 641d | 2022-10-31 | 2026-12-31 | 1089d | 2022-10-31 | 2026-12-31 | 106d |  |  | PMO | CPT | 5.0 | N/A | Green | GREEN |  |  |
| 10 | 1.2.1.6 | Ongoing identification of lessons learned relating to the PMO and implementation of improvements |  | 1089d | 2022-10-31 A | 2026-12-31 | 41% | 641d | 2022-10-31 | 2026-12-31 | 1089d | 2022-10-31 | 2026-12-31 | 106d |  |  | PMO | CPT | 5.0 | N/A | Green | GREEN |  |  |
| 11 | 1.2.2 | **Programme Internal Assurance Reviews** |  | 1089d | 2022-10-31 A | 2026-12-31 | 41% | 641d | 2022-10-31 | 2026-12-31 | 1089d | 2022-10-31 | 2026-12-31 | 106d |  |  | N/A | N/A | 5.0 | N/A |  |  | M9 | D18A - Quarterly Assurance Report |
| 12 | 1.2.2.1 | Programme Internal Assurance Reviews |  | 1089d | 2022-10-31 A | 2026-12-31 | 41% | 641d | 2022-10-31 | 2026-12-31 | 1089d | 2022-10-31 | 2026-12-31 | 106d |  |  | CPT | PMO | 5.0 | N/A | Green | GREEN |  | D18A - Quarterly Assurance Report |
| 13 | 1.2.3 | **Engagement with PPs** |  | 1089d | 2022-10-31 A | 2026-12-31 | 41% | 640.9d | 2022-10-31 | 2026-12-31 | 1089d | 2022-10-31 | 2026-12-31 | 106d |  |  | N/A | N/A | 5.0 | N/A |  |  | M5,M6 |  |
| 14 | 1.2.3.1 | Ongoing PP liaison activities |  | 1089d | 2022-10-31 A | 2026-12-31 | 41% | 641d | 2022-10-31 | 2026-12-31 | 1089d | 2022-10-31 | 2026-12-31 | 106d |  |  | PPC | CPT | 5.0 | N/A | Green | GREEN |  |  |
| 15 | 1.2.3.2 | Milestone and Control Point objective setting |  | 1089d | 2022-10-31 A | 2026-12-31 | 41% | 641d | 2022-10-31 | 2026-12-31 | 1089d | 2022-10-31 | 2026-12-31 | 106d |  |  | PPC | CPT | 5.0 | N/A | Green | GREEN |  |  |
| 16 | 1.2.3.3 | Reporting |  | 1089d | 2022-10-31 A | 2026-12-31 | 41% | 641d | 2022-10-31 | 2026-12-31 | 1089d | 2022-10-31 | 2026-12-31 | 106d |  |  | PPC |  | 5.0 | N/A | Green | GREEN |  |  |
| 17 | 1.2.3.4 | **PP Engagement Events** |  | 1089d | 2022-10-31 A | 2026-12-31 | 41% | 641d | 2022-10-31 | 2026-12-31 | 1089d | 2022-10-31 | 2026-12-31 | 106d |  |  | N/A | N/A | 5.0 | N/A |  |  |  |  |
| 18 | 1.2.3.4.1 | Bilateral meetings |  | 1089d | 2022-10-31 A | 2026-12-31 | 41% | 641d | 2022-10-31 | 2026-12-31 | 1089d | 2022-10-31 | 2026-12-31 | 106d |  |  | PPC | CPT | 5.0 | N/A | Green | GREEN |  |  |
| 19 | 1.2.3.4.2 | Monthly webinars |  | 1089d | 2022-10-31 A | 2026-12-31 | 41% | 641d | 2022-10-31 | 2026-12-31 | 1089d | 2022-10-31 | 2026-12-31 | 106d |  |  | PPC | CPT | 5.0 | N/A | Green | GREEN |  |  |
| 20 | 1.2.3.4.3 | Open days |  | 1089d | 2022-10-31 A | 2026-12-31 | 41% | 641d | 2022-10-31 | 2026-12-31 | 1089d | 2022-10-31 | 2026-12-31 | 106d |  |  | PPC | CPT | 5.0 | N/A | Green | GREEN |  |  |
| 21 | 1.2.3.5 | **PP Communications** |  | 1088d | 2022-10-31 A | 2026-12-30 | 41% | 640d | 2022-10-31 | 2026-12-30 | 1088d | 2022-10-31 | 2026-12-30 | 107d |  |  | N/A | N/A | 5.0 | N/A |  |  |  |  |
| 22 | 1.2.3.5.1 | The Clock updates (weekly) |  | 1088d | 2022-10-31 A | 2026-12-30 | 41% | 640d | 2022-10-31 | 2026-12-30 | 1088d | 2022-10-31 | 2026-12-30 | 107d |  |  | PPC |  | 5.0 | N/A | Green | GREEN |  |  |
| 23 | 1.2.3.5.2 | Maintain and update content on public-facing Portal (and ongoing feedback reviews to identify and implement Portal improvements) |  | 1088d | 2022-10-31 A | 2026-12-30 | 41% | 640d | 2022-10-31 | 2026-12-30 | 1088d | 2022-10-31 | 2026-12-30 | 107d |  |  | PPC |  | 5.0 | N/A | Green | GREEN |  |  |
| 24 | 1.2.4 | **Code Change Support / Other Programme Alignment** |  | 1089d | 2022-10-31 A | 2026-12-31 | 41% | 641d | 2022-10-31 | 2026-12-31 | 1089d | 2022-10-31 | 2026-12-31 | 106d |  |  | N/A | N/A | 5.0 | N/A |  |  | M6 | D17 - Code Change Report & Recommendations |
| 25 | 1.2.4.1 | Support DCC/BEIS on SEC change |  | 1089d | 2022-10-31 A | 2026-12-31 | 41% | 641d | 2022-10-31 | 2026-12-31 | 1089d | 2022-10-31 | 2026-12-31 | 106d |  |  | CPT |  | 5.0 | N/A | Green | GREEN |  |  |
| 26 | 1.2.4.2 | Support on Smart Meters Act changes |  | 1089d | 2022-10-31 A | 2026-12-31 | 41% | 641d | 2022-10-31 | 2026-12-31 | 1089d | 2022-10-31 | 2026-12-31 | 106d |  |  | CPT |  | 5.0 | N/A | Green | GREEN |  |  |
| 27 | 1.2.4.3 | Support DCC/RECCo on CSS change |  | 1089d | 2022-10-31 A | 2026-12-31 | 41% | 641d | 2022-10-31 | 2026-12-31 | 1089d | 2022-10-31 | 2026-12-31 | 106d |  |  | CPT |  | 5.0 | N/A | Green | GREEN |  |  |
| 28 | 1.2.4.4 | Support Elexon on BSC change |  | 1089d | 2022-10-31 A | 2026-12-31 | 41% | 641d | 2022-10-31 | 2026-12-31 | 1089d | 2022-10-31 | 2026-12-31 | 106d |  |  | CPT |  | 5.0 | N/A | Green | GREEN |  |  |
| 29 | 1.2.4.5 | Support code change inside & outside CCIAG |  | 1089d | 2022-10-31 A | 2026-12-31 | 41% | 641d | 2022-10-31 | 2026-12-31 | 1089d | 2022-10-31 | 2026-12-31 | 106d |  |  | CPT |  | 5.0 | N/A | Green | GREEN |  |  |
| 30 | 1.2.4.6 | Support code change inside & outside CCAG |  | 1089d | 2022-10-31 A | 2026-12-31 | 41% | 641d | 2022-10-31 | 2026-12-31 | 1089d | 2022-10-31 | 2026-12-31 | 106d |  |  | CPT |  | 5.0 | N/A | Green | GREEN |  |  |

| ID | WBS | Task | Type | Duration | Start | Finish | Predecessors | Complete | Remaining | Baseline start | Baseline finish | Baseline duration | Baseline 1 start | Baseline 1 finish | Total slack | Constraint | Baseline cost | Responsible | Involved | Task Status | Update Version | MHHS Resource Name | Sched Status | RAG | Milestone ID | Text29 | Tier | Text3 | MHHS Programme Phase | Artefact ID |
| --- | --- | --- | --- | --- | --- | --- | --- | --- | --- | --- | --- | --- | --- | --- | --- | --- | --- | --- | --- | --- | --- | --- | --- | --- | --- | --- | --- | --- | --- | --- |
| 31 | 1.2.5 | **Programme Replan Baseline** |  | 163d | 2022-10-31 A | 2023-06-14 A |  | 100% |  | 2022-10-31 | 2023-06-14 | 163d | 2022-10-31 | 2023-06-14 |  |  |  | N/A | N/A | M5+ | 5.0 | N/A |  |  |  |  |  |  |  |  |
| 32 | 1.2.5.1 | Round 3 consultation preparation |  | 32d | 2022-10-31 A | 2022-12-13 A |  | 100% |  | 2022-10-31 | 2022-12-13 | 32d | 2022-10-31 | 2022-12-13 |  |  |  | PMO | CPT |  | 5.0 | N/A | Complete | COMPLETE |  |  |  |  |  |  |
| 33 | 1.2.5.2 | PSG decision to launch Round 3 consultation | milestone | 0d | 2022-12-07 A | 2022-12-07 A | 32FS-5d | 100% |  | 2022-12-07 | 2022-12-07 | 0d | 2022-12-07 | 2022-12-07 |  |  |  | PMO | PPC |  | 5.0 | N/A | Complete | COMPLETE |  |  |  |  |  |  |
| 34 | 1.2.5.3 | Round 3 consultation (incl. walkthroughs and Q&A) |  | 35d | 2022-12-14 A | 2023-01-31 A | 33FS+5d | 100% |  | 2022-12-14 | 2023-01-31 | 35d | 2022-12-14 | 2023-01-31 |  |  |  | PP | PMO, PPC,IPA |  | 5.0 | N/A | Complete | COMPLETE |  |  |  |  |  |  |
| 35 | 1.2.5.4 | Review and uplift of foundational testing documents to align with replan approach |  | 92d | 2022-12-14 A | 2023-04-20 A | 34SS | 100% |  | 2022-12-14 | 2023-04-20 | 92d | 2022-12-14 | 2023-04-20 |  |  |  | SI Test | CPT |  | 5.0 | N/A | Complete | COMPLETE |  |  |  |  |  |  |
| 36 | 1.2.5.5 | Round 3 consultation responses analysis (incl. identification of SIT volunteers) |  | 10d | 2023-02-01 A | 2023-02-14 A | 34 | 100% |  | 2023-02-01 | 2023-02-14 | 10d | 2023-02-01 | 2023-02-14 |  |  |  | PMO | CPT |  | 5.0 | N/A | Complete | COMPLETE |  |  |  |  |  |  |
| 37 | 1.2.5.6 | Replan re-drafting and supporting artefact updates (incl. engagement with Ofgem) |  | 26d | 2023-02-15 A | 2023-03-22 A | 36 | 100% |  | 2023-02-15 | 2023-03-22 | 26d | 2023-02-15 | 2023-03-22 |  |  |  | PMO | CPT,IPA,Ofgem |  | 5.0 | N/A | Complete | COMPLETE |  |  |  |  |  |  |
| 38 | 1.2.5.7 | Draft Replan Change Request |  | 31d | 2023-02-15 A | 2023-03-29 A | 36 | 100% |  | 2023-02-15 | 2023-03-29 | 31d | 2023-02-15 | 2023-03-29 |  |  |  | PMO | CPT |  | 5.0 | N/A | Complete | COMPLETE |  |  |  |  |  |  |
| 39 | 1.2.5.8 | PSG decision to issue CR for industry impact assessment | milestone | 0d | 2023-04-05 A | 2023-04-05 A | 38FS+5d | 100% |  | 2023-04-05 | 2023-04-05 | 0d | 2023-04-05 | 2023-04-05 |  |  |  | PMO | CPT |  | 5.0 | N/A | Complete | COMPLETE |  |  |  |  |  |  |
| 40 | 1.2.5.9 | Industry impact assessment |  | 10d | 2023-04-06 A | 2023-04-19 A | 39 | 100% |  | 2023-04-06 | 2023-04-19 | 10d | 2023-04-06 | 2023-04-19 |  |  |  | PP | PMO,PPC |  | 5.0 | N/A | Complete | COMPLETE |  |  |  |  |  |  |
| 41 | 1.2.5.10 | Replan playbacks (to assist PPs in impact assessment) |  | 5d | 2023-04-11 A | 2023-04-17 A | 40SS+3d | 100% |  | 2023-04-11 | 2023-04-17 | 5d | 2023-04-11 | 2023-04-17 |  |  |  | CPT | PPC,PP |  | 5.0 | N/A | Complete | COMPLETE |  |  |  |  |  |  |
| 42 | 1.2.5.11 | Industry impact assessment responses analysis |  | 5d | 2023-04-20 A | 2023-04-26 A | 40 | 100% |  | 2023-04-20 | 2023-04-26 | 5d | 2023-04-20 | 2023-04-26 |  |  |  | PMO | CPT |  | 5.0 | N/A | Complete | COMPLETE |  |  |  |  |  |  |
| 43 | 1.2.5.12 | Extraordinary PSG decision to agree baseline recommendation | milestone | 0d | 2023-05-03 A | 2023-05-03 A | 42FS+5d | 100% |  | 2023-05-03 | 2023-05-03 | 0d | 2023-05-03 | 2023-05-03 |  |  |  | CPT | PMO,PP |  | 5.0 | N/A | Complete | COMPLETE |  |  |  |  |  |  |
| 44 | 1.2.5.13 | Plan Rebaselined (subject to Ofgem decision) | milestone | 0d | 2023-06-08 A | 2023-06-08 A | 43FS+25d | 100% |  | 2023-06-08 | 2023-06-08 | 0d? | 2023-06-07 | 2023-06-07 |  | start no earlier than 2023-06-08 | -0 | CPT | PMO,PP |  | 5.0 | N/A | Complete | COMPLETE | T1-PM-1000 | PSG | T1 |  |  |  |
| 45 | 1.2.5.14 | Programme Replan playbacks and drop-in sessions |  | 5d | 2023-06-08 A | 2023-06-14 A | 44 | 100% |  | 2023-06-08 | 2023-06-14 | 5d | 2023-06-08 | 2023-06-14 |  |  |  | PMO | PPC, PP |  | 5.0 | N/A | Complete | COMPLETE |  |  |  |  |  |  |
| 46 | 1.3 | **DESIGN, BUILD & TEST (PIT)** |  | 1101d | 2022-10-31 A | 2027-01-18 |  | 81% | 212.1d | 2022-10-31 | 2027-01-18 | 1101d | 2022-10-31 | 2027-01-18 | 94d |  | -0 | N/A | N/A |  |  | N/A |  |  |  |  |  | 1 May 2022 - 31 Jul 2023 | Design, Build & Test (PIT) |  |
| 47 | 1.3.1 | **Design Baseline & Enduring PP Support** |  | 1101d | 2022-10-31 A | 2027-01-18 |  | 71% | 319.69d | 2022-10-31 | 2027-01-18 | 1101d | 2022-10-31 | 2027-01-18 | 94d |  | -0 | N/A | N/A |  | 5.0 | N/A |  |  |  |  |  |  | Design, Build & Test (PIT) |  |
| 48 | 1.3.1.1 | Physical design baselined (M5) | milestone | 0d | 2022-10-31 A | 2022-10-31 A |  | 100% |  | 2022-10-31 | 2022-10-31 | 0d | 2022-10-31 | 2022-10-31 |  |  |  | SRO Design | SI Design,PP,IPA |  | 5.0 | Paul Pettitt | Complete | COMPLETE | T1-DB-1000 | PSG | T1 |  | Design, Build & Test (PIT) | MHHS-ART001 |
| 49 | 1.3.1.2 | **M5 Design Work-Off Plan Implementation & Approval** |  | 79d | 2022-10-31 A | 2023-02-16 A |  | 100% |  | 2022-10-31 | 2023-02-16 | 79d | 2022-10-31 | 2023-02-16 |  |  |  | N/A | N/A |  | 5.0 | N/A |  |  |  |  |  |  | Design, Build & Test (PIT) |  |
| 50 | 1.3.1.2.1 | Implementation of M5 design Work-Off Plan |  | 74d | 2022-10-31 A | 2023-02-09 A | 48 | 100% |  | 2022-10-31 | 2023-02-09 | 74d | 2022-10-31 | 2023-02-09 |  |  |  | SI Design | PP |  | 5.0 | Paul Pettitt | Complete | COMPLETE |  |  |  |  | Design, Build & Test (PIT) |  |
| 51 | 1.3.1.2.2 | M5 design Work-Off Plan completion approved | milestone | 0d | 2023-02-16 A | 2023-02-16 A | 50FS+5d | 100% |  | 2023-02-16 | 2023-02-16 | 0d | 2023-02-16 | 2023-02-16 |  |  |  | SI Design | PP |  | 5.0 | Paul Pettitt | Complete | COMPLETE | T3-DB-0014 | DAG | T3 |  | Design, Build & Test (PIT) |  |
| 52 | 1.3.1.3 | **Enduring PP Design Support** |  | 1089d | 2022-10-31 A | 2026-12-31 A |  | 100% |  | 2022-10-31 | 2026-12-31 | 1089d | 2022-10-31 | 2026-12-31 |  |  |  | N/A | N/A |  | 5.0 | N/A |  |  |  |  |  |  | Design, Build & Test (PIT) |  |
| 53 | 1.3.1.3.1 | Design playbacks and drop-in sessions |  | 45d | 2022-10-31 A | 2022-12-30 A | 48 | 100% |  | 2022-10-31 | 2022-12-30 | 45d | 2022-10-31 | 2022-12-30 |  |  |  | SI Design | PMO,PPC, SRO Design |  | 5.0 | Paul Pettitt | Complete | COMPLETE |  |  |  |  | Design, Build & Test (PIT) |  |
| 54 | 1.3.1.3.2 | Support participants on E2E MHHS Design |  | 1089d | 2022-10-31 A | 2026-12-31 A | 48 | 100% |  | 2022-10-31 | 2026-12-31 | 1089d | 2022-10-31 | 2026-12-31 |  |  |  | SI Design | PP |  | 5.0 | Paul Pettitt | Complete | COMPLETE |  |  |  |  | Design, Build & Test (PIT) |  |
| 55 | 1.3.1.3.3 | DIP Onboarding Support |  | 70d | 2022-11-14 A | 2023-02-17 A |  | 100% |  | 2022-11-14 | 2023-02-17 | 70d | 2022-11-14 | 2023-02-17 |  | must start on 2022-11-14 |  | SI Design | SRO Design |  | 5.0 | Paul Pettitt | Complete | COMPLETE |  |  |  |  | Design, Build & Test (PIT) |  |
| 56 | 1.3.1.3.4 | iServer Launch | milestone | 0d | 2023-02-16 A | 2023-02-16 A | 51 | 100% |  | 2023-02-16 | 2023-02-16 | 0d | 2023-02-16 | 2023-02-16 |  |  |  | SI Design | PP |  | 5.0 | Paul Pettitt | Complete | COMPLETE |  |  |  |  | Design, Build & Test (PIT) |  |

| ID | WBS | Task | Type | Duration | Start | Finish | Predecessors | Complete | Remaining | Baseline start | Baseline finish | Baseline duration | Baseline 1 start | Baseline 1 finish | Total slack | Constraint | Baseline cost | Responsible | Involved | Update Version | MHHS Resource Name | MHHS Programme Phase | Sched Status | RAG | Milestone ID | Text29 | Tier |
| --- | --- | --- | --- | --- | --- | --- | --- | --- | --- | --- | --- | --- | --- | --- | --- | --- | --- | --- | --- | --- | --- | --- | --- | --- | --- | --- | --- |
| 57 | 1.3.1.4 | **Establish Design Change Management Processes** |  | 1101d | 2022-10-31 A | 2027-01-18 |  | 36% | 706.22d | 2022-10-31 | 2027-01-18 | 1101d | 2022-10-31 | 2027-01-18 | 94d |  |  | N/A | N/A | 5.0 | N/A | Design, Build & Test (PIT) |  |  |  |  |  |
| 58 | 1.3.1.4.1 | Internal review of internal change management processes |  | 35d | 2022-10-31 A | 2022-12-16 A |  | 100% |  | 2022-10-31 | 2022-12-16 | 35d | 2022-10-31 | 2022-12-16 |  |  |  | SRO | SI Design | 5.0 | Paul Pettitt | Design, Build & Test (PIT) | Complete | COMPLETE |  |  |  |
| 59 | 1.3.1.4.2 | SRO approval of internal change management processes | milestone | 0d | 2022-12-16 A | 2022-12-16 A | 58FF | 100% |  | 2022-12-16 | 2022-12-16 | 0d | 2022-12-16 | 2022-12-16 |  |  |  | SRO | SI Design | 5.0 | Paul Pettitt | Design, Build & Test (PIT) | Complete | COMPLETE |  |  |  |
| 60 | 1.3.1.4.3 | Change Process Webinar | milestone | 0d | 2023-01-16 A | 2023-01-16 A |  | 100% |  | 2023-01-16 | 2023-01-16 | 0d | 2023-01-16 | 2023-01-16 |  | must start on 2023-01-16 |  | SI Design | PP | 5.0 | Paul Pettitt | Design, Build & Test (PIT) | Complete | COMPLETE |  |  |  |
| 61 | 1.3.1.4.4 | Enduring change management process approved | milestone | 0d | 2023-02-16 A | 2023-02-16 A | 51FF | 100% |  | 2023-02-16 | 2023-02-16 | 0d | 2023-02-16 | 2023-02-16 |  |  |  | SI Design | PP | 5.0 | Paul Pettitt | Design, Build & Test (PIT) | Complete | COMPLETE | T3-DB-0016 | DAG | T3 |
| 62 | 1.3.1.4.5 | Maintain E2E MHHS Design (post-M5 design change management processes operational) |  | 1022d | 2023-02-17 A | 2027-01-18 | 61 | 34% | 678d | 2023-02-17 | 2027-01-18 | 1022d | 2023-02-17 | 2027-01-18 | 94d |  |  | SI Design | PP | 5.0 | Paul Pettitt | Design, Build & Test (PIT) | Green | GREEN |  |  |  |
| 63 | 1.3.1.5 | **Design Authority Mobilisation** |  | 29d | 2022-12-14 A | 2023-01-23 A |  | 100% |  | 2022-12-14 | 2023-01-23 | 29d | 2022-12-14 | 2023-01-23 |  |  |  | N/A | N/A | 5.0 | N/A | Design, Build & Test (PIT) |  |  |  |  |  |
| 64 | 1.3.1.5.1 | Design Authority ToR approved | milestone | 0d | 2022-12-14 A | 2022-12-14 A |  | 100% |  | 2022-12-14 | 2022-12-14 | 0d | 2022-12-14 | 2022-12-14 |  | must start on 2022-12-14 |  | SI Design | PP | 5.0 | Paul Pettitt | Design, Build & Test (PIT) | Complete | COMPLETE | T3-DB-0010 | DAG | T3 |
| 65 | 1.3.1.5.2 | Inaugural Design Authority | milestone | 0d | 2023-01-23 A | 2023-01-23 A | 64FS+29d | 100% |  | 2023-01-23 | 2023-01-23 | 0d | 2023-01-23 | 2023-01-23 |  |  |  | SI Design | PP | 5.0 | Paul Pettitt | Design, Build & Test (PIT) | Complete | COMPLETE |  |  |  |
| 66 | 1.3.1.6 | **Network Operation Services Adaptor Procurement** |  | 0d | 2023-05-23 A | 2023-05-23 A |  | 100% |  | 2023-05-23 | 2023-05-23 | 0d | 2023-02-01 | 2025-03-14 |  |  | -0 | N/A | N/A | 5.0 | N/A | Design, Build & Test (PIT) |  |  |  |  |  |
| 67 | 1.3.1.6.1 | All SIT LDSOs have procured their adapter providers | milestone | 0d | 2023-05-23 A | 2023-05-23 A | 524SS | 100% |  | 2023-05-23 | 2023-05-23 | 0d | 2023-05-23 | 2023-05-23 |  |  |  | SI Design | PP | 5.0 | Paul Pettitt | Design, Build & Test (PIT) | Complete | COMPLETE | T3-DB-0020 | DAG | T3 |
| 68 | 1.3.2 | **PP Mobilisation** |  | 67d | 2022-10-31 A | 2023-01-31 A |  | 100% |  | 2022-10-31 | 2023-01-31 | 67d | 2022-10-31 | 2023-01-31 |  |  |  | N/A | N/A | 5.0 | N/A | Design, Build & Test (PIT) |  |  |  |  |  |
| 69 | 1.3.2.1 | Set up governance |  | 67d | 2022-10-31 A | 2023-01-31 A |  | 100% |  | 2022-10-31 | 2023-01-31 | 67d | 2022-10-31 | 2023-01-31 |  |  |  | PP |  | 5.0 | PP | Design, Build & Test (PIT) | Complete | COMPLETE |  |  |  |
| 70 | 1.3.2.2 | Set up reporting |  | 67d | 2022-10-31 A | 2023-01-31 A |  | 100% |  | 2022-10-31 | 2023-01-31 | 67d | 2022-10-31 | 2023-01-31 |  |  |  | PP |  | 5.0 | PP | Design, Build & Test (PIT) | Complete | COMPLETE |  |  |  |
| 71 | 1.3.2.3 | Obtain funding |  | 67d | 2022-10-31 A | 2023-01-31 A |  | 100% |  | 2022-10-31 | 2023-01-31 | 67d | 2022-10-31 | 2023-01-31 |  |  |  | PP |  | 5.0 | PP | Design, Build & Test (PIT) | Complete | COMPLETE |  |  |  |
| 72 | 1.3.2.4 | Earmark resources |  | 67d | 2022-10-31 A | 2023-01-31 A |  | 100% |  | 2022-10-31 | 2023-01-31 | 67d | 2022-10-31 | 2023-01-31 |  |  |  | PP |  | 5.0 | PP | Design, Build & Test (PIT) | Complete | COMPLETE |  |  |  |
| 73 | 1.3.2.5 | Mobilise initial team |  | 67d | 2022-10-31 A | 2023-01-31 A |  | 100% |  | 2022-10-31 | 2023-01-31 | 67d | 2022-10-31 | 2023-01-31 |  |  |  | PP |  | 5.0 | PP | Design, Build & Test (PIT) | Complete | COMPLETE |  |  |  |
| 74 | 1.3.3 | **PIT Stub Specification and Delivery** |  | 435d | 2022-10-31 A | 2024-06-28 A |  | 100% |  | 2022-10-31 | 2024-06-21 | 430d | 2022-10-31 | 2023-05-31 |  |  | -0 | N/A | N/A | 5.0 | N/A | Design, Build & Test (PIT) |  |  |  |  |  |
| 75 | 1.3.3.1 | **DIP Simulator** |  | 108d | 2022-10-31 A | 2023-03-29 A |  | 100% |  | 2022-10-31 | 2023-03-29 | 108d | 2022-10-31 | 2023-03-29 |  |  |  | N/A | N/A | 5.0 | N/A | Design, Build & Test (PIT) |  |  |  |  |  |
| 76 | 1.3.3.1.1 | Build & Test |  | 95d | 2022-10-31 A | 2023-03-10 A | 48 | 100% |  | 2022-10-31 | 2023-03-10 | 95d | 2022-10-31 | 2023-03-10 |  |  |  | SI DevOps |  | 5.0 | Rebecca Farooq | Design, Build & Test (PIT) | Complete | COMPLETE |  |  |  |
| 77 | 1.3.3.1.2 | UAT |  | 85d | 2022-11-14 A | 2023-03-10 A | 76SS+10d | 100% |  | 2022-11-14 | 2023-03-10 | 85d | 2022-11-14 | 2023-03-10 |  |  |  | SI Test |  | 5.0 | Rebecca Farooq | Design, Build & Test (PIT) | Complete | COMPLETE |  |  |  |
| 78 | 1.3.3.1.3 | Beta test |  | 95d | 2022-10-31 A | 2023-03-10 A | 76SS | 100% |  | 2022-10-31 | 2023-03-10 | 95d | 2022-10-31 | 2023-03-10 |  |  |  | PP | SI Test | 5.0 | Rebecca Farooq | Design, Build & Test (PIT) | Complete | COMPLETE |  |  |  |
| 79 | 1.3.3.1.4 | Prepare for release |  | 18d | 2023-03-06 A | 2023-03-29 A | 78FS-5d | 100% |  | 2023-03-06 | 2023-03-29 | 18d | 2023-03-06 | 2023-03-29 |  |  |  | SI DevOps |  | 5.0 | Rebecca Farooq | Design, Build & Test (PIT) | Complete | COMPLETE |  |  |  |
| 80 | 1.3.3.1.5 | DIP Simulator released | milestone | 0d | 2023-03-29 A | 2023-03-29 A | 79FF | 100% |  | 2023-03-29 | 2023-03-29 | 0d | 2023-03-29 | 2023-03-29 |  | start no earlier than 2023-01-30 |  | SI DevOps |  | 5.0 | Rebecca Farooq | Design, Build & Test (PIT) | Complete | COMPLETE | T3-DB-0018 | SITAG | T3 |

| ID | WBS | Task | Type | Duration | Start | Finish | Predecessors | Complete | Remaining | Baseline start | Baseline finish | Baseline duration | Baseline 1 start | Baseline 1 finish | Total slack | Constraint | Baseline cost | Responsible | Involved | Update Version | MHHS Resource Name | MHHS Programme Phase | Sched Status | RAG | Milestone ID | Text29 | Tier |
| --- | --- | --- | --- | --- | --- | --- | --- | --- | --- | --- | --- | --- | --- | --- | --- | --- | --- | --- | --- | --- | --- | --- | --- | --- | --- | --- | --- |
| 81 | 1.3.3.2 | **DIP Simulator Uplifts** |  | 257d | 2023-07-06 A | 2024-06-28 A |  | 100% |  | 2023-07-06 | 2024-06-21 | 252d |  |  |  |  | -0 | N/A | N/A | 5.1 | N/A | Design, Build & Test (PIT) |  |  |  |  |  |
| 82 | 1.3.3.2.1 | DIP Simulator uplifted to align with design releases - design/build/test |  | 27d | 2023-07-06 A | 2023-08-11 A | 118 | 100% |  | 2023-07-06 | 2023-08-11 | 27d |  |  |  |  |  | SI DevOps |  | 5.1 | Rebecca Farooq | Design, Build & Test (PIT) | Complete | COMPLETE |  |  |  |
| 83 | 1.3.3.2.2 | DIP Simulator uplifted to align with Interim Release 2 | milestone | 0d | 2023-08-11 A | 2023-08-11 A | 82 | 100% |  | 2023-08-11 | 2023-08-11 | 0d |  |  |  |  |  | SI DevOps |  | 5.1 | Rebecca Farooq | Design, Build & Test (PIT) | Complete | COMPLETE | T3-DB-0035 | SITAG | T3 |
| 84 | 1.3.3.2.3 | DIP Simulator uplifted to align with design releases - design/build/test |  | 20d | 2023-10-09 A | 2023-11-03 A | 127FS+2d | 100% |  | 2023-10-09 | 2023-11-03 | 20d |  |  |  |  |  | SI DevOps |  | 5.3 | Rebecca Farooq | Design, Build & Test (PIT) | Complete | COMPLETE |  |  |  |
| 85 | 1.3.3.2.4 | DIP Simulator uplifted to align with Interim Release 5 | milestone | 0d | 2023-11-03 A | 2023-11-03 A | 84 | 100% |  | 2023-11-03 | 2023-11-03 | 0d |  |  |  |  |  | SI DevOps |  | 5.11 | Rebecca Farooq | Design, Build & Test (PIT) | Complete | COMPLETE | T3-DB-0039 | SITAG | T3 |
| 86 | 1.3.3.2.5 | DIP Simulator uplifted to align with design releases - design/build/test |  | 37d | 2024-02-01 A | 2024-03-22 A | 135 | 100% |  | 2024-02-01 | 2024-03-22 | 37d |  |  |  |  |  | SI DevOps | PP,SRO,Testing | 5.14 | Matthew Bray | Design, Build & Test (PIT) | Complete | COMPLETE |  |  |  |
| 87 | 1.3.3.2.6 | DIP Simulator uplifted to align with Interim Release 7 | milestone | 0d | 2024-03-22 A | 2024-03-22 A | 86 | 100% |  | 2024-03-22 | 2024-03-22 | 0d |  |  |  |  |  | SI DevOps | PP,SRO,Testing | 5.14 | Matthew Bray | Design, Build & Test (PIT) | Complete | COMPLETE | T3-DB-0182 | SITAG | T3 |
| 88 | 1.3.3.2.7 | DIP Simulator uplifted to align with design releases - design/build/test |  | 57d | 2024-04-04 A | 2024-06-21 A | 139 | 100% |  | 2024-04-04 | 2024-06-21 | 57d |  |  |  |  |  | SI DevOps | PP,SRO,Testing | 5.14 | Matthew Bray | Design, Build & Test (PIT) | Complete | COMPLETE |  |  |  |
| 89 | 1.3.3.2.8 | DIP Simulator uplifted to align with Interim Release 8 | milestone | 0d | 2024-06-28 A | 2024-06-28 A | 88FS+5d | 100% |  | 2024-06-21 | 2024-06-21 | 0d |  |  |  |  |  | SI DevOps | PP,SRO,Testing | 5.28 | Matthew Bray | Design, Build & Test (PIT) | Complete | COMPLETE | T3-DB-0183 | SITAG | T3 |
| 90 | 1.3.3.3 | **Data Generator** |  | 130d | 2022-12-01 A | 2023-05-31 A |  | 100% |  | 2022-12-01 | 2023-05-31 | 130d | 2022-12-01 | 2023-05-31 |  |  |  | N/A | N/A | 5.0 | N/A | Design, Build & Test (PIT) |  |  |  |  |  |
| 91 | 1.3.3.3.1 | Design | manual | 15d | 2022-12-01 A | 2022-12-21 A |  | 100% |  | 2022-12-01 | 2022-12-21 | 15d | 2022-12-01 | 2022-12-21 |  |  |  | SI DevOps |  | 5.0 | Rebecca Farooq | Design, Build & Test (PIT) | Complete | COMPLETE |  |  |  |
| 92 | 1.3.3.3.2 | Build & Test |  | 50d | 2023-02-16 A | 2023-04-26 A | 91FS+40d | 100% |  | 2023-02-16 | 2023-04-26 | 50d | 2023-02-16 | 2023-04-26 |  |  |  | SI DevOps |  | 5.0 | Rebecca Farooq | Design, Build & Test (PIT) | Complete | COMPLETE |  |  |  |
| 93 | 1.3.3.3.3 | UAT |  | 10d | 2023-04-27 A | 2023-05-10 A | 92 | 100% |  | 2023-04-27 | 2023-05-10 | 10d | 2023-04-27 | 2023-05-10 |  |  |  | SI Test |  | 5.0 | Rebecca Farooq | Design, Build & Test (PIT) | Complete | COMPLETE |  |  |  |
| 94 | 1.3.3.3.4 | Beta test |  | 45d | 2023-03-30 A | 2023-05-31 A | 92FS-20d, 96FF | 100% |  | 2023-03-30 | 2023-05-31 | 45d | 2023-03-30 | 2023-05-31 |  |  |  | PP | SI Test | 5.0 | Rebecca Farooq | Design, Build & Test (PIT) | Complete | COMPLETE |  |  |  |
| 95 | 1.3.3.3.5 | Prepare for release |  | 24d | 2023-04-27 A | 2023-05-30 A | 93SS | 100% |  | 2023-04-27 | 2023-05-30 | 24d | 2023-04-27 | 2023-05-30 |  |  |  | SI DevOps |  | 5.0 | Rebecca Farooq | Design, Build & Test (PIT) | Complete | COMPLETE |  |  |  |
| 96 | 1.3.3.3.6 | Data Generator released | milestone | 0d | 2023-05-31 A | 2023-05-31 A | 95FS+1d | 100% |  | 2023-05-31 | 2023-05-31 | 0d | 2023-05-31 | 2023-05-31 |  |  |  | SI DevOps |  | 5.0 | Rebecca Farooq | Design, Build & Test (PIT) | Complete | COMPLETE | T3-DB-0022 | SITAG | T3 |
| 97 | 1.3.4 | **Design Artefact Releases** |  | 398d | 2023-02-22 A | 2024-08-30 |  | 97% | 10.7d | 2023-02-22 | 2024-08-30 | 398d | 2023-02-22 | 2023-09-29 | 5d |  | -0 | N/A | N/A | 5.0 | N/A | Design, Build & Test (PIT) |  |  |  |  |  |
| 98 | 1.3.4.1 | **Interim release 1** |  | 79d | 2023-02-22 A | 2023-06-12 A |  | 100% |  | 2023-02-22 | 2023-06-12 | 79d | 2023-02-22 | 2023-06-28 |  |  |  | N/A | N/A | 5.0 | N/A | Design, Build & Test (PIT) |  |  |  |  |  |
| 99 | 1.3.4.1.1 | Prioritise DINs and CR |  | 1d | 2023-02-22 A | 2023-02-22 A |  | 100% |  | 2023-02-22 | 2023-02-22 | 1d | 2023-02-22 | 2023-02-22 |  | must start on 2023-02-22 |  | SI Design |  | 5.0 | Paul Pettitt | Design, Build & Test (PIT) | Complete | COMPLETE |  |  |  |
| 100 | 1.3.4.1.2 | **Industry input session** |  | 7d | 2023-02-23 A | 2023-03-03 A |  | 100% |  | 2023-02-23 | 2023-03-03 | 7d | 2023-02-23 | 2023-03-03 |  |  |  | N/A | N/A | 5.0 | N/A | Design, Build & Test (PIT) |  |  |  |  |  |
| 101 | 1.3.4.1.2.1 | Raise a CR covering prioritized assessment cluster |  | 1d | 2023-02-23 A | 2023-02-23 A | 99 | 100% |  | 2023-02-23 | 2023-02-23 | 1d | 2023-02-23 | 2023-02-23 |  |  |  | SI Design |  | 5.0 | Paul Pettitt | Design, Build & Test (PIT) | Complete | COMPLETE |  |  |  |
| 102 | 1.3.4.1.2.2 | Organize Industry Input session to go through significant items to reach consensus |  | 1d | 2023-02-23 A | 2023-02-23 A | 101SS | 100% |  | 2023-02-23 | 2023-02-23 | 1d | 2023-02-23 | 2023-02-23 |  |  |  | SI Design | PP | 5.0 | Paul Pettitt,Berlinda Kugara | Design, Build & Test (PIT) | Complete | COMPLETE |  |  |  |
| 103 | 1.3.4.1.2.3 | Conduct Meeting |  | 1d | 2023-03-03 A | 2023-03-03 A | 102FS+5d | 100% |  | 2023-03-03 | 2023-03-03 | 1d | 2023-03-03 | 2023-03-03 |  |  |  | SI Design | PP | 5.0 | Paul Pettitt,Berlinda Kugara | Design, Build & Test (PIT) | Complete | COMPLETE |  |  |  |
| 104 | 1.3.4.1.3 | Update baselined artefacts |  | 10d | 2023-03-24 A | 2023-04-06 A |  | 100% |  | 2023-03-24 | 2023-04-06 | 10d | 2023-03-24 | 2023-04-06 |  |  |  | SI Design |  | 5.0 | Paul Pettitt | Design, Build & Test (PIT) | Complete | COMPLETE |  |  |  |

Notes:
- 85: Amber as S&E couldn't view design docs, & assess scope changes. Required workload likely more than 2 sprints (original estimate). Additional MS work & CIT testing support has stretched capacity further. Delivery could be delayed. / Action: 26/7/23 - forecast changed from 15/12/23 - 3/11/23 - Changed from Interim Release 6 to 5. Updated in milestone register
- 87: 11/12- Add new milestone to reflect confirmation of Interim Release Delivery dates. 20/12 - Approved at TMAG on 20/12
- 89: 20/6: Date missed because a decision was taken and agreed with SRO to bundle IR8 and IR8.1, meaning a later combined release date of 28/6. No PP impact as PIT for SIT Cycle 3 will be baselined against IR8.1

| ID | WBS | Task | Type | Duration | Start | Finish | Predecessors | Complete | Baseline start | Baseline finish | Baseline duration | Baseline 1 start | Baseline 1 finish | Constraint | Baseline cost | Responsible | Involved | Update Version | MHHS Resource Name | MHHS Programme Phase | Sched Status | RAG | Milestone ID | Text29 | Tier | Action |
| --- | --- | --- | --- | --- | --- | --- | --- | --- | --- | --- | --- | --- | --- | --- | --- | --- | --- | --- | --- | --- | --- | --- | --- | --- | --- | --- |
| 105 | 1.3.4.1.4 | **Participant review and impact assess changes** |  | 18d | 2023-04-14 A | 2023-05-09 A |  | 100% | 2023-04-14 | 2023-05-09 | 18d | 2023-04-14 | 2023-05-09 |  |  | N/A | N/A | 5.0 | N/A | Design, Build & Test (PIT) |  |  |  |  |  |  |
| 106 | 1.3.4.1.4.1 | Issue Redline Version of documents |  | 1d | 2023-04-14 A | 2023-04-14 A | 104FS+5d | 100% | 2023-04-14 | 2023-04-14 | 1d | 2023-04-14 | 2023-04-14 |  |  | SI Design |  | 5.0 | Paul Pettitt | Design, Build & Test (PIT) | Complete | COMPLETE |  |  |  |  |
| 107 | 1.3.4.1.4.2 | Participants provide review comments to common log |  | 17d | 2023-04-17 A | 2023-05-09 A | 106 | 100% | 2023-04-17 | 2023-05-09 | 17d | 2023-04-17 | 2023-05-09 |  |  | PP |  | 5.0 | Paul Pettitt | Design, Build & Test (PIT) | Complete | COMPLETE |  |  |  |  |
| 108 | 1.3.4.1.5 | **Assurance review** |  | 19d | 2023-05-10 A | 2023-06-05 A |  | 100% | 2023-05-10 | 2023-06-05 | 19d | 2023-05-10 | 2023-06-05 |  |  | N/A | N/A | 5.0 | N/A | Design, Build & Test (PIT) |  |  |  |  |  |  |
| 109 | 1.3.4.1.5.1 | SI Design Review and Respond to Comments |  | 5d | 2023-05-10 A | 2023-05-16 A | 107 | 100% | 2023-05-10 | 2023-05-16 | 5d | 2023-05-10 | 2023-05-16 |  |  | SI Design |  | 5.0 | Paul Pettitt | Design, Build & Test (PIT) | Complete | COMPLETE |  |  |  |  |
| 110 | 1.3.4.1.5.2 | Prep for Assurance Review Meeting |  | 7d | 2023-05-17 A | 2023-05-25 A | 109 | 100% | 2023-05-17 | 2023-05-25 | 7d | 2023-05-17 | 2023-05-25 |  |  | SI Design |  | 5.0 | Paul Pettitt | Design, Build & Test (PIT) | Complete | COMPLETE |  |  |  |  |
| 111 | 1.3.4.1.5.3 | Conduct Assurance Review Meeting |  | 1d | 2023-05-26 A | 2023-05-26 A | 110 | 100% | 2023-05-26 | 2023-05-26 | 1d | 2023-05-26 | 2023-05-26 |  |  | SI Design |  | 5.0 | Paul Pettitt | Design, Build & Test (PIT) | Complete | COMPLETE |  |  |  |  |
| 112 | 1.3.4.1.5.4 | Update Artefacts following Assurance Review |  | 6d | 2023-05-29 A | 2023-06-05 A | 111 | 100% | 2023-05-29 | 2023-06-05 | 6d | 2023-05-29 | 2023-06-05 |  |  | SI Design |  | 5.0 | Paul Pettitt | Design, Build & Test (PIT) | Complete | COMPLETE |  |  |  |  |
| 113 | 1.3.4.1.6 | PSG Approval of interim release plan |  | 1d | 2023-06-08 A | 2023-06-08 A |  | 100% | 2023-06-08 | 2023-06-08 | 1d |  |  | must start on 2023-06-08 |  | PP | SI Design | 5.1 | Paul Pettitt | Design, Build & Test (PIT) | Complete | COMPLETE |  |  |  |  |
| 114 | 1.3.4.1.7 | Publish updated baselined artefacts | milestone | 0d | 2023-06-06 A | 2023-06-12 A | 112 | 100% | 2023-06-06 | 2023-06-12 | 5d | 2023-06-15 | 2023-06-21 |  |  | SI Design |  | 5.0 | Paul Pettitt | Design, Build & Test (PIT) | Complete | COMPLETE |  |  |  |  |
| 115 | 1.3.4.1.8 | Interim release 1 Go live | milestone | 0d | 2023-06-12 A | 2023-06-12 A | 114 | 100% | 2023-06-12 | 2023-06-12 | 0d | 2023-06-28 | 2023-06-28 |  |  | SI Design |  | 5.0 | Paul Pettitt | Design, Build & Test (PIT) | Complete | COMPLETE | T3-DB-0095 | DAG | T3 |  |
| 116 | 1.3.4.2 | **Interim release 2** |  | 27d | 2023-05-30 A | 2023-07-05 A |  | 100% | 2023-05-30 | 2023-07-05 | 27d | 2023-05-24 | 2023-07-28 |  |  | N/A | N/A | 5.0 | N/A | Design, Build & Test (PIT) |  |  |  |  |  |  |
| 117 | 1.3.4.2.1 | Update baselined artefacts |  | 27d | 2023-05-30 A | 2023-07-05 A |  | 100% | 2023-05-30 | 2023-07-05 | 27d |  |  | must start on 2023-05-30 |  | SI Design | PP | 5.1 | Paul Pettitt | Design, Build & Test (PIT) | Complete | COMPLETE |  |  |  |  |
| 118 | 1.3.4.2.2 | Interim release 2 Go live | milestone | 0d | 2023-07-05 A | 2023-07-05 A | 117 | 100% | 2023-07-05 | 2023-07-05 | 0d | 2023-07-28 | 2023-07-28 |  |  | SI Design |  | 5.0 | Paul Pettitt | Design, Build & Test (PIT) | Complete | COMPLETE | T3-DB-0096 | DAG | T3 |  |
| 119 | 1.3.4.3 | **Interim release 3** |  | 35d | 2023-06-15 A | 2023-08-02 A |  | 100% | 2023-06-15 | 2023-08-02 | 35d | 2023-06-29 | 2023-09-29 |  |  | N/A | N/A | 5.0 | N/A | Design, Build & Test (PIT) |  |  |  |  |  |  |
| 120 | 1.3.4.3.1 | Update baselined artefacts |  | 35d | 2023-06-15 A | 2023-08-02 A |  | 100% | 2023-06-15 | 2023-08-02 | 35d |  |  | must start on 2023-06-15 |  | SI Design | PP | 5.1 | Paul Pettitt | Design, Build & Test (PIT) | Complete | COMPLETE |  |  |  |  |
| 121 | 1.3.4.3.2 | Interim release 3 Go live | milestone | 0d | 2023-08-02 A | 2023-08-02 A | 120 | 100% | 2023-08-02 | 2023-08-02 | 0d | 2023-09-29 | 2023-09-29 |  |  | SI Design |  | 5.0 | Paul Pettitt | Design, Build & Test (PIT) | Complete | COMPLETE | T3-DB-0097 | DAG | T3 |  |
| 122 | 1.3.4.4 | **Interim release 4** |  | 36d | 2023-07-12 A | 2023-08-30 A |  | 100% | 2023-07-12 | 2023-08-30 | 36d |  |  |  |  | N/A | N/A | 5.1 | N/A | Design, Build & Test (PIT) |  |  |  |  |  |  |
| 123 | 1.3.4.4.1 | Update baselined artefacts |  | 36d | 2023-07-12 A | 2023-08-30 A |  | 100% | 2023-07-12 | 2023-08-30 | 36d |  |  | must start on 2023-07-12 |  | SI Design | PP | 5.1 | Paul Pettitt | Design, Build & Test (PIT) | Complete | COMPLETE |  |  |  |  |
| 124 | 1.3.4.4.2 | Interim release 4 Go live | milestone | 0d | 2023-08-30 A | 2023-08-30 A | 123 | 100% | 2023-08-30 | 2023-08-30 | 0d |  |  |  |  | SI Design |  | 5.1 | Paul Pettitt | Design, Build & Test (PIT) | Complete | COMPLETE | T3-DB-0081 | DAG | T3 |  |
| 125 | 1.3.4.5 | **Interim release 5** |  | 147d | 2023-08-17 A | 2024-03-08 A |  | 100% | 2023-08-17 | 2024-03-08 | 147d |  |  |  | -0 | N/A | N/A | 5.1 | N/A | Design, Build & Test (PIT) |  |  |  |  |  |  |
| 126 | 1.3.4.5.1 | Update baselined artefacts |  | 35d | 2023-08-17 A | 2023-10-04 A |  | 100% | 2023-08-17 | 2023-10-04 | 35d |  |  | must start on 2023-08-17 |  | SI Design | PP | 5.1 | Paul Pettitt | Design, Build & Test (PIT) | Complete | COMPLETE |  |  |  |  |
| 127 | 1.3.4.5.2 | Interim release 5 Go live | milestone | 0d | 2023-10-04 A | 2023-10-04 A | 126 | 100% | 2023-10-04 | 2023-10-04 | 0d |  |  |  |  | SI Design |  | 5.1 | Paul Pettitt | Design, Build & Test (PIT) | Complete | COMPLETE | T3-DB-0083 | DAG | T3 | 11/8 - successor is SIT functional (starts in march) |
| 128 | 1.3.4.5.3 | Interim Release 5 Deployed to SIT |  | 10d | 2024-02-26 A | 2024-03-08 A | 127FS+102d | 100% | 2024-02-26 | 2024-03-08 | 10d |  |  |  |  | SI Testing | PP | 5.16 | Lee Cox |  | Complete | COMPLETE |  |  |  |  |

| ID | WBS | Task | Type | Duration | Start | Finish | Predecessors | Complete | Remaining | Baseline start | Baseline finish | Baseline duration | Baseline 1 start | Baseline 1 finish | Total slack | Free slack | Constraint | Baseline cost | Responsible | Involved | Update Version | MHHS Resource Name | MHHS Programme Phase | Sched Status | RAG | Milestone ID | Text29 | Tier | Action | Task Status |
| --- | --- | --- | --- | --- | --- | --- | --- | --- | --- | --- | --- | --- | --- | --- | --- | --- | --- | --- | --- | --- | --- | --- | --- | --- | --- | --- | --- | --- | --- | --- |
| 129 | 1.3.4.6 | **Interim release 6** |  | 192d | 2023-09-14 A | 2024-06-07 A |  | 100% |  | 2023-09-14 | 2024-06-07 | 192d |  |  |  |  |  | -0 | N/A | N/A | 5.1 | N/A | Design, Build & Test (PIT) |  |  |  |  |  |  |  |
| 130 | 1.3.4.6.1 | Update baselined artefacts |  | 35d | 2023-09-14 A | 2023-11-01 A |  | 100% |  | 2023-09-14 | 2023-10-27 | 32d |  |  |  |  | must start on 2023-09-14 |  | SI Design | PP | 5.1 | Paul Pettitt | Design, Build & Test (PIT) | Complete | COMPLETE |  |  |  |  |  |
| 131 | 1.3.4.6.2 | Interim release 6 Go live | milestone | 0d | 2023-11-01 A | 2023-11-01 A | 130 | 100% |  | 2023-10-27 | 2023-10-27 | 0d |  |  |  |  |  |  | SI Design |  | 5.11 | Paul Pettitt | Design, Build & Test (PIT) | Complete | COMPLETE | T3-DB-0085 | DAG | T3 |  |  |
| 132 | 1.3.4.6.3 | Interim Release 6 Deployed to SIT |  | 10d | 2024-05-27 A | 2024-06-07 A | 131FS+147d | 100% |  | 2024-05-27 | 2024-06-07 | 10d |  |  |  |  |  |  | SI Testing | PP | 5.16 | Lee Cox |  | Complete | COMPLETE |  |  |  |  |  |
| 133 | 1.3.4.7 | **Interim release 7** |  | 168d | 2023-10-18 A | 2024-06-07 A |  | 100% |  | 2023-10-18 | 2024-06-07 | 168d |  |  |  |  |  | -0 | N/A | N/A | 5.5 | N/A | Design, Build & Test (PIT) |  |  |  |  |  |  |  |
| 134 | 1.3.4.7.1 | Update baselined artefacts |  | 76d | 2023-10-18 A | 2024-01-31 A |  | 100% |  | 2023-10-18 | 2024-01-31 | 76d |  |  |  |  | start no earlier than 2023-10-18 |  | SI Design | PP | 5.5 | Paul Pettitt | Design, Build & Test (PIT) | Complete | COMPLETE |  |  |  |  |  |
| 135 | 1.3.4.7.2 | Interim release 7 Go live | milestone | 0d | 2024-01-31 A | 2024-01-31 A | 134 | 100% |  | 2024-01-31 | 2024-01-31 | 0d |  |  |  |  |  |  | SI Design | PP | 5.14 | Paul Pettitt | Design, Build & Test (PIT) | Complete | COMPLETE | T3-DB-0098 | DAG | T3 | 4/8 - add as t3 milestones. Awaiting approval at TMAG |  |
| 136 | 1.3.4.7.3 | Interim Release 7 Deployed to SIT |  | 10d | 2024-05-27 A | 2024-06-07 A | 135FS+82d | 100% |  | 2024-05-27 | 2024-06-07 | 10d |  |  |  |  |  |  | SI Testing | PP | 5.16 | Lee Cox |  | Complete | COMPLETE |  |  |  |  |  |
| 137 | 1.3.4.8 | **Interim release 8** |  | 143d | 2024-02-14 A | 2024-08-30 |  | 78% | 31.09d | 2024-02-14 | 2024-08-30 | 143d |  |  | 5d |  |  | -0 | N/A | N/A | 5.5 | N/A | Design, Build & Test (PIT) |  |  |  |  |  |  |  |
| 138 | 1.3.4.8.1 | Update baselined artefacts |  | 36d | 2024-02-14 A | 2024-04-03 A |  | 100% |  | 2024-02-14 | 2024-04-03 | 36d |  |  |  |  | start no earlier than 2024-02-14 |  | SI Design | PP | 5.5 | Paul Pettitt | Design, Build & Test (PIT) | Complete | COMPLETE |  |  |  |  |  |
| 139 | 1.3.4.8.2 | Interim release 8 Go live | milestone | 0d | 2024-04-03 A | 2024-04-03 A | 138 | 100% |  | 2024-04-03 | 2024-04-03 | 0d |  |  |  |  | start no earlier than 2024-01-10 |  | SI Design | PP | 5.14 | Paul Pettitt | Design, Build & Test (PIT) | Complete | COMPLETE | T3-DB-0099 | DAG | T3 | 4/8 - add as t3 milestones. Awaiting approval at TMAG |  |
| 140 | 1.3.4.8.3 | Interim Release 8 Deployed to SIT |  | 10d | 2024-08-19 | 2024-08-30 | 139FS+97d |  |  | 2024-08-19 | 2024-08-30 | 10d |  |  | 5d | 0d |  |  | SI Testing | PP | 5.16 | Roger Robar |  | Green | GREEN |  |  |  |  | 11.33 |
| 141 | 1.3.5 | **Queries Support / Knowledgebase & Tool Roll-Out (Systems)** |  | 325d | 2023-01-03 A | 2024-04-01 A |  | 100% |  | 2023-01-03 | 2024-04-01 | 325d | 2023-01-03 | 2024-04-01 |  |  |  |  | N/A | N/A | 5.0 | N/A | Design, Build & Test (PIT) |  |  |  |  |  |  |  |
| 142 | 1.3.5.1 | **Query Management** |  | 325d | 2023-01-03 A | 2024-04-01 A |  | 100% |  | 2023-01-03 | 2024-04-01 | 325d | 2023-01-03 | 2024-04-01 |  |  |  |  | N/A | N/A | 5.0 | N/A | Design, Build & Test (PIT) |  |  |  |  |  |  |  |
| 143 | 1.3.5.1.1 | Respond to Participant Queries |  | 325d | 2023-01-03 A | 2024-04-01 A |  | 100% |  | 2023-01-03 | 2024-04-01 | 325d | 2023-01-03 | 2024-04-01 |  |  | must start on 2023-01-03 |  | SI Design | PP | 5.0 | Paul Pettitt | Design, Build & Test (PIT) | Complete | COMPLETE |  |  |  | 11/8 - runs out to end of the programme |  |
| 144 | 1.3.5.1.2 | Respond to Programme Queries |  | 325d | 2023-01-03 A | 2024-04-01 A | 143SS | 100% |  | 2023-01-03 | 2024-04-01 | 325d | 2023-01-03 | 2024-04-01 |  |  |  |  | SI Design | PP | 5.0 | Paul Pettitt | Design, Build & Test (PIT) | Complete | COMPLETE |  |  |  | 11/8 - runs out to end of the programme |  |
| 145 | 1.3.5.2 | **Query Support tooling (FreshDesk)** |  | 23d | 2023-06-01 A | 2023-07-03 A |  | 100% |  | 2023-06-01 | 2023-07-03 | 23d | 2023-06-01 | 2023-07-03 |  |  |  |  | N/A | N/A | 5.0 | N/A | Design, Build & Test (PIT) |  |  |  |  |  |  |  |
| 146 | 1.3.5.2.1 | Migrate to Standalone Freshdesk |  | 10d | 2023-06-01 A | 2023-06-14 A |  | 100% |  | 2023-06-01 | 2023-06-14 | 10d | 2023-06-01 | 2023-06-14 |  |  | must start on 2023-06-01 |  | SI Design |  | 5.0 | Paul Pettitt | Design, Build & Test (PIT) | Complete | COMPLETE |  |  |  |  |  |
| 147 | 1.3.5.2.2 | Develop reporting dashboard |  | 5d | 2023-06-15 A | 2023-06-21 A | 146 | 100% |  | 2023-06-15 | 2023-06-21 | 5d | 2023-06-15 | 2023-06-21 |  |  |  |  | SI Design |  | 5.0 | Paul Pettitt | Design, Build & Test (PIT) | Complete | COMPLETE |  |  |  |  |  |
| 148 | 1.3.5.2.3 | Issue to SRO for Review |  | 5d | 2023-06-22 A | 2023-06-28 A | 147 | 100% |  | 2023-06-22 | 2023-06-28 | 5d | 2023-06-22 | 2023-06-28 |  |  |  |  | SI Design |  | 5.0 | Paul Pettitt | Design, Build & Test (PIT) | Complete | COMPLETE |  |  |  |  |  |
| 149 | 1.3.5.2.4 | Update following review |  | 2d | 2023-06-29 A | 2023-06-30 A | 148 | 100% |  | 2023-06-29 | 2023-06-30 | 2d | 2023-06-29 | 2023-06-30 |  |  |  |  | SI Design |  | 5.0 | Paul Pettitt | Design, Build & Test (PIT) | Complete | COMPLETE |  |  |  |  |  |
| 150 | 1.3.5.2.5 | Sign off |  | 1d | 2023-07-03 A | 2023-07-03 A | 149 | 100% |  | 2023-07-03 | 2023-07-03 | 1d | 2023-07-03 | 2023-07-03 |  |  |  |  | SI Design |  | 5.0 | Paul Pettitt | Design, Build & Test (PIT) | Complete | COMPLETE |  |  |  |  |  |
| 151 | 1.3.5.3 | **KnowledgeBase Development** |  | 72d | 2023-06-01 A | 2023-09-08 A |  | 100% |  | 2023-06-01 | 2023-09-08 | 72d | 2023-06-01 | 2023-09-08 |  |  |  |  | N/A | N/A | 5.0 | N/A | Design, Build & Test (PIT) |  |  |  |  |  |  |  |
| 152 | 1.3.5.3.1 | Define Scope of KB |  | 1d | 2023-06-01 A | 2023-06-01 A | 146SS | 100% |  | 2023-06-01 | 2023-06-01 | 1d | 2023-06-01 | 2023-06-01 |  |  |  |  | SI Design |  | 5.0 | Paul Pettitt | Design, Build & Test (PIT) | Complete | COMPLETE |  |  |  |  |  |
| 153 | 1.3.5.3.2 | Capture Existing KB artefacts |  | 20d | 2023-06-02 A | 2023-06-29 A | 152 | 100% |  | 2023-06-02 | 2023-06-29 | 20d | 2023-06-02 | 2023-06-29 |  |  |  |  | SI Design |  | 5.0 | Paul Pettitt | Design, Build & Test (PIT) | Complete | COMPLETE |  |  |  |  |  |
| 154 | 1.3.5.3.3 | Tag artefacts |  | 5d | 2023-06-30 A | 2023-07-06 A | 153 | 100% |  | 2023-06-30 | 2023-07-06 | 5d | 2023-06-30 | 2023-07-06 |  |  |  |  | SI Design |  | 5.0 | Paul Pettitt | Design, Build & Test (PIT) | Complete | COMPLETE |  |  |  |  |  |
| 155 | 1.3.5.3.4 | Develop Participant Interfaces |  | 20d | 2023-07-07 A | 2023-08-03 A | 154 | 100% |  | 2023-07-07 | 2023-08-03 | 20d | 2023-07-07 | 2023-08-03 |  |  |  |  | SI Design |  | 5.0 | Paul Pettitt | Design, Build & Test (PIT) | Complete | COMPLETE |  |  |  |  |  |
| 156 | 1.3.5.3.5 | Promote to Collaboration Portal |  | 21d | 2023-08-04 A | 2023-09-01 A | 155 | 100% |  | 2023-08-04 | 2023-09-01 | 21d | 2023-08-04 | 2023-09-01 |  |  |  |  | SI Design |  | 5.0 | Paul Pettitt | Design, Build & Test (PIT) | Complete | COMPLETE |  |  |  |  |  |
| 157 | 1.3.5.3.6 | Link into FreshDesk |  | 5d | 2023-09-04 A | 2023-09-08 A | 156 | 100% |  | 2023-09-04 | 2023-09-08 | 5d | 2023-09-04 | 2023-09-08 |  |  |  |  | SI Design |  | 5.0 | Paul Pettitt | Design, Build & Test (PIT) | Complete | COMPLETE |  |  |  |  |  |

Notes:
- 134: 4/8 - Added in as per PPs advice
- 135: 27/11- Red because forecast date has changed to align with Testing Release Management. Discussed with no objections at FTIG on 23/11. To be taken to Dec DAG for noting
- 138: 4/8 - Added in as per PPs advice
- 139: 27/11- Amber because forecast date has changed to align with Testing Release Management. Discussed with no objections at FTIG on 23/11. To be taken to Dec DAG for noting

| ID | WBS | Task | Type | Duration | Start | Finish | Predecessors | Complete | Remaining | Baseline start | Baseline finish | Baseline duration | Baseline 1 start | Baseline 1 finish | Total slack | Baseline cost | Responsible | Involved | Update Version | MHHS Resource Name | MHHS Programme Phase | Sched Status | RAG | Task Status | Milestone ID | Text29 | Tier |
| --- | --- | --- | --- | --- | --- | --- | --- | --- | --- | --- | --- | --- | --- | --- | --- | --- | --- | --- | --- | --- | --- | --- | --- | --- | --- | --- | --- |
| 158 | 1.3.6 | **PP Design, Build & Test (DBT)** |  | 495d | 2022-10-31 A | 2024-09-20 |  | 97% | 14.45d | 2022-10-31 | 2024-09-20 | 495d | 2022-10-31 | 2026-02-16 | 0d | -0 | N/A | N/A | 5.0 | N/A | Design, Build & Test (PIT) |  |  |  |  |  |  |
| 159 | 1.3.6.1 | **PP Impact Assessment, Planning & Procurement** |  | 110d | 2022-10-31 A | 2023-03-31 A |  | 100% |  | 2022-10-31 | 2023-03-31 | 110d | 2022-10-31 | 2023-03-31 |  |  | N/A | N/A | 5.0 | N/A | Design, Build & Test (PIT) |  |  |  |  |  |  |
| 160 | 1.3.6.1.1 | **PP Impact Assessment** |  | 67d | 2022-10-31 A | 2023-01-31 A |  | 100% |  | 2022-10-31 | 2023-01-31 | 67d | 2022-10-31 | 2023-01-31 |  |  | N/A | N/A | 5.0 | N/A | Design, Build & Test (PIT) |  |  |  |  |  |  |
| 161 | 1.3.6.1.1.1 | Develop heatmap for impact of MHHS |  | 67d | 2022-10-31 A | 2023-01-31 A | 48 | 100% |  | 2022-10-31 | 2023-01-31 | 67d | 2022-10-31 | 2023-01-31 |  |  | PP |  | 5.0 | PP | Design, Build & Test (PIT) | Complete | COMPLETE |  |  |  |  |
| 162 | 1.3.6.1.1.2 | Develop detailed impact assessment |  | 67d | 2022-10-31 A | 2023-01-31 A | 48 | 100% |  | 2022-10-31 | 2023-01-31 | 67d | 2022-10-31 | 2023-01-31 |  |  | PP |  | 5.0 | PP | Design, Build & Test (PIT) | Complete | COMPLETE |  |  |  |  |
| 163 | 1.3.6.1.2 | **PP Planning** |  | 67d | 2022-10-31 A | 2023-01-31 A |  | 100% |  | 2022-10-31 | 2023-01-31 | 67d | 2022-10-31 | 2023-01-31 |  |  | N/A | N/A | 5.0 | N/A | Design, Build & Test (PIT) |  |  |  |  |  |  |
| 164 | 1.3.6.1.2.1 | Develop detailed short-term plan |  | 23d | 2022-10-31 A | 2022-11-30 A | 48 | 100% |  | 2022-10-31 | 2022-11-30 | 23d | 2022-10-31 | 2022-11-30 |  |  | PP |  | 5.0 | PP | Design, Build & Test (PIT) | Complete | COMPLETE |  |  |  |  |
| 165 | 1.3.6.1.2.2 | Develop overall project plan for implementation |  | 67d | 2022-10-31 A | 2023-01-31 A | 48 | 100% |  | 2022-10-31 | 2023-01-31 | 67d | 2022-10-31 | 2023-01-31 |  |  | PP |  | 5.0 | PP | Design, Build & Test (PIT) | Complete | COMPLETE |  |  |  |  |
| 166 | 1.3.6.1.2.3 | Develop procurement plan |  | 67d | 2022-10-31 A | 2023-01-31 A | 48 | 100% |  | 2022-10-31 | 2023-01-31 | 67d | 2022-10-31 | 2023-01-31 |  |  | PP |  | 5.0 | PP | Design, Build & Test (PIT) | Complete | COMPLETE |  |  |  |  |
| 167 | 1.3.6.1.3 | **PP Software/Service Procurement** |  | 110d | 2022-10-31 A | 2023-03-31 A |  | 100% |  | 2022-10-31 | 2023-03-31 | 110d | 2022-10-31 | 2023-03-31 |  |  | N/A | N/A | 5.0 | N/A | Design, Build & Test (PIT) |  |  |  |  |  |  |
| 168 | 1.3.6.1.3.1 | Run tender process |  | 67d | 2022-10-31 A | 2023-01-31 A | 48 | 100% |  | 2022-10-31 | 2023-01-31 | 67d | 2022-10-31 | 2023-01-31 |  |  | PP |  | 5.0 | PP | Design, Build & Test (PIT) | Complete | COMPLETE |  |  |  |  |
| 169 | 1.3.6.1.3.2 | Select provider & sign commercials |  | 43d | 2023-02-01 A | 2023-03-31 A | 168 | 100% |  | 2023-02-01 | 2023-03-31 | 43d | 2023-02-01 | 2023-03-31 |  |  | PP |  | 5.0 | PP | Design, Build & Test (PIT) | Complete | COMPLETE |  |  |  |  |
| 170 | 1.3.6.2 | **Central Systems DBT** |  | 325d | 2022-10-31 A | 2024-01-26 A |  | 100% |  | 2022-10-31 | 2024-02-23 | 345d | 2022-10-31 | 2024-05-13 |  | -0 | N/A | N/A | 5.0 | N/A | Design, Build & Test (PIT) |  |  | -316.67 |  |  |  |
| 171 | 1.3.6.2.1 | **Elexon Central Systems DBT CIT (Entering at Interval 1)** |  | 248d | 2022-10-31 A | 2023-10-11 A |  | 100% |  | 2022-10-31 | 2023-10-12 | 249d | 2022-10-31 | 2023-09-29 |  | -0 | N/A | N/A | 5.0 | N/A | Design, Build & Test (PIT) |  |  |  |  |  |  |
| 172 | 1.3.6.2.1.1 | **Design and Build** |  | 235d | 2022-10-31 A | 2023-09-22 A |  | 100% |  | 2022-10-31 | 2023-09-29 | 240d | 2022-10-31 | 2023-09-29 |  |  | N/A | N/A | 5.0 | N/A | Design, Build & Test (PIT) |  |  | -259.67 |  |  |  |
| 173 | 1.3.6.2.1.1.1 | Helix Design and Build |  | 235d | 2022-10-31 A | 2023-09-22 A | 2 | 100% |  | 2022-10-31 | 2023-09-29 | 240d | 2022-10-31 | 2023-09-29 |  |  | PP | SI Test | 5.0 | Lee Cox | Design, Build & Test (PIT) | Complete | COMPLETE |  |  |  |  |
| 174 | 1.3.6.2.1.2 | **Test Approach & Plan** |  | 235d | 2022-10-31 A | 2023-09-22 A |  | 100% |  | 2022-10-31 | 2023-09-22 | 235d | 2022-10-31 | 2023-07-21 |  | -0 | N/A | N/A | 5.0 | N/A | Design, Build & Test (PIT) |  |  |  |  |  |  |
| 175 | 1.3.6.2.1.2.1 | Develop Test Approach & Plan |  | 180d | 2022-10-31 A | 2023-07-07 A |  | 100% |  | 2022-10-31 | 2023-07-07 | 180d | 2022-10-31 | 2023-07-07 |  |  | PP | SI Test | 5.0 | Lee Cox | Design, Build & Test (PIT) | Complete | COMPLETE |  |  |  |  |
| 176 | 1.3.6.2.1.2.2 | Elexon Central Systems Test Approach & Plan (PIT) submitted to Programme for assurance | milestone | 0d | 2023-07-13 A | 2023-07-13 A | 175FF+4d | 100% |  | 2023-07-13 | 2023-07-13 | 0d | 2023-07-07 | 2023-07-07 |  |  | PP | SI Test | 5.0 | Lee Cox | Design, Build & Test (PIT) | Complete | COMPLETE |  | T3-DB-0029 | SITAG | T3 |
| 177 | 1.3.6.2.1.2.3 | Elexon Central Systems Test Approach & Plan (PIT) V2 resubmitted to Programme for assurance | milestone, manual | 0d | 2023-07-27 A | 2023-07-27 A | 176FS+9d | 100% |  | 2023-07-27 | 2023-07-27 | 0d |  |  |  |  | PP | SI Test | 5.4 | Lee Cox | Design, Build & Test (PIT) | Complete | COMPLETE |  |  |  |  |
| 178 | 1.3.6.2.1.2.4 | Elexon Central Systems Test Approach & Plan (PIT) V3 resubmitted to Programme for assurance | milestone | 0d | 2023-08-18 A | 2023-08-18 A | 177FS+17d | 100% |  | 2023-08-18 | 2023-08-18 | 0d |  |  |  |  | PP | SI Test | 5.4 | Lee Cox | Design, Build & Test (PIT) | Complete | COMPLETE |  |  |  |  |
| 179 | 1.3.6.2.1.2.5 | Elexon Central Systems Test approach and plan MHHS Review Completed | milestone | 0d | 2023-09-22 A | 2023-09-22 A | 178FS+25d | 100% |  | 2023-09-22 | 2023-09-22 | 0d | 2023-07-10 | 2023-07-21 |  |  | SI Test | PP | 5.8 | Lee Cox | Design, Build & Test (PIT) | Complete | COMPLETE |  | T3-DB-0106 | SITAG | T3 |
| 180 | 1.3.6.2.1.3 | **Test Readiness Report** |  | 16d | 2023-07-28 A | 2023-08-18 A |  | 100% |  | 2023-08-03 | 2023-10-12 | 51d | 2023-07-21 | 2023-09-29 |  |  | N/A | N/A | 5.0 | N/A | Design, Build & Test (PIT) |  |  |  |  |  |  |
| 181 | 1.3.6.2.1.3.1 | Test readiness reporting |  | 16d | 2023-07-28 A | 2023-08-18 A | 176FS+10d | 100% |  | 2023-08-03 | 2023-10-12 | 51d | 2023-07-21 | 2023-09-29 |  |  | PP | 109 | 5.0 | Lee Cox | Design, Build & Test (PIT) | Complete | COMPLETE |  |  |  |  |

Notes:
- 179: 1/9 - to be raised as new T3 at TMAG. Approved at TMAG on 20/9

| ID | WBS | Task | Type | Duration | Start | Finish | Predecessors | Complete | Baseline start | Baseline finish | Baseline duration | Baseline 1 start | Baseline 1 finish | Constraint | Baseline cost | Responsible | Involved | Update Version | MHHS Resource Name | MHHS Programme Phase | Artefact ID | Sched Status | RAG | Milestone ID | Text29 | Tier |
| --- | --- | --- | --- | --- | --- | --- | --- | --- | --- | --- | --- | --- | --- | --- | --- | --- | --- | --- | --- | --- | --- | --- | --- | --- | --- | --- |
| 182 | 1.3.6.2.1.4 | **Requirements to test Traceability Matrix (RTTM)** |  | 35d | 2023-08-04 A | 2023-09-22 A |  | 100% | 2023-08-04 | 2023-09-22 | 35d | 2022-10-31 | 2023-08-18 |  | -0 | N/A | N/A | 5.0 | N/A | Design, Build & Test (PIT) |  |  |  |  |  |  |
| 183 | 1.3.6.2.1.4.1 | Elexon Central Systems RTTM submitted to Programme for assurance | milestone | 0d | 2023-08-04 A | 2023-08-04 A | 176 | 100% | 2023-08-04 | 2023-08-04 | 0d | 2023-08-04 | 2023-08-04 | start no earlier than 2023-04-28 |  | PP | SI Test | 5.0 | Lee Cox | Design, Build & Test (PIT) | MHHS-ART009 | Complete | COMPLETE | T3-DB-0030 | SITAG | T3 |
| 184 | 1.3.6.2.1.4.2 | Elexon Central Systems RTTM MHHS Review Completed | milestone | 0d | 2023-09-22 A | 2023-09-22 A | 183FS+35d | 100% | 2023-09-22 | 2023-09-22 | 0d | 2023-08-07 | 2023-08-18 |  |  | SI Test | PP | 5.8 | Lee Cox | Design, Build & Test (PIT) |  | Complete | COMPLETE | T3-DB-0107 | SITAG | T3 |
| 185 | 1.3.6.2.1.5 | **Test Scenarios** |  | 35d | 2023-08-04 A | 2023-09-22 A |  | 100% | 2023-08-04 | 2023-09-22 | 35d | 2022-10-31 | 2023-08-18 |  | -0 | N/A | N/A | 5.0 | N/A | Design, Build & Test (PIT) |  |  |  |  |  |  |
| 186 | 1.3.6.2.1.5.1 | Elexon Central Systems test scenarios submitted to Programme for assurance | milestone | 0d | 2023-08-04 A | 2023-08-04 A | 176 | 100% | 2023-08-04 | 2023-08-04 | 0d | 2023-08-04 | 2023-08-04 |  |  | PP | SI Test | 5.0 | Lee Cox | Design, Build & Test (PIT) |  | Complete | COMPLETE | T3-DB-0032 | SITAG | T3 |
| 187 | 1.3.6.2.1.5.2 | Elexon Central Systems Test scenarios MHHS Review Completed | milestone | 0d | 2023-09-22 A | 2023-09-22 A | 186FS+35d | 100% | 2023-09-22 | 2023-09-22 | 0d | 2023-08-07 | 2023-08-18 |  |  | SI Test | PP | 5.8 | Lee Cox | Design, Build & Test (PIT) |  | Complete | COMPLETE | T3-DB-0108 | SITAG | T3 |
| 188 | 1.3.6.2.1.6 | **PIT Execution** |  | 38d | 2023-08-21 A | 2023-10-11 A |  | 100% | 2022-10-31 | 2023-10-11 | 248d | 2022-10-31 | 2023-09-29 |  | -0 | N/A | N/A | 5.0 | N/A | Design, Build & Test (PIT) |  |  |  |  |  |  |
| 189 | 1.3.6.2.1.6.1 | PIT Test Execution Progress Report |  | 18d | 2023-09-04 A | 2023-09-27 A | 181FS+10d | 100% | 2022-10-31 | 2023-09-22 | 235d | 2022-10-31 | 2023-09-22 |  |  | PP | SI Test | 5.1 | Lee Cox | Design, Build & Test (PIT) |  | Complete | COMPLETE |  |  |  |
| 190 | 1.3.6.2.1.6.2 | Elexon Central Systems PIT Execution |  | 28d | 2023-08-21 A | 2023-09-27 A | 181 | 100% | 2022-11-08 | 2023-10-09 | 240d | 2022-10-31 | 2023-09-29 |  |  | PP | SI Test | 5.1 | Lee Cox | Design, Build & Test (PIT) |  | Complete | COMPLETE |  |  |  |
| 191 | 1.3.6.2.1.6.3 | Elexon Central Systems PIT Completion Report submitted to Programme for assurance | milestone | 0d | 2023-09-27 A | 2023-09-27 A | 190 | 100% | 2023-09-27 | 2023-09-27 | 0d | 2024-01-05 | 2024-01-05 |  |  | PP | SI Test | 5.8 | Lee Cox | Design, Build & Test (PIT) |  | Complete | COMPLETE | T3-DB-0109 | SITAG | T3 |
| 192 | 1.3.6.2.1.6.4 | Elexon Central Systems PIT Completion Report MHHS Review Completed | milestone | 0d | 2023-10-11 A | 2023-10-11 A | 184, 187, 189, 191FS+10d, 179 | 100% | 2023-10-11 | 2023-10-11 | 0d |  |  |  |  | SI Test | PP | 5.8 | Lee Cox | Design, Build & Test (PIT) |  | Complete | COMPLETE | T3-DB-0110 | SITAG | T3 |
| 193 | 1.3.6.2.2 | **DIP DBT CIT (Entering at Interval 1)** |  | 221d | 2023-01-02 A | 2023-11-06 A |  | 100% | 2022-10-31 | 2023-11-06 | 266d | 2022-10-31 | 2023-09-29 |  | -0 | N/A | N/A | 5.0 | N/A | Design, Build & Test (PIT) |  |  |  |  |  |  |
| 194 | 1.3.6.2.2.1 | Design |  | 80d | 2023-01-02 A | 2023-04-21 A |  | 100% | 2023-01-02 | 2023-04-21 | 80d | 2023-01-02 | 2023-04-21 | must start on 2023-01-02 |  | PP | SI Design | 5.0 | Lee Cox | Design, Build & Test (PIT) |  | Complete | COMPLETE |  |  |  |
| 195 | 1.3.6.2.2.2 | Build |  | 155d | 2023-01-09 A | 2023-08-11 A | 194SS+5d | 100% | 2023-01-09 | 2023-08-11 | 155d | 2023-01-09 | 2023-08-11 |  |  | PP |  | 5.5 | Lee Cox | Design, Build & Test (PIT) |  | Complete | COMPLETE |  |  |  |
| 196 | 1.3.6.2.2.3 | **Test Approach & Plan** |  | 9d | 2023-07-07 A | 2023-07-20 A |  | 100% | 2022-10-31 | 2023-07-21 | 190d | 2022-10-31 | 2023-07-21 |  |  | N/A | N/A | 5.0 | N/A | Design, Build & Test (PIT) |  |  |  |  |  |  |
| 197 | 1.3.6.2.2.3.1 | DIP Test Approach & Plan (PIT) submitted to Programme for assurance | milestone | 0d | 2023-07-07 A | 2023-07-07 A |  | 100% | 2023-07-07 | 2023-07-07 | 0d | 2023-07-07 | 2023-07-07 |  |  | PP | SI Test | 5.0 | Lee Cox | Design, Build & Test (PIT) | MHHS-ART073 | Complete | COMPLETE | T3-DB-0026 | SITAG | T3 |
| 198 | 1.3.6.2.2.3.2 | DIP Test Approach & Plan (PIT) MHHS Review Completed | milestone | 0d | 2023-07-20 A | 2023-07-20 A | 197FS+9d | 100% | 2023-07-10 | 2023-07-21 | 10d | 2023-07-10 | 2023-07-21 |  |  | SI Test | PP | 5.0 | Lee Cox | Design, Build & Test (PIT) |  | Complete | COMPLETE |  |  |  |
| 199 | 1.3.6.2.2.4 | **PIT Test Readiness Report** |  | 31d | 2023-07-21 A | 2023-09-01 A |  | 100% | 2023-07-21 | 2023-09-29 | 51d | 2023-07-21 | 2023-09-29 |  |  | N/A | N/A | 5.0 | N/A | Design, Build & Test (PIT) |  |  |  |  |  |  |
| 200 | 1.3.6.2.2.4.1 | Test readiness reporting |  | 31d | 2023-07-21 A | 2023-09-01 A | 197FS+9d | 100% | 2023-07-21 | 2023-09-29 | 51d | 2023-07-21 | 2023-09-29 |  |  | SI Test | 109 | 5.0 | Lee Cox | Design, Build & Test (PIT) |  | Complete | COMPLETE |  |  |  |
| 201 | 1.3.6.2.2.5 | **Requirements to test Traceability Matrix (RTTM)** |  | 18d | 2023-08-04 A | 2023-08-30 A |  | 100% | 2022-10-31 | 2023-08-18 | 210d | 2022-10-31 | 2023-08-18 |  |  | N/A | N/A | 5.0 | N/A | Design, Build & Test (PIT) |  |  |  |  |  |  |
| 202 | 1.3.6.2.2.5.1 | DIP RTTM submitted to Programme for assurance | milestone | 0d | 2023-08-04 A | 2023-08-04 A | 197FS+15d | 100% | 2023-08-04 | 2023-08-04 | 0d | 2023-08-04 | 2023-08-04 |  |  | PP | SI Test | 5.6 | Lee Cox | Design, Build & Test (PIT) | MHHS-ART009 | Complete | COMPLETE | T3-DB-0034 | SITAG | T3 |
| 203 | 1.3.6.2.2.5.2 | DIP RTTM MHHS Review Completed | milestone | 0d | 2023-08-30 A | 2023-08-30 A | 202FS+18d | 100% | 2023-08-07 | 2023-08-18 | 10d | 2023-08-07 | 2023-08-18 |  |  | SI Test | PP | 5.0 | Lee Cox | Design, Build & Test (PIT) |  | Complete | COMPLETE |  |  |  |
| 204 | 1.3.6.2.2.6 | **Test Scenarios** |  | 22d | 2023-07-31 A | 2023-08-30 A |  | 100% | 2022-10-31 | 2023-08-14 | 206d | 2022-10-31 | 2023-08-18 |  |  | N/A | N/A | 5.0 | N/A | Design, Build & Test (PIT) |  |  |  |  |  |  |
| 205 | 1.3.6.2.2.6.1 | DIP PIT test scenarios submitted to Programme for assurance | milestone | 0d | 2023-07-31 A | 2023-07-31 A | 197FS+15d | 100% | 2023-07-31 | 2023-07-31 | 0d | 2023-08-04 | 2023-08-04 |  |  | PP | SI Test | 5.0 | Lee Cox | Design, Build & Test (PIT) |  | Complete | COMPLETE | T3-DB-0036 | SITAG | T3 |
| 206 | 1.3.6.2.2.6.2 | DIP Test scenarios MHHS Review Completed | milestone | 0d | 2023-08-30 A | 2023-08-30 A | 205FS+22d | 100% | 2023-08-01 | 2023-08-14 | 10d | 2023-08-07 | 2023-08-18 |  |  | SI Test | PP | 5.0 | Lee Cox | Design, Build & Test (PIT) |  | Complete | COMPLETE |  |  |  |

Notes:
- 184: 1/9 - to be raised as new T3 at TMAG. Approved at TMAG on 20/9
- 187: 1/9 - to be raised as new T3 at TMAG. Approved at TMAG on 20/9
- 191: 1/9 - to be raised as new T3 at TMAG. Approved at TMAG on 20/9
- 192: 1/9 - to be raised as new T3 at TMAG. Approved at TMAG on 20/9
- 200: Action: 14/8 - Query from RG - IS this an SI Test deliverable or expected to be a DIP deliverable if so be more specific
- 202: RG confirmed Submitted on 10/8/23

| ID | WBS | Task | Type | Duration | Start | Finish | Predecessors | Complete | Baseline start | Baseline finish | Baseline duration | Baseline 1 start | Baseline 1 finish | Constraint | Baseline cost | Responsible | Involved | Update Version | MHHS Resource Name | MHHS Programme Phase | Sched Status | RAG | Milestone ID | Text29 | Tier |
| --- | --- | --- | --- | --- | --- | --- | --- | --- | --- | --- | --- | --- | --- | --- | --- | --- | --- | --- | --- | --- | --- | --- | --- | --- | --- |
| 207 | 1.3.6.2.2.7 | **PIT execution** |  | 50d | 2023-08-29 A | 2023-11-06 A |  | 100% | 2023-09-01 | 2023-11-06 | 47d | 2022-10-31 | 2023-09-29 |  | -0 | N/A | N/A | 5.0 | N/A | Design, Build & Test (PIT) |  |  |  |  |  |
| 208 | 1.3.6.2.2.7.1 | PIT Test Execution Progress Report |  | 37d | 2023-09-01 A | 2023-10-23 A | 209FF, 200 | 100% | 2023-09-01 | 2023-10-23 | 37d | 2022-10-31 | 2023-09-22 | start no earlier than 2023-08-29 |  | PP | SI Test | 5.6 | Lee Cox | Design, Build & Test (PIT) | Complete | COMPLETE |  |  |  |
| 209 | 1.3.6.2.2.7.2 | PIT Execution (Interim Release 1) |  | 30d | 2023-08-29 A | 2023-10-09 A |  | 100% | 2023-09-06 | 2023-10-09 | 24d | 2022-10-31 | 2023-09-29 | start no earlier than 2023-08-29 |  | PP | SI Test | 5.6 | Lee Cox | Design, Build & Test (PIT) | Complete | COMPLETE |  |  |  |
| 210 | 1.3.6.2.2.7.3 | PIT Execution (Interim Release 2) |  | 10d | 2023-10-10 A | 2023-10-23 A | 209 | 100% | 2023-10-10 | 2023-10-23 | 10d |  |  |  |  | PP | SI Test | 5.6 | Lee Cox | Design, Build & Test (PIT) | Complete | COMPLETE |  |  |  |
| 211 | 1.3.6.2.2.7.4 | DIP PIT Completion Report (Interim Release 1) submitted to Programme for assurance | milestone | 0d | 2023-10-09 A | 2023-10-09 A | 209 | 100% | 2023-10-09 | 2023-10-09 | 0d | 2024-01-05 | 2024-01-05 |  |  | PP | SI Test | 5.8 | Lee Cox | Design, Build & Test (PIT) | Complete | COMPLETE | T3-DB-0111 | SITAG | T3 |
| 212 | 1.3.6.2.2.7.5 | DIP PIT Completion Report (Interim Release 1) MHHS Review Completed | milestone | 0d | 2023-10-23 A | 2023-10-23 A | 211FS+10d | 100% | 2023-10-23 | 2023-10-23 | 0d |  |  |  |  | SI Test | SI Test | 5.10 | Lee Cox | Design, Build & Test (PIT) | Complete | COMPLETE | T3-DB-0112 | SITAG | T3 |
| 213 | 1.3.6.2.2.7.6 | DIP PIT Completion Report (Interim Release 2) submitted to Programme for assurance | milestone | 0d | 2023-10-23 A | 2023-10-23 A | 210, 208 | 100% | 2023-10-23 | 2023-10-23 | 0d | 2024-01-05 | 2024-01-05 |  |  | PP | SI Test | 5.10 | Lee Cox | Design, Build & Test (PIT) | Complete | COMPLETE | T3-DB-0113 | SITAG | T3 |
| 214 | 1.3.6.2.2.7.7 | DIP PIT Completion Report (Interim Release 2) MHHS Review Completed | milestone | 0d | 2023-11-06 A | 2023-11-06 A | 213FS+10d | 100% | 2023-11-06 | 2023-11-06 | 0d |  |  |  |  | SI Test | SI Test | 5.14 | Lee Cox | Design, Build & Test (PIT) | Complete | COMPLETE | T3-DB-0114 | SITAG | T3 |
| 215 | 1.3.6.2.3 | **DCC (DSP) DBT SIT Functional (Entering at SIT Functional)** |  | 325d | 2022-10-31 A | 2024-01-26 A |  | 100% | 2022-10-31 | 2024-02-23 | 345d | 2022-10-31 | 2024-01-05 |  | -0 | N/A | N/A | 5.18 | N/A | Design, Build & Test (PIT) |  |  |  |  |  |
| 216 | 1.3.6.2.3.1 | Design |  | 67d | 2022-10-31 A | 2023-01-31 A |  | 100% | 2022-10-31 | 2023-01-31 | 67d | 2022-10-31 | 2023-01-31 |  |  | PP | SI Design | 5.18 | Lee Cox | Design, Build & Test (PIT) | Complete | COMPLETE |  |  |  |
| 217 | 1.3.6.2.3.2 | **Test Approach & Plan** |  | 20d | 2023-11-17 A | 2023-12-15 A |  | 100% | 2023-11-17 | 2023-12-15 | 20d | 2022-10-31 | 2023-10-27 |  | -0 | N/A | N/A | 5.18 | N/A | Design, Build & Test (PIT) |  |  |  |  |  |
| 218 | 1.3.6.2.3.2.1 | DCC Test Approach & Plan (PIT) submitted to Programme for assurance | milestone | 0d | 2023-11-17 A | 2023-11-17 A | 216FS+208d | 100% | 2023-11-17 | 2023-11-17 | 0d | 2023-10-13 | 2023-10-13 |  |  | PP | SI Test | 5.18 | Lee Cox | Design, Build & Test (PIT) | Complete | COMPLETE | T3-DB-0068 | SITAG | T3 |
| 219 | 1.3.6.2.3.2.2 | DCC Test Approach & Plan (PIT) MHHS Review Completed | milestone | 0d | 2023-12-15 A | 2023-12-15 A | 218FS+20d | 100% | 2023-12-15 | 2023-12-15 | 0d | 2023-10-16 | 2023-10-27 |  |  | SI Test | PP | 5.18 | Lee Cox | Design, Build & Test (PIT) | Complete | COMPLETE | T3-DB-0115 | SITAG | T3 |
| 220 | 1.3.6.2.3.3 | **Test Readiness Report** |  | 22d | 2023-12-04 A | 2024-01-02 A |  | 100% | 2023-10-27 | 2024-01-05 | 51d | 2023-10-27 | 2024-01-05 |  |  | N/A | N/A | 5.18 | N/A | Design, Build & Test (PIT) |  |  |  |  |  |
| 221 | 1.3.6.2.3.3.1 | Test readiness reporting |  | 22d | 2023-12-04 A | 2024-01-02 A | 218FS+10d | 100% | 2023-10-27 | 2024-01-05 | 51d | 2023-10-27 | 2024-01-05 |  |  | PP | 109 | 5.18 | Lee Cox | Design, Build & Test (PIT) | Complete | COMPLETE |  |  |  |
| 222 | 1.3.6.2.3.4 | **Requirements to test Traceability Matrix (RTTM)** |  | 30d | 2023-12-15 A | 2024-01-26 A |  | 100% | 2023-12-15 | 2024-01-26 | 30d | 2022-10-31 | 2023-11-24 |  | -0 | N/A | N/A | 5.18 | N/A | Design, Build & Test (PIT) |  |  |  |  |  |
| 223 | 1.3.6.2.3.4.1 | DCC RTTM submitted to Programme for assurance | milestone | 0d | 2023-12-15 A | 2023-12-15 A | 218FS+20d | 100% | 2023-12-15 | 2023-12-15 | 0d | 2023-11-10 | 2023-11-10 | start no earlier than 2023-04-28 |  | PP | SI Test | 5.18 | Lee Cox | Design, Build & Test (PIT) | Complete | COMPLETE | T3-DB-0074 | SITAG | T3 |
| 224 | 1.3.6.2.3.4.2 | DCC RTTM MHHS Review Completed | milestone | 0d | 2024-01-26 A | 2024-01-26 A | 223FS+30d | 100% | 2024-01-26 | 2024-01-26 | 0d | 2023-11-13 | 2023-11-24 |  |  | SI Test | PP | 5.18 | Lee Cox | Design, Build & Test (PIT) | Complete | COMPLETE | T3-DB-0116 | SITAG | T3 |
| 225 | 1.3.6.2.3.5 | **Test Scenarios** |  | 30d | 2023-12-15 A | 2024-01-26 A |  | 100% | 2023-12-15 | 2024-01-26 | 30d | 2022-10-31 | 2023-11-24 |  | -0 | N/A | N/A | 5.18 | N/A | Design, Build & Test (PIT) |  |  |  |  |  |
| 226 | 1.3.6.2.3.5.1 | DCC test scenarios submitted to Programme for assurance | milestone | 0d | 2023-12-15 A | 2023-12-15 A | 218FS+20d | 100% | 2023-12-15 | 2023-12-15 | 0d | 2023-11-10 | 2023-11-10 |  |  | PP | SI Test | 5.18 | Lee Cox | Design, Build & Test (PIT) | Complete | COMPLETE | T3-DB-0078 | SITAG | T3 |
| 227 | 1.3.6.2.3.5.2 | DCC Test Scenarios MHHS Review Completed | milestone | 0d | 2024-01-26 A | 2024-01-26 A | 226FS+30d | 100% | 2024-01-26 | 2024-01-26 | 0d | 2023-11-13 | 2023-11-24 |  |  | SI Test | PP | 5.18 | Lee Cox | Design, Build & Test (PIT) | Complete | COMPLETE | T3-DB-0117 | SITAG | T3 |
| 228 | 1.3.6.2.4 | **RECCo (EES) DBT CIT (Entering at Interval 6)** |  | 71d | 2023-10-13 A | 2024-01-19 A |  | 100% | 2022-10-31 | 2024-01-19 | 320d | 2022-10-31 | 2024-01-05 |  | -0 | N/A | N/A | 5.0 | N/A | Design, Build & Test (PIT) |  |  |  |  |  |
| 229 | 1.3.6.2.4.1 | **Test Approach & Plan** |  | 20d | 2023-10-13 A | 2023-11-09 A |  | 100% | 2023-10-13 | 2023-11-09 | 20d | 2022-10-31 | 2023-10-27 |  | -0 | N/A | N/A | 5.0 | N/A | Design, Build & Test (PIT) |  |  |  |  |  |
| 230 | 1.3.6.2.4.1.1 | EES Test Approach & Plan (PIT) submitted to Programme for assurance | milestone | 0d | 2023-10-13 A | 2023-10-13 A |  | 100% | 2023-10-13 | 2023-10-13 | 0d | 2023-10-13 | 2023-10-13 | start no earlier than 2023-10-13 |  | PP | SI Test | 5.8 | Lee Cox | Design, Build & Test (PIT) | Complete | COMPLETE | T3-DB-0066 | SITAG | T3 |
| 231 | 1.3.6.2.4.1.2 | EES Test approach and plan (PIT) MHHS Review Completed | milestone | 0d | 2023-11-09 A | 2023-11-09 A | 230FS+20d | 100% | 2023-11-09 | 2023-11-09 | 0d | 2023-10-16 | 2023-10-27 |  |  | SI Test | PP | 5.8 | Lee Cox | Design, Build & Test (PIT) | Complete | COMPLETE | T3-DB-0119 | SITAG | T3 |

Notes:
- 208: 21/8 - due to complete 9/10 - advised by RG
- 209: 21/8 - due to complete 9/10 - advised by RG
- 210: 21/8 - new line added date are 9/10 - 23/10 - advised by RG.
- 211: 1/9 - to be raised as new T3 at TMAG. Approved at TMAG on 20/9. 9/10 - RG - After discussions with DM it was decided a completion report for IR1 wasn't required as we are entering IR2 ahead of schedule & draft completion report already submitted & assured
- 212: 1/9 - to be raised as new T3 at TMAG. Approved at TMAG on 20/9
- 213: 1/9 - to be raised as new T3 at TMAG. Approved at TMAG on 20/9
- 214: 7/11- Red because further clarity around remaining open low severity defect work off plan requested. No impact. Completed on 8/12 / Guidance: 6/10 - LC - Successor should be SIT Component Integration Testing 1 Preparation Complete but not linked as DIP test completion plus 10 day review breaks logic. Decision will be made to proceed without a conclusion of the report review
- 218: 21/11- Red because not received. Currently no impact. 30/1 - Completed on 26/1
- 219: 1/9 - to be raised as new T3 at TMAG DCC no longer in CIT, new dates relate to SIT Functional. Approved at TMAG on 20/9. 19/12 - Red because not received
- 223: 19/12- Red because not received. 30/1 - Completed on 26/1
- 224: 23/1- Amber because of potential late delivery of RTTM. No impact. No action. 30/1 - Completed on 26/1
- 226: 5/12- Red because of late delivery of PIT approach and plan. No impact. No action. 30/1 - Completed on 26/1
- 227: 23/1- Amber because of potential late delivery of test scenarios. No impact. No action. 30/1 - Completed on 26/1
- 228: Assumption that Migration/Reverse Migration DBT is not applicable to RECCo.
- 230: 12/9 - TMAG for name change. Approved at TMAG on 20/9. 17/10 - Red because document not yet received. No impact currently. Issuance from RECCo requested
- 231: 1/9 - to be raised as new T3 at TMAG. Approved at TMAG on 20/9. 17/10 - Amber because Late delivery of document plus earlier intervals backlog. Currently no impact

| ID | WBS | Task | Type | Duration | Start | Finish | Predecessors | Complete | Baseline start | Baseline finish | Baseline duration | Baseline 1 start | Baseline 1 finish | Constraint | Baseline cost | Responsible | Involved | Update Version | MHHS Resource Name | MHHS Programme Phase | Sched Status | RAG | Artefact ID | Milestone ID | Text29 | Tier |
| --- | --- | --- | --- | --- | --- | --- | --- | --- | --- | --- | --- | --- | --- | --- | --- | --- | --- | --- | --- | --- | --- | --- | --- | --- | --- | --- |
| 232 | 1.3.6.2.4.2 | **Test Readiness Report** |  | 10d | 2023-10-27 A | 2023-11-09 A |  | 100% | 2023-10-27 | 2024-01-05 | 51d | 2023-10-27 | 2024-01-05 |  |  | N/A | N/A | 5.0 | N/A | Design, Build & Test (PIT) |  |  |  |  |  |  |
| 233 | 1.3.6.2.4.2.1 | Test readiness reporting |  | 10d | 2023-10-27 A | 2023-11-09 A | 230FS+10d | 100% | 2023-10-27 | 2024-01-05 | 51d | 2023-10-27 | 2024-01-05 |  |  | PP | 109 | 5.0 | Lee Cox | Design, Build & Test (PIT) | Complete | COMPLETE |  |  |  |  |
| 234 | 1.3.6.2.4.3 | **Requirements to test Traceability Matrix (RTTM)** |  | 20d | 2023-11-02 A | 2023-11-30 A |  | 100% | 2023-11-02 | 2023-11-30 | 20d | 2022-10-31 | 2023-11-24 |  | -0 | N/A | N/A | 5.0 | N/A | Design, Build & Test (PIT) |  |  |  |  |  |  |
| 235 | 1.3.6.2.4.3.1 | EES RTTM submitted to Programme for assurance | milestone | 0d | 2023-11-02 A | 2023-11-02 A | 230FS+15d | 100% | 2023-11-02 | 2023-11-02 | 0d | 2023-11-10 | 2023-11-10 |  |  | PP | SI Test | 5.8 | Lee Cox | Design, Build & Test (PIT) | Complete | COMPLETE | MHHS-ART009 | T3-DB-0072 | SITAG | T3 |
| 236 | 1.3.6.2.4.3.2 | EES RTTM MHHS Review Completed | milestone | 0d | 2023-11-30 A | 2023-11-30 A | 235FS+20d | 100% | 2023-11-30 | 2023-11-30 | 0d | 2023-11-13 | 2023-11-24 |  |  | SI Test | PP | 5.14 | Lee Cox | Design, Build & Test (PIT) | Complete | COMPLETE |  | T3-DB-0120 | SITAG | T3 |
| 237 | 1.3.6.2.4.4 | **Test Scenarios** |  | 20d | 2023-11-02 A | 2023-11-30 A |  | 100% | 2023-11-02 | 2023-11-30 | 20d | 2022-10-31 | 2023-11-24 |  | -0 | N/A | N/A | 5.0 | N/A | Design, Build & Test (PIT) |  |  |  |  |  |  |
| 238 | 1.3.6.2.4.4.1 | EES test scenarios submitted to Programme for assurance | milestone | 0d | 2023-11-02 A | 2023-11-02 A | 230FS+15d | 100% | 2023-11-02 | 2023-11-02 | 0d | 2023-11-10 | 2023-11-10 |  |  | PP | SI Test | 5.8 | Lee Cox | Design, Build & Test (PIT) | Complete | COMPLETE |  | T3-DB-0031 | SITAG | T3 |
| 239 | 1.3.6.2.4.4.2 | EES Test scenarios MHHS Review Completed | milestone | 0d | 2023-11-30 A | 2023-11-30 A | 238FS+20d | 100% | 2023-11-30 | 2023-11-30 | 0d | 2023-11-13 | 2023-11-24 |  |  | SI Test | PP | 5.14 | Lee Cox | Design, Build & Test (PIT) | Complete | COMPLETE |  | T3-DB-0121 | SITAG | T3 |
| 240 | 1.3.6.2.4.5 | **PIT execution** |  | 51d | 2023-11-10 A | 2024-01-19 A |  | 100% | 2022-10-31 | 2024-01-19 | 320d | 2022-10-31 | 2024-01-05 |  | -0 | N/A | N/A | 5.0 | N/A | Design, Build & Test (PIT) |  |  |  |  |  |  |
| 241 | 1.3.6.2.4.5.1 | PIT Test Execution Progress Report |  | 41d | 2023-11-10 A | 2024-01-05 A | 233 | 100% | 2023-11-10 | 2024-01-05 | 41d | 2022-10-31 | 2023-12-29 |  |  | PP | SI Test | 5.0 | Lee Cox | Design, Build & Test (PIT) | Complete | COMPLETE |  |  |  |  |
| 242 | 1.3.6.2.4.5.2 | PIT Execution |  | 41d | 2023-11-10 A | 2024-01-05 A | 238FS+5d | 100% | 2022-10-31 | 2024-01-05 | 310d | 2022-10-31 | 2024-01-05 |  |  | PP | SI Test | 5.0 | Lee Cox | Design, Build & Test (PIT) | Complete | COMPLETE |  |  |  |  |
| 243 | 1.3.6.2.4.5.3 | EES PIT Completion Report submitted to Programme for assurance | milestone | 0d | 2024-01-05 A | 2024-01-05 A | 241, 242 | 100% | 2024-01-05 | 2024-01-05 | 0d | 2024-01-05 | 2024-01-05 |  |  | PP | SI Test | 5.14 | Lee Cox | Design, Build & Test (PIT) | Complete | COMPLETE |  | T3-DB-0122 | SITAG | T3 |
| 244 | 1.3.6.2.4.5.4 | EES PIT Completion Report MHHS Review Completed | milestone | 0d | 2024-01-19 A | 2024-01-19 A | 231, 236, 239, 243FS+10d | 100% | 2024-01-19 | 2024-01-19 | 0d |  |  |  |  | SI Test | PP | 5.14 | Lee Cox | Design, Build & Test (PIT) | Complete | COMPLETE |  | T3-DB-0123 | SITAG | T3 |
| 245 | 1.3.6.2.5 | **Registration Services DBT CIT (Entering at Interval 2)** |  | 70d | 2023-07-28 A | 2023-11-03 A |  | 100% | 2023-07-28 | 2023-11-03 | 70d | 2022-10-31 | 2024-02-28 |  | -0 | N/A | N/A | 5.0 | N/A | Design, Build & Test (PIT) |  |  |  |  |  |  |
| 246 | 1.3.6.2.5.1 | **Test Approach & Plan** |  | 40d | 2023-07-28 A | 2023-09-22 A |  | 100% | 2023-07-28 | 2023-09-22 | 40d | 2022-10-31 | 2023-08-11 |  | -0 | N/A | N/A | 5.0 | N/A | Design, Build & Test (PIT) |  |  |  |  |  |  |
| 247 | 1.3.6.2.5.1.1 | Registration Services Test Approach & Plan (PIT) submitted to Programme for assurance | milestone | 0d | 2023-07-28 A | 2023-07-28 A |  | 100% | 2023-07-28 | 2023-07-28 | 0d | 2023-07-28 | 2023-07-28 |  |  | PP | SI Test | 5.0 | Lee Cox | Design, Build & Test (PIT) | Complete | COMPLETE | MHHS-ART073 | T3-DB-0028 | SITAG | T3 |
| 248 | 1.3.6.2.5.1.2 | Registration Services Test approach and plan MHHS Review Completed | milestone | 0d | 2023-09-22 A | 2023-09-22 A | 247FS+40d | 100% | 2023-09-22 | 2023-09-22 | 0d | 2023-07-31 | 2023-08-11 |  |  | SI Test | PP | 5.8 | Lee Cox | Design, Build & Test (PIT) | Complete | COMPLETE |  | T3-DB-0124 | SITAG | T3 |
| 249 | 1.3.6.2.5.2 | **Test Readiness Report** |  | 20d | 2023-08-14 A | 2023-09-08 A |  | 100% | 2023-08-11 | 2023-10-20 | 51d | 2023-08-11 | 2023-10-20 |  |  | N/A | N/A | 5.0 | N/A | Design, Build & Test (PIT) |  |  |  |  |  |  |
| 250 | 1.3.6.2.5.2.1 | Test readiness reporting |  | 20d | 2023-08-14 A | 2023-09-08 A | 247FS+10d | 100% | 2023-08-11 | 2023-10-20 | 51d | 2023-08-11 | 2023-10-20 |  |  | PP | 109 | 5.0 | Lee Cox | Design, Build & Test (PIT) | Complete | COMPLETE |  |  |  |  |
| 251 | 1.3.6.2.5.3 | **Requirements to test Traceability Matrix (RTTM)** |  | 20d | 2023-09-01 A | 2023-09-29 A |  | 100% | 2023-09-01 | 2023-09-29 | 20d | 2022-10-31 | 2023-09-15 |  | -0 | N/A | N/A | 5.0 | N/A | Design, Build & Test (PIT) |  |  |  |  |  |  |
| 252 | 1.3.6.2.5.3.1 | Registration Services RTTM submitted to Programme for assurance | milestone | 0d | 2023-09-01 A | 2023-09-01 A | 247FS+15d | 100% | 2023-09-01 | 2023-09-01 | 0d | 2023-09-01 | 2023-09-01 | start no earlier than 2023-04-28 |  | PP | SI Test | 5.6 | Lee Cox | Design, Build & Test (PIT) | Complete | COMPLETE | MHHS-ART009 | T3-DB-0042 | SITAG | T3 |
| 253 | 1.3.6.2.5.3.2 | Registration Services RTTM MHHS Review Completed | milestone | 0d | 2023-09-29 A | 2023-09-29 A | 252FS+20d | 100% | 2023-09-29 | 2023-09-29 | 0d | 2023-09-04 | 2023-09-15 |  |  | SI Test | PP | 5.8 | Lee Cox | Design, Build & Test (PIT) | Complete | COMPLETE |  | T3-DB-0125 | SITAG | T3 |
| 254 | 1.3.6.2.5.4 | **Test Scenarios** |  | 20d | 2023-09-01 A | 2023-09-29 A |  | 100% | 2023-09-01 | 2023-09-29 | 20d | 2022-10-31 | 2023-09-15 |  | -0 | N/A | N/A | 5.0 | N/A | Design, Build & Test (PIT) |  |  |  |  |  |  |
| 255 | 1.3.6.2.5.4.1 | Registration Services test scenarios submitted to Programme for assurance | milestone | 0d | 2023-09-01 A | 2023-09-01 A | 247FS+15d | 100% | 2023-09-01 | 2023-09-01 | 0d | 2023-09-01 | 2023-09-01 |  |  | PP | SI Test | 5.6 | Lee Cox | Design, Build & Test (PIT) | Complete | COMPLETE |  | T3-DB-0044 | SITAG | T3 |
| 256 | 1.3.6.2.5.4.2 | Registration Services Test scenarios MHHS Review Completed | milestone | 0d | 2023-09-29 A | 2023-09-29 A | 255FS+20d | 100% | 2023-09-29 | 2023-09-29 | 0d | 2023-09-04 | 2023-09-15 |  |  | SI Test | PP | 5.8 | Lee Cox | Design, Build & Test (PIT) | Complete | COMPLETE |  | T3-DB-0126 | SITAG | T3 |

Notes:
- 235: 7/11 - Red because not submitted. No impact. No action
- 236: 5/12- Red because Assurance conducted. Comments issued and awaiting response. No impact. No action. Completed on 15/12
- 238: 7/11 - Red because not submitted. No impact. No action
- 239: 5/12- Red because Assurance conducted. Comments issued and awaiting response. No impact. No action. Completed on 15/12
- 243: 1/9 - to be raised as new T3 at TMAG. Approved at TMAG on 20/9. 19/12 - Completed on 15/12
- 244: 1/9 - to be raised as new T3 at TMAG. Approved at TMAG on 20/9. 19/12 - Completed on 15/12
- 248: 1/9 - to be raised as new T3 at TMAG. Approved at TMAG on 20/9
- 253: 1/9 - to be raised as new T3 at TMAG. Approved at TMAG on 20/9. 4/10 - Red because small number of comments still to be resolved, will be completed no later than 3/11 ahead of Interval 2 Readiness Assessment
- 256: 1/9 - to be raised as new T3 at TMAG

| ID | WBS | Task | Type | Duration | Start | Finish | Predecessors | Complete | Remaining | Baseline start | Baseline finish | Baseline duration | Baseline 1 start | Baseline 1 finish | Total slack | Constraint | Baseline cost | Responsible | Involved | Update Version | MHHS Resource Name | MHHS Programme Phase | Sched Status | RAG | Milestone ID | Text29 | Tier |
| --- | --- | --- | --- | --- | --- | --- | --- | --- | --- | --- | --- | --- | --- | --- | --- | --- | --- | --- | --- | --- | --- | --- | --- | --- | --- | --- | --- |
| 257 | 1.3.6.2.5.5 | **PIT execution** |  | 40d | 2023-09-11 A | 2023-11-03 A |  | 100% |  | 2023-09-11 | 2023-11-03 | 40d | 2023-01-02 | 2023-10-20 |  |  | -0 | N/A | N/A | 5.0 | N/A | Design, Build & Test (PIT) |  |  |  |  |  |
| 258 | 1.3.6.2.5.5.1 | PIT Test Execution Progress Report |  | 33d | 2023-09-11 A | 2023-10-25 A | 250 | 100% |  | 2023-09-11 | 2023-10-20 | 30d | 2023-01-02 | 2023-10-13 |  |  |  | PP | SI Test | 5.0 | Lee Cox | Design, Build & Test (PIT) | Complete | COMPLETE |  |  |  |
| 259 | 1.3.6.2.5.5.2 | PIT Execution |  | 30d | 2023-09-11 A | 2023-10-20 A | 255FS+5d | 100% |  | 2023-09-11 | 2023-10-20 | 30d | 2023-01-16 | 2023-10-20 |  |  |  | PP | SI Test | 5.0 | Lee Cox | Design, Build & Test (PIT) | Complete | COMPLETE |  |  |  |
| 260 | 1.3.6.2.5.5.3 | Registration Services PIT (CIT interval 2) Completion Report submitted to Programme for assurance | milestone | 0d | 2023-10-25 A | 2023-10-25 A | 258, 259 | 100% |  | 2023-10-20 | 2023-10-20 | 0d | 2024-01-05 | 2024-01-05 |  |  |  | PP | SI Test | 5.10 | Lee Cox | Design, Build & Test (PIT) | Complete | COMPLETE | T3-DB-0127 | SITAG | T3 |
| 261 | 1.3.6.2.5.5.4 | Registration Services PIT (CIT interval 2) Completion Report MHHS Review Completed | milestone | 0d | 2023-11-03 A | 2023-11-03 A | 248, 253, 256, 260FS+7d | 100% |  | 2023-11-03 | 2023-11-03 | 0d |  |  |  |  |  | SI Test | PP | 5.11 | Lee Cox | Design, Build & Test (PIT) | Complete | COMPLETE | T3-DB-0128 | SITAG | T3 |
| 262 | 1.3.6.3 | **SIT Participants DBT** |  | 291d | 2023-08-11 A | 2024-09-20 |  | 92% | 24.07d | 2022-10-31 | 2024-09-20 | 495d | 2022-10-31 | 2025-03-14 | 0d |  | -0 | N/A | N/A | 5.0 | N/A | Design, Build & Test (PIT) |  |  |  |  |  |
| 263 | 1.3.6.3.1 | **All Data Services DBT CIT (Entering at Interval 3)** |  | 71d | 2023-08-11 A | 2023-11-17 A |  | 100% |  | 2022-10-31 | 2023-11-17 | 275d | 2022-10-31 | 2023-11-03 |  |  | -0 | N/A | N/A | 5.0 | N/A | Design, Build & Test (PIT) |  |  |  |  |  |
| 264 | 1.3.6.3.1.1 | **Test Approach & Plan** |  | 30d | 2023-08-11 A | 2023-09-21 A |  | 100% |  | 2023-08-11 | 2023-09-21 | 29d | 2022-10-31 | 2023-08-25 |  |  | -0 | N/A | N/A | 5.0 | N/A | Design, Build & Test (PIT) |  |  |  |  |  |
| 265 | 1.3.6.3.1.1.1 | All Data Services Test Approach & Plans (PIT) submitted to Programme for assurance | milestone | 0d | 2023-08-11 A | 2023-08-11 A |  | 100% |  | 2023-08-11 | 2023-08-11 | 0d | 2023-08-11 | 2023-08-11 |  | start no earlier than 2023-08-11 |  | PP | SI Test | 5.0 | Lee Cox | Design, Build & Test (PIT) | Complete | COMPLETE | T3-DB-0038 | SITAG | T3 |
| 266 | 1.3.6.3.1.1.2 | All Data Services Test approach and plans MHHS Review Completed | milestone | 0d | 2023-09-21 A | 2023-09-21 A | 265FS+30d | 100% |  | 2023-09-21 | 2023-09-21 | 0d | 2023-08-14 | 2023-08-25 |  |  |  | SI Test | PP | 5.11 | Lee Cox | Design, Build & Test (PIT) | Complete | COMPLETE | T3-DB-0129 | SITAG | T3 |
| 267 | 1.3.6.3.1.2 | **Test Readiness Report** |  | 11d | 2023-08-25 A | 2023-09-08 A |  | 100% |  | 2023-08-25 | 2023-09-08 | 11d | 2023-08-25 | 2023-11-03 |  |  | -0 | N/A | N/A | 5.0 | N/A | Design, Build & Test (PIT) |  |  |  |  |  |
| 268 | 1.3.6.3.1.2.1 | Test readiness reporting |  | 11d | 2023-08-25 A | 2023-09-08 A | 265FS+10d | 100% |  | 2023-08-25 | 2023-09-08 | 11d | 2023-08-25 | 2023-11-03 |  |  |  | PP | 109 | 5.0 | Lee Cox | Design, Build & Test (PIT) | Complete | COMPLETE |  |  |  |
| 269 | 1.3.6.3.1.3 | **Requirements to test Traceability Matrix (RTTM)** |  | 7d | 2023-09-20 A | 2023-09-29 A |  | 100% |  | 2023-09-22 | 2023-09-29 | 5d | 2022-10-31 | 2023-10-06 |  |  | -0 | N/A | N/A | 5.0 | N/A | Design, Build & Test (PIT) |  |  |  |  |  |
| 270 | 1.3.6.3.1.3.1 | All Data Services RTTMs submitted to Programme for assurance | milestone | 0d | 2023-09-20 A | 2023-09-20 A | 265FS+29d | 100% |  | 2023-09-22 | 2023-09-22 | 0d | 2023-09-22 | 2023-09-22 |  |  |  | PP | SI Test | 5.7 | Lee Cox | Design, Build & Test (PIT) | Complete | COMPLETE | T3-DB-0058 | SITAG | T3 |
| 271 | 1.3.6.3.1.3.2 | All Data Services RTTMs MHHS Review Completed | milestone | 0d | 2023-09-29 A | 2023-09-29 A | 270FS+7d | 100% |  | 2023-09-29 | 2023-09-29 | 0d | 2023-09-25 | 2023-10-06 |  |  |  | SI Test | PP | 5.8 | Lee Cox | Design, Build & Test (PIT) | Complete | COMPLETE | T3-DB-0130 | SITAG | T3 |
| 272 | 1.3.6.3.1.4 | **Test Scenarios** |  | 6d | 2023-09-20 A | 2023-09-28 A |  | 100% |  | 2023-09-22 | 2023-09-28 | 4d | 2022-10-31 | 2023-10-06 |  |  | -0 | N/A | N/A | 5.0 | N/A | Design, Build & Test (PIT) |  |  |  |  |  |
| 273 | 1.3.6.3.1.4.1 | All Data Services test scenarios' submitted to Programme for assurance | milestone | 0d | 2023-09-20 A | 2023-09-20 A | 265FS+29d | 100% |  | 2023-09-22 | 2023-09-22 | 0d | 2023-09-22 | 2023-09-22 |  |  |  | PP | SI Test | 5.7 | Lee Cox | Design, Build & Test (PIT) | Complete | COMPLETE | T3-DB-0056 | SITAG | T3 |
| 274 | 1.3.6.3.1.4.2 | All Data Services Test scenarios' MHHS Review Completed | milestone | 0d | 2023-09-28 A | 2023-09-28 A | 273FS+6d | 100% |  | 2023-09-28 | 2023-09-28 | 0d | 2023-09-25 | 2023-10-06 |  |  |  | SI Test | PP | 5.11 | Lee Cox | Design, Build & Test (PIT) | Complete | COMPLETE | T3-DB-0131 | SITAG | T3 |
| 275 | 1.3.6.3.1.5 | **PIT execution** |  | 50d | 2023-09-11 A | 2023-11-17 A |  | 100% |  | 2022-10-31 | 2023-11-17 | 275d | 2022-10-31 | 2023-11-03 |  |  | -0 | N/A | N/A | 5.0 | N/A | Design, Build & Test (PIT) |  |  |  |  |  |
| 276 | 1.3.6.3.1.5.1 | PIT Test Execution Progress Report |  | 40d | 2023-09-11 A | 2023-11-03 A | 268 | 100% |  | 2022-10-31 | 2023-10-27 | 260d | 2022-10-31 | 2023-10-27 |  |  |  | PP | SI Test | 5.0 | Lee Cox | Design, Build & Test (PIT) | Complete | COMPLETE |  |  |  |
| 277 | 1.3.6.3.1.5.2 | PIT Execution |  | 27d | 2023-09-28 A | 2023-11-03 A | 273FS+5d | 100% |  | 2022-10-31 | 2023-11-03 | 265d | 2022-10-31 | 2023-11-03 |  |  |  | PP | SI Test | 5.0 | Lee Cox | Design, Build & Test (PIT) | Complete | COMPLETE |  |  |  |
| 278 | 1.3.6.3.1.5.3 | All Data Services PIT Completion Reports submitted to Programme for assurance | milestone | 0d | 2023-11-03 A | 2023-11-03 A | 276, 277 | 100% |  | 2023-11-03 | 2023-11-03 | 0d | 2024-01-05 | 2024-01-05 |  |  |  | PP | SI Test | 5.11 | Lee Cox | Design, Build & Test (PIT) | Complete | COMPLETE | T3-DB-0132 | SITAG | T3 |
| 279 | 1.3.6.3.1.5.4 | All Data Services PIT Completion Reports MHHS Review Completed | milestone | 0d | 2023-11-17 A | 2023-11-17 A | 266, 271, 274, 278FS+10d | 100% |  | 2023-11-17 | 2023-11-17 | 0d |  |  |  |  |  | SI Test | PP | 5.13 | Lee Cox | Design, Build & Test (PIT) | Complete | COMPLETE | T3-DB-0133 | SITAG | T3 |
| 280 | 1.3.6.3.2 | **All Metering Services DBT CIT (Entering at Interval 4)** |  | 70d | 2023-08-25 A | 2023-12-01 A |  | 100% |  | 2022-10-31 | 2023-12-01 | 285d | 2022-10-31 | 2023-11-17 |  |  | -0 | N/A | N/A | 5.0 | N/A | Design, Build & Test (PIT) |  |  |  |  |  |
| 281 | 1.3.6.3.2.1 | **Test Approach & Plan** |  | 40d | 2023-08-25 A | 2023-10-20 A |  | 100% |  | 2023-08-25 | 2023-10-20 | 40d | 2022-10-31 | 2023-09-08 |  |  | -0 | N/A | N/A | 5.0 | N/A | Design, Build & Test (PIT) |  |  |  |  |  |
| 282 | 1.3.6.3.2.1.1 | All Metering Services Test Approach & Plans (PIT) submitted to Programme for assurance | milestone | 0d | 2023-08-25 A | 2023-08-25 A |  | 100% |  | 2023-08-25 | 2023-08-25 | 0d | 2023-08-25 | 2023-08-25 |  |  |  | PP | SI Test | 5.6 | Lee Cox | Design, Build & Test (PIT) | Complete | COMPLETE | T3-DB-0040 | SITAG | T3 |
| 283 | 1.3.6.3.2.1.2 | All Metering Services Test approach and plans MHHS Review Completed | milestone | 0d | 2023-10-20 A | 2023-10-20 A | 282FS+40d | 100% |  | 2023-10-20 | 2023-10-20 | 0d | 2023-08-28 | 2023-09-08 |  |  |  | SI Test | PP | 5.8 | Lee Cox | Design, Build & Test (PIT) | Complete | COMPLETE | T3-DB-0134 | SITAG | T3 |

Notes:
- 259: 17/10 - Amber because St Clements assessment. No impact. Being monitored
- 260: 1/9 - to be raised as new T3 at TMAG. Approved at TMAG on 20/9. 24/10 - Red because 3 day delay to SCS PIT completion. No impact to CIT Interval 2.
- 261: 1/9 - to be raised as new T3 at TMAG. Approved at TMAG on 20/9. 17/10 - Amber because St Clements assessment. No impact. Being monitored
- 266: 1/9 - to be raised as new T3 at TMAG. Approved at TMAG on 20/9. Red due to high volume to be reviewed. Date change under consideration. Review will be completed no later than 17/11 ahead of Interval 3 Readiness Assessment
- 271: 1/9 - to be raised as new T3 at TMAG Approved at TMAG on 20/9. Red due to high volume to be reviewed. Date change under consideration. Review will be completed no later than 17/11 ahead of Interval 3 Readiness Assessment
- 274: 1/9 - to be raised as new T3 at TMAG. Approved at TMAG on 20/9. Red due to high volume to be reviewed. Date change under consideration. Review will be completed no later than 17/11 ahead of Interval 3 Readiness Assessment
- 276: 10/10 - LC - red because date in the past, not all participants have provided reports. No impact. No action
- 277: 10/10 - LC - red because date in the past, acceptable for some participants to have not started PIT yet
- 278: 1/9 - to be raised as new T3 at TMAG. Approved at TMAG on 20/9
- 279: 1/9 - to be raised as new T3 at TMAG. Approved at TMAG on 20/9. 21/11-Red because 1 report remains outstanding due to close 22/11. Completed on 22/11
- 283: 7/10 - Red due to high volume to be reviewed. Date change under consideration. Review will be completed no later than 04/12 ahead of Interval 4 Readiness Assessment

| ID | WBS | Task | Type | Duration | Start | Finish | Predecessors | Complete | Remaining | Baseline start | Baseline finish | Baseline duration | Baseline 1 start | Baseline 1 finish | Total slack | Constraint | Baseline cost | Responsible | Involved | Update Version | MHHS Resource Name | MHHS Programme Phase | Sched Status | RAG | Artefact ID | Milestone ID | Text29 | Tier |
| --- | --- | --- | --- | --- | --- | --- | --- | --- | --- | --- | --- | --- | --- | --- | --- | --- | --- | --- | --- | --- | --- | --- | --- | --- | --- | --- | --- | --- |
| 284 | 1.3.6.3.2.2 | **Test Readiness Report** |  | 11d | 2023-09-11 A | 2023-09-25 A |  | 100% |  | 2023-09-08 | 2023-11-17 | 51d | 2023-09-08 | 2023-11-17 |  |  |  | N/A | N/A | 5.0 | N/A | Design, Build & Test (PIT) |  |  |  |  |  |  |
| 285 | 1.3.6.3.2.2.1 | Test readiness reporting |  | 11d | 2023-09-11 A | 2023-09-25 A | 282FS+10d | 100% |  | 2023-09-08 | 2023-11-17 | 51d | 2023-09-08 | 2023-11-17 |  |  |  | PP | 109 | 5.0 | Lee Cox | Design, Build & Test (PIT) | Complete | COMPLETE |  |  |  |  |
| 286 | 1.3.6.3.2.3 | **Requirements to test Traceability Matrix (RTTM)** |  | 30d | 2023-09-15 A | 2023-10-27 A |  | 100% |  | 2023-09-15 | 2023-10-27 | 30d | 2022-10-31 | 2023-09-29 |  |  | -0 | N/A | N/A | 5.0 | N/A | Design, Build & Test (PIT) |  |  |  |  |  |  |
| 287 | 1.3.6.3.2.3.1 | All Metering Services RTTMs submitted to Programme for assurance | milestone | 0d | 2023-09-15 A | 2023-09-15 A | 282FS+15d | 100% |  | 2023-09-15 | 2023-09-15 | 0d | 2023-09-15 | 2023-09-15 |  |  |  | PP | SI Test | 5.8 | Lee Cox | Design, Build & Test (PIT) | Complete | COMPLETE | MHHS-ART009 | T3-DB-0048 | SITAG | T3 |
| 288 | 1.3.6.3.2.3.2 | All Metering Services MHHS Reviews Completed | milestone | 0d | 2023-10-27 A | 2023-10-27 A | 287FS+30d | 100% |  | 2023-10-27 | 2023-10-27 | 0d | 2023-09-18 | 2023-09-29 |  |  |  | SI Test | PP | 5.13 | Lee Cox | Design, Build & Test (PIT) | Complete | COMPLETE |  | T3-DB-0135 | SITAG | T3 |
| 289 | 1.3.6.3.2.4 | **Test Scenarios** |  | 30d | 2023-09-15 A | 2023-10-27 A |  | 100% |  | 2023-09-15 | 2023-10-27 | 30d | 2022-10-31 | 2023-09-29 |  |  | -0 | N/A | N/A | 5.0 | N/A | Design, Build & Test (PIT) |  |  |  |  |  |  |
| 290 | 1.3.6.3.2.4.1 | All Metering Services test scenarios' submitted to Programme for assurance | milestone | 0d | 2023-09-15 A | 2023-09-15 A | 282FS+15d | 100% |  | 2023-09-15 | 2023-09-15 | 0d | 2023-09-15 | 2023-09-15 |  |  |  | PP | SI Test | 5.8 | Lee Cox | Design, Build & Test (PIT) | Complete | COMPLETE |  | T3-DB-0050 | SITAG | T3 |
| 291 | 1.3.6.3.2.4.2 | All Metering Services Test scenarios' MHHS Review Completed | milestone | 0d | 2023-10-27 A | 2023-10-27 A | 290FS+30d | 100% |  | 2023-10-27 | 2023-10-27 | 0d | 2023-09-18 | 2023-09-29 |  |  |  | SI Test | PP | 5.13 | Lee Cox | Design, Build & Test (PIT) | Complete | COMPLETE |  | T3-DB-0136 | SITAG | T3 |
| 292 | 1.3.6.3.2.5 | **PIT execution** |  | 50d | 2023-09-25 A | 2023-12-01 A |  | 100% |  | 2022-10-31 | 2023-12-01 | 285d | 2022-10-31 | 2023-11-17 |  |  | -0 | N/A | N/A | 5.0 | N/A | Design, Build & Test (PIT) |  |  |  |  |  |  |
| 293 | 1.3.6.3.2.5.1 | PIT Test Execution Progress Report |  | 39d | 2023-09-26 A | 2023-11-17 A | 285 | 100% |  | 2023-09-26 | 2023-11-17 | 39d | 2022-10-31 | 2023-11-10 |  |  |  | PP | SI Test | 5.0 | Lee Cox | Design, Build & Test (PIT) | Complete | COMPLETE |  |  |  |  |
| 294 | 1.3.6.3.2.5.2 | PIT Execution |  | 40d | 2023-09-25 A | 2023-11-17 A | 290FS+5d | 100% |  | 2022-10-31 | 2023-11-17 | 275d | 2022-10-31 | 2023-11-17 |  |  |  | PP | SI Test | 5.0 | Lee Cox | Design, Build & Test (PIT) | Complete | COMPLETE |  |  |  |  |
| 295 | 1.3.6.3.2.5.3 | All Metering Services PIT Completion Reports submitted to Programme for assurance | milestone | 0d | 2023-11-17 A | 2023-11-17 A | 293, 294 | 100% |  | 2023-11-17 | 2023-11-17 | 0d | 2024-01-05 | 2024-01-05 |  |  |  | PP | SI Test | 5.13 | Lee Cox | Design, Build & Test (PIT) | Complete | COMPLETE |  | T3-DB-0137 | SITAG | T3 |
| 296 | 1.3.6.3.2.5.4 | All Metering Services PIT Completion Reports MHHS Review Completed | milestone | 0d | 2023-12-01 A | 2023-12-01 A | 283, 288, 291, 295FS+10d | 100% |  | 2023-12-01 | 2023-12-01 | 0d |  |  |  |  |  | SI Test | PP | 5.13 | Lee Cox | Design, Build & Test (PIT) | Complete | COMPLETE |  | T3-DB-0138 | SITAG | T3 |
| 297 | 1.3.6.3.3 | **All SIT Programme Participants PIT (SIT Functional)** |  | 221d | 2023-11-17 A | 2024-09-20 |  | 82% | 40.35d | 2022-12-30 | 2024-09-20 | 451d | 2022-12-30 | 2024-02-16 | 0d |  | -0 | N/A | N/A | 5.0 | N/A | Design, Build & Test (PIT) |  |  |  |  |  |  |
| 298 | 1.3.6.3.3.1 | **Test Approach & Plans** |  | 40d | 2023-11-17 A | 2024-01-11 A |  | 100% |  | 2023-11-17 | 2024-01-11 | 40d | 2022-12-30 | 2023-11-30 |  |  | -0 | N/A | N/A | 5.2 | N/A | Design, Build & Test (PIT) |  |  |  |  |  |  |
| 299 | 1.3.6.3.3.1.1 | SIT Functional PIT Test Approach & Plan (PIT) submitted to Programme for assurance | milestone | 0d | 2023-11-17 A | 2023-11-17 A |  | 100% |  | 2023-11-17 | 2023-11-17 | 0d | 2023-11-16 | 2023-11-16 |  | start no earlier than 2023-11-17 |  | PP | SI Test | 5.16 | Lee Cox | Design, Build & Test (PIT) | Complete | COMPLETE |  | T3-DB-0093 | SITAG | T3 |
| 300 | 1.3.6.3.3.1.2 | All SIT Functional Test approach and plans MHHS Reviews Completed | milestone | 0d | 2024-01-11 A | 2024-01-11 A | 299FS+40d | 100% |  | 2024-01-11 | 2024-01-11 | 0d | 2023-11-17 | 2023-11-30 |  |  |  | SI Test | PP | 5.8 | Lee Cox | Design, Build & Test (PIT) | Complete | COMPLETE |  | T3-DB-0139 | SITAG | T3 |
| 301 | 1.3.6.3.3.2 | **Test Readiness Reports** |  | 11d | 2023-12-01 A | 2023-12-15 A |  | 100% |  | 2023-12-01 | 2024-02-09 | 51d | 2023-11-30 | 2024-02-08 |  |  |  | N/A | N/A | 5.2 | N/A | Design, Build & Test (PIT) |  |  |  |  |  |  |
| 302 | 1.3.6.3.3.2.1 | Test readiness reporting |  | 11d | 2023-12-01 A | 2023-12-15 A | 299FS+10d | 100% |  | 2023-12-01 | 2023-12-15 | 51d | 2023-11-30 | 2024-02-08 |  |  |  | PP | 109 | 5.2 | Lee Cox | Design, Build & Test (PIT) | Complete | COMPLETE |  |  |  |  |
| 303 | 1.3.6.3.3.3 | **Requirements to test Traceability Matrices (RTTM)** |  | 30d | 2023-12-07 A | 2024-01-18 A |  | 100% |  | 2023-12-07 | 2024-01-18 | 30d | 2023-01-06 | 2024-01-05 |  |  | -0 | N/A | N/A | 5.2 | N/A | Design, Build & Test (PIT) |  |  |  |  |  |  |
| 304 | 1.3.6.3.3.3.1 | SIT Functional PIT RTTM submitted to Programme for assurance | milestone | 0d | 2023-12-07 A | 2023-12-07 A | 299FS+15d | 100% |  | 2023-12-07 | 2023-12-07 | 0d | 2023-12-14 | 2023-12-14 |  |  |  | PP | SI Test | 5.14 | Lee Cox | Design, Build & Test (PIT) | Complete | COMPLETE |  | T3-DB-0091 | SITAG | T3 |
| 305 | 1.3.6.3.3.3.2 | All SIT Functional RTTMs MHHS Reviews Completed | milestone | 0d | 2024-01-18 A | 2024-01-18 A | 304FS+30d | 100% |  | 2024-01-18 | 2024-01-18 | 0d | 2023-12-15 | 2024-01-05 |  |  |  | SI Test | PP | 5.14 | Lee Cox | Design, Build & Test (PIT) | Complete | COMPLETE |  | T3-DB-0140 | SITAG | T3 |
| 306 | 1.3.6.3.3.4 | **Test Scenarios** |  | 30d | 2023-12-07 A | 2024-01-18 A |  | 100% |  | 2023-12-07 | 2024-01-18 | 30d | 2023-01-06 | 2024-01-05 |  |  | -0 | N/A | N/A | 5.2 | N/A | Design, Build & Test (PIT) |  |  |  |  |  |  |
| 307 | 1.3.6.3.3.4.1 | SIT Functional PIT test scenarios submitted to Programme for assurance | milestone | 0d | 2023-12-07 A | 2023-12-07 A | 299FS+15d | 100% |  | 2023-12-07 | 2023-12-07 | 0d | 2023-12-14 | 2023-12-14 |  |  |  | PP | SI Test | 5.14 | Lee Cox | Design, Build & Test (PIT) | Complete | COMPLETE |  | T3-DB-0089 | SITAG | T3 |
| 308 | 1.3.6.3.3.4.2 | All SIT Functional Test scenarios' MHHS Reviews Completed | milestone | 0d | 2024-01-18 A | 2024-01-18 A | 307FS+30d | 100% |  | 2024-01-18 | 2024-01-18 | 0d | 2023-12-15 | 2024-01-05 |  |  |  | SI Test | PP | 5.14 | Lee Cox | Design, Build & Test (PIT) | Complete | COMPLETE |  | T3-DB-0141 | SITAG | T3 |

Notes:
- 287: 13/9 - name change at TMAG. Red because 9/10 received. Approved at TMAG on 20/9
- 288: 1/9 - to be raised as new T3 at TMAG. Approved at TMAG on 20/9. 17/10 - Red because assurance reviews open comments remain outstanding. Final reviews will be completed no later than 4/12 ahead of Interval 4 Readiness Report
- 290: 13/9 - name change at TMAG Red because 9/10 . Approved at TMAG on 20/9
- 291: 1/9 - to be raised as new T3 at TMAG. Approved at TMAG on 20/9. 17/10 - Red because assurance reviews open comments remain outstanding. Final reviews will be completed no later than 4/12 ahead of Interval 4 Readiness Report
- 295: 1/9 - to be raised as new T3 at TMAG. Approved at TMAG on 20/9. 21/11-Red because not all test completion reports received. No impact. No action
- 296: 1/9 - to be raised as new T3 at TMAG. Approved at TMAG on 20/9.28/11 - Amber because late delivery of some completion reports impairing ability to conclude on time. Expediting reviews ahead of RA 4
- 299: 12/9 - name change to TMAG. Approved at TMAG on 20/9. 5/12-Red because not all test approach and plans received. Escalated at FTIG and PSG. Completed 4/1/24
- 300: 1/9 - to be raised as new T3 at TMAG. Approved at TMAG on 20/9. 16/1- All remaining / late artefacts now received and reviewed by Programme with feedback provided to PPs. Awaiting PPs final feedback. Approved complete at SITAG on 21/2/24
- 304: 12/9 - name and date change to TMAG. Approved at TMAG on 20/9. 20/02 - 1 PP artefact not yet received. Escalated at FTIG
- 305: 1/9 - to be raised as new T3 at TMAG. Approved at TMAG on 20/9. 23/01 - Late due to late delivery of PP artefacts for review
- 307: 12/9 - name and date change to TMAG. Approved at TMAG on 20/9. 20/02 - 2 PP artefacts not yet received. Escalated at FTIG
- 308: 1/9 - to be raised as new T3 at TMAG. Approved at TMAG on 20/9. 12/12 - Late due to late delivery of PP artefacts for review

| ID | WBS | Task | Type | Duration | Start | Finish | Predecessors | Complete | Remaining | Baseline start | Baseline finish | Baseline duration | Baseline 1 start | Baseline 1 finish | Total slack | Constraint | Baseline cost | Responsible | Involved | Update Version | MHHS Resource Name | MHHS Programme Phase | Sched Status | RAG | Milestone ID | Text29 | Tier | Guidance |
| --- | --- | --- | --- | --- | --- | --- | --- | --- | --- | --- | --- | --- | --- | --- | --- | --- | --- | --- | --- | --- | --- | --- | --- | --- | --- | --- | --- | --- |
| 309 | 1.3.6.3.3.5 | **PIT execution** |  | 51d | 2023-12-15 A | 2024-02-23 A |  | 100% |  | 2022-12-30 | 2024-02-23 | 301d | 2022-12-30 | 2024-02-09 |  |  | -0 | N/A | N/A | 5.0 | N/A | Design, Build & Test (PIT) |  |  |  |  |  |  |
| 310 | 1.3.6.3.3.5.1 | PIT Test Execution Progress Reports |  | 40d | 2023-12-18 A | 2024-02-09 A | 302 | 100% |  | 2023-12-18 | 2024-02-09 | 40d | 2022-12-30 | 2024-02-01 |  |  |  | PP | SI Test | 5.0 | Lee Cox | Design, Build & Test (PIT) | Complete | COMPLETE |  |  |  |  |
| 311 | 1.3.6.3.3.5.2 | PIT Execution |  | 41d | 2023-12-15 A | 2024-02-09 A | 307FS+5d | 100% |  | 2022-12-30 | 2024-02-09 | 290d | 2022-12-30 | 2024-02-09 |  |  |  | PP | SI Test | 5.0 | Lee Cox | Design, Build & Test (PIT) | Complete | COMPLETE |  |  |  |  |
| 312 | 1.3.6.3.3.5.3 | All SIT Functional PIT Completion Reports submitted to Programme for Assurance | milestone | 0d | 2024-02-09 A | 2024-02-09 A | 310, 311 | 100% |  | 2024-02-09 | 2024-02-09 | 0d | 2024-01-05 | 2024-01-05 |  |  |  | PP | SI Test | 5.19 | Lee Cox | Design, Build & Test (PIT) | Complete | COMPLETE | T3-DB-0087 | SITAG | T3 |  |
| 313 | 1.3.6.3.3.5.4 | All SIT Functional PIT Completion Reports MHHS Review Completed | milestone | 0d | 2024-02-23 A | 2024-02-23 A | 300, 305, 308, 312FS+10d | 100% |  | 2024-02-23 | 2024-02-23 | 0d |  |  |  |  |  | SI Test | PP | 5.19 | Lee Cox | Design, Build & Test (PIT) | Complete | COMPLETE | T3-DB-0142 | SITAG | T3 |  |
| 314 | 1.3.6.3.3.6 | **All SIT Programme Participants PIT (SIT Migration)** |  | 71d | 2024-02-16 A | 2024-05-24 A |  | 100% |  | 2023-03-31 | 2024-05-24 | 301d |  |  |  |  | -0 | N/A | N/A | 5.1 | N/A | Design, Build & Test (PIT) |  |  |  |  |  |  |
| 315 | 1.3.6.3.3.6.1 | **Test Approach & Plans** |  | 40d | 2024-02-16 A | 2024-04-11 A |  | 100% |  | 2024-02-16 | 2024-04-11 | 40d |  |  |  |  | -0 | N/A | N/A | 5.2 | N/A | Design, Build & Test (PIT) |  |  |  |  |  |  |
| 316 | 1.3.6.3.3.6.1.1 | All SIT Migration PIT Test Approach & Plans submitted to Programme for assurance | milestone | 0d | 2024-02-16 A | 2024-02-16 A |  | 100% |  | 2024-02-16 | 2024-02-16 | 0d |  |  |  | start no earlier than 2024-02-16 |  | PP | SI Test | 5.8 | Lee Cox | Design, Build & Test (PIT) | Complete | COMPLETE | T3-DB-0143 | SITAG | T3 |  |
| 317 | 1.3.6.3.3.6.1.2 | All SIT Migration PIT Test approach and plans MHHS Reviews Completed | milestone | 0d | 2024-04-11 A | 2024-04-11 A | 316FS+40d | 100% |  | 2024-04-11 | 2024-04-11 | 0d |  |  |  |  |  | SI Test | PP | 5.23 | Lee Cox | Design, Build & Test (PIT) | Complete | COMPLETE | T3-DB-0144 | SITAG | T3 |  |
| 318 | 1.3.6.3.3.6.2 | **Test Readiness Reports** |  | 11d | 2024-03-01 A | 2024-03-15 A |  | 100% |  | 2024-03-01 | 2024-05-10 | 51d |  |  |  |  |  | N/A | N/A | 5.2 | N/A | Design, Build & Test (PIT) |  |  |  |  |  |  |
| 319 | 1.3.6.3.3.6.2.1 | Test readiness reporting |  | 11d | 2024-03-01 A | 2024-03-15 A | 316FS+10d | 100% |  | 2024-03-01 | 2024-05-10 | 51d |  |  |  |  |  | PP | 109 | 5.2 | Lee Cox | Design, Build & Test (PIT) | Complete | COMPLETE |  |  |  |  |
| 320 | 1.3.6.3.3.6.3 | **Requirements to test Traceability Matrices (RTTM)** |  | 30d | 2024-03-07 A | 2024-04-18 A |  | 100% |  | 2024-03-07 | 2024-04-18 | 30d |  |  |  |  | -0 | N/A | N/A | 5.2 | N/A | Design, Build & Test (PIT) |  |  |  |  |  |  |
| 321 | 1.3.6.3.3.6.3.1 | All SIT Migration PIT RTTMs submitted to Programme for assurance | milestone | 0d | 2024-03-07 A | 2024-03-07 A | 316FS+15d | 100% |  | 2024-03-07 | 2024-03-07 | 0d |  |  |  |  |  | PP | SI Test | 5.23 | Lee Cox | Design, Build & Test (PIT) | Complete | COMPLETE | T3-DB-0145 | SITAG | T3 |  |
| 322 | 1.3.6.3.3.6.3.2 | All SIT Migration RTTMs MHHS Reviews Completed | milestone | 0d | 2024-04-18 A | 2024-04-18 A | 321FS+30d | 100% |  | 2024-04-18 | 2024-04-18 | 0d |  |  |  |  |  | SI Test | PP | 5.25 | Lee Cox | Design, Build & Test (PIT) | Complete | COMPLETE | T3-DB-0146 | SITAG | T3 |  |
| 323 | 1.3.6.3.3.6.4 | **Test Scenarios** |  | 30d | 2024-03-07 A | 2024-04-18 A |  | 100% |  | 2024-03-07 | 2024-04-18 | 30d |  |  |  |  | -0 | N/A | N/A | 5.2 | N/A | Design, Build & Test (PIT) |  |  |  |  |  |  |
| 324 | 1.3.6.3.3.6.4.1 | All SIT Migration PIT test scenarios submitted to Programme for assurance | milestone | 0d | 2024-03-07 A | 2024-03-07 A | 316FS+15d | 100% |  | 2024-03-07 | 2024-03-07 | 0d |  |  |  |  |  | PP | SI Test | 5.23 | Lee Cox | Design, Build & Test (PIT) | Complete | COMPLETE | T3-DB-0147 | SITAG | T3 |  |
| 325 | 1.3.6.3.3.6.4.2 | All SIT Migration Test scenarios MHHS Reviews Completed | milestone | 0d | 2024-04-18 A | 2024-04-18 A | 324FS+30d | 100% |  | 2024-04-18 | 2024-04-18 | 0d |  |  |  |  |  | SI Test | PP | 5.25 | Lee Cox | Design, Build & Test (PIT) | Complete | COMPLETE | T3-DB-0148 | SITAG | T3 |  |
| 326 | 1.3.6.3.3.6.5 | **PIT execution** |  | 51d | 2024-03-15 A | 2024-05-24 A |  | 100% |  | 2023-03-31 | 2024-05-24 | 301d |  |  |  |  | -0 | N/A | N/A | 5.1 | N/A | Design, Build & Test (PIT) |  |  |  |  |  |  |
| 327 | 1.3.6.3.3.6.5.1 | PIT Test Execution Progress Reports |  | 40d | 2024-03-18 A | 2024-05-10 A | 319 | 100% |  | 2024-03-18 | 2024-05-10 | 40d |  |  |  |  |  | PP | SI Test | 5.1 | Lee Cox | Design, Build & Test (PIT) | Complete | COMPLETE |  |  |  |  |
| 328 | 1.3.6.3.3.6.5.2 | PIT Execution |  | 41d | 2024-03-15 A | 2024-05-10 A | 324FS+5d | 100% |  | 2023-03-31 | 2024-05-10 | 290d |  |  |  |  |  | PP | SI Test | 5.1 | Lee Cox | Design, Build & Test (PIT) | Complete | COMPLETE |  |  |  |  |
| 329 | 1.3.6.3.3.6.5.3 | All SIT Migration PIT Completion Reports submitted to Programme for assurance | milestone | 0d | 2024-05-10 A | 2024-05-10 A | 327, 328 | 100% |  | 2024-05-10 | 2024-05-10 | 0d | 2024-01-05 | 2024-01-05 |  |  |  | PP | SI Test | 5.8 | Lee Cox | Design, Build & Test (PIT) | Complete | COMPLETE | T3-DB-0149 | SITAG | T3 |  |
| 330 | 1.3.6.3.3.6.5.4 | All SIT Migration PIT Completion Reports MHHS Review Completed | milestone | 0d | 2024-05-24 A | 2024-05-24 A | 317, 322, 325, 329FS+10d | 100% |  | 2024-05-24 | 2024-05-24 | 0d |  |  |  |  |  | SI Test | PP | 5.8 | Lee Cox | Design, Build & Test (PIT) | Complete | COMPLETE | T3-DB-0150 | SITAG | T3 |  |
| 331 | 1.3.6.3.3.7 | **All SIT Programme Participants PIT (SIT Non Functional)** |  | 71d | 2024-05-10 A | 2024-08-16 |  | 75% | 17.95d | 2023-06-23 | 2024-08-16 | 301d |  |  | 11d |  | -0 | N/A | N/A | 5.1 | N/A | Design, Build & Test (PIT) |  |  |  |  |  |  |
| 332 | 1.3.6.3.3.7.1 | **Test Approach & Plan** |  | 40d | 2024-05-10 A | 2024-07-04 A |  | 100% |  | 2024-05-10 | 2024-07-04 | 40d |  |  |  |  | -0 | N/A | N/A | 5.2 | N/A | Design, Build & Test (PIT) |  |  |  |  |  |  |
| 333 | 1.3.6.3.3.7.1.1 | SIT Non-Functional PIT Test Approach & Plan (PIT) submitted to Programme for assurance | milestone | 0d | 2024-05-10 A | 2024-05-10 A |  | 100% |  | 2024-05-10 | 2024-05-10 | 0d |  |  |  | start no earlier than 2024-05-10 |  | PP | SI Test | 5.30 | Roger Robar | Design, Build & Test (PIT) | Complete | COMPLETE | T3-DB-0151 | SITAG | T3 |  |
| 334 | 1.3.6.3.3.7.1.2 | SIT Non-Functional Test approach and plan MHHS Review Completed | milestone | 0d | 2024-07-04 A | 2024-07-04 A | 333FS+40d | 100% |  | 2024-07-04 | 2024-07-04 | 0d |  |  |  |  |  | SI Test | PP | 5.30 | Roger Robar | Design, Build & Test (PIT) | Complete | COMPLETE | T3-DB-0152 | SITAG | T3 | 6/9/24: Approved at esitag on 26/7/24 |

Notes:
- 310: 16/4: completed 12/4
- 311: 16/4: completed 12/4
- 312: 1/9 - name change at TMAG. Approved at TMAG on 20/9. 20/2 - 23 reports received. The majority of late deliveries have been discussed and agreed with the Programme.5/3 - Approved 1/3 SITAG with work off
- 313: 1/9 - to be raised as new T3 at TMAG. Approved at TMAG on 20/9. 27/2 - Target date missed due to late delivery of some reports. 5/3 - Approved 1/3 SITAG with work off
- 316: 1/9 - to be raised as new T3 at TMAG. Approved at TMAG on 20/9.. 19/3 - 33/35 received
- 317: 1/9 - to be raised as new T3 at TMAG. Approved at TMAG on 20/9. 26/3: At risk because of late delivery of PIT test approach and plans by PPs. 16/4: All received. All but 1 reviewed
- 321: 1/9 - to be raised as new T3 at TMAG. Approved at TMAG on 20/9. 22/04: 33/34 received. Remainder to be chased
- 322: 1/9 - to be raised as new T3 at TMAG. Approved at TMAG on 20/9. 26/3: At risk because of late delivery of RTTMs by PPs 30/4: Late because of late delivery or RTTMS 33/34 reviewed
- 324: 1/9 - to be raised as new T3 at TMAG. Approved at TMAG on 20/9. 22/04: 31/34 received. Remainder to be chased
- 325: 1/9 - to be raised as new T3 at TMAG. Approved at TMAG on 20/9. 26/3: At risk because of late delivery of PIT test scenarios by PPs. 30/4: Late because of late delivery or Test scenarios. 33/34 reviewed
- 329: Sufficient PIT completion reports on track, some are known to be late. 11/6: 29/33 received. Small number of PPs will be PIT complete late, but before SIT migration. 1 PP will be post SIT Migration start. 11/6: eSITAG approved on 3/6 subject to Work-off
- 330: 1/9 - to be raised as new T3 at TMAG. Approved at TMAG on 20/9. 14/5: Won't deliver to forecast because of late delivery of by some PPs of PIT completion report. 11/6: eSITAG approved on 3/6 subject to Work-off
- 333: 33/34 plans have been submitted to the Programme. Because of the delay to all plans being submitted there is an increased risk to completion of SIT Non-Functional PIT. Re-forecasting the completion date isnt possible as delivery is dependent on the PPs
- 334: Late because the completion of the review is dependant on the delivery of all of the SIT Non-Functional Test Approach and Plans from the PPs. This increases the risk to SIT Non-Functional PIT completion

| ID | WBS | Task | Type | Duration | Start | Finish | Predecessors | Complete | Remaining | Baseline start | Baseline finish | Baseline duration | Baseline 1 start | Baseline 1 finish | Total slack | Free slack | Constraint | Baseline cost | Responsible | Involved | Update Version | MHHS Resource Name | MHHS Programme Phase | Sched Status | RAG | Task Status | Milestone ID | Text29 | Tier | Notes (2) |
| --- | --- | --- | --- | --- | --- | --- | --- | --- | --- | --- | --- | --- | --- | --- | --- | --- | --- | --- | --- | --- | --- | --- | --- | --- | --- | --- | --- | --- | --- | --- |
| 335 | 1.3.6.3.3.7.2 | **Test Readiness Report** |  | 11d | 2024-05-24 A | 2024-06-07 A |  | 100% |  | 2024-05-24 | 2024-08-02 | 51d |  |  |  |  |  |  | N/A | N/A | 5.2 | N/A | Design, Build & Test (PIT) |  |  |  |  |  |  |  |
| 336 | 1.3.6.3.3.7.2.1 | Test readiness reporting |  | 11d | 2024-05-24 A | 2024-06-07 A | 333FS+10d | 100% |  | 2024-05-24 | 2024-08-02 | 51d |  |  |  |  |  |  | PP | 109 | 5.2 | Lee Cox | Design, Build & Test (PIT) | Complete | COMPLETE |  |  |  |  |  |
| 337 | 1.3.6.3.3.7.3 | **Requirements to test Traceability Matrix (RTTM)** |  | 30d | 2024-05-30 | 2024-07-11 |  |  |  | 2024-05-30 | 2024-07-11 | 30d |  |  | 37d |  |  | -0 | N/A | N/A | 5.2 | N/A | Design, Build & Test (PIT) |  |  |  |  |  |  |  |
| 338 | 1.3.6.3.3.7.3.1 | SIT Non-Functional PIT RTTM submitted to Programme for assurance | milestone | 0d | 2024-05-30 | 2024-05-30 | 333FS+15d |  |  | 2024-05-30 | 2024-05-30 | 0d |  |  | 37d | 0d |  |  | PP | SI Test | 5.8 | Roger Robar | Design, Build & Test (PIT) | Overdue Start | RED | -69.29 | T3-DB-0153 | SITAG | T3 |  |
| 339 | 1.3.6.3.3.7.3.2 | SIT Non-Functional RTTM MHHS Review Completed | milestone | 0d | 2024-07-11 | 2024-07-11 | 338FS+30d |  |  | 2024-07-11 | 2024-07-11 | 0d |  |  | 37d | 26d |  |  | SI Test | PP | 5.8 | Roger Robar | Design, Build & Test (PIT) | Overdue Start | RED | -27.29 | T3-DB-0154 | SITAG | T3 |  |
| 340 | 1.3.6.3.3.7.4 | **Test Scenarios** |  | 30d | 2024-05-30 | 2024-07-11 |  |  |  | 2024-05-30 | 2024-07-11 | 30d |  |  | 29d |  |  | -0 | N/A | N/A | 5.2 | N/A | Design, Build & Test (PIT) |  |  |  |  |  |  |  |
| 341 | 1.3.6.3.3.7.4.1 | SIT Non-Functional PIT test scenarios submitted to Programme for assurance | milestone | 0d | 2024-05-30 | 2024-05-30 | 333FS+15d |  |  | 2024-05-30 | 2024-05-30 | 0d |  |  | 29d | 0d |  |  | PP | SI Test | 5.8 | Roger Robar | Design, Build & Test (PIT) | Overdue Start | RED | -69.29 | T3-DB-0155 | SITAG | T3 |  |
| 342 | 1.3.6.3.3.7.4.2 | SIT Non-Functional Test scenarios MHHS Review Completed | milestone | 0d | 2024-07-11 | 2024-07-11 | 341FS+30d |  |  | 2024-07-11 | 2024-07-11 | 0d |  |  | 37d | 26d |  |  | SI Test | PP | 5.8 | Roger Robar | Design, Build & Test (PIT) | Overdue Start | RED | -27.29 | T3-DB-0156 | SITAG | T3 |  |
| 343 | 1.3.6.3.3.7.5 | **PIT execution** |  | 51d | 2024-06-07 A | 2024-08-16 |  | 71% | 14.66d | 2023-06-23 | 2024-08-16 | 301d |  |  | 11d |  |  | -0 | N/A | N/A | 5.1 | N/A | Design, Build & Test (PIT) |  |  |  |  |  |  |  |
| 344 | 1.3.6.3.3.7.5.1 | PIT Test Execution Progress Report |  | 39d | 2024-06-10 A | 2024-08-01 | 336 | 72% | 11d | 2024-06-10 | 2024-08-01 | 39d |  |  | 12d | 1d |  |  | PP | SI Test | 5.1 | Roger Robar | Design, Build & Test (PIT) | Overdue | RED |  |  |  |  |  |
| 345 | 1.3.6.3.3.7.5.2 | PIT Execution |  | 41d | 2024-06-07 A | 2024-08-02 | 341FS+5d | 71% | 12d | 2023-06-23 | 2024-08-02 | 290d |  |  | 11d | 0d |  |  | PP | SI Test | 5.1 | Roger Robar | Design, Build & Test (PIT) | Overdue | RED |  |  |  |  |  |
| 346 | 1.3.6.3.3.7.5.3 | SIT Non-Functional PIT Completion Report submitted to Programme for assurance | milestone | 0d | 2024-08-02 | 2024-08-02 | 344, 345 |  |  | 2024-08-02 | 2024-08-02 | 0d | 2024-01-05 | 2024-01-05 | 11d | 0d |  |  | PP | SI Test | 5.10 | Roger Robar | Design, Build & Test (PIT) | Overdue Start | RED | -5.29 | T3-DB-0157 | SITAG | T3 |  |
| 347 | 1.3.6.3.3.7.5.4 | SIT Non-Functional PIT Completion Report MHHS Review Completed | milestone | 0d | 2024-08-16 | 2024-08-16 | 334, 339, 342, 346FS+10d |  |  | 2024-08-16 | 2024-08-16 | 0d |  |  | 11d | 6d |  |  | SI Test | PP | 5.8 | Roger Robar | Design, Build & Test (PIT) | Green | AMBER | 8.71 | T3-DB-0158 | SITAG | T3 |  |
| 348 | 1.3.6.3.3.8 | **All SIT Programme Participants PIT (SIT Operational)** |  | 71d | 2024-06-14 A | 2024-09-20 |  | 52% | 33.96d | 2024-06-14 | 2024-09-20 | 71d |  |  | 0d |  |  | -0 | N/A | N/A | 5.1 | N/A | Design, Build & Test (PIT) |  |  |  |  |  |  |  |
| 349 | 1.3.6.3.3.8.1 | **Test Approach & Plan** |  | 40d | 2024-06-14 | 2024-08-08 |  |  |  | 2024-06-14 | 2024-08-08 | 40d |  |  | 19d |  |  | -0 | N/A | N/A | 5.2 | N/A | Design, Build & Test (PIT) |  |  |  |  |  |  |  |
| 350 | 1.3.6.3.3.8.1.1 | SIT Operational PIT Test Approach & Plan (PIT) submitted to Programme for assurance | milestone | 0d | 2024-06-14 | 2024-06-14 |  |  |  | 2024-06-14 | 2024-06-14 | 0d |  |  | 19d | 0d | start no earlier than 2024-06-14 |  | PP | SI Test | 5.8 | Roger Robar | Design, Build & Test (PIT) | Overdue Start | RED | -54.67 | T3-DB-0159 | SITAG | T3 |  |
| 351 | 1.3.6.3.3.8.1.2 | SIT Operational Test approach and plan MHHS Review Completed | milestone | 0d | 2024-08-08 | 2024-08-08 | 350FS+40d |  |  | 2024-08-08 | 2024-08-08 | 0d |  |  | 31d |  |  |  | SI Test | PP | 5.8 | Roger Robar | Design, Build & Test (PIT) | Green | AMBER | 0.71 | T3-DB-0160 | SITAG | T3 |  |
| 352 | 1.3.6.3.3.8.2 | **Test Readiness Report** |  | 11d | 2024-06-28 A | 2024-07-12 A |  | 100% |  | 2024-06-28 | 2024-09-06 | 51d |  |  |  |  |  |  | N/A | N/A | 5.2 | N/A | Design, Build & Test (PIT) |  |  |  |  |  |  |  |
| 353 | 1.3.6.3.3.8.2.1 | Test readiness reporting |  | 11d | 2024-06-28 A | 2024-07-12 A | 350FS+10d | 100% |  | 2024-06-28 | 2024-09-06 | 51d |  |  |  |  |  |  | PP | 109 | 5.2 | Lee Cox | Design, Build & Test (PIT) | Complete | COMPLETE |  |  |  |  |  |
| 354 | 1.3.6.3.3.8.3 | **Requirements to test Traceability Matrix (RTTM)** |  | 30d | 2024-07-04 | 2024-08-15 |  |  |  | 2024-07-04 | 2024-08-15 | 30d |  |  | 26d |  |  | -0 | N/A | N/A | 5.2 | N/A | Design, Build & Test (PIT) |  |  |  |  |  |  |  |
| 355 | 1.3.6.3.3.8.3.1 | SIT Operational PIT RTTM submitted to Programme for assurance | milestone | 0d | 2024-07-04 | 2024-07-04 | 350FS+15d |  |  | 2024-07-04 | 2024-07-04 | 0d |  |  | 26d | 0d |  |  | PP | SI Test | 5.8 | Roger Robar | Design, Build & Test (PIT) | Overdue Start | RED | -34.29 | T3-DB-0161 | SITAG | T3 | dependent on the PPs |
| 356 | 1.3.6.3.3.8.3.2 | SIT Operational RTTM MHHS Review Completed | milestone | 0d | 2024-08-15 | 2024-08-15 | 355FS+30d |  |  | 2024-08-15 | 2024-08-15 | 0d |  |  | 26d |  |  |  | SI Test | PP | 5.8 | Roger Robar | Design, Build & Test (PIT) | Green | AMBER | 7.71 | T3-DB-0162 | SITAG | T3 |  |
| 357 | 1.3.6.3.3.8.4 | **Test Scenarios** |  | 30d | 2024-07-04 | 2024-08-15 |  |  |  | 2024-07-04 | 2024-08-15 | 30d |  |  | 19d |  |  | -0 | N/A | N/A | 5.2 | N/A | Design, Build & Test (PIT) |  |  |  |  |  |  |  |
| 358 | 1.3.6.3.3.8.4.1 | SIT Operational PIT test scenarios submitted to Programme for assurance | milestone | 0d | 2024-07-04 | 2024-07-04 | 350FS+15d |  |  | 2024-07-04 | 2024-07-04 | 0d |  |  | 19d | 0d |  |  | PP | SI Test | 5.8 | Roger Robar | Design, Build & Test (PIT) | Overdue Start | RED | -34.29 | T3-DB-0163 | SITAG | T3 | date isn’t possible as delivery is dependent on the PPs |
| 359 | 1.3.6.3.3.8.4.2 | SIT Operational Test scenarios MHHS Review Completed | milestone | 0d | 2024-08-15 | 2024-08-15 | 358FS+30d |  |  | 2024-08-15 | 2024-08-15 | 0d |  |  | 26d |  |  |  | SI Test | PP | 5.8 | Roger Robar | Design, Build & Test (PIT) | Green | AMBER | 7.71 | T3-DB-0164 | SITAG | T3 |  |

Notes:
- 338: 32/34 RTTMs have been submitted to the Programme. Because of the delay to all RTTMs being submitted there is an increased risk to completion of SIT Non-Functional PIT. Re-forecasting the completion date isnt possible as delivery is dependent on the PPs~
- 339: Date missed because the completion of the review is dependent on the delivery of all of the SIT Non-Functional RTTMs from the PPs. This increases the risk to SIT Non-Functional PIT completion
- 341: 28/34 test scenarios have been submitted to the Programme. Because of the delay to all test scenarios being submitted there is an increased risk to completion of SIT Non-Functional PIT. Re-forecasting the completion date isnt possible as delivery is
- 342: Date missed because the completion of the review is dependent on the delivery of all of the SIT Non-Functional Test Scenarios from the PPs. This increases the risk to SIT Non-Functional PIT completion
- 346: Date missed because the report was delayed due to lower engagement than expected. ~Start of NFT could be delayed. ~Escalated at FTIG to drive better engagement, continue to work with PPs to understand issues
- 347: Date at risk because of potential delay to submissions for SIT Non-Functional PIT completion reports. Impact may be a delay to the start of SIT Non Functional Testing. Continue engagement with PPs
- 350: 27/34 test approach and plans have been submitted to the Programme. Because of the delay to all Test Approach and plans being submitted there is an increased risk to completion of SIT Operational PIT. Re-forecasting the completion date isnt possible as
- 351: At risk because the completion of the review is dependant on the delivery of all of the SIT Operational Test Approach and Plans from the PPs. This increases the risk to SIT Operational PIT completion
- 355: 18/34 SIT Operational PIT RTTMs have been submitted to the Programme. Because of the delay to all RTTMs being submitted there is an increased risk to completion of SIT Operational PIT. Re-forecasting the completion date isnt possible as delivery is
- 356: At risk because the completion of the review is dependent on the delivery of all of the SIT Operational RTTMs from the PPs. This increases the risk to SIT Operational PIT completion
- 358: 14/34 SIT Operational PIT test scenarios have been submitted to the Programme. Because of the delay to all SIT Operational PIT test scenarios being submitted there is increased risk to the completion of SIT Operational PIT. Re-forecasting the completion
- 359: At risk because the completion of the review is dependent on the delivery of all of the SIT Operational Test Scenarios from the PPs. This increases the risk to SIT Operational PIT completion

| ID | WBS | Task | Type | Duration | Start | Finish | Predecessors | Complete | Remaining | Baseline start | Baseline finish | Baseline duration | Baseline 1 start | Baseline 1 finish | Total slack | Constraint | Baseline cost | Responsible | Involved | Update Version | MHHS Resource Name | MHHS Programme Phase | Sched Status | RAG | Task Status | Milestone ID | Text29 | Tier | Artefact ID |
| --- | --- | --- | --- | --- | --- | --- | --- | --- | --- | --- | --- | --- | --- | --- | --- | --- | --- | --- | --- | --- | --- | --- | --- | --- | --- | --- | --- | --- | --- |
| 360 | 1.3.6.3.3.8.5 | **PIT execution** |  | 51d | 2024-07-12 A | 2024-09-20 |  | 46% | 27.7d | 2024-07-12 | 2024-09-20 | 51d |  |  | 0d |  | -0 | N/A | N/A | 5.1 | N/A | Design, Build & Test (PIT) |  |  |  |  |  |  |  |
| 361 | 1.3.6.3.3.8.5.1 | PIT Test Execution Progress Report |  | 40d | 2024-07-15 A | 2024-09-06 | 353 | 45% | 22d | 2024-07-15 | 2024-09-06 | 40d |  |  | 0d |  |  | PP | SI Test | 5.1 | Roger Robar | Design, Build & Test (PIT) | Green | GREEN |  |  |  |  |  |
| 362 | 1.3.6.3.3.8.5.2 | PIT Execution |  | 41d | 2024-07-12 A | 2024-09-06 | 358FS+5d | 46% | 22d | 2024-07-12 | 2024-09-06 | 41d |  |  | 0d |  |  | PP | SI Test | 5.1 | Roger Robar | Design, Build & Test (PIT) | Green | GREEN |  |  |  |  |  |
| 363 | 1.3.6.3.3.8.5.3 | SIT Operational PIT Completion Report submitted to Programme for assurance | milestone | 0d | 2024-09-06 | 2024-09-06 | 361, 362 |  |  | 2024-09-06 | 2024-09-06 | 0d | 2024-01-05 | 2024-01-05 | 0d |  |  | PP | SI Test | 5.10 | Roger Robar | Design, Build & Test (PIT) | Green | AMBER | 29.71 | T3-DB-0165 | SITAG | T3 |  |
| 364 | 1.3.6.3.3.8.5.4 | SIT Operational PIT Completion Report MHHS Review Completed | milestone | 0d | 2024-09-20 | 2024-09-20 | 351, 356, 359, 363FS+10d |  |  | 2024-09-20 | 2024-09-20 | 0d |  |  | 0d |  |  | SI Test | PP | 5.8 | Roger Robar | Design, Build & Test (PIT) | Green | AMBER | 43.71 | T3-DB-0166 | SITAG | T3 |  |
| 365 | 1.3.6.3.4 | **All Suppliers DBT CIT (Entering at Interval 5)** |  | 71d | 2023-09-15 A | 2023-12-22 A |  | 100% |  | 2022-10-31 | 2023-12-22 | 300d | 2022-10-31 | 2025-03-14 |  |  | -0 | N/A | N/A | 5.0 | N/A | Design, Build & Test (PIT) |  |  |  |  |  |  |  |
| 366 | 1.3.6.3.4.1 | **Test Approach & Plan** |  | 20d | 2023-09-15 A | 2023-10-12 A |  | 100% |  | 2023-09-15 | 2023-10-12 | 19d | 2022-10-31 | 2023-09-29 |  |  | -0 | N/A | N/A | 5.0 | N/A | Design, Build & Test (PIT) |  |  |  |  |  |  |  |
| 367 | 1.3.6.3.4.1.1 | All SIT Suppliers Test Approach & Plans (PIT) submitted to Programme for assurance | milestone | 0d | 2023-09-15 A | 2023-09-15 A |  | 100% |  | 2023-09-15 | 2023-09-15 | 0d | 2023-09-15 | 2023-09-15 |  | start no earlier than 2023-09-15 |  | PP | SI Test | 5.8 | Lee Cox | Design, Build & Test (PIT) | Complete | COMPLETE |  | T3-DB-0046 | SITAG | T3 |  |
| 368 | 1.3.6.3.4.1.2 | All SIT Suppliers Test Approach & Plans MHHS Review Completed | milestone | 0d | 2023-10-12 A | 2023-10-12 A | 367FS+20d | 100% |  | 2023-10-12 | 2023-10-12 | 0d | 2023-09-18 | 2023-09-29 |  |  |  | SI Test | PP | 5.8 | Lee Cox | Design, Build & Test (PIT) | Complete | COMPLETE |  | T3-DB-0167 | SITAG | T3 |  |
| 369 | 1.3.6.3.4.2 | **Test Readiness Report** |  | 11d | 2023-09-29 A | 2023-10-13 A |  | 100% |  | 2023-09-29 | 2023-12-08 | 51d | 2023-09-29 | 2023-12-08 |  |  |  | N/A | N/A | 5.0 | N/A | Design, Build & Test (PIT) |  |  |  |  |  |  |  |
| 370 | 1.3.6.3.4.2.1 | Test readiness reporting |  | 11d | 2023-09-29 A | 2023-10-13 A | 367FS+10d | 100% |  | 2023-09-29 | 2023-12-08 | 51d | 2023-09-29 | 2023-12-08 |  |  |  | PP | 109 | 5.0 | Lee Cox | Design, Build & Test (PIT) | Complete | COMPLETE |  |  |  |  |  |
| 371 | 1.3.6.3.4.3 | **Requirements to test Traceability Matrix (RTTM)** |  | 20d | 2023-10-06 A | 2023-11-03 A |  | 100% |  | 2023-10-06 | 2023-11-03 | 21d | 2022-10-31 | 2023-10-20 |  |  | -0 | N/A | N/A | 5.0 | N/A | Design, Build & Test (PIT) |  |  |  |  |  |  |  |
| 372 | 1.3.6.3.4.3.1 | All SIT Suppliers RTTMs submitted to Programme for assurance | milestone | 0d | 2023-10-06 A | 2023-10-06 A | 367FS+16d | 100% |  | 2023-10-06 | 2023-10-06 | 1d | 2023-10-06 | 2023-10-06 |  |  |  | PP | SI Test | 5.8 | Lee Cox | Design, Build & Test (PIT) | Complete | COMPLETE |  | T3-DB-0064 | SITAG | T3 | MHHS-ART009 |
| 373 | 1.3.6.3.4.3.2 | All SIT Suppliers RTTMs MHHS Review Completed | milestone | 0d | 2023-11-03 A | 2023-11-03 A | 372FS+20d | 100% |  | 2023-11-03 | 2023-11-03 | 0d | 2023-10-09 | 2023-10-20 |  |  |  | SI Test | PP | 5.14 | Lee Cox | Design, Build & Test (PIT) | Complete | COMPLETE |  | T3-DB-0168 | SITAG | T3 |  |
| 374 | 1.3.6.3.4.4 | **Test Scenarios** |  | 20d | 2023-10-05 A | 2023-11-02 A |  | 100% |  | 2023-10-05 | 2023-11-02 | 20d | 2022-10-31 | 2023-10-20 |  |  | -0 | N/A | N/A | 5.0 | N/A | Design, Build & Test (PIT) |  |  |  |  |  |  |  |
| 375 | 1.3.6.3.4.4.1 | All SIT Suppliers test scenarios' submitted to Programme for assurance | milestone | 0d | 2023-10-05 A | 2023-10-05 A | 367FS+15d | 100% |  | 2023-10-05 | 2023-10-05 | 0d | 2023-10-06 | 2023-10-06 |  |  |  | PP | SI Test | 5.8 | Lee Cox | Design, Build & Test (PIT) | Complete | COMPLETE |  | T3-DB-0037 | SITAG | T3 |  |
| 376 | 1.3.6.3.4.4.2 | All SIT Suppliers Test scenarios' MHHS Review Completed | milestone | 0d | 2023-11-02 A | 2023-11-02 A | 375FS+20d | 100% |  | 2023-11-02 | 2023-11-02 | 0d | 2023-10-09 | 2023-10-20 |  |  |  | SI Test | PP | 5.14 | Lee Cox | Design, Build & Test (PIT) | Complete | COMPLETE |  | T3-DB-0169 | SITAG | T3 |  |
| 377 | 1.3.6.3.4.5 | **PIT execution** |  | 51d | 2023-10-13 A | 2023-12-22 A |  | 100% |  | 2022-10-31 | 2023-12-22 | 300d | 2022-10-31 | 2023-12-08 |  |  | -0 | N/A | N/A | 5.0 | N/A | Design, Build & Test (PIT) |  |  |  |  |  |  |  |
| 378 | 1.3.6.3.4.5.1 | PIT Test Execution Progress Report |  | 40d | 2023-10-16 A | 2023-12-08 A | 375FS+5d, 370 | 100% |  | 2023-10-16 | 2023-12-08 | 40d | 2022-10-31 | 2023-12-01 |  |  |  | PP | SI Test | 5.0 | Lee Cox | Design, Build & Test (PIT) | Complete | COMPLETE |  |  |  |  |  |
| 379 | 1.3.6.3.4.5.2 | PIT Execution |  | 41d | 2023-10-13 A | 2023-12-08 A | 375FS+5d | 100% |  | 2022-10-31 | 2023-12-08 | 290d | 2022-10-31 | 2023-12-08 |  |  |  | PP | SI Test | 5.0 | Lee Cox | Design, Build & Test (PIT) | Complete | COMPLETE |  |  |  |  |  |
| 380 | 1.3.6.3.4.5.3 | All SIT Suppliers PIT Completion Reports submitted to Programme for assurance | milestone | 0d | 2023-12-08 A | 2023-12-08 A | 379, 378 | 100% |  | 2023-12-08 | 2023-12-08 | 0d | 2024-01-05 | 2024-01-05 |  |  |  | PP | SI Test | 5.14 | Lee Cox | Design, Build & Test (PIT) | Complete | COMPLETE |  | T3-DB-0170 | SITAG | T3 |  |
| 381 | 1.3.6.3.4.5.4 | All SIT Suppliers PIT Completion Reports MHHS Review Completed | milestone | 0d | 2023-12-22 A | 2023-12-22 A | 380FS+10d, 368, 373, 376 | 100% |  | 2023-12-22 | 2023-12-22 | 0d |  |  |  |  |  | SI Test | PP | 5.14 | Lee Cox | Design, Build & Test (PIT) | Complete | COMPLETE |  | T3-DB-0171 | SITAG | T3 |  |
| 382 | 1.3.6.3.5 | **All LDSO Network Operations DBT CIT (Entering at Interval 5)** |  | 71d | 2023-09-15 A | 2023-12-22 A |  | 100% |  | 2022-10-31 | 2024-01-05 | 310d | 2022-10-31 | 2025-03-14 |  |  | -0 | N/A | N/A | 5.0 | N/A | Design, Build & Test (PIT) |  |  |  |  |  |  |  |
| 383 | 1.3.6.3.5.1 | **Test Approach & Plan** |  | 71d | 2023-09-15 A | 2023-12-22 A |  | 100% |  | 2022-10-31 | 2024-01-05 | 310d | 2022-10-31 | 2023-08-11 |  |  | -0 | N/A | N/A | 5.0 | N/A | Design, Build & Test (PIT) |  |  |  |  |  |  |  |
| 384 | 1.3.6.3.5.1.1 | All Network Operation Test Approach & Plans (PIT) submitted to Programme for assurance | milestone | 0d | 2023-09-15 A | 2023-09-15 A |  | 100% |  | 2023-09-15 | 2023-09-15 | 0d | 2023-07-28 | 2023-07-28 |  | start no earlier than 2023-09-15 |  | PP | SI Test | 5.8 | Lee Cox | Design, Build & Test (PIT) | Complete | COMPLETE |  | T3-DB-0054 | SITAG | T3 |  |
| 385 | 1.3.6.3.5.1.2 | All Network Operation Test Approach & Plans MHHS Review Completed | milestone | 0d | 2023-10-12 A | 2023-10-12 A | 384FS+20d | 100% |  | 2023-10-12 | 2023-10-12 | 0d | 2023-07-31 | 2023-08-11 |  |  |  | SI Test | PP | 5.8 | Lee Cox | Design, Build & Test (PIT) | Complete | COMPLETE |  | T3-DB-0172 | SITAG | T3 |  |

Notes:
- 363: 6/8/24: Date at risk because of potential delay to submissions for SIT Operational PIT completion reports. Impact may be a delay to the start of SIT Operational Testing. Continue engagement with PPs
- 364: 6/8/24: Date at risk because of potential delay to submissions for SIT Operational PIT completion reports. Impact may be a delay to the start of SIT Operational Testing. Continue engagement with PPs
- 367: 12/9 - TMAG for name change Red because 7/9 received. Approved at TMAG on 20/9
- 368: 7/11 - Red due to high volume to be reviewed. Date change under consideration. Initial reviews complete. Final review will be completed no later than 08/01/24 ahead of Interval 5 Readiness Assessment
- 372: 12/9 - TMAG for name change. Approved at TMAG on 20/9. 10/10 - Red because small number of RTTMs still outstanding
- 373: 17/10 - Red because open comments still outstanding. Assurance reviews complete. Review will be completed no later than 08/01/24 ahead of Interval 5 Readiness Report . Completed on 14/12
- 375: 12/9 - TMAG for name change. Approved at TMAG on 20/9. 10/10 - Red because small number of Test Scenarios still outstanding
- 376: 1/9 - to be raised as new T3 at TMAG. Approved at TMAG on 20/9. 17/10 - Red due to high volume and backlog to be reviewed. Review will be completed no later than 08/01/24 ahead of Interval 5 Readiness Report. Completed 14/12
- 380: 1/9 - to be raised as new T3 at TMAG. Approved at TMAG on 20/9. 12/12 - Red because not all received. No impact as of yet. No action. Completed 12/12
- 381: 1/9 - to be raised as new T3 at TMAG. Approved at TMAG on 20/9. 12/12 - Amber because not all artefacts received. No impact. No action. Completed 15/12
- 384: 12/9 - TMAG for name and date change Red because only received 1/2 test approach and plans. Approved at TMAG on 20/9
- 385: 11/9 - to be raised as new T3 at TMAG. Approved at TMAG on 20/9. Red due to high volume to be reviewed. Date change under consideration. Review will be completed no later than 08/01/24 ahead of Interval 5 Readiness Assessment

| ID | WBS | Task | Type | Duration | Start | Finish | Predecessors | Complete | Actual start | Actual finish | Baseline start | Baseline finish | Baseline duration | Baseline 1 start | Baseline 1 finish | Constraint | Baseline cost | Responsible | Involved | Update Version | MHHS Resource Name | MHHS Programme Phase | Sched Status | RAG | Artefact ID | Milestone ID | Text29 | Tier |
| --- | --- | --- | --- | --- | --- | --- | --- | --- | --- | --- | --- | --- | --- | --- | --- | --- | --- | --- | --- | --- | --- | --- | --- | --- | --- | --- | --- | --- |
| 386 | 1.3.6.3.5.1.3 | **Test Readiness Report** |  | 11d | 2023-09-29 A | 2023-10-13 A |  | 100% |  |  | 2023-08-11 | 2023-10-20 | 51d | 2023-08-11 | 2023-10-20 |  |  | N/A | N/A | 5.0 | N/A | Design, Build & Test (PIT) |  |  |  |  |  |  |
| 387 | 1.3.6.3.5.1.3.1 | Test readiness reporting |  | 11d | 2023-09-29 A | 2023-10-13 A | 384FS+10d | 100% |  |  | 2023-08-11 | 2023-10-20 | 51d | 2023-08-11 | 2023-10-20 |  |  | PP | 109 | 5.0 | Lee Cox | Design, Build & Test (PIT) | Complete | COMPLETE |  |  |  |  |
| 388 | 1.3.6.3.5.1.4 | **Requirements to test Traceability Matrix (RTTM)** |  | 20d | 2023-10-05 A | 2023-11-02 A |  | 100% |  |  | 2023-10-05 | 2023-11-02 | 20d | 2022-10-31 | 2023-09-15 |  | -0 | N/A | N/A | 5.0 | N/A | Design, Build & Test (PIT) |  |  |  |  |  |  |
| 389 | 1.3.6.3.5.1.4.1 | All Network Operation RTTMs submitted to Programme for assurance | milestone | 0d | 2023-10-05 A | 2023-10-05 A | 384FS+15d | 100% |  |  | 2023-10-05 | 2023-10-05 | 0d | 2023-09-01 | 2023-09-01 | start no earlier than 2023-04-28 |  | PP | SI Test | 5.8 | Lee Cox | Design, Build & Test (PIT) | Complete | COMPLETE | MHHS-ART009 | T3-DB-0062 | SITAG | T3 |
| 390 | 1.3.6.3.5.1.4.2 | All Network Operation RTTMs MHHS Review Completed | milestone | 0d | 2023-11-02 A | 2023-11-02 A | 389FS+20d | 100% |  |  | 2023-11-02 | 2023-11-02 | 0d | 2023-09-04 | 2023-09-15 |  |  | SI Test | PP | 5.14 | Lee Cox | Design, Build & Test (PIT) | Complete | COMPLETE |  | T3-DB-0173 | SITAG | T3 |
| 391 | 1.3.6.3.5.1.5 | **Test Scenarios** |  | 20d | 2023-10-05 A | 2023-11-02 A |  | 100% |  |  | 2023-10-05 | 2023-11-02 | 20d | 2022-10-31 | 2023-09-15 |  | -0 | N/A | N/A | 5.0 | N/A | Design, Build & Test (PIT) |  |  |  |  |  |  |
| 392 | 1.3.6.3.5.1.5.1 | All Network Operation test scenarios' submitted to Programme for assurance | milestone | 0d | 2023-10-05 A | 2023-10-05 A | 384FS+15d | 100% |  |  | 2023-10-05 | 2023-10-05 | 0d | 2023-09-01 | 2023-09-01 |  |  | PP | SI Test | 5.8 | Lee Cox | Design, Build & Test (PIT) | Complete | COMPLETE |  | T3-DB-0011 | SITAG | T3 |
| 393 | 1.3.6.3.5.1.5.2 | All Network Operation test scenarios' MHHS Review Completed | milestone | 0d | 2023-11-02 A | 2023-11-02 A | 392FS+20d | 100% |  |  | 2023-11-02 | 2023-11-02 | 0d | 2023-09-04 | 2023-09-15 |  |  | SI Test | PP | 5.14 | Lee Cox | Design, Build & Test (PIT) | Complete | COMPLETE |  | T3-DB-0174 | SITAG | T3 |
| 394 | 1.3.6.3.5.1.6 | **PIT execution** |  | 51d | 2023-10-13 A | 2023-12-22 A |  | 100% |  |  | 2022-10-31 | 2024-01-05 | 310d | 2022-10-31 | 2024-01-05 |  | -0 | N/A | N/A | 5.0 | N/A | Design, Build & Test (PIT) |  |  |  |  |  |  |
| 395 | 1.3.6.3.5.1.6.1 | PIT Test Execution Progress Report |  | 40d | 2023-10-16 A | 2023-12-08 A | 392FS+5d, 387 | 100% |  |  | 2022-10-31 | 2023-12-29 | 305d | 2022-10-31 | 2023-12-29 |  |  | PP | SI Test | 5.0 | Lee Cox | Design, Build & Test (PIT) | Complete | COMPLETE |  |  |  |  |
| 396 | 1.3.6.3.5.1.6.2 | PIT Execution |  | 41d | 2023-10-13 A | 2023-12-08 A | 392FS+5d | 100% |  |  | 2022-10-31 | 2024-01-05 | 310d | 2022-10-31 | 2024-01-05 |  |  | PP | SI Test | 5.0 | Lee Cox | Design, Build & Test (PIT) | Complete | COMPLETE |  |  |  |  |
| 397 | 1.3.6.3.5.1.6.3 | All Network Operation PIT (CIT interval 5) Completion Reports submitted to Programme for assurance | milestone | 0d | 2023-12-08 A | 2023-12-08 A | 396, 395 | 100% |  |  | 2023-12-08 | 2023-12-08 | 0d | 2024-01-05 | 2024-01-05 |  |  | PP | SI Test | 5.0 | Lee Cox | Design, Build & Test (PIT) | Complete | COMPLETE |  | T3-DB-0175 | SITAG | T3 |
| 398 | 1.3.6.3.5.1.6.4 | All Network Operation PIT (CIT interval 5) Completion Reports MHHS Review Completed | milestone | 0d | 2023-12-22 A | 2023-12-22 A | 397FS+10d, 385, 390, 393 | 100% |  |  | 2023-12-22 | 2023-12-22 | 0d |  |  |  |  | SI Test | PP | 5.15 | Lee Cox | Design, Build & Test (PIT) | Complete | COMPLETE |  | T3-DB-0176 | SITAG | T3 |
| 399 | 1.3.6.3.6 | **All UMSO DBT CIT (Entering at Interval 6)** |  | 81d | 2023-09-29 | 2024-01-19 A |  | 100% | 2023-10-13 |  | 2022-10-31 | 2024-01-19 | 320d | 2022-10-31 | 2024-05-13 |  | -0 | N/A | N/A | 5.0 | N/A | Design, Build & Test (PIT) |  |  |  |  |  |  |
| 400 | 1.3.6.3.6.1 | **Test Approach & Plan** |  | 20d | 2023-10-13 A | 2023-11-09 A |  | 100% |  |  | 2023-09-15 | 2023-11-09 | 40d | 2022-10-31 | 2023-09-29 |  | -0 | N/A | N/A | 5.0 | N/A | Design, Build & Test (PIT) |  |  |  |  |  |  |
| 401 | 1.3.6.3.6.1.1 | All UMSO Test Approach & Plans (PIT) submitted to Programme for assurance | milestone | 0d | 2023-10-13 A | 2023-10-13 A |  | 100% |  |  | 2023-09-15 | 2023-09-15 | 0d | 2023-09-15 | 2023-09-15 | start no earlier than 2023-10-13 |  | PP | SI Test | 5.11 | Lee Cox | Design, Build & Test (PIT) | Complete | COMPLETE |  | T3-DB-0052 | SITAG | T3 |
| 402 | 1.3.6.3.6.1.2 | All UMSO Test Approach & Plans MHHS Review Completed | milestone | 0d | 2023-11-09 A | 2023-11-09 A | 401FS+20d | 100% |  |  | 2023-11-09 | 2023-11-09 | 0d | 2023-09-18 | 2023-09-29 |  |  | SI Test | PP | 5.10 | Lee Cox | Design, Build & Test (PIT) | Complete | COMPLETE |  | T3-DB-0177 | SITAG | T3 |
| 403 | 1.3.6.3.6.2 | **Test Readiness Report** |  | 11d | 2023-09-29 | 2023-10-13 |  | 100% | 2023-10-27 | 2023-11-10 | 2023-10-27 | 2023-11-10 | 11d | 2023-09-29 | 2023-12-08 |  | -0 | N/A | N/A | 5.0 | N/A | Design, Build & Test (PIT) |  |  |  |  |  |  |
| 404 | 1.3.6.3.6.2.1 | Test readiness reporting |  | 11d | 2023-10-27 A | 2023-11-10 A | 401FS+10d | 100% |  |  | 2023-10-27 | 2023-11-10 | 11d | 2023-09-29 | 2023-12-08 |  |  | PP | 109 | 5.0 | Lee Cox | Design, Build & Test (PIT) | Complete | COMPLETE |  |  |  |  |
| 405 | 1.3.6.3.6.3 | **Requirements to test Traceability Matrix (RTTM)** |  | 20d | 2023-10-05 | 2023-11-01 |  | 100% | 2023-11-02 | 2023-11-30 | 2023-11-02 | 2023-11-30 | 20d | 2022-10-31 | 2023-10-20 |  | -0 | N/A | N/A | 5.0 | N/A | Design, Build & Test (PIT) |  |  |  |  |  |  |
| 406 | 1.3.6.3.6.3.1 | All UMSO RTTMs submitted to Programme for assurance | milestone | 0d | 2023-11-02 A | 2023-11-02 A | 401FS+15d | 100% |  |  | 2023-11-02 | 2023-11-02 | 0d | 2023-10-06 | 2023-10-06 |  |  | PP | SI Test | 5.12 | Lee Cox | Design, Build & Test (PIT) | Complete | COMPLETE | MHHS-ART009 | T3-DB-0060 | SITAG | T3 |
| 407 | 1.3.6.3.6.3.2 | All UMSO RTTMs MHHS Review Completed | milestone | 0d | 2023-11-30 A | 2023-11-30 A | 406FS+20d | 100% |  |  | 2023-11-30 | 2023-11-30 | 0d | 2023-10-09 | 2023-10-20 |  |  | SI Test | PP | 5.12 | Lee Cox | Design, Build & Test (PIT) | Complete | COMPLETE |  | T3-DB-0178 | SITAG | T3 |
| 408 | 1.3.6.3.6.4 | **Test Scenarios** |  | 20d | 2023-10-05 | 2023-11-01 |  | 100% | 2023-11-02 | 2023-11-30 | 2023-11-02 | 2023-11-30 | 20d | 2022-10-31 | 2023-10-20 |  | -0 | N/A | N/A | 5.0 | N/A | Design, Build & Test (PIT) |  |  |  |  |  |  |
| 409 | 1.3.6.3.6.4.1 | All UMSO test scenarios' submitted to Programme for assurance | milestone | 0d | 2023-11-02 A | 2023-11-02 A | 401FS+15d | 100% |  |  | 2023-11-02 | 2023-11-02 | 0d | 2023-10-06 | 2023-10-06 |  |  | PP | SI Test | 5.12 | Lee Cox | Design, Build & Test (PIT) | Complete | COMPLETE |  | T3-DB-0025 | SITAG | T3 |
| 410 | 1.3.6.3.6.4.2 | All UMSO Test scenarios' MHHS Review Completed | milestone | 0d | 2023-11-30 A | 2023-11-30 A | 409FS+20d | 100% |  |  | 2023-11-30 | 2023-11-30 | 0d | 2023-10-09 | 2023-10-20 |  |  | SI Test | PP | 5.10 | Lee Cox | Design, Build & Test (PIT) | Complete | COMPLETE |  | T3-DB-0179 | SITAG | T3 |

Notes:
- 389: 12/9 - TMAG for name and date change Approved at TMAG on 20/9. 10/10 - Red because 50% of RTTMs outstanding
- 390: 17/10 - Red because open comments still outstanding. Assurance reviews complete. Review will be completed no later than 08/01/24 ahead of Interval 5 Readiness Report . 19/12 - completed 14/12
- 392: 12/9 - TMAG for name and date change. Approved at TMAG on 20/9. 17/10 - Red because currently 50% have been received. Date change under consideration.
- 393: 17/10 - Red because open comments still outstanding. Assurance reviews complete. Review will be completed no later than 08/01/24 ahead of Interval 5 Readiness Assessment . 19/12 - completed 14/12
- 397: 11/9 - to be raised as new T3 at TMAG. Approved at TMAG on 20/9. 19/12 - completed 14/12
- 398: 11/9 - to be raised as new T3 at TMAG. Approved at TMAG on 20/9. 12/12 - Amber because all reviews complete, clarifications are requested
- 401: 12/9 - TMAG for name and date change. Approved at TMAG on 20/9. 17/10 - Red because not all received. Currently no impact. Issuance request sent. Complete 1/11
- 402: To go to TMAG for date change. Approved for date change at TMAG on 23/10/23. 7/11-Amber because of high volume and backlog to be reviewed. Review will be completed no later than 22/01/24 ahead of Interval 6 Readiness Assessment
- 406: 4/10 - Red because baseline date incorrect. To go to TMAG for date change. Approved for date change at TMAG on 23/10/23. 14/11-Red because up to 50% not received. No impact. No action
- 407: 1/9 - to be raised as new T3 at TMAG. Approved at TMAG on 20/9. 4/10 - Red because baseline date incorrect. To go to TMAG for date change. Approved for date change at TMAG on 23/10/23
- 409: Approved at TMAG on 20/9. 4/10 - Red because baseline date incorrect. To go to TMAG for date change. Approved for date change at TMAG on 23/10/23. 7/11-Red because not received. Expected 10/11. No impact No action
- 410: 1/9 - to be raised as new T3 at TMAG. Approved at TMAG on 20/9. 5/12 - Assurance review conducted, but outstanding comments to be addressed

| ID | WBS | Task | Type | Duration | Start | Finish | Predecessors | Complete | Remaining | Baseline start | Baseline finish | Baseline duration | Baseline 1 start | Baseline 1 finish | Total slack | Constraint | Baseline cost | Responsible | Involved | Update Version | MHHS Resource Name | MHHS Programme Phase | Sched Status | RAG | Milestone ID | Text29 | Tier | Task Status | Artefact ID |
| --- | --- | --- | --- | --- | --- | --- | --- | --- | --- | --- | --- | --- | --- | --- | --- | --- | --- | --- | --- | --- | --- | --- | --- | --- | --- | --- | --- | --- | --- |
| 411 | 1.3.6.3.6.5 | **PIT execution** |  | 51d | 2023-11-10 A | 2024-01-19 A |  | 100% |  | 2022-10-31 | 2024-01-19 | 320d | 2022-10-31 | 2023-12-08 |  |  | -0 | N/A | N/A | 5.0 | N/A | Design, Build & Test (PIT) |  |  |  |  |  |  |  |
| 412 | 1.3.6.3.6.5.1 | PIT Test Execution Progress Report |  | 40d | 2023-11-13 A | 2024-01-05 A | 409FS+5d, 404 | 100% |  | 2023-11-13 | 2024-01-05 | 40d | 2022-10-31 | 2023-12-01 |  |  |  | PP | SI Test | 5.0 | Lee Cox | Design, Build & Test (PIT) | Complete | COMPLETE |  |  |  |  |  |
| 413 | 1.3.6.3.6.5.2 | PIT Execution |  | 40d | 2023-11-10 A | 2024-01-04 A | 409FS+5d | 100% |  | 2022-10-31 | 2024-01-05 | 290d | 2022-10-31 | 2023-12-08 |  |  |  | PP | SI Test | 5.0 | Lee Cox | Design, Build & Test (PIT) | Complete | COMPLETE |  |  |  |  |  |
| 414 | 1.3.6.3.6.5.3 | All UMSO PIT (CIT interval 6) Completion Reports submitted to Programme for assurance | milestone | 0d | 2024-01-05 A | 2024-01-05 A | 413, 412 | 100% |  | 2024-01-05 | 2024-01-05 | 0d | 2024-01-05 | 2024-01-05 |  |  |  | PP | SI Test | 5.10 | Lee Cox | Design, Build & Test (PIT) | Complete | COMPLETE | T3-DB-0180 | SITAG | T3 |  |  |
| 415 | 1.3.6.3.6.5.4 | All UMSO PIT (CIT interval 6) Completion Reports MHHS Review Completed | milestone | 0d | 2024-01-19 A | 2024-01-19 A | 402, 407, 410, 414FS+10d | 100% |  | 2024-01-19 | 2024-01-19 | 0d |  |  |  |  |  | SI Test | PP | 5.10 | Lee Cox | Design, Build & Test (PIT) | Complete | COMPLETE | T3-DB-0181 | SITAG | T3 |  |  |
| 416 | 1.3.7 | **DBT Monitoring and Assurance** |  | 842d | 2022-10-31 A | 2026-01-20 |  | 64% | 301d | 2022-10-31 | 2026-01-20 | 842d | 2022-10-31 | 2026-01-19 | 353d |  |  | N/A | N/A | 5.0 | N/A | Design, Build & Test (PIT) |  |  |  |  |  |  |  |
| 417 | 1.3.7.1 | **Planning and DBT Progress Monitoring of PPs** |  | 696d | 2022-10-31 A | 2025-06-30 |  | 67% | 233d | 2022-10-31 | 2025-06-30 | 696d | 2022-10-31 | 2025-06-30 | 499d |  |  | N/A | N/A | 5.0 | N/A | Design, Build & Test (PIT) |  |  |  |  |  | M9 |  |
| 418 | 1.3.7.1.1 | Monitor Non-SIT PPs Planning and DBT1 progress (to inform confirmation of Qualification Testing Tranche participants milestones) |  | 696d | 2022-10-31 A | 2025-06-30 | 164SS | 67% | 233d | 2022-10-31 | 2025-06-30 | 696d | 2022-10-31 | 2025-06-30 | 499d |  |  | Code Bodies | SI Test,PPC | 5.0 | Roger Robar | Design, Build & Test (PIT) | Green | GREEN |  |  |  |  |  |
| 419 | 1.3.7.2 | **DBT Progress Monitoring of Consequential Change** |  | 774d | 2023-02-02 A | 2026-01-20 |  | 51% | 379d | 2023-02-02 | 2026-01-20 | 774d | 2023-02-01 | 2026-01-19 | 353d |  |  | N/A | N/A | 5.0 | N/A | Design, Build & Test (PIT) |  |  |  |  |  | M9 |  |
| 420 | 1.3.7.2.1 | Monitor & report data cleanse progress |  | 774d | 2023-02-02 A | 2026-01-20 |  | 51% | 379d | 2023-02-02 | 2026-01-20 | 774d | 2023-02-01 | 2026-01-19 | 353d |  |  | SI Test | PPC | 5.0 | Matthew Breen | Design, Build & Test (PIT) | Green | GREEN |  |  |  |  |  |
| 421 | 1.3.7.3 | **Design Assurance** |  | 713d | 2022-11-14 A | 2025-08-06 |  | 71% | 206.27d | 2022-11-14 | 2025-08-06 | 713d | 2022-11-14 | 2025-08-06 | 472d |  |  | N/A | N/A | 5.0 | N/A | Design, Build & Test (PIT) |  |  |  |  |  | M9 |  |
| 422 | 1.3.7.3.1 | **Design Assurance Readiness Assessment Preparation** |  | 39d | 2023-02-28 A | 2023-04-21 A |  | 100% |  | 2023-02-28 | 2023-04-21 | 39d | 2023-02-28 | 2023-04-21 |  |  |  | N/A | N/A | 5.0 | N/A | Design, Build & Test (PIT) |  |  |  |  |  |  |  |
| 423 | 1.3.7.3.1.1 | Set up FTIG |  | 15d | 2023-04-03 A | 2023-04-21 A |  | 100% |  | 2023-04-03 | 2023-04-21 | 15d | 2023-04-03 | 2023-04-21 |  | must start on 2023-04-03 |  | SI Design |  | 5.0 | Paul Pettitt | Design, Build & Test (PIT) | Complete | COMPLETE |  |  |  |  |  |
| 424 | 1.3.7.3.1.2 | Produce Draft Questions |  | 10d | 2023-02-28 A | 2023-03-13 A |  | 100% |  | 2023-02-28 | 2023-03-13 | 10d | 2023-02-28 | 2023-03-13 |  | must start on 2023-02-28 |  | SI Design |  | 5.0 | Paul Pettitt | Design, Build & Test (PIT) | Complete | COMPLETE |  |  |  |  |  |
| 425 | 1.3.7.3.1.3 | Pilot with SRO |  | 1d | 2023-03-14 A | 2023-03-14 A | 424 | 100% |  | 2023-03-14 | 2023-03-14 | 1d | 2023-03-14 | 2023-03-14 |  |  |  | SI Design |  | 5.0 | Paul Pettitt | Design, Build & Test (PIT) | Complete | COMPLETE |  |  |  |  |  |
| 426 | 1.3.7.3.1.4 | Finalise questions |  | 10d | 2023-03-15 A | 2023-03-28 A | 425 | 100% |  | 2023-03-15 | 2023-03-28 | 10d | 2023-03-15 | 2023-03-28 |  |  |  | SI Design |  | 5.0 | Paul Pettitt | Design, Build & Test (PIT) | Complete | COMPLETE |  |  |  |  |  |
| 427 | 1.3.7.3.1.5 | Prepare on-line RA tooling |  | 10d | 2023-03-29 A | 2023-04-11 A | 426 | 100% |  | 2023-03-29 | 2023-04-11 | 10d | 2023-03-29 | 2023-04-11 |  |  |  | SI Design |  | 5.0 | Paul Pettitt | Design, Build & Test (PIT) | Complete | COMPLETE |  |  |  |  |  |
| 428 | 1.3.7.3.1.6 | Prepare webinar content |  | 5d | 2023-03-20 A | 2023-03-24 A | 424FS+4d | 100% |  | 2023-03-20 | 2023-03-24 | 5d | 2023-03-20 | 2023-03-24 |  |  |  | SI Design |  | 5.0 | Paul Pettitt | Design, Build & Test (PIT) | Complete | COMPLETE |  |  |  |  |  |
| 429 | 1.3.7.3.1.7 | Conduct webinar |  | 1d | 2023-03-30 A | 2023-03-30 A | 428FS+3d | 100% |  | 2023-03-30 | 2023-03-30 | 1d | 2023-03-30 | 2023-03-30 |  |  |  | SI Design | PP | 5.0 | Paul Pettitt | Design, Build & Test (PIT) | Complete | COMPLETE |  |  |  |  |  |
| 430 | 1.3.7.3.2 | **Participant Design Assurance Approach** |  | 43d | 2022-11-14 A | 2023-01-11 A |  | 100% |  | 2022-11-14 | 2023-01-11 | 43d | 2022-11-14 | 2023-01-11 |  |  |  | N/A | N/A | 5.0 | N/A | Design, Build & Test (PIT) |  |  |  |  |  |  |  |
| 431 | 1.3.7.3.2.1 | Develop document |  | 20d | 2022-11-14 A | 2022-12-09 A | 48FS+10d | 100% |  | 2022-11-14 | 2022-12-09 | 20d | 2022-11-14 | 2022-12-09 |  | start no earlier than 2022-11-14 |  | SI Design | PP | 5.0 | Paul Pettitt | Design, Build & Test (PIT) | Complete | COMPLETE |  |  |  |  |  |
| 432 | 1.3.7.3.2.2 | Review document |  | 18d | 2022-12-12 A | 2023-01-04 A | 431 | 100% |  | 2022-12-12 | 2023-01-04 | 18d | 2022-12-12 | 2023-01-04 |  |  |  | PP | SI Design,IPA | 5.0 | Paul Pettitt | Design, Build & Test (PIT) | Complete | COMPLETE |  |  |  |  |  |
| 433 | 1.3.7.3.2.3 | Participant Design Assurance Approach approved | milestone | 0d | 2023-01-11 A | 2023-01-11 A | 432FF+5d | 100% |  | 2023-01-11 | 2023-01-11 | 0d | 2023-01-11 | 2023-01-11 |  |  |  | SI Design | PP | 5.0 | Paul Pettitt | Design, Build & Test (PIT) | Complete | COMPLETE | T3-DB-0012 | DAG | T3 |  |  |
| 434 | 1.3.7.3.3 | **Phase 1 - SIT Volunteers (Core Providers)** |  | 145d | 2023-04-10 A | 2023-10-27 A |  | 100% |  | 2023-04-10 | 2023-10-27 | 145d | 2023-04-10 | 2023-10-27 |  |  |  | N/A | N/A | 5.0 | N/A | Design, Build & Test (PIT) |  |  |  |  |  |  |  |
| 435 | 1.3.7.3.3.1 | Send on-line questionnaire to core capability providers and current SIT volunteers (from Round 3 consultation) |  | 1d | 2023-04-10 A | 2023-04-10 A |  | 100% |  | 2023-04-10 | 2023-04-10 | 1d | 2023-04-10 | 2023-04-10 |  | must start on 2023-04-10 |  | SI Design | PP | 5.0 | Paul Pettitt | Design, Build & Test (PIT) | Complete | COMPLETE |  |  |  |  |  |
| 436 | 1.3.7.3.3.2 | Participants Provide Responses to questionnaires |  | 15d | 2023-04-11 A | 2023-05-01 A | 435 | 100% |  | 2023-04-11 | 2023-05-01 | 15d | 2023-04-11 | 2023-05-01 |  |  |  | PP |  | 5.0 | Paul Pettitt | Design, Build & Test (PIT) | Complete | COMPLETE |  |  |  |  |  |
| 437 | 1.3.7.3.3.3 | Assess on-line responses and provided evidence |  | 5d | 2023-05-02 A | 2023-05-08 A | 436 | 100% |  | 2023-05-02 | 2023-05-08 | 5d | 2023-05-02 | 2023-05-08 |  |  |  | SI Design |  | 5.0 | Paul Pettitt | Design, Build & Test (PIT) | Complete | COMPLETE |  |  |  |  |  |
| 438 | 1.3.7.3.3.4 | Bi-lateral meeting with each responder, to walk and navigate through provided materials |  | 31d | 2023-05-09 A | 2023-06-20 A | 437 | 100% |  | 2023-05-09 | 2023-06-20 | 31d | 2023-05-09 | 2023-06-20 |  |  |  | SI Design | PP | 5.0 | Paul Pettitt | Design, Build & Test (PIT) | Complete | COMPLETE |  |  |  |  |  |
| 439 | 1.3.7.3.3.5 | Plan for, create and execute deep dive assurance interviews based on agreed priorities (participants, design areas) |  | 62d | 2023-06-07 A | 2023-08-31 A | 438FS-10d | 100% |  | 2023-06-07 | 2023-08-31 | 62d | 2023-06-07 | 2023-08-01 |  |  |  | SI Design |  | 5.2 | Paul Pettitt | Design, Build & Test (PIT) | Complete | COMPLETE |  |  |  |  |  |
| 440 | 1.3.7.3.3.6 | SI endorsement of participants’ design – assurance reports |  | 43d | 2023-08-02 A | 2023-09-29 A | 439FS-22d | 100% |  | 2023-08-02 | 2023-09-29 | 43d | 2023-08-02 | 2023-08-15 |  |  |  | SI Design |  | 5.2 | Paul Pettitt | Design, Build & Test (PIT) | Complete | COMPLETE |  |  |  |  |  |
| 441 | 1.3.7.3.3.7 | Post-assurance review of recommendations take-up by assured participants |  | 44d | 2023-08-29 A | 2023-10-27 A | 440SS+19d | 100% |  | 2023-10-02 | 2023-10-27 | 20d | 2023-08-16 | 2023-10-27 |  |  |  | SI Design |  | 5.2 | Paul Pettitt | Design, Build & Test (PIT) | Complete | COMPLETE |  |  |  |  |  |
| 442 | 1.3.7.3.3.8 | Phase 1 - SIT Volunteers (Core Providers) complete | milestone | 0d | 2023-10-27 A | 2023-10-27 A | 441 | 100% |  | 2023-10-27 | 2023-10-27 | 0d | 2023-10-27 | 2023-10-27 |  |  |  | SI Design |  | 5.11 | Paul Pettitt | Design, Build & Test (PIT) | Complete | COMPLETE | T2-DB-0100 | DAG | T2 |  | MHHS-ART002 |

Notes:
- 414: . 4/10 - Red because baseline date incorrect. To go to TMAG for date change. Approved for date change at TMAG on 23/10/23. 16/1 - Not all completion reports yet received. Completed on 21/2
- 415: Red because baseline date incorrect. To go to TMAG for date change. Approved for date change at TMAG on 23/10/23. 16/01 - Late due to late delivery of PP artefacts for review. Completed on 21/2
- 418: 15/9 - hold in plan until qualification sections updated
- 420: 15/9 - query with John Wiggins where this sits
- 442: 16/10 Awaiting the issuing of backlog reports. But no significant design impacts identified. No impact to commencing SIT

| ID | WBS | Task | Type | Duration | Start | Finish | Predecessors | Complete | Remaining | Baseline start | Baseline finish | Baseline duration | Baseline 1 start | Baseline 1 finish | Total slack | Constraint | Baseline cost | Responsible | Involved | Update Version | MHHS Resource Name | MHHS Programme Phase | Sched Status | RAG | Artefact ID | Milestone ID | Text29 | Tier | Task Status | Text3 |
| --- | --- | --- | --- | --- | --- | --- | --- | --- | --- | --- | --- | --- | --- | --- | --- | --- | --- | --- | --- | --- | --- | --- | --- | --- | --- | --- | --- | --- | --- | --- |
| 443 | 1.3.7.3.4 | **Phase 2 - SIT all other participants** |  | 143d | 2023-05-08 A | 2023-11-22 A |  | 100% |  | 2023-05-08 | 2023-11-22 | 143d | 2023-05-08 | 2023-11-22 |  |  |  | N/A | N/A | 5.0 | N/A | Design, Build & Test (PIT) |  |  |  |  |  |  |  |  |
| 444 | 1.3.7.3.4.1 | Send on-line questionnaire to core capability providers and current SIT volunteers (from Round 3 consultation) |  | 1d | 2023-05-08 A | 2023-05-08 A |  | 100% |  | 2023-05-08 | 2023-05-08 | 1d | 2023-05-08 | 2023-05-08 |  | must start on 2023-05-08 |  | SI Design | PP | 5.0 | Paul Pettitt | Design, Build & Test (PIT) | Complete | COMPLETE |  |  |  |  |  |  |
| 445 | 1.3.7.3.4.2 | Participants Provide Responses to questionnaires |  | 15d | 2023-05-09 A | 2023-05-29 A | 444 | 100% |  | 2023-05-09 | 2023-05-29 | 15d | 2023-05-09 | 2023-05-29 |  |  |  | PP |  | 5.0 | Paul Pettitt | Design, Build & Test (PIT) | Complete | COMPLETE |  |  |  |  |  |  |
| 446 | 1.3.7.3.4.3 | Assess on-line responses and provided evidence |  | 5d | 2023-05-30 A | 2023-06-05 A | 445 | 100% |  | 2023-05-30 | 2023-06-05 | 5d | 2023-05-30 | 2023-06-05 |  |  |  | SI Design |  | 5.0 | Paul Pettitt | Design, Build & Test (PIT) | Complete | COMPLETE |  |  |  |  |  |  |
| 447 | 1.3.7.3.4.4 | Bi-lateral meeting with each responder, to walk and navigate through provided materials |  | 84d | 2023-06-06 A | 2023-09-29 A | 446 | 100% |  | 2023-06-06 | 2023-09-29 | 84d | 2023-06-06 | 2023-07-18 |  |  |  | SI Design | PP | 5.2 | Paul Pettitt | Design, Build & Test (PIT) | Complete | COMPLETE |  |  |  |  |  |  |
| 448 | 1.3.7.3.4.5 | Plan for, create and execute deep dive assurance interviews based on agreed priorities (participants, design areas) |  | 69d | 2023-06-27 A | 2023-09-29 A | 447SS+15d | 100% |  | 2023-06-27 | 2023-09-29 | 69d | 2023-07-05 | 2023-08-29 |  |  |  | SI Design |  | 5.2 | Paul Pettitt | Design, Build & Test (PIT) | Complete | COMPLETE |  |  |  |  |  |  |
| 449 | 1.3.7.3.4.6 | SI endorsement of participants’ design – assurance reports |  | 54d | 2023-07-18 A | 2023-09-29 A | 448SS+15d | 100% |  | 2023-07-18 | 2023-09-29 | 54d | 2023-08-30 | 2023-09-12 |  |  |  | SI Design |  | 5.2 | Paul Pettitt | Design, Build & Test (PIT) | Complete | COMPLETE |  |  |  |  |  |  |
| 450 | 1.3.7.3.4.7 | Post-assurance review of recommendations take-up by assured participants |  | 73d | 2023-08-14 A | 2023-11-22 A | 449SS+19d | 100% |  | 2023-10-02 | 2023-11-22 | 38d | 2023-09-13 | 2023-11-22 |  |  |  | SI Design |  | 5.2 | Paul Pettitt | Design, Build & Test (PIT) | Complete | COMPLETE |  |  |  |  |  |  |
| 451 | 1.3.7.3.4.8 | SIT PPs design assurance (excl Migration/Reverse Migration) complete | milestone | 0d | 2023-11-22 A | 2023-11-22 A | 450 | 100% |  | 2023-11-22 | 2023-11-22 | 0d | 2023-11-22 | 2023-11-22 |  |  |  | SI Design |  | 5.11 | Paul Pettitt | Design, Build & Test (PIT) | Complete | COMPLETE | MHHS-ART002 | T2-DB-0200 | DAG | T2 |  |  |
| 452 | 1.3.7.3.5 | **Non-SIT PPs design assurance** |  | 445d | 2023-11-23 A | 2025-08-06 |  | 33% | 300d | 2023-11-23 | 2025-08-06 | 445d | 2023-11-23 | 2025-08-06 | 472d |  |  | N/A | N/A | 5.0 | N/A | Design, Build & Test (PIT) |  |  |  |  |  |  |  |  |
| 453 | 1.3.7.3.5.1 | Non-SIT PPs design assurance (risk-based sample) |  | 445d | 2023-11-23 A | 2025-08-06 | 451 | 33% | 300d | 2023-11-23 | 2025-08-06 | 445d | 2023-11-23 | 2025-08-06 | 472d |  |  | SI Design | PPC | 5.0 | Paul Pettitt | Design, Build & Test (PIT) | Green | GREEN |  |  |  |  |  |  |
| 454 | 1.3.7.4 | **Test Assurance** |  | 629d | 2023-02-01 A | 2025-06-30 |  | 63% | 233d | 2022-10-31 | 2025-06-30 | 696d | 2022-10-31 | 2025-06-30 | 499d |  |  | N/A | N/A | 5.0 | N/A | Design, Build & Test (PIT) |  |  |  |  |  |  | M9 |  |
| 455 | 1.3.7.4.1 | Non-SIT PPs test assurance |  | 629d | 2023-02-01 A | 2025-06-30 |  | 63% | 233d | 2023-02-01 | 2025-06-30 | 629d | 2023-02-01 | 2025-06-30 | 499d |  |  | Code Bodies | PP,PPC,SI Test | 5.0 | Roger Robar | Design, Build & Test (PIT) | Green | GREEN |  |  |  |  |  |  |
| 456 | 1.3.7.5 | **Pre-Qualification Guidance (PIT Guidance)** |  | 67d | 2022-10-31 A | 2023-01-31 A |  | 100% |  | 2022-10-31 | 2023-01-31 | 67d | 2022-10-31 | 2023-01-31 |  |  |  | N/A | N/A | 5.0 | N/A | Design, Build & Test (PIT) |  |  |  |  |  |  |  |  |
| 457 | 1.3.7.5.1 | Develop document (incl. collaboration with code bodies, as required) |  | 56d | 2022-10-31 A | 2023-01-16 A |  | 100% |  | 2022-10-31 | 2023-01-16 | 56d | 2022-10-31 | 2023-01-16 |  |  |  | SI Test | Code Bodies | 5.0 | Lee Cox | Design, Build & Test (PIT) | Complete | COMPLETE |  |  |  |  |  |  |
| 458 | 1.3.7.5.2 | Review, update and agree Pre-Qualification Guidance internally |  | 11d | 2023-01-17 A | 2023-01-31 A | 457 | 100% |  | 2023-01-17 | 2023-01-31 | 11d | 2023-01-17 | 2023-01-31 |  |  |  | SRO Function | IPA,SI Test | 5.0 | Lee Cox | Design, Build & Test (PIT) | Complete | COMPLETE |  |  |  |  |  |  |
| 459 | 1.3.7.6 | **External Programme Dependency Management** |  | 0d | 2022-11-03 A | 2022-11-03 A |  | 100% |  | 2022-11-03 | 2022-11-03 | 0d | 2022-11-03 | 2022-11-03 |  |  |  | N/A | N/A | 5.0 | N/A | Design, Build & Test (PIT) |  |  |  |  |  |  |  |  |
| 460 | 1.3.7.6.1 | **SLC47** |  | 0d | 2022-11-03 A | 2022-11-03 A |  | 100% |  | 2022-11-03 | 2022-11-03 | 0d | 2022-11-03 | 2022-11-03 |  |  |  | N/A | N/A | 5.0 | N/A | Design, Build & Test (PIT) |  |  |  |  |  |  |  |  |
| 461 | 1.3.7.6.1.1 | SLC47 implementation date | milestone | 0d | 2022-11-03 A | 2022-11-03 A |  | 100% |  | 2022-11-03 | 2022-11-03 | 0d | 2022-11-03 | 2022-11-03 |  | start no earlier than 2022-11-03 |  | Ofgem |  | 5.0 | Lee Cox | Design, Build & Test (PIT) | Complete | COMPLETE |  |  |  |  |  |  |
| 462 | 1.4 | **SYSTEMS INTEGRATION TESTING (SIT)** |  | 910d | 2022-10-31 A | 2026-04-24 |  | 66% | 305.01d | 2022-10-31 | 2026-01-19 | 841d | 2022-10-31 | 2026-01-19 | 285d |  | -0 | N/A | N/A |  | N/A | Systems Integration Testing (SIT) |  |  |  |  |  |  |  | 1 Aug 2023 - 30 Sep 2024 |
| 463 | 1.4.1 | **SIT Preparation** |  | 520d | 2022-10-31 A | 2024-10-25 |  | 98% | 11.87d | 2022-10-31 | 2025-03-03 | 611d | 2022-10-31 | 2025-03-10 | 675d |  | -0 | N/A | N/A | 5.0 | N/A | Systems Integration Testing (SIT) |  |  |  |  |  |  |  |  |
| 464 | 1.4.1.1 | **Test Artefact Development** |  | 472d | 2022-10-31 A | 2024-08-21 |  | 99% | 2.69d | 2022-10-31 | 2024-08-21 | 472d | 2022-10-31 | 2023-09-01 | 723d |  | -0 | N/A | N/A | 5.0 | N/A | Systems Integration Testing (SIT) |  |  |  |  |  |  | M9 |  |
| 465 | 1.4.1.1.1 | **Environment Approach & Plan** |  | 460d | 2022-11-16 A | 2024-08-21 A |  | 100% |  | 2022-11-16 | 2024-08-21 | 460d | 2022-11-16 | 2023-06-30 |  |  | -0 | N/A | N/A | 5.0 | N/A | Systems Integration Testing (SIT) |  |  |  |  |  |  |  |  |
| 466 | 1.4.1.1.1.1 | Environment Approach & Plan approved | milestone | 0d | 2022-11-16 A | 2022-11-16 A |  | 100% |  | 2022-11-16 | 2022-11-16 | 0d | 2022-11-16 | 2022-11-16 |  | start no earlier than 2022-11-16 |  | SI Test | PP | 5.0 | Simon Berry | Systems Integration Testing (SIT) | Complete | COMPLETE | MHHS-ART139 | T3-TE-0010 | SITAG | T3 |  |  |
| 467 | 1.4.1.1.1.2 | Environment Approach & Plan - Work Off |  | 157d | 2022-11-17 A | 2023-06-23 A | 466FS+1d | 100% |  | 2022-11-17 | 2023-06-23 | 157d | 2022-11-17 | 2023-06-23 |  |  |  | SI Test | PP | 5.0 | Simon Berry | Systems Integration Testing (SIT) | Complete | COMPLETE |  |  |  |  |  |  |
| 468 | 1.4.1.1.1.3 | Environment Approach & Plan - Work Off Approved | milestone | 0d | 2023-08-16 A | 2023-08-16 A | 467FS+5d | 100% |  | 2023-08-16 | 2023-08-16 | 0d | 2023-06-30 | 2023-06-30 |  | start no earlier than 2023-08-16 |  | SI Test | PP | 5.0 | Simon Berry | Systems Integration Testing (SIT) | Complete | COMPLETE | MHHS-ART139 | T3-TE-0068 | SITAG | T3 |  |  |
| 469 | 1.4.1.1.1.4 | Environment Approach and Plan - SIT Functional | milestone | 0d | 2023-11-20 A | 2023-11-20 A |  | 100% |  | 2023-11-15 | 2023-11-15 | 0d |  |  |  | start no earlier than 2023-11-20 |  | SI Test | PP | 5.12 | Simon Berry | Systems Integration Testing (SIT) | Complete | COMPLETE | MHHS-DEL 618 | T3-TE-0090 | SITAG | T3 |  |  |
| 470 | 1.4.1.1.1.5 | Define Approach to Simulator for Non-SIT LDSO | milestone | 0d | 2023-11-15 A | 2023-11-15 A |  | 100% |  | 2023-11-15 | 2023-11-15 | 0d |  |  |  | start no earlier than 2023-11-15 |  | SI Test | PP | 5.12 | Simon Berry |  | Complete | COMPLETE |  |  |  |  |  |  |
| 471 | 1.4.1.1.1.6 | Environment Approach and Plan - Non SIT LDSO Testing | milestone | 0d | 2024-04-17 A | 2024-04-17 A |  | 100% |  | 2024-04-17 | 2024-04-17 | 0d |  |  |  | start no earlier than 2024-04-17 |  | SI Test | PP | 5.22 | Simon Berry | Systems Integration Testing (SIT) | Complete | COMPLETE | MHHS-DEL 619 | T3-TE-0091 | SITAG/QAG | T3 |  |  |
| 472 | 1.4.1.1.1.7 | Environment Approach and Plan - S and A Testing | milestone | 0d | 2024-07-17 A | 2024-07-17 A |  | 100% |  | 2024-07-17 | 2024-07-17 | 0d |  |  |  | start no earlier than 2024-07-17 |  | SI Test | PP | 5.27 | Simon Berry | Systems Integration Testing (SIT) | Complete | COMPLETE | MHHS-DEL 619 | T3-TE-0120 | SITAG/QAG | T3 |  |  |
| 473 | 1.4.1.1.1.8 | Environment Approach and Plan - SIT Non Functional | milestone | 0d | 2024-06-19 A | 2024-06-19 A |  | 100% |  | 2024-06-19 | 2024-06-19 | 0d |  |  |  | start no earlier than 2024-06-19 |  | SI Test | PP | 5.27 | Simon Berry | Systems Integration Testing (SIT) | Complete | COMPLETE | MHHS-DEL 620 | T3-TE-0092 | SITAG | T3 |  |  |
| 474 | 1.4.1.1.1.9 | Environment Approach and Plan - Sandbox | milestone | 0d | 2024-08-21 A | 2024-08-21 A |  | 100% |  | 2024-08-21 | 2024-08-21 | 0d |  |  |  | start no earlier than 2024-08-21 |  | SI Test | PP | 5.27 | Simon Berry | Systems Integration Testing (SIT) | Complete | COMPLETE | MHHS-DEL 621 | T3-TE-0093 | SITAG/QAG | T3 |  |  |

Notes:
- 450: 6/11 - last report sent out 27/10
- 451: 6/11 - last report sent out 27/10
- 455: 15/9 - keep in plan until qualification reviewed
- 463: Action: 11/3: Ask Simon B for the link (line 1312) dip onboarding to non sit ldso
- 465: Action: 16/8 - add to milestone register. Build out detail further
- 466: Action: 25/7 - Simon to provide update
- 467: Action: 25/7 - Simon to provide update
- 468: Action: 25/7 - Simon to provide update
- 469: The LDSO element is on hold whilst discussions are being held between Programme and Code Bodies re: LDSO testing. When concluded, that update will be re-planned by agreement with TMAG. 20/11- Approved at TMAG / Action: 16/8 - add to milestone register. Build out detail further
- 471: 25/03: To go to Apr QAG for name change as Non-SIT LDSO and S and A will deliver on different timelines so '& S and A' will be removed. 17/4: Approved for name change at SITAG on 17/4/24. / Action: 16/8 - add to milestone register. Build out detail further
- 472: . 25/03: New milestone to go to Apr QAG as Non-SIT LDSO and S and A will deliver on different timelines so need to create a new milestone for S and A. 17/4: Approved as new milestone at SITAG on 17/4/24. 19/6: Approved at SITAG on 19/6 / Action: 16/8 - add to milestone register. Build out detail further
- 473: 26/3/24: To go to April SITAG for date change approval. Because of dependency on NF test approach and plan. Currently under PP review 17/4: Approved date change at SITAG on 17/4/24. 19/6: Approved at SITAG on 19/6 / Action: 16/8 - add to milestone register. Build out detail further
- 474: Name change to remove 'qualification and' to reflect sandbox only scope. Name and date change approved at QAG on 21/3/24. 19/6: Approved at SITAG on 19/6 / Action: 16/8 - add to milestone register. Build out detail further

| ID | WBS | Task | Type | Duration | Start | Finish | Predecessors | Complete | Remaining | Baseline start | Baseline finish | Baseline duration | Baseline 1 start | Baseline 1 finish | Total slack | Constraint | Baseline cost | Responsible | Involved | Update Version | MHHS Resource Name | MHHS Programme Phase | Sched Status | RAG | Task Status | Milestone ID | Text29 | Tier |
| --- | --- | --- | --- | --- | --- | --- | --- | --- | --- | --- | --- | --- | --- | --- | --- | --- | --- | --- | --- | --- | --- | --- | --- | --- | --- | --- | --- | --- |
| 475 | 1.4.1.1.2 | **Overarching Test Scope (for all stages)** |  | 65d | 2022-10-31 A | 2023-01-27 A |  | 100% |  | 2022-10-31 | 2023-06-30 | 175d | 2022-10-31 | 2023-06-30 |  |  |  | N/A | N/A | 5.0 | N/A | Systems Integration Testing (SIT) |  |  |  |  |  |  |
| 476 | 1.4.1.1.2.1 | **Overarching Test Scope (excl. Migration/Reverse Migration, NFT and Ops components)** |  | 65d | 2022-10-31 A | 2023-01-27 A |  | 100% |  | 2022-10-31 | 2023-01-27 | 65d | 2022-10-31 | 2023-01-27 |  |  |  | N/A | N/A | 5.0 | N/A | Systems Integration Testing (SIT) |  |  |  |  |  |  |
| 477 | 1.4.1.1.2.1.1 | Develop document (excl Migration/Reverse Migration, NFT and Ops components) |  | 55d | 2022-10-31 A | 2023-01-13 A | 48 | 100% |  | 2022-10-31 | 2023-01-13 | 55d | 2022-10-31 | 2023-01-13 |  |  |  | SI Test |  | 5.0 | Lee Cox | Systems Integration Testing (SIT) | Complete | COMPLETE |  |  |  |  |
| 478 | 1.4.1.1.2.1.2 | Review, update & agree document (excl Migration/Reverse Migration, NFT and Ops components) |  | 10d | 2023-01-16 A | 2023-01-27 A | 477 | 100% |  | 2023-01-16 | 2023-01-27 | 10d | 2023-01-16 | 2023-01-27 |  |  |  | SI Test | IPA,Code Bodies,PP | 5.0 | Lee Cox | Systems Integration Testing (SIT) | Complete | COMPLETE |  |  |  |  |
| 479 | 1.4.1.1.3 | **Configuration and Release Management Approach & Plan** |  | 164d | 2022-11-01 A | 2023-06-16 A |  | 100% |  | 2022-11-01 | 2023-06-16 | 164d | 2022-11-01 | 2023-04-28 |  |  |  | N/A | N/A | 5.0 | N/A | Systems Integration Testing (SIT) |  |  | M9 |  |  |  |
| 480 | 1.4.1.1.3.1 | Develop document |  | 69d | 2022-11-01 A | 2023-06-16 A |  | 100% |  | 2022-11-01 | 2023-06-16 | 69d | 2022-11-01 | 2023-01-31 |  | start no earlier than 2022-11-01 |  | SI Test |  | 5.0 | Simon Berry | Systems Integration Testing (SIT) | Complete | COMPLETE |  |  |  |  |
| 481 | 1.4.1.1.3.2 | Review, update and agree Configuration and Release Management Approach & Plan internally |  | 63d | 2023-02-01 A | 2023-04-28 A | 480 | 100% |  | 2023-02-01 | 2023-04-28 | 63d | 2023-02-01 | 2023-04-28 |  |  |  | SRO Function | IPA,SI Test | 5.0 | Simon Berry | Systems Integration Testing (SIT) | Complete | COMPLETE |  |  |  |  |
| 482 | 1.4.1.1.4 | **Test Data Overarching Approach & Plan** |  | 179d | 2022-11-14 A | 2023-07-20 A |  | 100% |  | 2022-11-14 | 2023-07-20 | 179d | 2022-11-14 | 2023-05-18 |  |  |  | N/A | N/A | 5.0 | N/A | Systems Integration Testing (SIT) |  |  | M9 |  |  |  |
| 483 | 1.4.1.1.4.1 | Develop document |  | 20d | 2022-11-14 A | 2022-12-09 A |  | 100% |  | 2022-11-14 | 2022-12-09 | 20d | 2022-11-14 | 2022-12-09 |  | start no earlier than 2022-11-14 |  | SI Test | PP | 5.0 | Cesar Lopes | Systems Integration Testing (SIT) | Complete | COMPLETE |  |  |  |  |
| 484 | 1.4.1.1.4.2 | Document review and update |  | 155d | 2022-12-12 A | 2023-07-14 A | 483 | 100% |  | 2022-12-12 | 2023-07-14 | 155d | 2022-12-12 | 2023-05-17 |  |  |  | PP | SI Test,IPA | 5.0 | Cesar Lopes | Systems Integration Testing (SIT) | Complete | COMPLETE |  |  |  |  |
| 485 | 1.4.1.1.4.3 | Test Data Overarching Approach & Plan approved by TMAG | milestone | 0d | 2023-07-19 A | 2023-07-19 A | 484FS+3d | 100% |  | 2023-07-19 | 2023-07-19 | 0d | 2023-05-17 | 2023-05-17 |  |  |  | SRO Test | PP,IPA,Code Bodies | 5.0 | Cesar Lopes | Systems Integration Testing (SIT) | Complete | COMPLETE |  | T3-TE-0072 | SITAG | T3 |
| 486 | 1.4.1.1.4.4 | Document publication final version |  | 1d | 2023-07-20 A | 2023-07-20 A | 485 | 100% |  | 2023-07-20 | 2023-07-20 | 1d | 2023-05-18 | 2023-05-18 |  |  |  | SI Test |  | 5.0 | Cesar Lopes | Systems Integration Testing (SIT) | Complete | COMPLETE |  |  |  |  |
| 487 | 1.4.1.1.5 | **Interface Code of Connection (dates subject to DIP Service Provider's plan)** |  | 48d | 2023-03-01 A | 2023-05-05 A |  | 100% |  | 2023-03-01 | 2023-05-05 | 48d | 2023-03-01 | 2023-05-05 |  |  |  | N/A | N/A | 5.0 | N/A | Systems Integration Testing (SIT) |  |  |  |  |  |  |
| 488 | 1.4.1.1.5.1 | Develop Interface Code of Connection with DIP Service Provider |  | 43d | 2023-03-01 A | 2023-04-28 A |  | 100% |  | 2023-03-01 | 2023-04-28 | 43d | 2023-03-01 | 2023-04-28 |  | must start on 2023-03-01 |  | DIP Provider | SI Test | 5.0 | Lee Cox | Systems Integration Testing (SIT) | Complete | COMPLETE |  |  |  |  |
| 489 | 1.4.1.1.5.2 | Interface Code of Connection approved at SDWG | milestone | 0d | 2023-05-05 A | 2023-05-05 A | 488FS+5d | 100% |  | 2023-05-05 | 2023-05-05 | 0d | 2023-05-05 | 2023-05-05 |  |  |  | SI Test | PP | 5.0 | Lee Cox | Systems Integration Testing (SIT) | Complete | COMPLETE |  |  |  |  |
| 490 | 1.4.1.1.6 | **Test Traceability** |  | 165d | 2023-06-01 A | 2024-01-17 |  | 98% | 2.71d | 2023-06-01 | 2024-01-17 | 165d | 2023-06-01 | 2023-09-01 | 877d |  | -0 | N/A | N/A | 5.0 | N/A | Systems Integration Testing (SIT) |  |  |  |  |  |  |
| 491 | 1.4.1.1.6.1 | RTM containing Method Statement Implied Requirements into Azure DevOps |  | 22d | 2023-06-01 A | 2023-06-30 A |  | 100% |  | 2023-06-01 | 2023-06-30 | 22d | 2023-06-01 | 2023-06-30 |  | must start on 2023-06-01 |  | SI Test |  | 5.0 | Lee Cox | Systems Integration Testing (SIT) | Complete | COMPLETE |  |  |  |  |
| 492 | 1.4.1.1.6.2 | RTM Containing Interface Catalogue Implied Requirements |  | 27d | 2023-06-01 A | 2023-07-07 A |  | 100% |  | 2023-06-01 | 2023-07-07 | 27d | 2023-06-01 | 2023-07-07 |  | must start on 2023-06-01 |  | SI Test |  | 5.0 | Lee Cox | Systems Integration Testing (SIT) | Complete | COMPLETE |  |  |  |  |
| 493 | 1.4.1.1.6.3 | SIT CIT Full Traceability & Coverage complete |  | 118d | 2023-07-10 A | 2023-12-20 A | 492, 491 | 100% |  | 2023-07-10 | 2023-12-08 | 110d | 2023-07-10 | 2023-07-28 |  |  |  | SI Test |  | 5.0 | Lee Cox | Systems Integration Testing (SIT) | Complete | COMPLETE |  |  |  |  |
| 494 | 1.4.1.1.6.4 | SIT Functional Full Traceability & Coverage complete |  | 138d | 2023-07-10 A | 2024-01-17 | 492, 491 | 96% | 5d | 2023-07-10 | 2024-01-17 | 138d | 2023-07-10 | 2023-09-01 | 877d |  |  | SI Test |  | 5.0 | Roger Robar | Systems Integration Testing (SIT) | Overdue | RED |  |  |  |  |
| 495 | 1.4.1.2 | **Test Tool Development** |  | 256d | 2022-10-31 A | 2023-10-23 |  | 99% | 0d | 2022-10-31 | 2023-06-30 | 175d | 2022-10-31 | 2023-06-30 | 939d |  |  | N/A | N/A | 5.0 | N/A | Systems Integration Testing (SIT) |  |  |  |  |  |  |
| 496 | 1.4.1.2.1 | **Test Management Tool** |  | 256d | 2022-10-31 A | 2023-10-23 A |  | 100% |  | 2022-10-31 | 2023-06-30 | 175d | 2022-10-31 | 2023-06-30 |  |  |  | N/A | N/A | 5.0 | N/A | Systems Integration Testing (SIT) |  |  |  |  |  |  |
| 497 | 1.4.1.2.1.1 | **Test Management Tool Implementation** |  | 256d | 2022-10-31 A | 2023-10-23 A |  | 100% |  | 2022-10-31 | 2023-06-30 | 175d | 2022-10-31 | 2023-06-30 |  |  |  | N/A | N/A | 5.0 | N/A | Systems Integration Testing (SIT) |  |  |  |  |  |  |
| 498 | 1.4.1.2.1.1.1 | Requirements identification |  | 40d | 2022-10-31 A | 2022-12-23 A |  | 100% |  | 2022-10-31 | 2022-12-23 | 40d | 2022-10-31 | 2022-12-23 |  |  |  | SI DevOps | SI Test | 5.0 | Simon Berry | Systems Integration Testing (SIT) | Complete | COMPLETE |  |  |  |  |
| 499 | 1.4.1.2.1.1.2 | Development |  | 125d | 2023-01-02 A | 2023-06-23 A | 498FS+5d | 100% |  | 2023-01-02 | 2023-06-23 | 125d | 2023-01-02 | 2023-06-23 |  |  |  | SI DevOps | SI Test | 5.0 | Simon Berry | Systems Integration Testing (SIT) | Complete | COMPLETE |  |  |  |  |
| 500 | 1.4.1.2.1.1.3 | Testing |  | 125d | 2023-01-02 A | 2023-06-23 A | 499FF | 100% |  | 2023-01-02 | 2023-06-23 | 125d | 2023-01-02 | 2023-06-23 |  |  |  | SI DevOps | SI Test | 5.0 | Simon Berry | Systems Integration Testing (SIT) | Complete | COMPLETE |  |  |  |  |
| 501 | 1.4.1.2.1.1.4 | Accept tool | milestone | 0d | 2023-06-23 A | 2023-06-23 A | 500FF | 100% |  | 2023-06-23 | 2023-06-23 | 0d | 2023-06-23 | 2023-06-23 |  |  |  | SI DevOps | SI Test | 5.0 | Simon Berry | Systems Integration Testing (SIT) | Complete | COMPLETE |  |  |  |  |
| 502 | 1.4.1.2.1.1.5 | Implementation |  | 1d | 2023-10-23 A | 2023-10-23 A | 501FS+85d | 100% |  | 2023-06-30 | 2023-06-30 | 1d | 2023-06-30 | 2023-06-30 |  |  |  | SI DevOps | PPC | 5.0 | Simon Berry | Systems Integration Testing (SIT) | Complete | COMPLETE |  |  |  |  |

Notes:
- 479: Action: 1280 DIP available for Onboarding (need to add a link - non sit ldso)
- 494: Stays red till delivery plan agreed at SITAG

| ID | WBS | Task | Type | Duration | Start | Finish | Predecessors | Complete | Baseline start | Baseline finish | Baseline duration | Baseline 1 start | Baseline 1 finish | Total slack | Free slack | Constraint | Responsible | Involved | Update Version | MHHS Resource Name | MHHS Programme Phase | Sched Status | RAG | Task Status | Milestone ID | Text29 | Tier |
| --- | --- | --- | --- | --- | --- | --- | --- | --- | --- | --- | --- | --- | --- | --- | --- | --- | --- | --- | --- | --- | --- | --- | --- | --- | --- | --- | --- |
| 503 | 1.4.1.2.1.2 | **Test Management Tool User Guide** |  | 115d | 2023-01-02 A | 2023-06-09 A |  | 100% | 2023-01-02 | 2023-06-09 | 115d | 2023-01-02 | 2023-06-09 |  |  |  | N/A | N/A | 5.0 | N/A | Systems Integration Testing (SIT) |  |  |  |  |  |  |
| 504 | 1.4.1.2.1.2.1 | Develop document |  | 100d | 2023-01-02 A | 2023-05-19 A | 499SS, 500SS | 100% | 2023-01-02 | 2023-05-19 | 100d | 2023-01-02 | 2023-05-19 |  |  | start no earlier than 2023-01-02 | SI DevOps |  | 5.0 | Lee Cox | Systems Integration Testing (SIT) | Complete | COMPLETE |  |  |  |  |
| 505 | 1.4.1.2.1.2.2 | Review, update and agree Test Management Tool User Guide internally |  | 15d | 2023-05-22 A | 2023-06-09 A | 504 | 100% | 2023-05-22 | 2023-06-09 | 15d | 2023-05-22 | 2023-06-09 |  |  |  | SRO Function | SI DevOps,SI Test,IPA,PPC | 5.0 | Lee Cox | Systems Integration Testing (SIT) | Complete | COMPLETE |  |  |  |  |
| 506 | 1.4.1.2.1.3 | **Test Management Tool Configuration Guide** |  | 60d | 2023-01-02 A | 2023-03-24 A |  | 100% | 2023-01-02 | 2023-03-24 | 60d | 2023-01-02 | 2023-03-24 |  |  |  | N/A | N/A | 5.0 | N/A | Systems Integration Testing (SIT) |  |  |  |  |  |  |
| 507 | 1.4.1.2.1.3.1 | Develop document |  | 45d | 2023-01-02 A | 2023-03-03 A | 498 | 100% | 2023-01-02 | 2023-03-03 | 45d | 2023-01-02 | 2023-03-03 |  |  | start no earlier than 2023-01-02 | SI DevOps | SI Test,IPA | 5.0 | Lee Cox | Systems Integration Testing (SIT) | Complete | COMPLETE |  |  |  |  |
| 508 | 1.4.1.2.1.3.2 | Review, update and agree Test Management Tool Configuration Guide internally |  | 15d | 2023-03-06 A | 2023-03-24 A | 507 | 100% | 2023-03-06 | 2023-03-24 | 15d | 2023-03-06 | 2023-03-24 |  |  |  | SRO Function | SI DevOps,SI Test,IPA | 5.0 | Lee Cox | Systems Integration Testing (SIT) | Complete | COMPLETE |  |  |  |  |
| 509 | 1.4.1.2.2 | **Test Query Tool** |  | 0d | 2022-10-31 | 2022-10-31 |  |  | 2022-10-31 | 2023-04-28 | 130d | 2022-10-31 | 2023-04-28 | 1195d |  |  | N/A | N/A | 5.0 | N/A | Systems Integration Testing (SIT) |  |  |  |  |  |  |
| 510 | 1.4.1.2.2.1 | **Test Query Tool Implementation** | inactive | 130d | 2022-10-31 | 2023-04-28 |  |  | 2022-10-31 | 2023-04-28 | 130d | 2022-10-31 | 2023-04-28 | 96d |  |  | N/A | N/A | 5.0 | N/A | Systems Integration Testing (SIT) |  |  |  |  |  |  |
| 511 | 1.4.1.2.2.1.1 | Requirements identification | inactive | 20d | 2022-10-31 | 2022-11-25 |  |  | 2022-10-31 | 2022-11-25 | 20d | 2022-10-31 | 2022-11-25 | 96d |  |  | SI DevOps | SI Test | 5.0 | Roger Robar | Systems Integration Testing (SIT) |  | RED | -646.67 |  |  |  |
| 512 | 1.4.1.2.2.1.2 | Development | inactive | 10d | 2023-04-11 | 2023-04-24 | 511 |  | 2023-04-11 | 2023-04-24 | 10d | 2023-04-11 | 2023-04-24 | 0d |  | must start on 2023-04-11 | SI DevOps | SI Test | 5.0 | Roger Robar | Systems Integration Testing (SIT) |  | RED | -484.67 |  |  |  |
| 513 | 1.4.1.2.2.1.3 | Testing | inactive | 5d | 2023-04-18 | 2023-04-24 | 512FF |  | 2023-04-18 | 2023-04-24 | 5d | 2023-04-18 | 2023-04-24 | 1065d | 0d |  | SI DevOps | SI Test | 5.0 | Roger Robar | Systems Integration Testing (SIT) |  | RED | -477.67 |  |  |  |
| 514 | 1.4.1.2.2.1.4 | Accept tool | milestone, inactive | 0d | 2023-04-24 | 2023-04-24 | 513FF |  | 2023-04-24 | 2023-04-24 | 0d | 2023-04-24 | 2023-04-24 | 1065d | 0d |  | SI DevOps | SI Test | 5.0 | Roger Robar | Systems Integration Testing (SIT) |  | RED | -471.29 |  |  |  |
| 515 | 1.4.1.2.2.1.5 | Implementation | inactive | 1d | 2023-04-28 | 2023-04-28 | 514FS+3d |  | 2023-04-28 | 2023-04-28 | 1d | 2023-04-28 | 2023-04-28 | 1065d |  |  | SI DevOps | PPC | 5.0 | Roger Robar | Systems Integration Testing (SIT) |  | RED | -467.67 |  |  |  |
| 516 | 1.4.1.2.2.2 | **Test Query Tool User Guide** | inactive | 14d | 2023-04-11 | 2023-04-28 |  |  | 2023-04-11 | 2023-04-28 | 14d | 2023-04-11 | 2023-04-28 | 1065d |  |  | N/A | N/A | 5.0 | N/A | Systems Integration Testing (SIT) |  |  |  |  |  |  |
| 517 | 1.4.1.2.2.2.1 | Develop document | inactive | 10d | 2023-04-11 | 2023-04-24 | 512SS |  | 2023-04-11 | 2023-04-24 | 10d | 2023-04-11 | 2023-04-24 | 1065d | 0d | start no earlier than 2022-11-28 | SI DevOps |  | 5.0 | Roger Robar | Systems Integration Testing (SIT) |  | RED | -484.67 |  |  |  |
| 518 | 1.4.1.2.2.2.2 | Review, update and agree Test Query Tool User Guide internally | inactive | 4d | 2023-04-25 | 2023-04-28 | 517 |  | 2023-04-25 | 2023-04-28 | 4d | 2023-04-25 | 2023-04-28 | 1065d |  |  | SRO Function | IPA,SI Test | 5.0 | Roger Robar | Systems Integration Testing (SIT) |  | RED | -470.67 |  |  |  |
| 519 | 1.4.1.3 | **SIT Participation** |  | 147d | 2022-10-31 A | 2023-05-23 A |  | 100% | 2022-10-31 | 2023-05-23 | 147d | 2022-10-31 | 2023-05-23 |  |  |  | N/A | N/A | 5.0 | N/A | Systems Integration Testing (SIT) |  |  |  |  |  |  |
| 520 | 1.4.1.3.1 | PPs decide whether to volunteer to participate in SIT and inform Programme of decision via Round 3 Replan consultation |  | 67d | 2022-10-31 A | 2023-01-31 A | 34FF | 100% | 2022-10-31 | 2023-01-31 | 67d | 2022-10-31 | 2023-01-31 |  |  |  | PP | SI Test,PMO | 5.0 | Lee Cox | Systems Integration Testing (SIT) | Complete | COMPLETE |  |  |  |  |
| 521 | 1.4.1.3.2 | Assurance of SIT volunteers' plans (submitted via Round 3 Replan Consultation) |  | 10d | 2023-02-01 A | 2023-02-14 A | 520, 34 | 100% | 2023-02-01 | 2023-02-14 | 10d | 2023-02-01 | 2023-02-14 |  |  |  | SI Test | PP | 5.0 | Lee Cox | Systems Integration Testing (SIT) | Complete | COMPLETE |  |  |  |  |
| 522 | 1.4.1.3.3 | SIT Participant Volunteers Identified | milestone | 0d | 2023-02-14 A | 2023-02-14 A | 521FF | 100% | 2023-02-14 | 2023-02-14 | 0d | 2023-02-14 | 2023-02-14 |  |  |  | SI Test | PP | 5.0 | Lee Cox | Systems Integration Testing (SIT) | Complete | COMPLETE |  | T2-TE-0100 | SITAG | T2 |
| 523 | 1.4.1.3.4 | Engagement with SIT volunteers |  | 147d | 2022-10-31 A | 2023-05-23 A |  | 100% | 2022-10-31 | 2023-05-23 | 147d | 2022-10-31 | 2023-05-23 |  |  |  | SI Test | PP | 5.0 | Lee Cox | Systems Integration Testing (SIT) | Complete | COMPLETE |  |  |  |  |
| 524 | 1.4.1.3.5 | SIT Participants Agreed | milestone | 0d | 2023-05-23 A | 2023-05-23 A | 523, 581FS-74d | 100% | 2023-05-23 | 2023-05-23 | 0d | 2023-05-23 | 2023-05-23 |  |  |  | SI Test | PP | 5.0 | Lee Cox | Systems Integration Testing (SIT) | Complete | COMPLETE |  | T2-TE-0150 | SITAG | T2 |
| 525 | 1.4.1.4 | **Data Protection Impact Assessment (DPIA)** |  | 32d | 2023-06-01 A | 2023-07-14 A |  | 100% | 2023-06-01 | 2023-07-14 | 32d | 2023-06-01 | 2023-07-14 |  |  |  | N/A | N/A | 5.0 | N/A | Systems Integration Testing (SIT) |  |  |  |  |  |  |
| 526 | 1.4.1.4.1 | Conduct DPIA on Overall Test Data Approach |  | 22d | 2023-06-01 A | 2023-06-30 A | 485 | 100% | 2023-06-01 | 2023-06-30 | 22d | 2023-06-01 | 2023-06-30 |  |  | start no earlier than 2023-06-01 | PP | SI Test | 5.0 | Cesar Lopes | Systems Integration Testing (SIT) | Complete | COMPLETE |  |  |  |  |
| 527 | 1.4.1.4.2 | Revise Overarching Test Data Approach & plan for DPIA (if required), including engagement with DWG |  | 9d | 2023-07-03 A | 2023-07-13 A | 526 | 100% | 2023-07-03 | 2023-07-13 | 9d | 2023-07-03 | 2023-07-13 |  |  |  | SI Test Data |  | 5.0 | Cesar Lopes | Systems Integration Testing (SIT) | Complete | COMPLETE |  |  |  |  |
| 528 | 1.4.1.4.3 | Review (internal), update and approve revised Overarching Test Data Approach & Plan (if required) |  | 1d | 2023-07-14 A | 2023-07-14 A | 527 | 100% | 2023-07-14 | 2023-07-14 | 1d | 2023-07-14 | 2023-07-14 |  |  |  | SI Test Data | PP,IPA | 5.0 | Cesar Lopes | Systems Integration Testing (SIT) | Complete | COMPLETE |  |  |  |  |

| ID | WBS | Task | Type | Duration | Start | Finish | Predecessors | Complete | Remaining | Baseline start | Baseline finish | Baseline duration | Baseline 1 start | Baseline 1 finish | Total slack | Constraint | Baseline cost | Responsible | Involved | Task Status | Update Version | MHHS Resource Name | MHHS Programme Phase | Sched Status | RAG | Milestone ID | Text29 | Tier | Guidance | Artefact ID |
| --- | --- | --- | --- | --- | --- | --- | --- | --- | --- | --- | --- | --- | --- | --- | --- | --- | --- | --- | --- | --- | --- | --- | --- | --- | --- | --- | --- | --- | --- | --- |
| 529 | 1.4.1.5 | **Data Sharing Agreements** |  | 44d | 2023-07-17 A | 2023-09-14 A |  | 100% |  | 2023-07-17 | 2023-09-14 | 44d |  |  |  |  |  | N/A | N/A | -275.67 | 5.5 | N/A | Systems Integration Testing (SIT) |  |  |  |  |  |  |  |
| 530 | 1.4.1.5.1 | Produce Data Sharing Agreement for Industry Review |  | 15d | 2023-07-17 A | 2023-08-04 A | 528 | 100% |  | 2023-07-17 | 2023-08-04 | 15d |  |  |  |  |  | SI Test Data | PPC, Elexon |  | 5.5 | Cesar Lopes | Systems Integration Testing (SIT) | Complete | COMPLETE |  |  |  |  |  |
| 531 | 1.4.1.5.2 | Manage Participant Queries and Contract Agreement Execution |  | 29d | 2023-08-07 A | 2023-09-14 A | 530 | 100% |  | 2023-08-07 | 2023-09-14 | 29d |  |  |  |  |  | SI Test Data | PPC, Elexon |  | 5.5 | Cesar Lopes | Systems Integration Testing (SIT) | Complete | COMPLETE |  |  |  |  |  |
| 532 | 1.4.1.5.3 | Data Sharing Agreements Complete | milestone | 0d | 2023-09-14 A | 2023-09-14 A | 531 | 100% |  | 2023-09-14 | 2023-09-14 | 0d |  |  |  |  |  | SI Test Data | PPC, Elexon |  | 5.5 | Cesar Lopes | Systems Integration Testing (SIT) | Complete | COMPLETE | T3-TE-0086 | SITAG | T3 |  |  |
| 533 | 1.4.1.6 | **Production Data Cut & Data Obfuscation** |  | 109d | 2023-04-04 A | 2023-09-01 A |  | 100% |  | 2023-04-04 | 2023-09-01 | 109d | 2023-04-04 | 2023-09-01 |  |  |  | N/A | N/A |  | 5.0 | N/A | Systems Integration Testing (SIT) |  |  |  |  |  |  |  |
| 534 | 1.4.1.6.1 | **SI Data Cut Preparation & Infrastructure** |  | 99d | 2023-04-04 A | 2023-08-18 A |  | 100% |  | 2023-04-04 | 2023-08-18 | 99d | 2023-04-04 | 2023-07-31 |  |  |  | N/A | N/A |  | 5.0 | N/A | Systems Integration Testing (SIT) |  |  |  |  |  |  |  |
| 535 | 1.4.1.6.1.1 | SI Data Cut Planning activities (incl. pre-cut and post-cut cleansing and population approach) |  | 55d | 2023-04-04 A | 2023-06-19 A |  | 100% |  | 2023-04-04 | 2023-06-19 | 55d | 2023-04-04 | 2023-06-19 |  | must start on 2023-04-04 |  | SI Test Data | SI Test |  | 5.0 | Cesar Lopes | Systems Integration Testing (SIT) | Complete | COMPLETE |  |  |  |  |  |
| 536 | 1.4.1.6.1.2 | Set up SI database and transmission structure |  | 44d | 2023-06-19 A | 2023-08-17 A | 535 | 100% |  | 2023-06-19 | 2023-08-17 | 44d | 2023-06-19 | 2023-07-31 |  | must start on 2023-06-19 |  | SI Test Data | SI Test |  | 5.0 | Cesar Lopes | Systems Integration Testing (SIT) | Complete | COMPLETE |  |  |  |  |  |
| 537 | 1.4.1.6.1.3 | Mechanism for transfer of data in place |  | 1d | 2023-08-18 A | 2023-08-18 A | 536 | 100% |  | 2023-08-18 | 2023-08-18 | 1d | 2023-07-31 | 2023-07-31 |  |  |  | SI Test Data | SI Test |  | 5.0 | Cesar Lopes | Systems Integration Testing (SIT) | Complete | COMPLETE |  |  |  |  |  |
| 538 | 1.4.1.6.1.4 | SI Data Cut Preparation & Infrastructure Complete | milestone | 0d | 2023-08-18 A | 2023-08-18 A | 537 | 100% |  | 2023-08-18 | 2023-08-18 | 0d |  |  |  |  |  | SI Test Data | SI Test |  | 5.5 | Cesar Lopes | Systems Integration Testing (SIT) | Complete | COMPLETE | T3-TE-0087 | SITAG | T3 |  |  |
| 539 | 1.4.1.6.2 | **Production Data Cut** |  | 55d | 2023-06-19 A | 2023-09-01 A |  | 100% |  | 2023-06-19 | 2023-09-01 | 55d | 2023-06-19 | 2023-09-01 |  |  |  | N/A | N/A |  | 5.0 | N/A | Systems Integration Testing (SIT) |  |  |  |  |  |  |  |
| 540 | 1.4.1.6.2.1 | Notification of Production Data Cut issued to relevant participants | milestone | 0d | 2023-06-19 A | 2023-06-19 A | 485 | 100% |  | 2023-06-19 | 2023-06-19 | 0d | 2023-06-19 | 2023-06-19 |  |  |  | SI Test Data | PP |  | 5.0 | Cesar Lopes | Systems Integration Testing (SIT) | Complete | COMPLETE | T3-TE-0011 | SITAG | T3 |  |  |
| 541 | 1.4.1.6.2.2 | Coordinate relevant participants taking data cut from production systems |  | 40d | 2023-06-19 A | 2023-08-11 A | 540 | 100% |  | 2023-06-19 | 2023-08-11 | 40d | 2023-06-19 | 2023-08-11 |  |  |  | SI Test Data | PP |  | 5.0 | Cesar Lopes | Systems Integration Testing (SIT) | Complete | COMPLETE |  |  |  |  |  |
| 542 | 1.4.1.6.2.3 | Production data cut GONG decision | milestone | 0d | 2023-08-16 A | 2023-08-16 A | 541FS+3d | 100% |  | 2023-08-16 | 2023-08-16 | 0d | 2023-08-16 | 2023-08-16 |  |  |  | SI Test Data | PP |  | 5.0 | Cesar Lopes | Systems Integration Testing (SIT) | Complete | COMPLETE | T3-TE-0017 | SITAG | T3 |  |  |
| 543 | 1.4.1.6.2.4 | Relevant participants take data cut from production systems (Saturday 19 August) |  | 1d | 2023-08-21 A | 2023-08-21 A | 542FS+2d | 100% |  | 2023-08-21 | 2023-08-21 | 1d | 2023-08-21 | 2023-08-21 |  |  |  | SI Test Data | SI Test |  | 5.0 | Cesar Lopes | Systems Integration Testing (SIT) | Complete | COMPLETE |  |  |  |  |  |
| 544 | 1.4.1.6.2.5 | EES transmit request data to SI |  | 5d | 2023-08-21 A | 2023-08-25 A | 543SS | 100% |  | 2023-08-21 | 2023-08-25 | 5d | 2023-08-21 | 2023-08-25 |  |  |  | SI Test Data | SI Test |  | 5.0 | Cesar Lopes | Systems Integration Testing (SIT) | Complete | COMPLETE |  |  |  |  |  |
| 545 | 1.4.1.6.2.6 | Check data alignment and integrity of data cut |  | 5d | 2023-08-28 A | 2023-09-01 A | 544 | 100% |  | 2023-08-28 | 2023-09-01 | 5d | 2023-08-28 | 2023-09-01 |  |  |  | SI Test Data | PP |  | 5.0 | Cesar Lopes | Systems Integration Testing (SIT) | Complete | COMPLETE |  |  |  |  |  |
| 546 | 1.4.1.6.2.7 | Data cut from relevant participants' production systems completed (Saturday 19 August) | milestone | 0d | 2023-08-21 A | 2023-08-21 A | 543, 526 | 100% |  | 2023-08-21 | 2023-08-21 | 0d | 2023-08-21 | 2023-08-21 |  |  |  | SI Test Data | PP |  | 5.0 | Cesar Lopes | Systems Integration Testing (SIT) | Complete | COMPLETE | T2-TE-0200 | SITAG | T2 | 28/07 - Starts on Sat 19th Aug |  |
| 547 | 1.4.1.6.2.8 | Production Data Cut Complete | milestone | 0d | 2023-08-21 A | 2023-08-21 A | 546 | 100% |  | 2023-08-21 | 2023-08-21 | 0d |  |  |  |  |  | SI Test Data | PP |  | 5.4 | Cesar Lopes | Systems Integration Testing (SIT) | Complete | COMPLETE |  |  |  | 28/07 - Starts on Sat 19th Aug |  |
| 548 | 1.4.1.7 | **SIT Stage-Specific Preparation** |  | 520d | 2022-10-31 A | 2024-10-25 |  | 97% | 15.82d | 2022-10-31 | 2025-03-03 | 611d | 2022-10-31 | 2025-03-10 | 675d |  | -0 | N/A | N/A |  | 5.0 | N/A | Systems Integration Testing (SIT) |  |  |  |  |  |  |  |
| 549 | 1.4.1.7.1 | **SIT Component Integration Preparation** |  | 320d | 2022-10-31 A | 2024-01-19 A |  | 100% |  | 2022-10-31 | 2024-01-22 | 321d | 2022-10-31 | 2024-01-22 |  |  | -0 | N/A | N/A |  | 5.0 | N/A | Systems Integration Testing (SIT) |  |  |  |  |  |  |  |
| 550 | 1.4.1.7.1.1 | **Test Approach & Plan** |  | 188d | 2022-10-31 A | 2023-07-19 A |  | 100% |  | 2022-10-31 | 2023-07-19 | 188d | 2022-10-31 | 2023-07-19 |  |  |  | N/A | N/A |  | 5.0 | N/A | Systems Integration Testing (SIT) |  |  |  |  |  |  |  |
| 551 | 1.4.1.7.1.1.1 | Develop document with SITWG |  | 159d | 2022-10-31 A | 2023-06-08 A |  | 100% |  | 2022-10-31 | 2023-06-08 | 159d | 2022-10-31 | 2023-05-12 |  |  |  | SI Test |  |  | 5.0 | Lee Cox | Systems Integration Testing (SIT) | Complete | COMPLETE |  |  |  |  |  |
| 552 | 1.4.1.7.1.1.2 | Industry consultation |  | 10d | 2023-06-09 A | 2023-06-22 A | 551 | 100% |  | 2023-06-09 | 2023-06-22 | 10d |  |  |  |  |  | PP |  |  | 5.1 | Lee Cox | Systems Integration Testing (SIT) | Complete | COMPLETE |  |  |  |  |  |
| 553 | 1.4.1.7.1.1.3 | Artefact review (via TMAG) and updates |  | 19d | 2023-06-23 A | 2023-07-19 A | 552 | 100% |  | 2023-06-23 | 2023-07-19 | 19d | 2023-06-09 | 2023-07-06 |  | finish no earlier than 2023-07-06 |  | SI Test | PP,IPA,Code Bodies |  | 5.0 | Lee Cox | Systems Integration Testing (SIT) | Complete | COMPLETE |  |  |  |  |  |
| 554 | 1.4.1.7.1.1.4 | SIT Component Integration Testing Test Approach & Plan approved | milestone | 0d | 2023-07-19 A | 2023-07-19 A | 553 | 100% |  | 2023-07-19 | 2023-07-19 | 0d | 2023-07-19 | 2023-07-19 |  | finish no earlier than 2023-07-19 |  | SI Test | PP |  | 5.0 | Lee Cox | Systems Integration Testing (SIT) | Complete | COMPLETE | T3-TE-0012 | SITAG | T3 |  | MHHS-ART073 |

Notes:
- 529: 3/8 - JW and CL Meeting - Added in to align with FTIG plan as critical programme activity
- 530: 3/8 - JW and CL - Added in to align with FTIG plan as critical programme activity
- 531: 3/8 - JW and CL - Added in to align with FTIG plan as critical programme activity
- 532: 22/8 - no issue as long as ready by 14/9 when data starts to be transmitted to Helix / Action: 3/8 - add as t3 milestones. Awaiting approval at TMAG
- 538: 3/8 - JW and CL Meeting - added in as new T3 milestone / Action: 3/8 - add as t3 milestones. Awaiting approval at TMAG. 8/8 - update name in register
- 547: Action: 2/8 - check isn't a duplicate of t2-te-0200

| ID | WBS | Task | Type | Duration | Start | Finish | Predecessors | Complete | Baseline start | Baseline finish | Baseline duration | Baseline 1 start | Baseline 1 finish | Constraint | Baseline cost | Responsible | Involved | Update Version | MHHS Resource Name | MHHS Programme Phase | Sched Status | RAG | Artefact ID | Milestone ID | Text29 | Tier | Task Status |
| --- | --- | --- | --- | --- | --- | --- | --- | --- | --- | --- | --- | --- | --- | --- | --- | --- | --- | --- | --- | --- | --- | --- | --- | --- | --- | --- | --- |
| 555 | 1.4.1.7.1.2 | **Test Data Approach & Plan** |  | 29d | 2023-06-09 A | 2023-07-19 A |  | 100% | 2023-06-09 | 2023-07-19 | 29d | 2023-06-09 | 2023-07-19 |  |  | N/A | N/A | 5.0 | N/A | Systems Integration Testing (SIT) |  |  |  |  |  |  |  |
| 556 | 1.4.1.7.1.2.1 | Industry consultation |  | 10d | 2023-06-09 A | 2023-06-22 A | 552SS | 100% | 2023-06-09 | 2023-06-22 | 10d |  |  |  |  | PP |  | 5.1 | Cesar Lopes | Systems Integration Testing (SIT) | Complete | COMPLETE |  |  |  |  |  |
| 557 | 1.4.1.7.1.2.2 | Artefact review (via TMAG) and updates |  | 19d | 2023-06-23 A | 2023-07-19 A | 556 | 100% | 2023-06-23 | 2023-07-19 | 19d | 2023-06-09 | 2023-07-06 |  |  | SI Test | PP | 5.0 | Cesar Lopes | Systems Integration Testing (SIT) | Complete | COMPLETE |  |  |  |  |  |
| 558 | 1.4.1.7.1.2.3 | SIT Component Integration Testing Test Data Approach & Plan approved | milestone | 0d | 2023-07-19 A | 2023-07-19 A | 557 | 100% | 2023-07-19 | 2023-07-19 | 0d | 2023-07-19 | 2023-07-19 |  |  | SI Test | IPA | 5.0 | Cesar Lopes | Systems Integration Testing (SIT) | Complete | COMPLETE |  |  |  |  |  |
| 559 | 1.4.1.7.1.3 | **Test scenarios** |  | 173d | 2023-01-02 A | 2023-08-30 A |  | 100% | 2023-01-02 | 2023-08-30 | 173d | 2023-01-02 | 2023-06-02 |  |  | N/A | N/A | 5.0 | N/A | Systems Integration Testing (SIT) |  |  |  |  |  |  |  |
| 560 | 1.4.1.7.1.3.1 | Development of test scenarios | milestone | 0d | 2023-01-02 A | 2023-04-28 A | 551SS+45d | 100% | 2023-01-02 | 2023-04-28 | 85d | 2023-01-02 | 2023-04-28 |  |  | SI Test | PP, Code Bodies | 5.0 | Lee Cox | Systems Integration Testing (SIT) | Complete | COMPLETE |  |  |  |  |  |
| 561 | 1.4.1.7.1.3.2 | Review test scenarios with SIT Working Group |  | 11d | 2023-02-01 A | 2023-08-09 A | 560SS+22d | 100% | 2023-02-01 | 2023-08-09 | 136d | 2023-02-01 | 2023-05-26 |  |  | SI Test | PP, Code Bodies, IPA | 5.0 | Lee Cox | Systems Integration Testing (SIT) | Complete | COMPLETE |  |  |  |  |  |
| 562 | 1.4.1.7.1.3.3 | SIT Component Integration Testing Test scenarios approved | milestone | 0d | 2023-08-30 A | 2023-08-30 A | 561FS+15d | 100% | 2023-08-30 | 2023-08-30 | 0d | 2023-06-02 | 2023-06-02 |  |  | SI Test | PP | 5.6 | Lee Cox | Systems Integration Testing (SIT) | Complete | COMPLETE | MHHS-ART148 | T3-TE-0014 | SITAG | T3 |  |
| 563 | 1.4.1.7.1.4 | **Test cases** |  | 160d | 2023-05-01 A | 2023-12-08 A |  | 100% | 2023-05-01 | 2023-12-08 | 160d | 2023-05-01 | 2023-09-01 |  |  | N/A | N/A | 5.6 | N/A | Systems Integration Testing (SIT) |  |  |  |  |  |  |  |
| 564 | 1.4.1.7.1.4.1 | **SI Test cases** |  | 160d | 2023-05-01 A | 2023-12-08 A |  | 100% | 2023-05-01 | 2023-12-08 | 160d | 2023-05-01 | 2023-09-01 |  |  | N/A | N/A | 5.6 | N/A | Systems Integration Testing (SIT) |  |  |  |  |  |  |  |
| 565 | 1.4.1.7.1.4.1.1 | **Batch 1 (CIT Intervals 1 and 2)** |  | 110d | 2023-05-01 A | 2023-09-29 A |  | 100% | 2023-05-01 | 2023-09-29 | 110d |  |  |  |  | N/A | N/A | 5.6 | N/A | Systems Integration Testing (SIT) |  |  |  |  |  |  | -290.67 |
| 566 | 1.4.1.7.1.4.1.1.1 | Develop Test cases |  | 100d | 2023-05-01 A | 2023-09-15 A | 560 | 100% | 2023-05-01 | 2023-09-15 | 100d | 2023-05-01 | 2023-07-28 |  |  | SI Test |  | 5.6 | Lee Cox | Systems Integration Testing (SIT) | Complete | COMPLETE |  |  |  |  |  |
| 567 | 1.4.1.7.1.4.1.1.2 | Review Test cases with SIT Working Group |  | 9d | 2023-09-18 A | 2023-09-28 A | 566 | 100% | 2023-09-18 | 2023-09-28 | 9d | 2023-05-26 | 2023-08-25 |  |  | SI Test | PP,IPA | 5.6 | Lee Cox | Systems Integration Testing (SIT) | Complete | COMPLETE |  |  |  |  |  |
| 568 | 1.4.1.7.1.4.1.1.3 | SIT Component Integration Testing Test cases Batch 1 (CIT Intervals 1 and 2) approved at ETMAG | milestone | 0d | 2023-09-29 A | 2023-09-29 A | 567FS+1d | 100% | 2023-09-29 | 2023-09-29 | 0d | 2023-09-01 | 2023-09-01 |  |  | SI Test | PP | 5.6 | Lee Cox | Systems Integration Testing (SIT) | Complete | COMPLETE | MHHS-ART073 | T3-TE-0069 | SITAG | T3 |  |
| 569 | 1.4.1.7.1.4.1.2 | **Batch 2 (CIT Intervals 3 and 4)** |  | 25d | 2023-10-02 A | 2023-11-03 A |  | 100% | 2023-10-02 | 2023-11-03 | 25d |  |  |  |  | N/A | N/A | 5.6 | N/A | Systems Integration Testing (SIT) |  |  |  |  |  |  | -290.67 |
| 570 | 1.4.1.7.1.4.1.2.1 | Develop Test cases |  | 15d | 2023-10-02 A | 2023-10-20 A | 568 | 100% | 2023-10-02 | 2023-10-20 | 15d | 2023-05-01 | 2023-07-28 |  |  | SI Test |  | 5.6 | Lee Cox | Systems Integration Testing (SIT) | Complete | COMPLETE |  |  |  |  |  |
| 571 | 1.4.1.7.1.4.1.2.2 | Review Test cases with SIT Working Group |  | 9d | 2023-10-23 A | 2023-11-02 A | 570 | 100% | 2023-10-23 | 2023-11-02 | 9d | 2023-05-26 | 2023-08-25 |  |  | SI Test | PP,IPA | 5.6 | Lee Cox | Systems Integration Testing (SIT) | Complete | COMPLETE |  |  |  |  |  |
| 572 | 1.4.1.7.1.4.1.2.3 | SIT Component Integration Testing Test cases Batch 2 (CIT Intervals 3 and 4) approved at ETMAG | milestone | 0d | 2023-11-03 A | 2023-11-03 A | 571FS+1d | 100% | 2023-11-03 | 2023-11-03 | 0d | 2023-09-01 | 2023-09-01 |  |  | SI Test | PP | 5.11 | Lee Cox | Systems Integration Testing (SIT) | Complete | COMPLETE |  | T3-TE-0104 | SITAG | T3 |  |
| 573 | 1.4.1.7.1.4.1.3 | **Batch 3 (CIT Intervals 5 and 6)** |  | 25d | 2023-11-03 A | 2023-12-08 A |  | 100% | 2023-11-03 | 2023-12-08 | 25d |  |  |  |  | N/A | N/A | 5.6 | N/A | Systems Integration Testing (SIT) |  |  |  |  |  |  | -290.67 |
| 574 | 1.4.1.7.1.4.1.3.1 | Develop Test cases |  | 15d | 2023-11-03 A | 2023-11-24 A | 572 | 100% | 2023-11-03 | 2023-11-24 | 15d | 2023-05-01 | 2023-07-28 |  |  | SI Test |  | 5.6 | Lee Cox | Systems Integration Testing (SIT) | Complete | COMPLETE |  |  |  |  |  |
| 575 | 1.4.1.7.1.4.1.3.2 | Review Test cases with SIT Working Group |  | 9d | 2023-11-27 A | 2023-12-07 A | 574 | 100% | 2023-11-27 | 2023-12-07 | 9d | 2023-05-26 | 2023-08-25 |  |  | SI Test | PP,IPA | 5.6 | Lee Cox | Systems Integration Testing (SIT) | Complete | COMPLETE |  |  |  |  |  |
| 576 | 1.4.1.7.1.4.1.3.3 | SIT Component Integration Testing Test cases Batch 3 (CIT Intervals 5 and 6) approved at ETMAG | milestone | 0d | 2023-12-08 A | 2023-12-08 A | 575FS+1d | 100% | 2023-12-08 | 2023-12-08 | 0d | 2023-09-01 | 2023-09-01 |  |  | SI Test | PP | 5.14 | Lee Cox | Systems Integration Testing (SIT) | Complete | COMPLETE |  | T3-TE-0105 | SITAG | T3 |  |
| 577 | 1.4.1.7.1.5 | **CIT Interval 1 Preparation** |  | 283d | 2022-11-16 A | 2023-12-15 A |  | 100% | 2022-11-16 | 2023-12-08 | 278d | 2022-11-16 | 2023-10-23 |  | -0 | N/A | N/A | 5.6 | N/A | Systems Integration Testing (SIT) |  |  |  |  |  |  |  |
| 578 | 1.4.1.7.1.5.1 | **Environments (SIT A)** |  | 246d | 2022-11-16 A | 2023-10-25 A |  | 100% | 2022-11-16 | 2023-10-16 | 239d | 2022-11-16 | 2023-10-06 |  |  | N/A | N/A | 5.0 | N/A | Systems Integration Testing (SIT) |  |  |  |  |  |  |  |
| 579 | 1.4.1.7.1.5.1.1 | PPs register PKI Officers and request PKI certificates |  | 5d | 2023-10-09 A | 2023-10-13 A |  | 100% | 2023-10-09 | 2023-10-13 | 5d | 2023-08-28 | 2023-09-01 | start no earlier than 2023-10-09 |  | PP | DIP Provider | 5.5 | Simon Berry | Systems Integration Testing (SIT) | Complete | COMPLETE |  |  |  |  |  |
| 580 | 1.4.1.7.1.5.1.2 | PPs register PKI Officers and request PKI certificates Complete - Interval 1 | milestone | 0d | 2023-10-25 A | 2023-10-25 A | 579FS+8d | 100% | 2023-10-13 | 2023-10-13 | 0d |  |  |  |  | PP | DIP Provider | 5.10 | Simon Berry | Systems Integration Testing (SIT) | Complete | COMPLETE |  | T3-TE-0094 | SITAG | T3 |  |
| 581 | 1.4.1.7.1.5.1.3 | PP SIT A environment preparation (incl. security certificates and security compliance) |  | 238d | 2022-11-16 A | 2023-10-13 A | 466 | 100% | 2022-11-16 | 2023-09-01 | 208d | 2022-11-16 | 2023-09-01 |  |  | PP | SI Test | 5.8 | Simon Berry | Systems Integration Testing (SIT) | Complete | COMPLETE |  |  |  |  |  |
| 582 | 1.4.1.7.1.5.1.4 | SI coordinate SIT Participants' SIT A environment preparation |  | 238d | 2022-11-16 A | 2023-10-13 A | 581SS | 100% | 2022-11-16 | 2023-09-01 | 208d | 2022-11-16 | 2023-09-01 |  |  | SI Test | PP | 5.8 | Simon Berry | Systems Integration Testing (SIT) | Complete | COMPLETE |  |  |  |  |  |
| 583 | 1.4.1.7.1.5.1.5 | PP submit self-declaration of environment preparation complete (incl. security certificates and security compliance) to Programme for assurance | milestone | 0d | 2023-10-13 A | 2023-10-13 A | 581FF | 100% | 2023-09-01 | 2023-09-01 | 0d | 2023-09-01 | 2023-09-01 | start no earlier than 2023-10-13 |  | PP | SI Test | 5.8 | Simon Berry | Systems Integration Testing (SIT) | Complete | COMPLETE |  |  |  |  |  |
| 584 | 1.4.1.7.1.5.1.6 | SI assure PPs' self-declaration of environment preparation complete (incl. security certificates and security compliance) |  | 5d | 2023-10-16 A | 2023-10-20 A | 583FF+5d | 100% | 2023-09-04 | 2023-09-08 | 5d | 2023-09-04 | 2023-09-08 |  |  | SI Test | PP | 5.8 | Simon Berry | Systems Integration Testing (SIT) | Complete | COMPLETE |  |  |  |  |  |
| 585 | 1.4.1.7.1.5.1.7 | SIT Participants' SIT A environments ready to start connectivity proving CIT Interval 1 | milestone | 0d | 2023-09-01 A | 2023-09-01 A | 583SS | 100% | 2023-09-01 | 2023-09-01 | 0d | 2023-09-01 | 2023-09-01 |  |  | PP | PP,IPA | 5.6 | Simon Berry | Systems Integration Testing (SIT) | Complete | COMPLETE | MHHS-ART139 | T3-TE-0019 | SITAG | T3 |  |
| 586 | 1.4.1.7.1.5.1.8 | PP SIT A environment connectivity proving |  | 10d | 2023-09-04 A | 2023-09-15 A | 585 | 100% | 2023-09-12 | 2023-10-09 | 20d | 2023-09-04 | 2023-09-29 |  |  | PP | SI Test | 5.8 | Simon Berry | Systems Integration Testing (SIT) | Complete | COMPLETE |  |  |  |  |  |
| 587 | 1.4.1.7.1.5.1.9 | SI coordinate SIT Participants' SIT A environment connectivity proving |  | 10d | 2023-09-04 A | 2023-09-15 A | 586SS | 100% | 2023-09-12 | 2023-10-09 | 20d | 2023-09-04 | 2023-09-29 |  |  | SI Test | PP | 5.8 | Simon Berry | Systems Integration Testing (SIT) | Complete | COMPLETE |  |  |  |  |  |
| 588 | 1.4.1.7.1.5.1.10 | PP deployment of MHHS solution code to SIT A environments |  | 10d | 2023-09-25 A | 2023-10-06 A | 629FF | 100% | 2023-09-26 | 2023-10-09 | 10d | 2023-09-18 | 2023-09-29 |  |  | PP | SI Test | 5.0 | Simon Berry | Systems Integration Testing (SIT) | Complete | COMPLETE |  |  |  |  |  |
| 589 | 1.4.1.7.1.5.1.11 | SI coordinate deployment of MHHS solution code to SIT Participants' SIT A environments |  | 10d | 2023-09-25 A | 2023-10-06 A | 629FF | 100% | 2023-09-26 | 2023-10-09 | 10d | 2023-09-18 | 2023-09-29 |  |  | SI Test | PP | 5.0 | Simon Berry | Systems Integration Testing (SIT) | Complete | COMPLETE |  |  |  |  |  |
| 590 | 1.4.1.7.1.5.1.12 | PP submit evidence of SIT A environment connectivity proving and code deployment completion to Programme for assurance |  | 30d | 2023-09-04 A | 2023-10-13 A | 586SS | 100% | 2023-09-12 | 2023-10-09 | 20d | 2023-09-04 | 2023-09-29 |  |  | PP | SI Test | 5.8 | Simon Berry | Systems Integration Testing (SIT) | Complete | COMPLETE |  |  |  |  |  |
| 591 | 1.4.1.7.1.5.1.13 | SI assurance of SIT Participants' SIT A environment connectivity proving and code deployment completion |  | 25d | 2023-09-18 A | 2023-10-20 A | 590FF+5d | 100% | 2023-09-12 | 2023-10-16 | 25d | 2023-09-04 | 2023-10-06 |  |  | SI Test | PP | 5.8 | Simon Berry | Systems Integration Testing (SIT) | Complete | COMPLETE |  |  |  |  |  |

Notes:
- 562: 17/8 - to go to ETMAG on 30/8
- 563: 18/8 - added in with LC to reflect his ppt slide
- 564: 18/8 - added in with LC to reflect his ppt slide
- 565: 18/8 - added in with LC to reflect his ppt slide
- 566: 18/8 - added in with LC to reflect his ppt slide
- 567: 18/8 - added in with LC to reflect his ppt slide
- 568: 18/8 - added in with LC to reflect his ppt slide / Guidance: 18/8 - needs to finish on 29/9 for ETWAG / Action: 18/8 - needs to finish on 29/9 for ETWAG. Update Milestone register after approval
- 569: 18/8 - added in with LC to reflect his ppt slide
- 570: 18/8 - added in with LC to reflect his ppt slide
- 571: 18/8 - added in with LC to reflect his ppt slide
- 572: 18/8 - added in with LC to reflect his ppt slide / Guidance: 18/8 - needs to finish on 3/11 for ETWAG / Action: 18/8 - needs to finish on 29/9 for ETWAG
- 573: 18/8 - added in with LC to reflect his ppt slide
- 574: 18/8 - added in with LC to reflect his ppt slide
- 575: 18/8 - added in with LC to reflect his ppt slide
- 576: 18/8 - added in with LC to reflect his ppt slide. 28/11 - Red because TMAG date has moved from 8/12 to 20/12 due to reduction in Dec TMAGs. No impact. No action. 20/12 - Approved at TMAG on 20/12 / Guidance: 28/11 - Red because TMAG date has moved from 8/12 to 20/12 due to reduction in Dec TMAGs. No impact. No action
- 580: 16/8- new milestones added in and date change. Approved at TMAG on 16/8. 18/10 - Red because there is an issue that is preventing the issue of PKI certificates. ~Avanade are working with GlobalSign to resolve.~A fix is in the process of being tested

| ID | WBS | Task | Type | Duration | Start | Finish | Predecessors | Complete | Baseline start | Baseline finish | Baseline duration | Baseline cost | Responsible | Involved | Task Status | Update Version | MHHS Resource Name | MHHS Programme Phase | Sched Status | RAG | Action | Milestone ID | Text29 | Tier | Artefact ID |
| --- | --- | --- | --- | --- | --- | --- | --- | --- | --- | --- | --- | --- | --- | --- | --- | --- | --- | --- | --- | --- | --- | --- | --- | --- | --- |
| 592 | 1.4.1.7.1.5.2 | **Test Data - ISD Creation** |  | 9d | 2023-08-22 A | 2023-09-01 A |  | 100% | 2023-08-22 | 2023-09-01 | 9d |  | N/A | N/A | -275.67 | 5.5 | N/A | Systems Integration Testing (SIT) |  |  |  |  |  |  |  |
| 593 | 1.4.1.7.1.5.2.1 | Set-up Market Participants and DIP ID Data |  | 8d | 2023-08-22 A | 2023-08-31 A | 547 | 100% | 2023-08-22 | 2023-08-31 | 8d |  | SI Test Data | SI Test, DIP, Helix |  | 5.5 | Cesar Lopes | Systems Integration Testing (SIT) | Complete | COMPLETE |  |  |  |  |  |
| 594 | 1.4.1.7.1.5.2.2 | Distribute ISD Data to Participants |  | 1d | 2023-09-01 A | 2023-09-01 A | 593 | 100% | 2023-09-01 | 2023-09-01 | 1d |  | SI Test Data | SI Test, DIP, Helix |  | 5.5 | Cesar Lopes | Systems Integration Testing (SIT) | Complete | COMPLETE |  |  |  |  |  |
| 595 | 1.4.1.7.1.5.2.3 | Test Data - ISD Creation Complete | milestone | 0d | 2023-09-01 A | 2023-09-01 A | 594 | 100% | 2023-09-01 | 2023-09-01 | 0d |  | SI Test Data | SI Test, DIP, Helix |  | 5.5 | Cesar Lopes | Systems Integration Testing (SIT) | Complete | COMPLETE | 3/8 - add as t3 milestones. Awaiting approval at TMAG | T3-TE-0083 | SITAG | T3 |  |
| 596 | 1.4.1.7.1.5.3 | **Test Data - SFTP Onboarding** |  | 70d | 2023-08-21 A | 2023-11-24 A |  | 100% | 2023-08-21 | 2023-11-24 | 70d | -0 | N/A | N/A | -275.67 | 5.5 | N/A | Systems Integration Testing (SIT) |  |  |  |  |  |  |  |
| 597 | 1.4.1.7.1.5.3.1 | Create Containers and Keys for Participants |  | 3d | 2023-08-21 A | 2023-08-23 A | 538 | 100% | 2023-08-21 | 2023-08-23 | 3d |  | SI Test Data | SI Test |  | 5.5 | Cesar Lopes | Systems Integration Testing (SIT) | Complete | COMPLETE |  |  |  |  |  |
| 598 | 1.4.1.7.1.5.3.2 | Share SFTP Access with Participants |  | 5d | 2023-08-24 A | 2023-08-30 A | 597 | 100% | 2023-08-24 | 2023-08-30 | 5d |  | SI Test Data | SI Test, PP |  | 5.5 | Cesar Lopes | Systems Integration Testing (SIT) | Complete | COMPLETE |  |  |  |  |  |
| 599 | 1.4.1.7.1.5.3.3 | Test SFTP Connectivity |  | 5d | 2023-08-31 A | 2023-09-06 A | 598 | 100% | 2023-08-31 | 2023-09-06 | 5d |  | SI Test Data | SI Test, PP |  | 5.5 | Cesar Lopes | Systems Integration Testing (SIT) | Complete | COMPLETE |  |  |  |  |  |
| 600 | 1.4.1.7.1.5.3.4 | Test Data - SFTP Onboarding Complete | milestone | 0d | 2023-11-24 A | 2023-11-24 A | 599FS+57d | 100% | 2023-11-24 | 2023-11-24 | 0d |  | SI Test Data | SI Test, PP |  | 5.13 | Cesar Lopes | Systems Integration Testing (SIT) | Complete | COMPLETE |  | T3-TE-0084 | SITAG | T3 |  |
| 601 | 1.4.1.7.1.5.4 | **Test Data - Provide Sample Files** |  | 10d | 2023-08-21 A | 2023-09-01 A |  | 100% | 2023-08-21 | 2023-09-01 | 10d |  | N/A | N/A | -275.67 | 5.5 | N/A | Systems Integration Testing (SIT) |  |  |  |  |  |  |  |
| 602 | 1.4.1.7.1.5.4.1 | Generate Sample Files off IF Messages |  | 8d | 2023-08-21 A | 2023-08-30 A | 538 | 100% | 2023-08-21 | 2023-08-30 | 8d |  | SI Test Data | SI Test |  | 5.5 | Cesar Lopes | Systems Integration Testing (SIT) | Complete | COMPLETE |  |  |  |  |  |
| 603 | 1.4.1.7.1.5.4.2 | Transmit Sample Files off IF Messages to Participants (More detail needs to be planned for a POC) |  | 2d | 2023-08-31 A | 2023-09-01 A | 602 | 100% | 2023-08-31 | 2023-09-01 | 2d |  | SI Test Data | SI Test |  | 5.5 | Cesar Lopes | Systems Integration Testing (SIT) | Complete | COMPLETE |  |  |  |  |  |
| 604 | 1.4.1.7.1.5.4.3 | Test Data - Provide Sample Files Complete | milestone | 0d | 2023-09-01 A | 2023-09-01 A | 603 | 100% | 2023-09-01 | 2023-09-01 | 0d |  | SI Test Data | SI Test |  | 5.5 | Cesar Lopes | Systems Integration Testing (SIT) | Complete | COMPLETE | 3/8 - add as t3 milestones. Awaiting approval at TMAG | T3-TE-0085 | SITAG | T3 |  |
| 605 | 1.4.1.7.1.5.5 | **Test Data - Detailed SIT Data Load Guidance** |  | 65d | 2023-09-07 A | 2023-12-06 A |  | 100% | 2023-09-07 | 2023-12-01 | 62d | -0 | N/A | N/A | -275.67 | 5.5 | N/A | Systems Integration Testing (SIT) |  |  |  |  |  |  |  |
| 606 | 1.4.1.7.1.5.5.1 | Document Guidance |  | 21d | 2023-09-07 A | 2023-10-05 A | 604FS+3d | 100% | 2023-09-07 | 2023-09-28 | 16d |  | SI Test Data | SI Test |  | 5.9 | Cesar Lopes | Systems Integration Testing (SIT) | Complete | COMPLETE |  |  |  |  |  |
| 607 | 1.4.1.7.1.5.5.2 | Provide Guidance to PPs |  | 1d | 2023-10-06 A | 2023-10-06 A | 606 | 100% | 2023-09-29 | 2023-09-29 | 1d |  | SI Test Data | SI Test |  | 5.9 | Cesar Lopes | Systems Integration Testing (SIT) | Complete | COMPLETE |  |  |  |  |  |
| 608 | 1.4.1.7.1.5.5.3 | Test Data - Detailed SIT Functional Data Load Guidance Complete | milestone | 0d | 2023-12-06 A | 2023-12-06 A | 607FS+43d | 100% | 2023-12-01 | 2023-12-01 | 0d |  | SI Test Data | SI Test |  | 5.13 | Richard Puddephatt | Systems Integration Testing (SIT) | Complete | COMPLETE |  | T3-TE-0095 | SITAG | T3 | MHHS-DEL 1545 |
| 609 | 1.4.1.7.1.5.6 | **Test Data - Population of Data Items for Testing Guidance - Draft** |  | 80d | 2023-08-17 A | 2023-12-06 A |  | 100% | 2023-08-17 | 2023-12-01 | 77d | -0 | N/A | N/A | -275.67 | 5.5 | N/A | Systems Integration Testing (SIT) |  |  |  |  |  |  |  |
| 610 | 1.4.1.7.1.5.6.1 | Document Guidance - Draft |  | 11d | 2023-08-17 A | 2023-08-31 A | 798 | 100% | 2023-08-17 | 2023-08-31 | 11d |  | SI Test Data | SI Test |  | 5.6 | Cesar Lopes | Systems Integration Testing (SIT) | Complete | COMPLETE |  |  |  |  |  |
| 611 | 1.4.1.7.1.5.6.2 | Provide Guidance to PPs - Draft |  | 1d | 2023-09-01 A | 2023-09-01 A | 610 | 100% | 2023-09-01 | 2023-09-01 | 1d |  | SI Test Data | SI Test |  | 5.6 | Cesar Lopes | Systems Integration Testing (SIT) | Complete | COMPLETE |  |  |  |  |  |
| 612 | 1.4.1.7.1.5.6.3 | Test Data - Population of Data Items for Testing Guidance - Draft Complete | milestone | 0d | 2023-12-06 A | 2023-12-06 A | 611FS+68d | 100% | 2023-12-01 | 2023-12-01 | 0d |  | SI Test Data | SI Test |  | 5.13 | Richard Puddephatt | Systems Integration Testing (SIT) | Complete | COMPLETE |  | T3-TE-0096 | SITAG | T3 | MHHS-DEL 816 |
| 613 | 1.4.1.7.1.5.7 | **Test Data - Population of Data Items for Testing Guidance - Final** |  | 87d | 2023-08-17 A | 2023-12-15 A |  | 100% | 2023-10-09 | 2023-12-08 | 45d |  | N/A | N/A | -275.67 | 5.5 | N/A | Systems Integration Testing (SIT) |  |  |  |  |  |  |  |
| 614 | 1.4.1.7.1.5.7.1 | Update Document Guidance With PPS Feedback |  | 81d | 2023-08-17 A | 2023-12-07 A | 610SS | 100% | 2023-10-09 | 2023-12-07 | 44d |  | SI Test Data | SI Test |  | 5.5 | Richard Puddephatt | Systems Integration Testing (SIT) | Complete | COMPLETE |  |  |  |  |  |
| 615 | 1.4.1.7.1.5.7.2 | Provide Final Guidance to PPs |  | 1d | 2023-12-08 A | 2023-12-08 A | 614 | 100% | 2023-12-08 | 2023-12-08 | 1d |  | SI Test Data | SI Test |  | 5.5 | Richard Puddephatt | Systems Integration Testing (SIT) | Complete | COMPLETE |  |  |  |  |  |
| 616 | 1.4.1.7.1.5.7.3 | Test Data - Population of Data Items for Testing Guidance - Final Complete | milestone | 0d | 2023-12-15 A | 2023-12-15 A | 615FS+5d | 100% | 2023-12-08 | 2023-12-08 | 0d |  | SI Test Data | SI Test |  | 5.14 | Richard Puddephatt | Systems Integration Testing (SIT) | Complete | COMPLETE |  | T3-TE-0097 | SITAG | T3 | MHHS-DEL 816 |

Notes:
- 592: 3/8 - JW and CL meeting - added in to give e more clarity around work being undertaken
- 593: 3/8 - JW and CL meeting - added in to give e more clarity around work being undertaken
- 594: 3/8 - JW and CL meeting - added in to give e more clarity around work being undertaken
- 595: 3/8 - JW and CL meeting - added in to give more clarity around work being undertaken
- 596: 3/8 - JW and CL meeting - added in to give more clarity around work being undertaken
- 597: 3/8 - JW and CL meeting - added in to give more clarity around work being undertaken
- 598: 3/8 - JW and CL meeting - added in to give more clarity around work being undertaken
- 599: 3/8 - JW and CL meeting - added in to give more clarity around work being undertaken
- 600: Approved at TMAG on 20/9. 26/9 - RP - Red because we have changed the approach to SFTP onboarding to be phased by interval. To go to TMAG for date change approval. Approved for date change at TMAG on 23/10/23
- 601: 3/8 - JW and CL meeting - added in to give more clarity around work being undertaken
- 602: 3/8 - JW and CL meeting - added in to give more clarity around work being undertaken
- 603: 3/8 - JW and CL meeting - added in to give more clarity around work being undertaken
- 604: 3/8 - JW and CL meeting - added in to give more clarity around work being undertaken
- 605: 3/8 - JW and CL meeting - added in to give more clarity around work being undertaken
- 606: 3/8 - JW and CL meeting - added in to give more clarity around work being undertaken
- 607: 3/8 - JW and CL meeting - added in to give more clarity around work being undertaken
- 608: 28/11- Red because of slow start to CIT Interval 3, doc timelines may need to be extended. Currently no impact on final doc. Aim to update the doc incrementally
- 609: 3/8 - JW and CL meeting - added in to give more clarity around work being undertaken
- 610: 3/8 - JW and CL meeting - added in to give more clarity around work being undertaken
- 611: 3/8 - JW and CL meeting - added in to give more clarity around work being undertaken
- 612: 28/11- Red because of slow start to CIT Interval 3, doc timelines may need to be extended. Currently no impact on final doc. Aim to update the doc incrementally
- 613: 3/8 - JW and CL meeting - added in to give more clarity around work being undertaken
- 614: 3/8 - JW and CL meeting - added in to give more clarity around work being undertaken
- 615: 3/8 - JW and CL meeting - added in to give more clarity around work being undertaken
- 616: 15/8 - JW and CL meeting - added in to give more clarity around work being undertaken. 12/12 - Red because we needed to provide the SRO 5 more working days to review. No impact. No action

| ID | WBS | Task | Type | Duration | Start | Finish | Predecessors | Complete | Baseline start | Baseline finish | Baseline duration | Baseline 1 start | Baseline 1 finish | Constraint | Baseline cost | Responsible | Involved | Update Version | MHHS Resource Name | MHHS Programme Phase | Sched Status | RAG | Artefact ID | Milestone ID | Text29 | Tier |
| --- | --- | --- | --- | --- | --- | --- | --- | --- | --- | --- | --- | --- | --- | --- | --- | --- | --- | --- | --- | --- | --- | --- | --- | --- | --- | --- |
| 617 | 1.4.1.7.1.5.8 | **Test Data (SIT A) Interval 1** |  | 40d | 2023-09-04 A | 2023-10-27 A |  | 100% | 2023-09-04 | 2023-09-29 | 20d | 2023-09-04 | 2023-09-29 |  |  | N/A | N/A | 5.0 | N/A | Systems Integration Testing (SIT) |  |  |  |  |  |  |
| 618 | 1.4.1.7.1.5.8.1 | Run data allocation |  | 4d | 2023-09-04 A | 2023-09-07 A | 545, 558, 547, 595 | 100% | 2023-09-04 | 2023-09-07 | 4d | 2023-09-04 | 2023-09-07 |  |  | SI Test |  | 5.0 | Cesar Lopes | Systems Integration Testing (SIT) | Complete | COMPLETE |  |  |  |  |
| 619 | 1.4.1.7.1.5.8.2 | Cleanse, anonymise and populate data post cut |  | 4d | 2023-09-08 A | 2023-09-13 A | 618 | 100% | 2023-09-08 | 2023-09-13 | 4d | 2023-09-08 | 2023-09-13 |  |  | SI Test |  | 5.0 | Cesar Lopes | Systems Integration Testing (SIT) | Complete | COMPLETE |  |  |  |  |
| 620 | 1.4.1.7.1.5.8.3 | Transmit data sets to PPs |  | 3d | 2023-09-15 A | 2023-09-19 A | 619, 532 | 100% | 2023-09-15 | 2023-09-15 | 1d | 2023-09-14 | 2023-09-15 |  |  | SI Test |  | 5.0 | Cesar Lopes | Systems Integration Testing (SIT) | Complete | COMPLETE |  |  |  |  |
| 621 | 1.4.1.7.1.5.8.4 | PP - Load test data to test environments |  | 7d | 2023-09-20 A | 2023-09-28 A | 620, 604 | 100% | 2023-09-18 | 2023-09-22 | 5d | 2023-09-18 | 2023-09-22 |  |  | PP |  | 5.0 | Cesar Lopes | Systems Integration Testing (SIT) | Complete | COMPLETE |  |  |  |  |
| 622 | 1.4.1.7.1.5.8.5 | PP Check data integrity on test environment |  | 1d | 2023-09-29 A | 2023-09-29 A | 621 | 100% | 2023-09-25 | 2023-09-29 | 5d | 2023-09-25 | 2023-09-29 |  |  | PP |  | 5.0 | Cesar Lopes | Systems Integration Testing (SIT) | Complete | COMPLETE |  |  |  |  |
| 623 | 1.4.1.7.1.5.8.6 | PP submit self-declaration to Programme to confirm loading & verification of test data | milestone | 0d | 2023-09-29 A | 2023-09-29 A | 622FF | 100% | 2023-09-29 | 2023-09-29 | 0d | 2023-09-29 | 2023-09-29 |  |  | PP | SI Test | 5.0 | Cesar Lopes | Systems Integration Testing (SIT) | Complete | COMPLETE |  |  |  |  |
| 624 | 1.4.1.7.1.5.8.7 | Test Data (SIT A) Interval 1 Complete | milestone | 0d | 2023-10-27 A | 2023-10-27 A | 623FS+20d | 100% | 2023-09-29 | 2023-09-29 | 0d |  |  |  |  | SI Test | PP | 5.10 | Cesar Lopes | Systems Integration Testing (SIT) | Complete | COMPLETE | MHHS-ART148/169 | T3-TE-0073 | SITAG | T3 |
| 625 | 1.4.1.7.1.5.9 | **Other Preparation** |  | 45d | 2023-07-03 A | 2023-09-01 A |  | 100% | 2023-07-03 | 2023-09-01 | 45d | 2023-07-03 | 2023-09-01 |  |  | N/A | N/A | 5.0 | N/A | Systems Integration Testing (SIT) |  |  |  |  |  |  |
| 626 | 1.4.1.7.1.5.9.1 | Onboarding of Test Participants to Test Management Tool (Azure DevOps) |  | 45d | 2023-07-03 A | 2023-09-01 A | 585SF | 100% | 2023-07-03 | 2023-09-01 | 45d | 2023-07-03 | 2023-09-01 |  |  | SI Test | PP | 5.0 | Lee Cox | Systems Integration Testing (SIT) | Complete | COMPLETE |  |  |  |  |
| 627 | 1.4.1.7.1.5.9.2 | Test Management Tool onboarding |  | 45d | 2023-07-03 A | 2023-09-01 A | 585SF | 100% | 2023-07-03 | 2023-09-01 | 45d | 2023-07-03 | 2023-09-01 |  |  | PP | SI Test | 5.0 | Lee Cox | Systems Integration Testing (SIT) | Complete | COMPLETE |  |  |  |  |
| 628 | 1.4.1.7.1.5.10 | **SIT Component Integration Test Readiness Report** |  | 28d | 2023-09-14 A | 2023-10-23 A |  | 100% | 2023-10-09 | 2023-10-20 | 9d | 2023-09-11 | 2023-10-20 |  |  | N/A | N/A | 5.6 | N/A | Systems Integration Testing (SIT) |  |  |  |  |  |  |
| 629 | 1.4.1.7.1.5.10.1 | PP submit Test Readiness Report to Programme for assurance | milestone | 0d | 2023-10-20 A | 2023-10-20 A | 627, 568, 624 | 100% | 2023-10-09 | 2023-10-09 | 0d | 2023-09-29 | 2023-09-29 | start no earlier than 2023-10-09 |  | PP | SI Test | 5.6 | Lee Cox | Systems Integration Testing (SIT) | Complete | COMPLETE |  |  |  |  |
| 630 | 1.4.1.7.1.5.10.2 | SI assure Test Participants' Test Readiness Reports |  | 1d | 2023-10-23 A | 2023-10-23 A | 629SS | 100% | 2023-10-10 | 2023-10-16 | 5d | 2023-10-02 | 2023-10-06 |  |  | SI Test | PP,IPA | 5.6 | Lee Cox | Systems Integration Testing (SIT) | Complete | COMPLETE |  |  |  |  |
| 631 | 1.4.1.7.1.5.10.3 | SI develop Overarching SIT Component Integration Test Readiness Report |  | 23d | 2023-09-14 A | 2023-10-16 A | 554FS+40d | 100% | 2023-10-10 | 2023-10-13 | 4d | 2023-09-11 | 2023-10-06 |  |  | SI Test |  | 5.6 | Lee Cox | Systems Integration Testing (SIT) | Complete | COMPLETE |  |  |  |  |
| 632 | 1.4.1.7.1.5.10.4 | Artefact review (via TMAG) and updates |  | 4d | 2023-10-17 A | 2023-10-20 A | 631 | 100% | 2023-10-16 | 2023-10-20 | 5d | 2023-10-09 | 2023-10-20 |  |  | SI Test | PP,IPA | 5.6 | Lee Cox | Systems Integration Testing (SIT) | Complete | COMPLETE |  |  |  |  |
| 633 | 1.4.1.7.1.5.11 | SIT Component Integration Testing 1 Preparation Complete (incl. approval of SI SIT Component Integration Test Readiness Report) | milestone | 0d | 2023-10-27 A | 2023-10-27 A | 632FS+1d, 629, 585, 627, 624, 198, 203, 192, 212, 213, 630 | 100% | 2023-10-23 | 2023-10-23 | 0d | 2023-10-23 | 2023-10-23 |  |  | SI Test | PP,IPA | 5.11 | Lee Cox | Systems Integration Testing (SIT) | Complete | COMPLETE | MHHS-ART071 | T2-TE-0250 | SITAG | T2 |
| 634 | 1.4.1.7.1.6 | **CIT Interval 2 Preparation** |  | 103d | 2023-07-03 A | 2023-11-22 A |  | 100% | 2023-07-03 | 2023-11-10 | 95d | 2022-11-16 | 2023-11-06 |  | -0 | N/A | N/A | 5.0 | N/A | Systems Integration Testing (SIT) |  |  |  |  |  |  |
| 635 | 1.4.1.7.1.6.1 | **Environments (SIT A)** |  | 43d | 2023-09-22 A | 2023-11-22 A |  | 100% | 2023-09-22 | 2023-11-10 | 35d | 2022-11-16 | 2023-10-27 |  | -0 | N/A | N/A | 5.0 | N/A | Systems Integration Testing (SIT) |  |  |  |  |  |  |
| 636 | 1.4.1.7.1.6.1.1 | SIT Participants' SIT A environments ready to start connectivity proving CIT Interval 2 | milestone | 0d | 2023-09-22 A | 2023-09-22 A |  | 100% | 2023-09-22 | 2023-09-22 | 0d | 2023-09-22 | 2023-09-22 |  |  | PP | PP,IPA | 5.6 | Simon Berry | Systems Integration Testing (SIT) | Complete | COMPLETE | MHHS-ART139 | T3-TE-0020 | SITAG | T3 |
| 637 | 1.4.1.7.1.6.1.2 | Programme Participants Ready to Start Connectivity Proving | milestone | 0d | 2023-09-22 A | 2023-09-22 A |  | 100% | 2023-09-22 | 2023-09-22 | 0d |  |  | finish no earlier than 2023-09-22 |  | PP |  | 5.10 | Simon Berry | Systems Integration Testing (SIT) | Complete | COMPLETE |  |  |  |  |
| 638 | 1.4.1.7.1.6.1.3 | Internal Connectivity Proving Phase |  | 10d | 2023-09-25 A | 2023-10-06 A | 637 | 100% | 2023-09-25 | 2023-10-06 | 10d |  |  |  |  | PP |  | 5.10 | Simon Berry | Systems Integration Testing (SIT) | Complete | COMPLETE |  |  |  |  |
| 639 | 1.4.1.7.1.6.1.4 | Internal Connectivity Proving Phase Complete | milestone | 0d | 2023-10-06 A | 2023-10-06 A | 638 | 100% | 2023-10-06 | 2023-10-06 | 0d |  |  | start no earlier than 2023-10-06 |  | PP |  | 5.10 | Simon Berry | Systems Integration Testing (SIT) | Complete | COMPLETE |  |  |  |  |
| 640 | 1.4.1.7.1.6.1.5 | DIP Onboarding Activity (1. PKI Officers and Certificates, 2. Set-up Validation, 3. End Point Creation, 4. Controlled Smoke Test ) |  | 28d | 2023-10-16 A | 2023-11-22 A | 639FS+5d | 100% | 2023-10-16 | 2023-11-10 | 20d |  |  |  |  | PP |  | 5.10 | Simon Berry | Systems Integration Testing (SIT) | Complete | COMPLETE |  |  |  |  |
| 641 | 1.4.1.7.1.6.1.6 | DIP Onboarding Complete | milestone | 0d | 2023-11-22 A | 2023-11-22 A | 640 | 100% | 2023-11-10 | 2023-11-10 | 0d |  |  |  |  | PP |  | 5.10 | Simon Berry | Systems Integration Testing (SIT) | Complete | COMPLETE |  |  |  |  |
| 642 | 1.4.1.7.1.6.1.7 | PPs Register PKI Officers and request PKI certificates Complete - Interval 2 | milestone | 0d | 2023-11-22 A | 2023-11-22 A | 641 | 100% | 2023-10-20 | 2023-10-20 | 0d |  |  |  |  | PP | DIP Provider | 5.15 | Simon Berry | Systems Integration Testing (SIT) | Complete | COMPLETE |  | T3-TE-0098 | SITAG | T3 |
| 643 | 1.4.1.7.1.6.1.8 | PP Code Deployment | milestone | 0d | 2023-10-20 A | 2023-10-20 A |  | 100% | 2023-10-20 | 2023-10-20 | 0d |  |  | start no earlier than 2023-10-20 |  | PP |  | 5.10 | Simon Berry | Systems Integration Testing (SIT) | Complete | COMPLETE |  |  |  |  |

Notes:
- 624: 28/7: CH: added in to be aT3 milestone. 10/10 - RP - Red because Avanade plan to load Test Data on week commencing 23/10, this is the earliest it can be planned due to latest code being required (M9 dependant) / Action: 28/7: CH: Needs to be set-up as a reporting milestone. 31/7: Check with Cesar if has been approved so can be baselined
- 628: Action: 21/8 - Rework with Lee
- 629: 18/8 - dates changed to reflect PIT Execution date changes advised by RG
- 630: 18/8 - dates changed to reflect PIT Execution date changes advised by RG / Action: 21/8 - Rework with Lee
- 631: 18/8 - dates changed to reflect PIT Execution date changes advised by RG / Action: 21/8 - Rework with Lee
- 632: 18/8 - dates changed to reflect PIT Execution date changes advised by RG / Action: 21/8 - Rework with Lee
- 633: Red because prep now dependant on an agreed work-off plan.
- 642: 5/12- Red because only 1 PP has successfully registered their PKI Officers; received their PKI certificates; set-up validation compete; end point creation complete; and completed controlled smoke test. The other PP is currently in Step 4 of E2E onboarding

| ID | WBS | Task | Type | Duration | Start | Finish | Predecessors | Complete | Baseline start | Baseline finish | Baseline duration | Baseline 1 start | Baseline 1 finish | Constraint | Baseline cost | Responsible | Involved | Update Version | MHHS Resource Name | MHHS Programme Phase | Sched Status | RAG | Artefact ID | Milestone ID | Text29 | Tier |
| --- | --- | --- | --- | --- | --- | --- | --- | --- | --- | --- | --- | --- | --- | --- | --- | --- | --- | --- | --- | --- | --- | --- | --- | --- | --- | --- |
| 644 | 1.4.1.7.1.6.2 | **Test Data (SIT A) Interval 2** |  | 43d | 2023-09-20 A | 2023-11-17 A |  | 100% | 2023-09-18 | 2023-10-20 | 25d | 2023-09-18 | 2023-10-20 |  |  | N/A | N/A | 5.0 | N/A | Systems Integration Testing (SIT) |  |  |  |  |  |  |
| 645 | 1.4.1.7.1.6.2.1 | Run data allocation |  | 7d | 2023-09-20 A | 2023-09-28 A | 621SS | 100% | 2023-09-18 | 2023-09-22 | 5d | 2023-09-18 | 2023-09-22 |  |  | SI Test |  | 5.0 | Cesar Lopes | Systems Integration Testing (SIT) | Complete | COMPLETE |  |  |  |  |
| 646 | 1.4.1.7.1.6.2.2 | Cleanse and populate data post cut |  | 2d | 2023-09-29 A | 2023-10-02 A | 645 | 100% | 2023-09-25 | 2023-09-29 | 5d | 2023-09-25 | 2023-09-29 |  |  | SI Test |  | 5.0 | Cesar Lopes | Systems Integration Testing (SIT) | Complete | COMPLETE |  |  |  |  |
| 647 | 1.4.1.7.1.6.2.3 | Transmit data sets to PPs |  | 1d | 2023-10-03 A | 2023-10-03 A | 646 | 100% | 2023-10-02 | 2023-10-03 | 2d | 2023-10-02 | 2023-10-03 |  |  | SI Test |  | 5.0 | Cesar Lopes | Systems Integration Testing (SIT) | Complete | COMPLETE |  |  |  |  |
| 648 | 1.4.1.7.1.6.2.4 | PP - Load test data to test environments |  | 33d | 2023-10-04 A | 2023-11-17 A | 647 | 100% | 2023-10-04 | 2023-10-13 | 8d | 2023-10-04 | 2023-10-13 |  |  | PP |  | 5.0 | Cesar Lopes | Systems Integration Testing (SIT) | Complete | COMPLETE |  |  |  |  |
| 649 | 1.4.1.7.1.6.2.5 | PP Check data integrity on test environment |  | 15d | 2023-10-23 A | 2023-11-17 A | 648FF | 100% | 2023-10-16 | 2023-10-20 | 5d | 2023-10-16 | 2023-10-20 |  |  | PP |  | 5.0 | Cesar Lopes | Systems Integration Testing (SIT) | Complete | COMPLETE |  |  |  |  |
| 650 | 1.4.1.7.1.6.2.6 | PP submit self-declaration to Programme to confirm loading & verification of test data | milestone | 0d | 2023-11-17 A | 2023-11-17 A | 649FF | 100% | 2023-10-20 | 2023-10-20 | 0d | 2023-10-20 | 2023-10-20 |  |  | PP | SI Test | 5.0 | Cesar Lopes | Systems Integration Testing (SIT) | Complete | COMPLETE |  |  |  |  |
| 651 | 1.4.1.7.1.6.2.7 | Test Data (SIT A) Interval 2 Complete | milestone | 0d | 2023-11-17 A | 2023-11-17 A | 650 | 100% | 2023-10-20 | 2023-10-20 | 0d |  |  |  |  | SI Test | PP | 5.12 | Cesar Lopes | Systems Integration Testing (SIT) | Complete | COMPLETE | MHHS-ART148/169 | T3-TE-0074 | SITAG | T3 |
| 652 | 1.4.1.7.1.6.3 | **Other Preparation** |  | 87d | 2023-07-03 A | 2023-10-31 A |  | 100% | 2023-07-03 | 2023-10-31 | 87d | 2023-07-03 | 2023-09-22 |  | -0 | N/A | N/A | 5.0 | N/A | Systems Integration Testing (SIT) |  |  |  |  |  |  |
| 653 | 1.4.1.7.1.6.3.1 | Onboarding of Test Participants to Test Management Tool (Azure DevOps) |  | 60d | 2023-07-03 A | 2023-09-22 A | 636SF | 100% | 2023-07-03 | 2023-09-22 | 60d | 2023-07-03 | 2023-09-22 |  |  | SI Test | PP | 5.0 | Lee Cox | Systems Integration Testing (SIT) | Complete | COMPLETE |  |  |  |  |
| 654 | 1.4.1.7.1.6.3.2 | Test Management Tool onboarding |  | 27d | 2023-09-25 A | 2023-10-31 A | 653 | 100% | 2023-09-25 | 2023-10-31 | 27d | 2023-07-03 | 2023-09-22 |  |  | PP | SI Test | 5.0 | Simon Berry | Systems Integration Testing (SIT) | Complete | COMPLETE |  |  |  |  |
| 655 | 1.4.1.7.1.6.4 | **SIT Component Integration Test Readiness Report** |  | 25d | 2023-10-02 A | 2023-11-03 A |  | 100% | 2023-10-02 | 2023-11-03 | 25d | 2023-10-02 | 2023-11-03 |  |  | N/A | N/A | 5.0 | N/A | Systems Integration Testing (SIT) |  |  |  |  |  |  |
| 656 | 1.4.1.7.1.6.4.1 | PP submit Test Readiness Report to Programme for assurance | milestone | 0d | 2023-10-25 A | 2023-10-25 A | 568FS+18d | 100% | 2023-10-20 | 2023-10-20 | 0d | 2023-10-20 | 2023-10-20 |  |  | PP | SI Test | 5.0 | Lee Cox | Systems Integration Testing (SIT) | Complete | COMPLETE |  |  |  |  |
| 657 | 1.4.1.7.1.6.4.2 | SI assure Test Participants' Test Readiness Reports |  | 2d | 2023-10-26 A | 2023-10-27 A | 656 | 100% | 2023-10-23 | 2023-10-27 | 5d | 2023-10-23 | 2023-10-27 |  |  | SI Test | PP,IPA | 5.0 | Lee Cox | Systems Integration Testing (SIT) | Complete | COMPLETE |  |  |  |  |
| 658 | 1.4.1.7.1.6.4.3 | SI develop Overarching SIT Component Integration Test Readiness Report |  | 20d | 2023-10-02 A | 2023-10-27 A | 657FF | 100% | 2023-10-02 | 2023-10-27 | 20d | 2023-10-02 | 2023-10-27 |  |  | SI Test |  | 5.0 | Lee Cox | Systems Integration Testing (SIT) | Complete | COMPLETE |  |  |  |  |
| 659 | 1.4.1.7.1.6.4.4 | Artefact review (via TMAG) and updates |  | 5d | 2023-10-30 A | 2023-11-03 A | 658 | 100% | 2023-10-30 | 2023-11-03 | 5d | 2023-10-30 | 2023-11-03 |  |  | SI Test | PP,IPA | 5.0 | Lee Cox | Systems Integration Testing (SIT) | Complete | COMPLETE |  |  |  |  |
| 660 | 1.4.1.7.1.6.5 | SIT Component Integration Testing 2 Preparation Complete (incl. approval of SI SIT Component Integration Test Readiness Report) | milestone | 0d | 2023-11-06 A | 2023-11-06 A | 654, 659FS+1d, 636, 261 | 100% | 2023-11-06 | 2023-11-06 | 0d | 2023-11-06 | 2023-11-06 |  |  | SI Test | PP,IPA | 5.11 | Lee Cox | Systems Integration Testing (SIT) | Complete | COMPLETE | MHHS-ART071 | T2-TE-0300 | SITAG | T2 |
| 661 | 1.4.1.7.1.7 | **CIT Interval 3 Preparation** |  | 54d | 2023-10-03 A | 2023-12-15 A |  | 100% | 2023-07-17 | 2023-11-20 | 91d | 2022-11-16 | 2023-11-20 |  | -0 | N/A | N/A | 5.0 | N/A | Systems Integration Testing (SIT) |  |  |  |  |  |  |
| 662 | 1.4.1.7.1.7.1 | **PIT Test Completion Report (incl. evidence)** |  | 26d | 2023-10-13 A | 2023-11-17 A |  | 100% | 2023-10-13 | 2023-11-10 | 21d | 2023-10-13 | 2023-11-10 |  |  | N/A | N/A | 5.0 | N/A | Systems Integration Testing (SIT) |  |  |  |  |  |  |
| 663 | 1.4.1.7.1.7.1.1 | Submit draft PIT Test Completion Report (incl. evidence) and submit to Programme for assurance |  | 11d | 2023-10-13 A | 2023-10-27 A |  | 100% | 2023-10-13 | 2023-10-13 | 1d | 2023-10-13 | 2023-10-13 | must start on 2023-10-13 |  | PP | SI Test | 5.0 | Lee Cox | Systems Integration Testing (SIT) | Complete | COMPLETE |  |  |  |  |
| 664 | 1.4.1.7.1.7.1.2 | Finalise PIT Test Completion Report (incl. evidence) |  | 5d | 2023-10-30 A | 2023-11-03 A | 663 | 100% | 2023-10-16 | 2023-11-03 | 15d | 2023-10-16 | 2023-11-03 |  |  | PP | SI Test | 5.0 | Lee Cox | Systems Integration Testing (SIT) | Complete | COMPLETE |  |  |  |  |
| 665 | 1.4.1.7.1.7.1.3 | PP PIT Completion Report (excl. Migration/Reverse Migration) submitted to Programme for assurance CIT Interval 3 | milestone | 0d | 2023-11-03 A | 2023-11-03 A | 664, 80, 96 | 100% | 2023-11-03 | 2023-11-03 | 0d | 2023-11-03 | 2023-11-03 |  |  | PP | SI Test | 5.11 | Lee Cox | Systems Integration Testing (SIT) | Complete | COMPLETE |  | T3-DB-0017 | SITAG | T3 |
| 666 | 1.4.1.7.1.7.1.4 | PP Final PIT Completion Reports assured by SI |  | 10d | 2023-11-06 A | 2023-11-17 A | 665 | 100% | 2023-11-06 | 2023-11-10 | 5d | 2023-11-06 | 2023-11-10 |  |  | SI Test | PP | 5.0 | Lee Cox | Systems Integration Testing (SIT) | Complete | COMPLETE |  |  |  |  |
| 667 | 1.4.1.7.1.7.2 | **Environments (SIT A)** |  | 51d | 2023-10-06 A | 2023-12-15 A |  | 100% | 2023-10-06 | 2023-11-10 | 26d | 2022-11-16 | 2023-11-10 |  | -0 | N/A | N/A | 5.0 | N/A | Systems Integration Testing (SIT) |  |  |  |  |  |  |
| 668 | 1.4.1.7.1.7.2.1 | Programme Participants Ready to Start Connectivity Proving | milestone | 0d | 2023-10-06 A | 2023-10-06 A |  | 100% | 2023-10-06 | 2023-10-06 | 0d |  |  | start no earlier than 2023-10-06 |  | PP | PP.SI Test | 5.10 | Simon Berry | Systems Integration Testing (SIT) | Complete | COMPLETE |  |  |  |  |
| 669 | 1.4.1.7.1.7.2.2 | SIT Participants' SIT A environments ready to start connectivity proving CIT Interval 3 | milestone | 0d | 2023-10-06 A | 2023-10-06 A | 668 | 100% | 2023-10-06 | 2023-10-06 | 0d | 2023-10-06 | 2023-10-06 |  |  | PP | PP,SI Test | 5.10 | Simon Berry | Systems Integration Testing (SIT) | Complete | COMPLETE | MHHS-ART139 | T3-TE-0021 | SITAG | T3 |
| 670 | 1.4.1.7.1.7.2.3 | Internal Connectivity Proving Phase |  | 10d | 2023-10-09 A | 2023-10-20 A | 668FS+1d | 100% | 2023-10-09 | 2023-10-20 | 10d |  |  |  |  | PP | PP,SI Test | 5.10 | Simon Berry | Systems Integration Testing (SIT) | Complete | COMPLETE |  |  |  |  |
| 671 | 1.4.1.7.1.7.2.4 | Internal Connectivity Proving Phase Complete | milestone | 0d | 2023-10-20 A | 2023-10-20 A | 670 | 100% | 2023-10-20 | 2023-10-20 | 0d |  |  |  |  | PP | PP,SI Test | 5.10 | Simon Berry | Systems Integration Testing (SIT) | Complete | COMPLETE |  |  |  |  |
| 672 | 1.4.1.7.1.7.2.5 | DIP Onboarding Activity (1. PKI Officers and Certificates, 2. Set-up Validation, 3. End Point Creation, 4. Controlled Smoke Test ) |  | 35d | 2023-10-30 A | 2023-12-15 A | 671FS+5d | 100% | 2023-10-30 | 2023-11-10 | 10d |  |  |  |  | PP | PP,DIP Provider | 5.10 | Simon Berry | Systems Integration Testing (SIT) | Complete | COMPLETE |  |  |  |  |
| 673 | 1.4.1.7.1.7.2.6 | DIP Onboarding Complete | milestone | 0d | 2023-12-15 A | 2023-12-15 A | 672 | 100% | 2023-11-10 | 2023-11-10 | 0d |  |  |  |  | PP | PP,DIP Provider | 5.10 | Simon Berry | Systems Integration Testing (SIT) | Complete | COMPLETE |  |  |  |  |
| 674 | 1.4.1.7.1.7.2.7 | PPs Register PKI Officers and Request PKI certificates Complete - Interval 3 | milestone | 0d | 2023-12-15 A | 2023-12-15 A | 673FF | 100% | 2023-11-10 | 2023-11-10 | 0d | 2023-10-02 | 2023-10-06 |  |  | PP | PP,DIP Provider | 5.13 | Simon Berry | Systems Integration Testing (SIT) | Complete | COMPLETE |  | T3-TE-0099 | SITAG | T3 |
| 675 | 1.4.1.7.1.7.2.8 | PP Code Deployment | milestone | 0d | 2023-11-10 A | 2023-11-10 A | 671FS+15d | 100% | 2023-11-10 | 2023-11-10 | 0d |  |  | start no earlier than 2023-10-20 |  | PP | PP | 5.10 | Simon Berry | Systems Integration Testing (SIT) | Complete | COMPLETE |  |  |  |  |

Notes:
- 651: 28/7: CH: added in to be aT3 milestone. 15/11 - Red because of Data Customisation requirement for St. Clements and additional DIP message requirement. Impact is CIT able to start on selected MPANS remaining MPANS to be fixed by 16/11 / Action: 28/7: CH: Needs to be set-up as a reporting milestone. 31/7: Check with Cesar if has been approved so can be baselined
- 660: Amber because of dependency on PPs PIT and known reduced window to review and prepare documentation. No impact currently known. No action. 7/11 - Approved at TMAG on 6/11 with work-off
- 669: Action: 30/8 - lee said date is 30/10
- 674: 09/01 - 1 participant yet to complete onboarding. Anticipated resolution unknown

| ID | WBS | Task | Type | Duration | Start | Finish | Predecessors | Complete | Baseline start | Baseline finish | Baseline duration | Baseline 1 start | Baseline 1 finish | Constraint | Baseline cost | Responsible | Involved | Update Version | MHHS Resource Name | MHHS Programme Phase | Sched Status | RAG | Artefact ID | Milestone ID | Text29 | Tier |
| --- | --- | --- | --- | --- | --- | --- | --- | --- | --- | --- | --- | --- | --- | --- | --- | --- | --- | --- | --- | --- | --- | --- | --- | --- | --- | --- |
| 676 | 1.4.1.7.1.7.3 | **Test Data (SIT A) Interval 3** |  | 34d | 2023-10-03 A | 2023-11-17 A |  | 100% | 2023-10-02 | 2023-11-03 | 25d | 2023-10-02 | 2023-11-03 |  |  | N/A | N/A | 5.0 | N/A | Systems Integration Testing (SIT) |  |  |  |  |  |  |
| 677 | 1.4.1.7.1.7.3.1 | Run data allocation |  | 4d | 2023-10-03 A | 2023-10-06 A | 647SS | 100% | 2023-10-02 | 2023-10-06 | 5d | 2023-10-02 | 2023-10-06 |  |  | SI Test |  | 5.0 | Cesar Lopes | Systems Integration Testing (SIT) | Complete | COMPLETE |  |  |  |  |
| 678 | 1.4.1.7.1.7.3.2 | Cleanse and populate data post cut |  | 5d | 2023-10-09 A | 2023-10-13 A | 677 | 100% | 2023-10-09 | 2023-10-13 | 5d | 2023-10-09 | 2023-10-13 |  |  | SI Test |  | 5.0 | Cesar Lopes | Systems Integration Testing (SIT) | Complete | COMPLETE |  |  |  |  |
| 679 | 1.4.1.7.1.7.3.3 | Transmit data sets to PPs |  | 2d | 2023-10-16 A | 2023-10-17 A | 678 | 100% | 2023-10-16 | 2023-10-17 | 2d | 2023-10-16 | 2023-10-17 |  |  | SI Test |  | 5.0 | Cesar Lopes | Systems Integration Testing (SIT) | Complete | COMPLETE |  |  |  |  |
| 680 | 1.4.1.7.1.7.3.4 | PP - Load test data to test environments |  | 8d | 2023-10-18 A | 2023-10-27 A | 679 | 100% | 2023-10-18 | 2023-10-27 | 8d | 2023-10-18 | 2023-10-27 |  |  | PP |  | 5.0 | Cesar Lopes | Systems Integration Testing (SIT) | Complete | COMPLETE |  |  |  |  |
| 681 | 1.4.1.7.1.7.3.5 | PP Check data integrity on test environment |  | 15d | 2023-10-30 A | 2023-11-17 A | 680 | 100% | 2023-10-30 | 2023-11-03 | 5d | 2023-10-30 | 2023-11-03 |  |  | PP |  | 5.0 | Cesar Lopes | Systems Integration Testing (SIT) | Complete | COMPLETE |  |  |  |  |
| 682 | 1.4.1.7.1.7.3.6 | PP submit self-declaration to Programme to confirm loading & verification of test data | milestone | 0d | 2023-11-17 A | 2023-11-17 A | 681FF | 100% | 2023-11-03 | 2023-11-03 | 0d | 2023-11-03 | 2023-11-03 |  |  | PP | SI Test | 5.0 | Cesar Lopes | Systems Integration Testing (SIT) | Complete | COMPLETE |  |  |  |  |
| 683 | 1.4.1.7.1.7.3.7 | Test Data (SIT A) Interval 3 Complete | milestone | 0d | 2023-11-17 A | 2023-11-17 A | 682 | 100% | 2023-11-03 | 2023-11-03 | 0d |  |  |  |  | SI Test | PP | 5.13 | Cesar Lopes | Systems Integration Testing (SIT) | Complete | COMPLETE | MHHS-ART148/169 | T3-TE-0075 | SITAG | T3 |
| 684 | 1.4.1.7.1.7.4 | **Other Preparation** |  | 25d | 2023-10-16 A | 2023-11-17 A |  | 100% | 2023-07-17 | 2023-10-06 | 60d | 2023-07-17 | 2023-10-06 |  |  | N/A | N/A | 5.0 | N/A | Systems Integration Testing (SIT) |  |  |  |  |  |  |
| 685 | 1.4.1.7.1.7.4.1 | Onboarding of Test Participants to Test Management Tool (Azure DevOps) |  | 25d | 2023-10-16 A | 2023-11-17 A |  | 100% | 2023-07-17 | 2023-10-06 | 60d | 2023-07-17 | 2023-10-06 | start no earlier than 2023-10-16 |  | SI Test | PP | 5.0 | Simon Berry | Systems Integration Testing (SIT) | Complete | COMPLETE |  |  |  |  |
| 686 | 1.4.1.7.1.7.4.2 | Test Management Tool onboarding |  | 25d | 2023-10-16 A | 2023-11-17 A |  | 100% | 2023-07-17 | 2023-10-06 | 60d | 2023-07-17 | 2023-10-06 | start no earlier than 2023-10-16 |  | PP | SI Test | 5.0 | Simon Berry | Systems Integration Testing (SIT) | Complete | COMPLETE |  |  |  |  |
| 687 | 1.4.1.7.1.7.5 | **SIT Component Integration Test Readiness Report** |  | 25d | 2023-10-16 A | 2023-11-17 A |  | 100% | 2023-10-16 | 2023-11-17 | 25d | 2023-10-16 | 2023-11-17 |  |  | N/A | N/A | 5.0 | N/A | Systems Integration Testing (SIT) |  |  |  |  |  |  |
| 688 | 1.4.1.7.1.7.5.1 | PP submit Test Readiness Report to Programme for assurance | milestone | 0d | 2023-11-03 A | 2023-11-03 A | 572 | 100% | 2023-11-03 | 2023-11-03 | 0d | 2023-11-03 | 2023-11-03 |  |  | PP | SI Test | 5.0 | Lee Cox | Systems Integration Testing (SIT) | Complete | COMPLETE |  |  |  |  |
| 689 | 1.4.1.7.1.7.5.2 | SI assure Test Participants' Test Readiness Reports |  | 5d | 2023-11-06 A | 2023-11-10 A | 688FF+5d | 100% | 2023-11-06 | 2023-11-10 | 5d | 2023-11-06 | 2023-11-10 |  |  | SI Test | PP,IPA | 5.0 | Lee Cox | Systems Integration Testing (SIT) | Complete | COMPLETE |  |  |  |  |
| 690 | 1.4.1.7.1.7.5.3 | SI develop Overarching SIT Component Integration Test Readiness Report |  | 20d | 2023-10-16 A | 2023-11-10 A | 689FF | 100% | 2023-10-16 | 2023-11-10 | 20d | 2023-10-16 | 2023-11-10 |  |  | SI Test |  | 5.0 | Lee Cox | Systems Integration Testing (SIT) | Complete | COMPLETE |  |  |  |  |
| 691 | 1.4.1.7.1.7.5.4 | Artefact review (via TMAG) and updates |  | 5d | 2023-11-13 A | 2023-11-17 A | 690 | 100% | 2023-11-13 | 2023-11-17 | 5d | 2023-11-13 | 2023-11-17 |  |  | SI Test | PP,IPA | 5.0 | Lee Cox | Systems Integration Testing (SIT) | Complete | COMPLETE |  |  |  |  |
| 692 | 1.4.1.7.1.7.6 | SIT Component Integration Testing 3 Preparation Complete (incl. approval of SI SIT Component Integration Test Readiness Report) | milestone | 0d | 2023-11-20 A | 2023-11-20 A | 691FS+1d, 665, 669, 688, 686, 683, 279 | 100% | 2023-11-20 | 2023-11-20 | 0d | 2023-11-20 | 2023-11-20 |  |  | SI Test | PP,IPA | 5.12 | Lee Cox | Systems Integration Testing (SIT) | Complete | COMPLETE | MHHS-ART071 | T2-TE-0350 | SITAG | T2 |
| 693 | 1.4.1.7.1.8 | **CIT Interval 4 Preparation** |  | 36d | 2023-10-16 A | 2023-12-04 A |  | 100% | 2023-10-16 | 2023-12-04 | 36d | 2022-11-16 | 2023-12-04 |  | -0 | N/A | N/A | 5.0 | N/A | Systems Integration Testing (SIT) |  |  |  |  |  |  |
| 694 | 1.4.1.7.1.8.1 | **PIT Test Completion Report (incl. evidence)** |  | 21d | 2023-10-27 A | 2023-11-24 A |  | 100% | 2023-10-27 | 2023-11-24 | 21d | 2023-10-27 | 2023-11-24 |  |  | N/A | N/A | 5.0 | N/A | Systems Integration Testing (SIT) |  |  |  |  |  |  |
| 695 | 1.4.1.7.1.8.1.1 | Submit draft PIT Test Completion Report (incl. evidence) and submit to Programme for assurance |  | 1d | 2023-10-27 A | 2023-10-27 A |  | 100% | 2023-10-27 | 2023-10-27 | 1d | 2023-10-27 | 2023-10-27 | must start on 2023-10-27 |  | PP | SI Test | 5.0 | Lee Cox | Systems Integration Testing (SIT) | Complete | COMPLETE |  |  |  |  |
| 696 | 1.4.1.7.1.8.1.2 | Finalise PIT Test Completion Report (incl. evidence) |  | 15d | 2023-10-30 A | 2023-11-17 A | 695 | 100% | 2023-10-30 | 2023-11-17 | 15d | 2023-10-30 | 2023-11-17 |  |  | PP | SI Test | 5.0 | Lee Cox | Systems Integration Testing (SIT) | Complete | COMPLETE |  |  |  |  |
| 697 | 1.4.1.7.1.8.1.3 | PP PIT Completion Report (excl. Migration/Reverse Migration) submitted to Programme for assurance CIT Interval 4 | milestone | 0d | 2023-11-17 A | 2023-11-17 A | 696, 80, 96 | 100% | 2023-11-17 | 2023-11-17 | 0d | 2023-11-17 | 2023-11-17 |  |  | PP | SI Test | 5.13 | Lee Cox | Systems Integration Testing (SIT) | Complete | COMPLETE |  | T3-DB-0019 | SITAG | T3 |
| 698 | 1.4.1.7.1.8.1.4 | PP Final PIT Completion Reports assured by SI |  | 5d | 2023-11-20 A | 2023-11-24 A | 697 | 100% | 2023-11-20 | 2023-11-24 | 5d | 2023-11-20 | 2023-11-24 |  |  | SI Test | PP | 5.0 | Lee Cox | Systems Integration Testing (SIT) | Complete | COMPLETE |  |  |  |  |
| 699 | 1.4.1.7.1.8.2 | **Environments (SIT A)** |  | 25d | 2023-10-23 A | 2023-11-24 A |  | 100% | 2023-10-20 | 2023-11-24 | 25d | 2022-11-16 | 2023-11-24 |  | -0 | N/A | N/A | 5.0 | N/A | Systems Integration Testing (SIT) |  |  |  |  |  |  |
| 700 | 1.4.1.7.1.8.2.1 | Programme Participants Ready to Start Connectivity Proving | milestone | 0d | 2023-10-23 A | 2023-10-23 A |  | 100% | 2023-10-23 | 2023-10-23 | 0d |  |  | start no earlier than 2023-10-23 |  | PP |  | 5.10 | Simon Berry | Systems Integration Testing (SIT) | Complete | COMPLETE |  |  |  |  |
| 701 | 1.4.1.7.1.8.2.2 | SIT Participants' SIT A environments ready to start connectivity proving CIT Interval 4 | milestone | 0d | 2023-10-23 A | 2023-10-23 A | 700 | 100% | 2023-10-20 | 2023-10-20 | 0d | 2023-10-20 | 2023-10-20 |  |  | PP | PP,IPA | 5.10 | Simon Berry | Systems Integration Testing (SIT) | Complete | COMPLETE | MHHS-ART139 | T3-TE-0022 | SITAG | T3 |
| 702 | 1.4.1.7.1.8.2.3 | Internal Connectivity Proving Phase |  | 10d | 2023-10-23 A | 2023-11-03 A | 701 | 100% | 2023-10-23 | 2023-11-03 | 10d |  |  |  |  | PP |  | 5.10 | Simon Berry | Systems Integration Testing (SIT) | Complete | COMPLETE |  |  |  |  |
| 703 | 1.4.1.7.1.8.2.4 | Internal Connectivity Proving Phase Complete | milestone | 0d | 2023-11-03 A | 2023-11-03 A | 702 | 100% | 2023-11-03 | 2023-11-03 | 0d |  |  |  |  | PP |  | 5.10 | Simon Berry | Systems Integration Testing (SIT) | Complete | COMPLETE |  |  |  |  |
| 704 | 1.4.1.7.1.8.2.5 | DIP Onboarding Activity (1. PKI Officers and Certificates, 2. Set-up Validation, 3. End Point Creation, 4. Controlled Smoke Test ) |  | 10d | 2023-11-13 A | 2023-11-24 A | 703FS+5d | 100% | 2023-11-13 | 2023-11-24 | 10d |  |  |  |  | PP |  | 5.10 | Simon Berry | Systems Integration Testing (SIT) | Complete | COMPLETE |  |  |  |  |
| 705 | 1.4.1.7.1.8.2.6 | DIP Onboarding Complete | milestone | 0d | 2023-11-24 A | 2023-11-24 A | 704 | 100% | 2023-11-24 | 2023-11-24 | 0d |  |  |  |  | PP |  | 5.10 | Simon Berry | Systems Integration Testing (SIT) | Complete | COMPLETE |  |  |  |  |
| 706 | 1.4.1.7.1.8.2.7 | PPs register PKI Officers and Request PKI Certificates Complete - Interval 4 | milestone | 0d | 2023-11-24 A | 2023-11-24 A | 705 | 100% | 2023-11-24 | 2023-11-24 | 0d |  |  |  |  | PP | DIP Provider | 5.16 | Simon Berry | Systems Integration Testing (SIT) | Complete | COMPLETE |  | T3-TE-0100 | SITAG | T3 |
| 707 | 1.4.1.7.1.8.2.8 | PP Code Deployment | milestone | 0d | 2023-11-17 A | 2023-11-17 A |  | 100% | 2023-11-17 | 2023-11-17 | 0d |  |  | start no earlier than 2023-11-17 |  | PP |  | 5.10 | Simon Berry | Systems Integration Testing (SIT) | Complete | COMPLETE |  |  |  |  |

Notes:
- 683: 28/7: CH: added in to be aT3 milestone. 14/11-Red because 8 out of 9 participants complete. Final data checks from PP to be made this week. No impact to CIT interval 3 start. / Action: 28/7: CH: Needs to be set-up as a reporting milestone. 31/7: Check with Cesar if has been approved so can be baselined
- 697: 21/11-Red because not all received. Reminders sent. No impact. No issue
- 706: 16/02 - Red because 2 participants yet to complete onboarding. Completed 19/1/24

| ID | WBS | Task | Type | Duration | Start | Finish | Predecessors | Complete | Baseline start | Baseline finish | Baseline duration | Baseline 1 start | Baseline 1 finish | Constraint | Baseline cost | Responsible | Involved | Update Version | MHHS Resource Name | MHHS Programme Phase | Sched Status | RAG | Artefact ID | Milestone ID | Text29 | Tier |
| --- | --- | --- | --- | --- | --- | --- | --- | --- | --- | --- | --- | --- | --- | --- | --- | --- | --- | --- | --- | --- | --- | --- | --- | --- | --- | --- |
| 708 | 1.4.1.7.1.8.3 | **Test Data (SIT A) Interval 4** |  | 30d | 2023-10-23 A | 2023-12-01 A |  | 100% | 2023-10-16 | 2023-11-17 | 25d | 2023-10-16 | 2023-11-17 |  |  | N/A | N/A | 5.0 | N/A | Systems Integration Testing (SIT) |  |  |  |  |  |  |
| 709 | 1.4.1.7.1.8.3.1 | Run data allocation |  | 5d | 2023-10-23 A | 2023-10-27 A | 678FS+5d | 100% | 2023-10-16 | 2023-10-20 | 5d | 2023-10-16 | 2023-10-20 |  |  | SI Test |  | 5.0 | Cesar Lopes | Systems Integration Testing (SIT) | Complete | COMPLETE |  |  |  |  |
| 710 | 1.4.1.7.1.8.3.2 | Cleanse and populate data post cut |  | 2d | 2023-10-30 A | 2023-10-31 A | 709 | 100% | 2023-10-23 | 2023-10-27 | 5d | 2023-10-23 | 2023-10-27 |  |  | SI Test |  | 5.0 | Cesar Lopes | Systems Integration Testing (SIT) | Complete | COMPLETE |  |  |  |  |
| 711 | 1.4.1.7.1.8.3.3 | Transmit data sets to PPs |  | 5d | 2023-11-01 A | 2023-11-07 A | 710 | 100% | 2023-10-30 | 2023-10-31 | 2d | 2023-10-30 | 2023-10-31 |  |  | SI Test |  | 5.0 | Cesar Lopes | Systems Integration Testing (SIT) | Complete | COMPLETE |  |  |  |  |
| 712 | 1.4.1.7.1.8.3.4 | PP - Load test data to test environments |  | 5d | 2023-11-08 A | 2023-11-14 A | 711 | 100% | 2023-11-01 | 2023-11-10 | 8d | 2023-11-01 | 2023-11-10 |  |  | PP |  | 5.0 | Cesar Lopes | Systems Integration Testing (SIT) | Complete | COMPLETE |  |  |  |  |
| 713 | 1.4.1.7.1.8.3.5 | PP Check data integrity on test environment |  | 13d | 2023-11-15 A | 2023-12-01 A | 712 | 100% | 2023-11-13 | 2023-11-17 | 5d | 2023-11-13 | 2023-11-17 |  |  | PP |  | 5.0 | Richard Puddephatt | Systems Integration Testing (SIT) | Complete | COMPLETE |  |  |  |  |
| 714 | 1.4.1.7.1.8.3.6 | PP submit self-declaration to Programme to confirm loading & verification of test data | milestone | 0d | 2023-12-01 A | 2023-12-01 A | 713FF | 100% | 2023-11-17 | 2023-11-17 | 0d | 2023-11-17 | 2023-11-17 |  |  | PP | SI Test | 5.0 | Richard Puddephatt | Systems Integration Testing (SIT) | Complete | COMPLETE |  |  |  |  |
| 715 | 1.4.1.7.1.8.3.7 | Test Data (SIT A) Interval 4 Complete | milestone | 0d | 2023-12-01 A | 2023-12-01 A | 714 | 100% | 2023-11-17 | 2023-11-17 | 0d |  |  |  |  | SI Test | PP | 5.13 | Richard Puddephatt | Systems Integration Testing (SIT) | Complete | COMPLETE | MHHS-ART148/169 | T3-TE-0076 | SITAG | T3 |
| 716 | 1.4.1.7.1.8.4 | **Other Preparation** |  | 25d | 2023-10-30 A | 2023-12-01 A |  | 100% | 2023-10-30 | 2023-12-01 | 25d | 2023-07-31 | 2023-10-20 |  | -0 | N/A | N/A | 5.0 | N/A | Systems Integration Testing (SIT) |  |  |  |  |  |  |
| 717 | 1.4.1.7.1.8.4.1 | Onboarding of Test Participants to Test Management Tool (Azure DevOps) |  | 25d | 2023-10-30 A | 2023-12-01 A |  | 100% | 2023-10-30 | 2023-12-01 | 25d | 2023-07-31 | 2023-10-20 | start no earlier than 2023-10-30 |  | SI Test | PP | 5.0 | Simon Berry | Systems Integration Testing (SIT) | Complete | COMPLETE |  |  |  |  |
| 718 | 1.4.1.7.1.8.4.2 | Test Management Tool onboarding |  | 25d | 2023-10-30 A | 2023-12-01 A |  | 100% | 2023-10-30 | 2023-12-01 | 25d | 2023-07-31 | 2023-10-20 | start no earlier than 2023-10-30 |  | PP | SI Test | 5.0 | Simon Berry | Systems Integration Testing (SIT) | Complete | COMPLETE |  |  |  |  |
| 719 | 1.4.1.7.1.8.5 | **SIT Component Integration Test Readiness Report** |  | 27d | 2023-10-16 A | 2023-11-21 A |  | 100% | 2023-10-30 | 2023-12-01 | 25d | 2023-10-30 | 2023-12-01 |  |  | N/A | N/A | 5.0 | N/A | Systems Integration Testing (SIT) |  |  |  |  |  |  |
| 720 | 1.4.1.7.1.8.5.1 | PP submit Test Readiness Report to Programme for assurance | milestone | 0d | 2023-11-03 A | 2023-11-03 A | 572 | 100% | 2023-11-17 | 2023-11-17 | 0d | 2023-11-17 | 2023-11-17 |  |  | PP | SI Test | 5.0 | Lee Cox | Systems Integration Testing (SIT) | Complete | COMPLETE |  |  |  |  |
| 721 | 1.4.1.7.1.8.5.2 | SI assure Test Participants' Test Readiness Reports |  | 5d | 2023-11-06 A | 2023-11-10 A | 720FF+5d | 100% | 2023-11-20 | 2023-11-24 | 5d | 2023-11-20 | 2023-11-24 |  |  | SI Test | PP,IPA | 5.0 | Lee Cox | Systems Integration Testing (SIT) | Complete | COMPLETE |  |  |  |  |
| 722 | 1.4.1.7.1.8.5.3 | SI develop Overarching SIT Component Integration Test Readiness Report |  | 20d | 2023-10-16 A | 2023-11-10 A | 721FF | 100% | 2023-10-30 | 2023-11-24 | 20d | 2023-10-30 | 2023-11-24 |  |  | SI Test |  | 5.0 | Lee Cox | Systems Integration Testing (SIT) | Complete | COMPLETE |  |  |  |  |
| 723 | 1.4.1.7.1.8.5.4 | Artefact review (via SITAG) and updates |  | 7d | 2023-11-13 A | 2023-11-21 A | 722 | 100% | 2023-11-27 | 2023-12-01 | 5d | 2023-11-27 | 2023-12-01 |  |  | SI Test | PP,IPA | 5.0 | Lee Cox | Systems Integration Testing (SIT) | Complete | COMPLETE |  |  |  |  |
| 724 | 1.4.1.7.1.8.6 | SIT Component Integration Testing 4 Preparation Complete (incl. approval of SI SIT Component Integration Test Readiness Report) | milestone | 0d | 2023-12-04 A | 2023-12-04 A | 723FS+2d, 697, 701, 720, 715, 296FS+1d | 100% | 2023-12-04 | 2023-12-04 | 0d | 2023-12-04 | 2023-12-04 |  |  | SI Test | PP,IPA | 5.13 | Lee Cox | Systems Integration Testing (SIT) | Complete | COMPLETE | MHHS-ART071 | T2-TE-0400 | SITAG | T2 |
| 725 | 1.4.1.7.1.9 | **CIT Interval 5 Preparation** |  | 53d | 2023-11-01 A | 2024-01-12 A |  | 100% | 2023-10-30 | 2024-01-12 | 55d | 2022-11-16 | 2024-01-08 |  | -0 | N/A | N/A | 5.0 | N/A | Systems Integration Testing (SIT) |  |  |  |  |  |  |
| 726 | 1.4.1.7.1.9.1 | **PIT Test Completion Report (incl. evidence)** |  | 21d | 2023-11-17 A | 2023-12-15 A |  | 100% | 2023-11-17 | 2023-12-15 | 21d | 2023-11-17 | 2023-12-15 |  |  | N/A | N/A | 5.0 | N/A | Systems Integration Testing (SIT) |  |  |  |  |  |  |
| 727 | 1.4.1.7.1.9.1.1 | Submit draft PIT Test Completion Report (incl. evidence) and submit to Programme for assurance |  | 1d | 2023-11-17 A | 2023-11-17 A |  | 100% | 2023-11-17 | 2023-11-17 | 1d | 2023-11-17 | 2023-11-17 | must start on 2023-11-17 |  | PP | SI Test | 5.0 | Lee Cox | Systems Integration Testing (SIT) | Complete | COMPLETE |  |  |  |  |
| 728 | 1.4.1.7.1.9.1.2 | Finalise PIT Test Completion Report (incl. evidence) |  | 15d | 2023-11-20 A | 2023-12-08 A | 727 | 100% | 2023-11-20 | 2023-12-08 | 15d | 2023-11-20 | 2023-12-08 |  |  | PP | SI Test | 5.0 | Lee Cox | Systems Integration Testing (SIT) | Complete | COMPLETE |  |  |  |  |
| 729 | 1.4.1.7.1.9.1.3 | PP PIT Completion Report (excl. Migration/Reverse Migration) submitted to Programme for assurance CIT Interval 5 | milestone | 0d | 2023-12-08 A | 2023-12-08 A | 728, 80, 96 | 100% | 2023-12-08 | 2023-12-08 | 0d | 2023-12-08 | 2023-12-08 |  |  | PP | SI Test | 5.14 | Lee Cox | Systems Integration Testing (SIT) | Complete | COMPLETE |  | T3-DB-0021 | SITAG | T3 |
| 730 | 1.4.1.7.1.9.1.4 | PP Final PIT Completion Reports assured by SI |  | 5d | 2023-12-11 A | 2023-12-15 A | 729 | 100% | 2023-12-11 | 2023-12-15 | 5d | 2023-12-11 | 2023-12-15 |  |  | SI Test | PP | 5.0 | Lee Cox | Systems Integration Testing (SIT) | Complete | COMPLETE |  |  |  |  |
| 731 | 1.4.1.7.1.9.2 | **Environments (SIT A)** |  | 21d | 2023-11-10 A | 2023-12-08 A |  | 100% | 2023-11-10 | 2023-12-08 | 21d | 2022-11-16 | 2023-12-15 |  | -0 | N/A | N/A | 5.0 | N/A | Systems Integration Testing (SIT) |  |  |  |  |  |  |
| 732 | 1.4.1.7.1.9.2.1 | Programme Participants Ready to Start Connectivity Proving | milestone | 0d | 2023-11-10 A | 2023-11-10 A |  | 100% | 2023-11-10 | 2023-11-10 | 0d |  |  | start no earlier than 2023-11-10 |  | PP |  | 5.10 | Simon Berry | Systems Integration Testing (SIT) | Complete | COMPLETE |  |  |  |  |
| 733 | 1.4.1.7.1.9.2.2 | SIT Participants' SIT A environments ready to start connectivity proving CIT Interval 5 | milestone | 0d | 2023-11-10 A | 2023-11-10 A | 732 | 100% | 2023-11-10 | 2023-11-10 | 0d | 2023-11-10 | 2023-11-10 |  |  | PP | PP,IPA | 5.6 | Simon Berry | Systems Integration Testing (SIT) | Complete | COMPLETE | MHHS-ART139 | T3-TE-0023 | SITAG | T3 |
| 734 | 1.4.1.7.1.9.2.3 | Internal Connectivity Proving Phase |  | 10d | 2023-11-13 A | 2023-11-24 A | 732FS+1d | 100% | 2023-11-13 | 2023-11-24 | 10d |  |  |  |  | PP |  | 5.10 | Simon Berry | Systems Integration Testing (SIT) | Complete | COMPLETE |  |  |  |  |
| 735 | 1.4.1.7.1.9.2.4 | Internal Connectivity Proving Phase Complete | milestone | 0d | 2023-11-24 A | 2023-11-24 A | 734 | 100% | 2023-11-24 | 2023-11-24 | 0d |  |  |  |  | PP |  | 5.10 | Simon Berry | Systems Integration Testing (SIT) | Complete | COMPLETE |  |  |  |  |
| 736 | 1.4.1.7.1.9.2.5 | DIP Onboarding Activity (1. PKI Officers and Certificates, 2. Set-up Validation, 3. End Point Creation, 4. Controlled Smoke Test ) |  | 10d | 2023-11-27 A | 2023-12-08 A | 735 | 100% | 2023-11-27 | 2023-12-08 | 10d |  |  |  |  | PP |  | 5.10 | Simon Berry | Systems Integration Testing (SIT) | Complete | COMPLETE |  |  |  |  |
| 737 | 1.4.1.7.1.9.2.6 | DIP Onboarding Complete | milestone | 0d | 2023-12-08 A | 2023-12-08 A | 736 | 100% | 2023-12-08 | 2023-12-08 | 0d |  |  |  |  | PP |  | 5.10 | Simon Berry | Systems Integration Testing (SIT) | Complete | COMPLETE |  |  |  |  |
| 738 | 1.4.1.7.1.9.2.7 | PPs register PKI Officers and Request PKI Certificates Complete - Interval 5 | milestone | 0d | 2023-12-08 A | 2023-12-08 A | 737 | 100% | 2023-12-08 | 2023-12-08 | 0d | 2023-11-06 | 2023-11-10 |  |  | PP | DIP Provider | 5.17 | Simon Berry | Systems Integration Testing (SIT) | Complete | COMPLETE |  | T3-TE-0101 | SITAG | T3 |
| 739 | 1.4.1.7.1.9.2.8 | PP Code Deployment | milestone | 0d | 2023-12-08 A | 2023-12-08 A | 738 | 100% | 2023-12-08 | 2023-12-08 | 0d |  |  | start no earlier than 2023-10-20 |  | PP |  | 5.10 | Simon Berry | Systems Integration Testing (SIT) | Complete | COMPLETE |  |  |  |  |

Notes:
- 715: 28/11 - red because data was delivered 1 week late. This led to an onward impact. We expect data to be loaded and checked by 1/12. No impact on CIT Tests Start date
- 724: 5/12 - Approved at Etmag on 4/12 with work off plan
- 729: 4/12- Amber because not all received yet. No impact. No action. 19/12 - complete on 14/12
- 738: 16/01- Red because 1 has yet to complete onboarding. 30/1 - Completed on 26/1/24

| ID | WBS | Task | Type | Duration | Start | Finish | Predecessors | Complete | Baseline start | Baseline finish | Baseline duration | Baseline 1 start | Baseline 1 finish | Constraint | Baseline cost | Responsible | Involved | Update Version | MHHS Resource Name | MHHS Programme Phase | Sched Status | RAG | Artefact ID | Milestone ID | Text29 | Tier |
| --- | --- | --- | --- | --- | --- | --- | --- | --- | --- | --- | --- | --- | --- | --- | --- | --- | --- | --- | --- | --- | --- | --- | --- | --- | --- | --- |
| 740 | 1.4.1.7.1.9.3 | **Test Data (SIT A) Interval 5** |  | 33d | 2023-11-01 A | 2023-12-15 A |  | 100% | 2023-10-30 | 2023-12-08 | 30d | 2023-10-30 | 2023-12-08 |  |  | N/A | N/A | 5.0 | N/A | Systems Integration Testing (SIT) |  |  |  |  |  |  |
| 741 | 1.4.1.7.1.9.3.1 | Run data allocation |  | 5d | 2023-11-01 A | 2023-11-07 A | 711SS | 100% | 2023-10-30 | 2023-11-10 | 10d | 2023-10-30 | 2023-11-10 |  |  | SI Test |  | 5.0 | Cesar Lopes | Systems Integration Testing (SIT) | Complete | COMPLETE |  |  |  |  |
| 742 | 1.4.1.7.1.9.3.2 | Cleanse and populate data post cut |  | 8d | 2023-11-08 A | 2023-11-17 A | 741 | 100% | 2023-11-13 | 2023-11-17 | 5d | 2023-11-13 | 2023-11-17 |  |  | SI Test |  | 5.0 | Cesar Lopes | Systems Integration Testing (SIT) | Complete | COMPLETE |  |  |  |  |
| 743 | 1.4.1.7.1.9.3.3 | Transmit data sets to PPs |  | 2d | 2023-11-20 A | 2023-11-21 A | 742 | 100% | 2023-11-20 | 2023-11-21 | 2d | 2023-11-20 | 2023-11-21 |  |  | SI Test |  | 5.0 | Cesar Lopes | Systems Integration Testing (SIT) | Complete | COMPLETE |  |  |  |  |
| 744 | 1.4.1.7.1.9.3.4 | PP - Load test data to test environments |  | 8d | 2023-11-22 A | 2023-12-01 A | 743 | 100% | 2023-11-22 | 2023-12-01 | 8d | 2023-11-22 | 2023-12-01 |  |  | PP |  | 5.0 | Richard Puddephatt | Systems Integration Testing (SIT) | Complete | COMPLETE |  |  |  |  |
| 745 | 1.4.1.7.1.9.3.5 | PP Check data integrity on test environment |  | 10d | 2023-12-04 A | 2023-12-15 A | 744 | 100% | 2023-12-04 | 2023-12-08 | 5d | 2023-12-04 | 2023-12-08 |  |  | PP |  | 5.0 | Richard Puddephatt | Systems Integration Testing (SIT) | Complete | COMPLETE |  |  |  |  |
| 746 | 1.4.1.7.1.9.3.6 | PP submit self-declaration to Programme to confirm loading & verification of test data | milestone | 0d | 2023-12-15 A | 2023-12-15 A | 745FF | 100% | 2023-12-08 | 2023-12-08 | 0d | 2023-12-08 | 2023-12-08 |  |  | PP | SI Test | 5.0 | Richard Puddephatt | Systems Integration Testing (SIT) | Complete | COMPLETE |  |  |  |  |
| 747 | 1.4.1.7.1.9.3.7 | Test Data (SIT A) Interval 5 Complete | milestone | 0d | 2023-12-15 A | 2023-12-15 A | 746 | 100% | 2023-12-08 | 2023-12-08 | 0d |  |  |  |  | SI Test | PP | 5.14 | Richard Puddephatt | Systems Integration Testing (SIT) | Complete | COMPLETE | MHHS-ART148/169 | T3-TE-0077 | SITAG | T3 |
| 748 | 1.4.1.7.1.9.4 | **Other Preparation** |  | 40d | 2023-11-20 A | 2024-01-12 A |  | 100% | 2023-11-20 | 2024-01-12 | 40d | 2023-08-21 | 2023-11-10 |  | -0 | N/A | N/A | 5.0 | N/A | Systems Integration Testing (SIT) |  |  |  |  |  |  |
| 749 | 1.4.1.7.1.9.4.1 | Onboarding of Test Participants to Test Management Tool (Azure DevOps) |  | 40d | 2023-11-20 A | 2024-01-12 A |  | 100% | 2023-11-20 | 2024-01-12 | 40d | 2023-08-21 | 2023-11-10 | start no earlier than 2023-11-20 |  | SI Test | PP | 5.0 | Simon Berry | Systems Integration Testing (SIT) | Complete | COMPLETE |  |  |  |  |
| 750 | 1.4.1.7.1.9.4.2 | Test Management Tool onboarding |  | 36d | 2023-11-20 A | 2024-01-08 A |  | 100% | 2023-11-20 | 2024-01-08 | 36d | 2023-08-21 | 2023-11-10 | start no earlier than 2023-11-20 |  | PP | SI Test | 5.0 | Simon Berry | Systems Integration Testing (SIT) | Complete | COMPLETE |  |  |  |  |
| 751 | 1.4.1.7.1.9.5 | **SIT Component Integration Test Readiness Report** |  | 35d | 2023-11-20 A | 2024-01-05 A |  | 100% | 2023-11-20 | 2024-01-05 | 35d | 2023-11-20 | 2024-01-05 |  |  | N/A | N/A | 5.0 | N/A | Systems Integration Testing (SIT) |  |  |  |  |  |  |
| 752 | 1.4.1.7.1.9.5.1 | PP submit Test Readiness Report to Programme for assurance | milestone | 0d | 2023-12-08 A | 2023-12-08 A | 576 | 100% | 2023-12-08 | 2023-12-08 | 0d | 2023-12-08 | 2023-12-08 |  |  | PP | SI Test | 5.0 | Lee Cox | Systems Integration Testing (SIT) | Complete | COMPLETE |  |  |  |  |
| 753 | 1.4.1.7.1.9.5.2 | SI assure Test Participants' Test Readiness Reports |  | 5d | 2023-12-11 A | 2023-12-15 A | 752FF+5d | 100% | 2023-12-11 | 2023-12-15 | 5d | 2023-12-11 | 2023-12-15 |  |  | SI Test | PP,IPA | 5.0 | Lee Cox | Systems Integration Testing (SIT) | Complete | COMPLETE |  |  |  |  |
| 754 | 1.4.1.7.1.9.5.3 | SI develop Overarching SIT Component Integration Test Readiness Report |  | 20d | 2023-11-20 A | 2023-12-15 A | 753FF | 100% | 2023-11-20 | 2023-12-15 | 20d | 2023-11-20 | 2023-12-15 |  |  | SI Test |  | 5.0 | Lee Cox | Systems Integration Testing (SIT) | Complete | COMPLETE |  |  |  |  |
| 755 | 1.4.1.7.1.9.5.4 | Artefact review (via SITAG) and updates |  | 15d | 2023-12-18 A | 2024-01-05 A | 754 | 100% | 2023-12-18 | 2024-01-05 | 15d | 2023-12-18 | 2024-01-05 |  |  | SI Test | PP,IPA | 5.0 | Lee Cox | Systems Integration Testing (SIT) | Complete | COMPLETE |  |  |  |  |
| 756 | 1.4.1.7.1.9.6 | SIT Component Integration Testing 5 Preparation Complete (incl. approval of SI SIT Component Integration Test Readiness Report) | milestone | 0d | 2024-01-08 A | 2024-01-08 A | 755FS+1d, 729, 733, 750, 752, 747, 398, 381 | 100% | 2024-01-08 | 2024-01-08 | 0d | 2024-01-08 | 2024-01-08 |  |  | SI Test | PP,IPA | 5.15 | Lee Cox | Systems Integration Testing (SIT) | Complete | COMPLETE | MHHS-ART071 | T2-TE-0450 | SITAG | T2 |
| 757 | 1.4.1.7.1.10 | **CIT Interval 6 Preparation** |  | 45d | 2023-11-20 A | 2024-01-19 A |  | 100% | 2023-11-20 | 2024-01-22 | 46d | 2022-11-16 | 2024-01-22 |  | -0 | N/A | N/A | 5.0 | N/A | Systems Integration Testing (SIT) |  |  |  |  |  |  |
| 758 | 1.4.1.7.1.10.1 | **PIT Test Completion Report (incl. evidence)** |  | 31d | 2023-12-01 A | 2024-01-12 A |  | 100% | 2023-12-01 | 2024-01-12 | 31d | 2023-12-01 | 2024-01-12 |  |  | N/A | N/A | 5.0 | N/A | Systems Integration Testing (SIT) |  |  |  |  |  |  |
| 759 | 1.4.1.7.1.10.1.1 | Submit draft PIT Test Completion Report (incl. evidence) and submit to Programme for assurance |  | 1d | 2023-12-01 A | 2023-12-01 A |  | 100% | 2023-12-01 | 2023-12-01 | 1d | 2023-12-01 | 2023-12-01 | must start on 2023-12-01 |  | PP | SI Test | 5.0 | Lee Cox | Systems Integration Testing (SIT) | Complete | COMPLETE |  |  |  |  |
| 760 | 1.4.1.7.1.10.1.2 | Finalise PIT Test Completion Report (incl. evidence) |  | 25d | 2023-12-04 A | 2024-01-05 A | 759 | 100% | 2023-12-04 | 2024-01-05 | 25d | 2023-12-04 | 2024-01-05 |  |  | PP | SI Test | 5.0 | Lee Cox | Systems Integration Testing (SIT) | Complete | COMPLETE |  |  |  |  |
| 761 | 1.4.1.7.1.10.1.3 | PP PIT Completion Report (excl. Migration/Reverse Migration) submitted to Programme for assurance CIT Interval 6 | milestone | 0d | 2024-01-05 A | 2024-01-05 A | 760, 80, 96, 218, 223, 226 | 100% | 2024-01-05 | 2024-01-05 | 0d | 2024-01-05 | 2024-01-05 |  |  | PP | SI Test | 5.19 | Lee Cox | Systems Integration Testing (SIT) | Complete | COMPLETE |  | T3-DB-0023 | SITAG | T3 |
| 762 | 1.4.1.7.1.10.1.4 | PP Final PIT Completion Reports assured by SI |  | 5d | 2024-01-08 A | 2024-01-12 A | 761 | 100% | 2024-01-08 | 2024-01-12 | 5d | 2024-01-08 | 2024-01-12 |  |  | SI Test | PP | 5.19 | Lee Cox | Systems Integration Testing (SIT) | Complete | COMPLETE |  |  |  |  |
| 763 | 1.4.1.7.1.10.2 | **Environments (SIT A)** |  | 30d | 2023-11-24 A | 2024-01-05 A |  | 100% | 2023-11-24 | 2024-01-05 | 30d | 2022-11-16 | 2024-01-05 |  | -0 | N/A | N/A | 5.0 | N/A | Systems Integration Testing (SIT) |  |  |  |  |  |  |
| 764 | 1.4.1.7.1.10.2.1 | Programme Participants Ready to Start Connectivity Proving | milestone | 0d | 2023-11-24 A | 2023-11-24 A |  | 100% | 2023-11-24 | 2023-11-24 | 0d |  |  | start no earlier than 2023-11-24 |  | PP |  | 5.10 | Simon Berry | Systems Integration Testing (SIT) | Complete | COMPLETE |  |  |  |  |
| 765 | 1.4.1.7.1.10.2.2 | SIT Participants' SIT A environments ready to start connectivity proving CIT Interval 6 | milestone | 0d | 2023-11-24 A | 2023-11-24 A | 764 | 100% | 2023-11-24 | 2023-11-24 | 0d | 2023-11-24 | 2023-11-24 |  |  | PP | PP,IPA | 5.6 | Simon Berry | Systems Integration Testing (SIT) | Complete | COMPLETE | MHHS-ART139 | T3-TE-0024 | SITAG | T3 |
| 766 | 1.4.1.7.1.10.2.3 | Internal Connectivity Proving Phase |  | 10d | 2023-11-27 A | 2023-12-08 A | 765FS+1d | 100% | 2023-11-27 | 2023-12-08 | 10d |  |  |  |  | PP |  | 5.10 | Simon Berry | Systems Integration Testing (SIT) | Complete | COMPLETE |  |  |  |  |
| 767 | 1.4.1.7.1.10.2.4 | Internal Connectivity Proving Phase Complete | milestone | 0d | 2023-12-08 A | 2023-12-08 A | 766 | 100% | 2023-12-08 | 2023-12-08 | 0d |  |  |  |  | PP |  | 5.10 | Simon Berry | Systems Integration Testing (SIT) | Complete | COMPLETE |  |  |  |  |
| 768 | 1.4.1.7.1.10.2.5 | DIP Onboarding Activity (1. PKI Officers and Certificates, 2. Set-up Validation, 3. End Point Creation, 4. Controlled Smoke Test ) |  | 5d | 2023-12-04 A | 2023-12-08 A | 765FS+6d | 100% | 2023-12-04 | 2023-12-08 | 5d |  |  |  |  | PP |  | 5.10 | Simon Berry | Systems Integration Testing (SIT) | Complete | COMPLETE |  |  |  |  |
| 769 | 1.4.1.7.1.10.2.6 | DIP Onboarding Complete | milestone | 0d | 2023-12-08 A | 2023-12-08 A | 768 | 100% | 2023-12-08 | 2023-12-08 | 0d |  |  |  |  | PP |  | 5.10 | Simon Berry | Systems Integration Testing (SIT) | Complete | COMPLETE |  |  |  |  |
| 770 | 1.4.1.7.1.10.2.7 | PPs register PKI Officers and Request PKI Certificates Complete - Interval 6 | milestone | 0d | 2023-12-08 A | 2023-12-08 A | 769 | 100% | 2023-12-08 | 2023-12-08 | 0d | 2023-11-20 | 2023-11-24 | start no earlier than 2023-12-08 |  | PP | DIP Provider | 5.17 | Simon Berry | Systems Integration Testing (SIT) | Complete | COMPLETE |  | T3-TE-0102 | SITAG | T3 |
| 771 | 1.4.1.7.1.10.2.8 | PP Code Deployment | milestone | 0d | 2024-01-05 A | 2024-01-05 A |  | 100% | 2024-01-05 | 2024-01-05 | 0d |  |  | start no earlier than 2024-01-05 |  | PP |  | 5.10 | Simon Berry | Systems Integration Testing (SIT) | Complete | COMPLETE |  |  |  |  |

Notes:
- 747: 28/7: CH: added in to be aT3 milestone. 12/12 - Red because PPs required additional time due to some data changes required. No impact. Action to follow-up with PPs for latest progress / Action: 28/7: CH: Needs to be set-up as a reporting milestone. 31/7: Check with Cesar if has been approved so can be baselined
- 756: 2/1/24 - Approved at Dec TMAG following change in CIT governance
- 761: 9/1 - Not all completion reports yet received. Completed 22/2/24
- 765: 29/11 - Red because forecast date missed. Participants status to be determined by 4th December. No risk to future milestones
- 768: 5/12 -
- 770: 12/12 - Red because 1 Participant still to complete. 30/1 - Completed 29/1/24

| ID | WBS | Task | Type | Duration | Start | Finish | Predecessors | Complete | Remaining | Baseline start | Baseline finish | Baseline duration | Baseline 1 start | Baseline 1 finish | Total slack | Constraint | Baseline cost | Responsible | Involved | Update Version | MHHS Resource Name | MHHS Programme Phase | Sched Status | RAG | Artefact ID | Milestone ID | Text29 | Tier |
| --- | --- | --- | --- | --- | --- | --- | --- | --- | --- | --- | --- | --- | --- | --- | --- | --- | --- | --- | --- | --- | --- | --- | --- | --- | --- | --- | --- | --- |
| 772 | 1.4.1.7.1.10.3 | **Test Data (SIT A) Interval 6** |  | 25d | 2023-11-20 A | 2023-12-22 A |  | 100% |  | 2023-11-20 | 2023-12-22 | 25d | 2023-11-20 | 2023-12-22 |  |  |  | N/A | N/A | 5.0 | N/A | Systems Integration Testing (SIT) |  |  |  |  |  |  |
| 773 | 1.4.1.7.1.10.3.1 | Run data allocation |  | 10d | 2023-11-20 A | 2023-12-01 A | 743SS | 100% |  | 2023-11-20 | 2023-11-24 | 5d | 2023-11-20 | 2023-11-24 |  |  |  | SI Test |  | 5.0 | Richard Puddephatt | Systems Integration Testing (SIT) | Complete | COMPLETE |  |  |  |  |
| 774 | 1.4.1.7.1.10.3.2 | Cleanse and populate data post cut |  | 1d | 2023-12-04 A | 2023-12-04 A | 773 | 100% |  | 2023-11-27 | 2023-12-01 | 5d | 2023-11-27 | 2023-12-01 |  |  |  | SI Test |  | 5.0 | Richard Puddephatt | Systems Integration Testing (SIT) | Complete | COMPLETE |  |  |  |  |
| 775 | 1.4.1.7.1.10.3.3 | Transmit data sets to PPs |  | 1d | 2023-12-05 A | 2023-12-05 A | 774 | 100% |  | 2023-12-04 | 2023-12-05 | 2d | 2023-12-04 | 2023-12-05 |  |  |  | SI Test |  | 5.0 | Richard Puddephatt | Systems Integration Testing (SIT) | Complete | COMPLETE |  |  |  |  |
| 776 | 1.4.1.7.1.10.3.4 | PP - Load test data to test environments |  | 8d | 2023-12-06 A | 2023-12-15 A | 775 | 100% |  | 2023-12-06 | 2023-12-15 | 8d | 2023-12-06 | 2023-12-15 |  |  |  | PP |  | 5.0 | Richard Puddephatt | Systems Integration Testing (SIT) | Complete | COMPLETE |  |  |  |  |
| 777 | 1.4.1.7.1.10.3.5 | PP Check data integrity on test environment |  | 5d | 2023-12-18 A | 2023-12-22 A | 776 | 100% |  | 2023-12-18 | 2023-12-22 | 5d | 2023-12-18 | 2023-12-22 |  |  |  | PP |  | 5.0 | Richard Puddephatt | Systems Integration Testing (SIT) | Complete | COMPLETE |  |  |  |  |
| 778 | 1.4.1.7.1.10.3.6 | PP submit self-declaration to Programme to confirm loading & verification of test data | milestone | 0d | 2023-12-22 A | 2023-12-22 A | 777FF | 100% |  | 2023-12-22 | 2023-12-22 | 0d | 2023-12-22 | 2023-12-22 |  |  |  | PP | SI Test | 5.0 | Richard Puddephatt | Systems Integration Testing (SIT) | Complete | COMPLETE |  |  |  |  |
| 779 | 1.4.1.7.1.10.3.7 | Test Data (SIT A) Interval 6 Complete | milestone | 0d | 2023-12-22 A | 2023-12-22 A | 778 | 100% |  | 2023-12-22 | 2023-12-22 | 0d |  |  |  |  |  | SI Test | PP | 5.5 | Richard Puddephatt | Systems Integration Testing (SIT) | Complete | COMPLETE | MHHS-ART148/169 | T3-TE-0078 | SITAG | T3 |
| 780 | 1.4.1.7.1.10.4 | **Other Preparation** |  | 31d | 2023-12-04 A | 2024-01-15 A |  | 100% |  | 2023-12-04 | 2024-01-15 | 31d | 2023-09-04 | 2023-11-24 |  |  | -0 | N/A | N/A | 5.0 | N/A | Systems Integration Testing (SIT) |  |  |  |  |  |  |
| 781 | 1.4.1.7.1.10.4.1 | Onboarding of Test Participants to Test Management Tool (Azure DevOps) |  | 31d | 2023-12-04 A | 2024-01-15 A |  | 100% |  | 2023-12-04 | 2024-01-15 | 31d | 2023-09-04 | 2023-11-24 |  | start no earlier than 2023-12-04 |  | SI Test | PP | 5.0 | Simon Berry | Systems Integration Testing (SIT) | Complete | COMPLETE |  |  |  |  |
| 782 | 1.4.1.7.1.10.4.2 | Test Management Tool onboarding |  | 31d | 2023-12-04 A | 2024-01-15 A |  | 100% |  | 2023-12-04 | 2024-01-15 | 31d | 2023-09-04 | 2023-11-24 |  | start no earlier than 2023-12-04 |  | PP | SI Test | 5.0 | Simon Berry | Systems Integration Testing (SIT) | Complete | COMPLETE |  |  |  |  |
| 783 | 1.4.1.7.1.10.5 | **SIT Component Integration Test Readiness Report** |  | 25d | 2023-11-20 A | 2023-12-22 A |  | 100% |  | 2023-12-18 | 2024-01-19 | 25d | 2023-12-18 | 2024-01-19 |  |  |  | N/A | N/A | 5.0 | N/A | Systems Integration Testing (SIT) |  |  |  |  |  |  |
| 784 | 1.4.1.7.1.10.5.1 | PP submit Test Readiness Report to Programme for assurance | milestone | 0d | 2023-12-08 A | 2023-12-08 A | 576 | 100% |  | 2024-01-05 | 2024-01-05 | 0d | 2024-01-05 | 2024-01-05 |  |  |  | PP | SI Test | 5.0 | Lee Cox | Systems Integration Testing (SIT) | Complete | COMPLETE |  |  |  |  |
| 785 | 1.4.1.7.1.10.5.2 | SI assure Test Participants' Test Readiness Reports |  | 5d | 2023-12-11 A | 2023-12-15 A | 784FF+5d | 100% |  | 2024-01-08 | 2024-01-12 | 5d | 2024-01-08 | 2024-01-12 |  |  |  | SI Test | PP,IPA | 5.0 | Lee Cox | Systems Integration Testing (SIT) | Complete | COMPLETE |  |  |  |  |
| 786 | 1.4.1.7.1.10.5.3 | SI develop Overarching SIT Component Integration Test Readiness Report |  | 20d | 2023-11-20 A | 2023-12-15 A | 785FF | 100% |  | 2023-12-18 | 2024-01-12 | 20d | 2023-12-18 | 2024-01-12 |  |  |  | SI Test |  | 5.0 | Lee Cox | Systems Integration Testing (SIT) | Complete | COMPLETE |  |  |  |  |
| 787 | 1.4.1.7.1.10.5.4 | Artefact review (via TMAG) and updates |  | 5d | 2023-12-18 A | 2023-12-22 A | 786 | 100% |  | 2024-01-15 | 2024-01-19 | 5d | 2024-01-15 | 2024-01-19 |  |  |  | SI Test | PP,IPA | 5.0 | Lee Cox | Systems Integration Testing (SIT) | Complete | COMPLETE |  |  |  |  |
| 788 | 1.4.1.7.1.10.6 | SIT Component Integration Testing 6 Preparation Complete (incl. approval of SI SIT Component Integration Test Readiness Report) | milestone | 0d | 2024-01-19 A | 2024-01-19 A | 787FS+1d, 761, 765, 782, 784, 779, 244, 415 | 100% |  | 2024-01-22 | 2024-01-22 | 0d | 2024-01-22 | 2024-01-22 |  |  |  | SI Test | PP,IPA | 5.15 | Lee Cox | Systems Integration Testing (SIT) | Complete | COMPLETE | MHHS-ART071 | T2-TE-0500 | SITAG | T2 |
| 789 | 1.4.1.7.2 | **SIT Functional Preparation** |  | 520d | 2022-10-31 A | 2024-10-25 |  | 93% | 37.55d | 2022-10-31 | 2024-10-25 | 520d | 2022-10-31 | 2024-03-01 | 17d |  | -0 | N/A | N/A | 5.0 | N/A | Systems Integration Testing (SIT) |  |  |  |  |  |  |
| 790 | 1.4.1.7.2.1 | **Test Approach & Plan** |  | 208d | 2022-10-31 A | 2023-08-16 A |  | 100% |  | 2022-10-31 | 2023-08-16 | 208d | 2022-10-31 | 2023-08-16 |  |  |  | N/A | N/A | 5.0 | N/A | Systems Integration Testing (SIT) |  |  |  |  |  |  |
| 791 | 1.4.1.7.2.1.1 | Develop document with SITWG |  | 179d | 2022-10-31 A | 2023-07-06 A |  | 100% |  | 2022-10-31 | 2023-07-06 | 179d | 2022-10-31 | 2023-07-06 |  | finish no earlier than 2023-07-06 |  | SI Test |  | 5.0 | Lee Cox | Systems Integration Testing (SIT) | Complete | COMPLETE |  |  |  |  |
| 792 | 1.4.1.7.2.1.2 | Industry Consultation |  | 10d | 2023-07-07 A | 2023-07-20 A | 791 | 100% |  | 2023-07-07 | 2023-07-20 | 10d |  |  |  |  |  | PP |  | 5.1 |  | Systems Integration Testing (SIT) | Complete | COMPLETE |  |  |  |  |
| 793 | 1.4.1.7.2.1.3 | Artefact review (via TMAG) and updates |  | 19d | 2023-07-21 A | 2023-08-16 A | 792 | 100% |  | 2023-07-21 | 2023-08-16 | 19d | 2023-07-07 | 2023-08-03 |  | finish no earlier than 2023-08-03 |  | SI Test | PP,IPA,Code Bodies | 5.5 | Lee Cox | Systems Integration Testing (SIT) | Complete | COMPLETE |  |  |  |  |
| 794 | 1.4.1.7.2.1.4 | SIT Functional Testing Test Approach & Plan approved | milestone | 0d | 2023-08-16 A | 2023-08-16 A |  | 100% |  | 2023-08-16 | 2023-08-16 | 0d | 2023-08-16 | 2023-08-16 |  | finish no earlier than 2023-08-16 |  | SI Test | PP | 5.0 | Lee Cox | Systems Integration Testing (SIT) | Complete | COMPLETE | MHHS-ART073 | T3-TE-0013 | SITAG | T3 |
| 795 | 1.4.1.7.2.2 | **Test Data Approach & Plan** |  | 29d | 2023-07-07 A | 2023-08-16 A |  | 100% |  | 2023-07-07 | 2023-08-16 | 29d | 2023-07-07 | 2023-08-16 |  |  |  | N/A | N/A | 5.0 | N/A | Systems Integration Testing (SIT) |  |  |  |  |  |  |
| 796 | 1.4.1.7.2.2.1 | Industry Consultation |  | 10d | 2023-07-07 A | 2023-07-20 A | 792SS | 100% |  | 2023-07-07 | 2023-07-20 | 10d |  |  |  |  |  | PP |  | 5.1 | Cesar Lopes | Systems Integration Testing (SIT) | Complete | COMPLETE |  |  |  |  |
| 797 | 1.4.1.7.2.2.2 | Artefact review (via TMAG) and updates |  | 19d | 2023-07-21 A | 2023-08-16 A | 796 | 100% |  | 2023-07-21 | 2023-08-16 | 19d | 2023-07-07 | 2023-08-03 |  |  |  | SI Test |  | 5.5 | Cesar Lopes | Systems Integration Testing (SIT) | Complete | COMPLETE |  |  |  |  |
| 798 | 1.4.1.7.2.2.3 | SIT Functional Testing Test Data Approach & Plan approved | milestone | 0d | 2023-08-16 A | 2023-08-16 A | 797 | 100% |  | 2023-08-16 | 2023-08-16 | 0d | 2023-08-16 | 2023-08-16 |  |  |  | SI Test | PP,IPA | 5.5 | Cesar Lopes | Systems Integration Testing (SIT) | Complete | COMPLETE |  |  |  |  |

Notes:
- 779: 28/7: CH: added in to be aT3 milestone / Action: 28/7: CH: Needs to be set-up as a reporting milestone. 31/7: Check with Cesar if has been approved so can be baselined
- 788: 2/1/24 - Approved at Dec TMAG following change in CIT governance

| ID | WBS | Task | Type | Duration | Start | Finish | Predecessors | Complete | Baseline start | Baseline finish | Baseline duration | Baseline 1 start | Baseline 1 finish | Constraint | Baseline cost | Responsible | Involved | Update Version | MHHS Resource Name | MHHS Programme Phase | Sched Status | RAG | Artefact ID | Milestone ID | Text29 | Tier | Action | Guidance | Task Status |
| --- | --- | --- | --- | --- | --- | --- | --- | --- | --- | --- | --- | --- | --- | --- | --- | --- | --- | --- | --- | --- | --- | --- | --- | --- | --- | --- | --- | --- | --- |
| 799 | 1.4.1.7.2.3 | **Test scenarios** |  | 298d | 2023-01-02 A | 2024-02-21 A |  | 100% | 2023-01-02 | 2024-02-21 | 298d | 2023-01-02 | 2023-06-02 |  | -0 | N/A | N/A | 5.0 | N/A | Systems Integration Testing (SIT) |  |  |  |  |  |  |  |  |  |
| 800 | 1.4.1.7.2.3.1 | Development of test scenarios |  | 85d | 2023-01-02 A | 2023-04-28 A | 791SS+45d | 100% | 2023-01-02 | 2023-04-28 | 85d | 2023-01-02 | 2023-04-28 |  |  | SI Test | PP, Code Bodies | 5.0 | Lee Cox | Systems Integration Testing (SIT) | Complete | COMPLETE |  |  |  |  |  |  |  |
| 801 | 1.4.1.7.2.3.2 | Review test scenarios with SIT Working Group |  | 65d | 2023-08-17 A | 2023-11-15 A | 800FS+78d | 100% | 2023-08-17 | 2023-11-15 | 65d | 2023-02-01 | 2023-05-26 |  |  | SI Test | PP, Code Bodies, IPA | 5.0 | Lee Cox | Systems Integration Testing (SIT) | Complete | COMPLETE |  |  |  |  |  |  |  |
| 802 | 1.4.1.7.2.3.3 | SIT Functional Testing Test scenarios (themes 1-5) approved | milestone | 0d | 2023-12-08 A | 2023-12-08 A | 801FS+17d | 100% | 2023-12-08 | 2023-12-08 | 0d | 2023-06-02 | 2023-06-02 |  |  | SI Test | PP | 5.14 | Lee Cox | Systems Integration Testing (SIT) | Complete | COMPLETE | MMHS-ART073 | T3-TE-0015 | SITAG | T3 |  |  |  |
| 803 | 1.4.1.7.2.3.4 | SIT Functional Testing Test scenarios (themes 6,7,9) approved | milestone | 0d | 2024-01-17 A | 2024-01-17 A | 802FS+28d | 100% | 2024-01-17 | 2024-01-17 | 0d | 2023-06-02 | 2023-06-02 |  |  | SI Test | PP | 5.16 | Lee Cox | Systems Integration Testing (SIT) | Complete | COMPLETE | MMHS-ART073 | T3-TE-0106 | SITAG | T3 |  |  |  |
| 804 | 1.4.1.7.2.3.5 | SIT Functional Testing Test scenarios (theme 8) approved | milestone | 0d | 2024-02-21 A | 2024-02-21 A | 803FS+25d | 100% | 2024-02-21 | 2024-02-21 | 0d | 2023-06-02 | 2023-06-02 |  |  | SI Test | PP | 5.14 | Lee Cox | Systems Integration Testing (SIT) | Complete | COMPLETE | MMHS-ART073 | T3-TE-0107 | SITAG | T3 |  |  |  |
| 805 | 1.4.1.7.2.4 | **Test cases** |  | 213d | 2023-05-01 A | 2024-02-21 A |  | 100% | 2023-05-01 | 2024-02-21 | 213d | 2023-05-01 | 2023-09-01 |  |  | N/A | N/A | 5.0 | N/A | Systems Integration Testing (SIT) |  |  |  |  |  |  | 25/7 - needs to be replanned |  |  |
| 806 | 1.4.1.7.2.4.1 | **SI Test cases** |  | 213d | 2023-05-01 A | 2024-02-21 A |  | 100% | 2023-05-01 | 2024-02-21 | 213d | 2023-05-01 | 2023-09-01 |  |  | N/A | N/A | 5.0 | N/A | Systems Integration Testing (SIT) |  |  |  |  |  |  | 25/7 - needs to be replanned |  |  |
| 807 | 1.4.1.7.2.4.1.1 | Development of Test cases |  | 150d | 2023-05-01 A | 2023-11-24 A | 800 | 100% | 2023-05-01 | 2023-11-24 | 150d | 2023-05-01 | 2023-07-28 |  |  | SI Test |  | 5.0 | Lee Cox | Systems Integration Testing (SIT) | Complete | COMPLETE |  |  |  |  | 25/7 - needs to be replanned |  |  |
| 808 | 1.4.1.7.2.4.1.2 | Review Test cases with SIT Working Group |  | 78d | 2023-09-25 A | 2024-01-10 A | 807SS+105d | 100% | 2023-09-25 | 2024-01-10 | 78d | 2023-05-26 | 2023-08-25 |  |  | SI Test | PP,IPA | 5.0 | Lee Cox | Systems Integration Testing (SIT) | Complete | COMPLETE |  |  |  |  | 25/7 - needs to be replanned |  |  |
| 809 | 1.4.1.7.2.4.1.3 | SIT Functional Testing Test Cases (themes 1-5) approved | milestone | 0d | 2024-01-17 A | 2024-01-17 A | 808FS+5d | 100% | 2024-01-17 | 2024-01-17 | 0d | 2023-09-01 | 2023-09-01 |  |  | SI Test | PP | 5.14 | Lee Cox | Systems Integration Testing (SIT) | Complete | COMPLETE | MHHS-ART140 | T3-TE-0070 | SITAG | T3 |  | 2/1/24 - Approved at Dec TMAG |  |
| 810 | 1.4.1.7.2.4.1.4 | SIT Functional Testing Test cases (themes 6,7,9) approved | milestone | 0d | 2024-01-17 A | 2024-01-17 A | 809 | 100% | 2024-01-17 | 2024-01-17 | 0d | 2023-09-01 | 2023-09-01 |  |  | SI Test | PP | 5.14 | Lee Cox | Systems Integration Testing (SIT) | Complete | COMPLETE | MHHS-ART140 | T3-TE-0108 | SITAG | T3 |  |  |  |
| 811 | 1.4.1.7.2.4.1.5 | SIT Functional Testing Test cases (theme 8) approved | milestone | 0d | 2024-02-21 A | 2024-02-21 A | 810FS+25d | 100% | 2024-02-21 | 2024-02-21 | 0d | 2023-09-01 | 2023-09-01 |  |  | SI Test | PP | 5.14 | Lee Cox | Systems Integration Testing (SIT) | Complete | COMPLETE | MHHS-ART140 | T3-TE-0109 | SITAG | T3 |  |  |  |
| 812 | 1.4.1.7.2.5 | **Environments (SIT-Staging)** |  | 10d | 2023-12-04 A | 2023-12-15 A |  | 100% | 2022-11-16 | 2024-02-09 | 323d | 2022-11-16 | 2024-02-09 |  |  | N/A | N/A | 5.0 | N/A | Systems Integration Testing (SIT) |  |  |  |  |  |  |  |  |  |
| 813 | 1.4.1.7.2.5.1 | **SIT Functional pre-requisites** |  | 10d | 2023-12-04 A | 2023-12-15 A |  | 100% | 2023-12-04 | 2023-12-15 | 10d |  |  |  |  | N/A | N/A | 5.3 | N/A | Systems Integration Testing (SIT) |  |  |  |  |  |  |  |  |  |
| 814 | 1.4.1.7.2.5.1.1 | **DCC** |  | 10d | 2023-12-04 A | 2023-12-15 A |  | 100% | 2023-12-04 | 2023-12-15 | 10d |  |  |  |  | N/A | N/A | 5.3 | N/A | Systems Integration Testing (SIT) |  |  |  |  |  |  |  |  | -254.67 |
| 815 | 1.4.1.7.2.5.1.1.1 | **CSS** |  | 10d | 2023-12-04 A | 2023-12-15 A |  | 100% | 2023-12-04 | 2023-12-15 | 10d |  |  |  |  | N/A | N/A | 5.3 | N/A | Systems Integration Testing (SIT) |  |  |  |  |  |  |  |  | -254.67 |
| 816 | 1.4.1.7.2.5.1.1.1.1 | SIT participants have requested DCC CSS PKI certificates for access to UIT-B environment |  | 10d | 2023-12-04 A | 2023-12-15 A |  | 100% | 2023-12-04 | 2023-12-15 | 10d |  |  | start no earlier than 2023-12-04 |  | SIT Participants (Suppliers & Third Parties) | PP | 5.3 | Simon Berry | Systems Integration Testing (SIT) | Complete | COMPLETE |  |  |  |  |  |  |  |
| 817 | 1.4.1.7.2.5.1.1.1.2 | SIT participants have received DCC CSS PKI certificates for UIT-B environment | milestone | 0d | 2023-12-15 A | 2023-12-15 A | 816 | 100% | 2023-12-15 | 2023-12-15 | 0d |  |  |  |  | SIT Participants (Suppliers & Third Parties) | PP | 5.5 | Simon Berry | Systems Integration Testing (SIT) | Complete | COMPLETE |  | T3-TE-0088 | SITAG | T3 | 7/8 - added as a T3 milestone. Awaiting approval at TMAG |  |  |
| 818 | 1.4.1.7.2.5.1.1.2 | **DSP** |  | 10d | 2023-12-04 A | 2023-12-15 A |  | 100% | 2023-12-04 | 2023-12-15 | 10d |  |  |  |  | N/A | N/A | 5.3 | N/A | Systems Integration Testing (SIT) |  |  |  |  |  |  |  |  | -254.67 |
| 819 | 1.4.1.7.2.5.1.1.2.1 | SIT participants have requested DCC DSP PKI certificates for access to UIT-B environment |  | 10d | 2023-12-04 A | 2023-12-15 A |  | 100% | 2023-12-04 | 2023-12-15 | 10d |  |  | start no earlier than 2023-12-04 |  | PPs in SDS Market Role | PP | 5.3 | Simon Berry | Systems Integration Testing (SIT) | Complete | COMPLETE |  |  |  |  |  |  |  |
| 820 | 1.4.1.7.2.5.1.1.2.2 | SIT participants have received DCC DSP PKI certificates for UIT-B environment | milestone | 0d | 2023-12-15 A | 2023-12-15 A | 819 | 100% | 2023-12-15 | 2023-12-15 | 0d |  |  |  |  | PPs in SDS Market Role | PP | 5.5 | Simon Berry | Systems Integration Testing (SIT) | Complete | COMPLETE |  | T3-TE-0089 | SITAG | T3 | 7/8 - added as a T3 milestone. Awaiting approval at TMAG |  |  |
| 821 | 1.4.1.7.2.6 | **Environments (SIT A)** |  | 25d | 2024-02-05 A | 2024-03-08 A |  | 100% | 2024-01-08 | 2024-02-09 | 25d | 2024-02-05 | 2024-02-09 |  |  | N/A | N/A | 5.0 | N/A | Systems Integration Testing (SIT) |  |  |  |  |  |  |  |  |  |
| 822 | 1.4.1.7.2.6.1 | **SIT Functional Connectivity Proving** |  | 15d | 2024-02-12 A | 2024-03-01 A |  | 100% | 2024-01-08 | 2024-02-02 | 20d |  |  |  |  | N/A | N/A | 5.5 | N/A | Systems Integration Testing (SIT) |  |  |  |  |  |  |  |  | -288.67 |
| 823 | 1.4.1.7.2.6.1.1 | SIT Functional Connectivity Proving Period |  | 15d | 2024-02-12 A | 2024-03-01 A |  | 100% | 2024-02-12 | 2024-03-01 | 20d |  |  | start no earlier than 2024-01-08 |  | SI Test | PP | 5.19 | Simon Berry | Systems Integration Testing (SIT) | Complete | COMPLETE |  |  |  |  |  |  |  |
| 824 | 1.4.1.7.2.6.1.2 | SIT Functional Connectivity Proving Complete | milestone | 0d | 2024-03-01 A | 2024-03-01 A | 823 | 100% | 2024-03-01 | 2024-03-01 | 0d |  |  | start no earlier than 2024-03-01 |  | SI Test | PP | 5.19 | Simon Berry | Systems Integration Testing (SIT) | Complete | COMPLETE |  | T3-TE-0103 | SITAG | T3 |  |  |  |

Notes:
- 802: Red because 8/12 TMAG moved to 20/12 due to reduction of Dec TMAGS. 5/12 Name change to SIT Functional Testing Test scenarios (themes 1-5) approved 20/12 - Approved at TMAG on 20/12
- 803: 5/12 - New milestone to go to 20/12 TMAG for approval. Added because of new delivery approach for SIT functional artifacts 20/12 - Approved at TMAG on 20/12
- 804: 5/12 - New milestone to go to 20/12 TMAG for approval. Added because of new delivery approach for SIT functional artifacts 20/12 - Approved at TMAG on 20/12
- 807: 15/9 - Potentially add in additional lines to track against progress
- 809: 5/12 Name change to SIT Functional Testing Test Cases (themes 1-5) approved 20/12 - Approved at TMAG on 20/12
- 810: 5/12- New milestone added because revised delivery approach for SIT Functional 20/12 - Approved at TMAG on 20/12
- 811: 5/12- New milestone added because revised delivery approach for SIT Functional
- 817: To be proposed as a T3 Milestone at next TMAG
- 820: 19/12 - MHHS PPs who require DCC, DSP, PKI certificates will request them in order to participate in DCC UEPT
- 823: 16/8 - Needs to start 8 weeks before SIT Functional Testing starts
- 824: 21/2/24 - Date change approved at SITAG on 21/2/24. 4/3 - PPs in the process of completing the activity, two thirds complete, the remain under in various stages of completeness

| ID | WBS | Task | Type | Duration | Start | Finish | Predecessors | Complete | Remaining | Baseline start | Baseline finish | Baseline duration | Baseline 1 start | Baseline 1 finish | Total slack | Free slack | Constraint | Baseline cost | Responsible | Involved | Update Version | MHHS Resource Name | MHHS Programme Phase | Sched Status | RAG | Task Status | Artefact ID | Action | Milestone ID | Text29 | Tier |
| --- | --- | --- | --- | --- | --- | --- | --- | --- | --- | --- | --- | --- | --- | --- | --- | --- | --- | --- | --- | --- | --- | --- | --- | --- | --- | --- | --- | --- | --- | --- | --- |
| 825 | 1.4.1.7.2.6.2 | **PP Environments (SIT A)** |  | 25d | 2024-02-05 A | 2024-03-08 A |  | 100% |  | 2024-02-05 | 2024-02-09 | 5d | 2024-02-05 | 2024-02-09 |  |  |  |  | N/A | N/A | 5.0 | N/A | Systems Integration Testing (SIT) |  |  |  |  |  |  |  |  |
| 826 | 1.4.1.7.2.6.2.1 | Deployment of MHHS solution code to SIT A environments |  | 25d | 2024-02-05 A | 2024-03-08 A |  | 100% |  | 2024-02-05 | 2024-02-09 | 5d | 2024-02-05 | 2024-02-09 |  |  | start no earlier than 2024-02-05 |  | PP | SI Test | 5.0 | Simon Berry | Systems Integration Testing (SIT) | Complete | COMPLETE |  |  |  |  |  |  |
| 827 | 1.4.1.7.2.6.3 | **SI Environments (SIT A)** |  | 25d | 2024-02-05 A | 2024-03-08 A |  | 100% |  | 2024-02-05 | 2024-02-09 | 5d | 2024-02-05 | 2024-02-09 |  |  |  |  | N/A | N/A | 5.0 | N/A | Systems Integration Testing (SIT) |  |  |  |  |  |  |  |  |
| 828 | 1.4.1.7.2.6.3.1 | Coordinate deployment of MHHS solution code to SIT Participants' SIT A environments |  | 25d | 2024-02-05 A | 2024-03-08 A | 826SS | 100% |  | 2024-02-05 | 2024-02-09 | 5d | 2024-02-05 | 2024-02-09 |  |  |  |  | SI Test | PP | 5.0 | Simon Berry | Systems Integration Testing (SIT) | Complete | COMPLETE |  |  |  |  |  |  |
| 829 | 1.4.1.7.2.7 | **Test data (SIT A)** |  | 225d | 2023-12-18 A | 2024-10-25 |  | 61% | 87.83d | 2023-12-18 | 2024-10-25 | 225d |  |  | 17d |  |  | -0 | N/A | N/A | 5.4 | N/A | Systems Integration Testing (SIT) |  |  | -269.67 |  |  |  |  |  |
| 830 | 1.4.1.7.2.7.1 | **Cycle 1 Test data (SIT A)** |  | 55d | 2023-12-18 A | 2024-03-01 A |  | 100% |  | 2023-12-18 | 2024-03-01 | 55d |  |  |  |  |  | -0 | N/A | N/A | 5.4 | N/A | Systems Integration Testing (SIT) |  |  | -269.67 |  |  |  |  |  |
| 831 | 1.4.1.7.2.7.1.1 | Prepare, Generate and Allocate Test Data |  | 28d | 2023-12-18 A | 2024-01-24 A | 608, 616 | 100% |  | 2023-12-18 | 2024-01-24 | 28d |  |  |  |  | start no earlier than 2023-12-11 |  | SI Test Data |  | 5.14 | Richard Puddephatt | Systems Integration Testing (SIT) | Complete | COMPLETE |  |  |  |  |  |  |
| 832 | 1.4.1.7.2.7.1.2 | Transmit Data Sets to PPs |  | 4d | 2024-01-26 A | 2024-01-31 A | 831FS+1d | 100% |  | 2024-01-25 | 2024-01-26 | 2d |  |  |  |  |  |  | SI Test Data |  | 5.14 | Richard Puddephatt | Systems Integration Testing (SIT) | Complete | COMPLETE |  |  |  |  |  |  |
| 833 | 1.4.1.7.2.7.1.3 | PP's Iterative load and data integrity check |  | 22d | 2024-02-01 A | 2024-03-01 A | 832 | 100% |  | 2024-01-29 | 2024-02-09 | 10d |  |  |  |  |  |  | PP |  | 5.14 | Richard Puddephatt | Systems Integration Testing (SIT) | Complete | COMPLETE |  |  |  |  |  |  |
| 834 | 1.4.1.7.2.7.1.4 | Cycle 1 - PP's confirmation that test data is ready for SIT Functional | milestone | 0d | 2024-03-01 A | 2024-03-01 A | 833 | 100% |  | 2024-03-01 | 2024-03-01 | 0d |  |  |  |  |  |  | SI Test Data |  | 5.18 | Richard Puddephatt | Systems Integration Testing (SIT) | Complete | COMPLETE |  | MHHS-ART140 MHHS-ART169 | 2/8 - added as a T3 milestone. Awaiting approval at TMAG | T3-TE-0079 | SITAG | T3 |
| 835 | 1.4.1.7.2.7.2 | **Cycle 2 Test data (SIT A)** |  | 57d | 2024-03-28 A | 2024-06-14 A |  | 100% |  | 2024-03-28 | 2024-05-31 | 47d |  |  |  |  |  | -0 | N/A | N/A | 5.4 | N/A | Systems Integration Testing (SIT) |  |  |  |  |  |  |  |  |
| 836 | 1.4.1.7.2.7.2.1 | Prepare, Generate and Allocate Test Data |  | 31d | 2024-03-28 A | 2024-05-09 A | 834FS+18d | 100% |  | 2024-03-28 | 2024-05-09 | 31d |  |  |  |  |  |  | SI Test Data |  | 5.14 | Richard Puddephatt | Systems Integration Testing (SIT) | Complete | COMPLETE |  |  |  |  |  |  |
| 837 | 1.4.1.7.2.7.2.2 | Transmit Data Sets to PPs |  | 3d | 2024-05-10 A | 2024-05-14 A | 836 | 100% |  | 2024-05-10 | 2024-05-14 | 3d |  |  |  |  |  |  | SI Test Data |  | 5.14 | Richard Puddephatt | Systems Integration Testing (SIT) | Complete | COMPLETE |  |  |  |  |  |  |
| 838 | 1.4.1.7.2.7.2.3 | PP's Iterative load and data integrity check |  | 13d | 2024-05-15 A | 2024-05-31 A | 837 | 100% |  | 2024-05-15 | 2024-05-31 | 13d |  |  |  |  |  |  | PP |  | 5.14 | Richard Puddephatt | Systems Integration Testing (SIT) | Complete | COMPLETE |  |  |  |  |  |  |
| 839 | 1.4.1.7.2.7.2.4 | Cycle 2 - PP's confirmation that test data is ready for SIT Functional | milestone | 0d | 2024-06-14 A | 2024-06-14 A | 838FS+10d | 100% |  | 2024-05-31 | 2024-05-31 | 0d |  |  |  |  |  |  | SI Test Data |  | 5.27 | Richard Puddephatt | Systems Integration Testing (SIT) | Complete | COMPLETE |  | MHHS-ART140 MHHS-ART169 | 2/8 - added as a T3 milestone. Awaiting approval at TMAG | T3-TE-0080 | SITAG | T3 |
| 840 | 1.4.1.7.2.7.3 | **Cycle 3 Test data (SIT A)** |  | 41d | 2024-06-24 A | 2024-08-19 |  | 32% | 28d | 2024-06-24 | 2024-08-19 | 41d |  |  | 17d |  |  | -0 | N/A | N/A | 5.4 | N/A | Systems Integration Testing (SIT) |  |  |  |  |  |  |  |  |
| 841 | 1.4.1.7.2.7.3.1 | Prepare, Generate and Allocate Test Data |  | 18d | 2024-06-24 A | 2024-07-17 | 839FS+5d | 72% | 5d | 2024-06-24 | 2024-07-17 | 18d |  |  | 17d | 0d |  |  | SI Test Data |  | 5.14 | Richard Puddephatt | Systems Integration Testing (SIT) | Overdue | RED |  |  |  |  |  |  |
| 842 | 1.4.1.7.2.7.3.2 | Transmit Data Sets to PPs |  | 2d | 2024-07-18 | 2024-07-19 | 841 |  |  | 2024-07-18 | 2024-07-19 | 2d |  |  | 17d | 0d |  |  | SI Test Data |  | 5.14 | Richard Puddephatt | Systems Integration Testing (SIT) | Overdue Start | RED | -20.67 |  |  |  |  |  |
| 843 | 1.4.1.7.2.7.3.3 | PP's Iterative load and data integrity check |  | 21d | 2024-07-22 | 2024-08-19 | 842 |  |  | 2024-07-22 | 2024-08-19 | 21d |  |  | 17d | 0d |  |  | PP |  | 5.14 | Richard Puddephatt | Systems Integration Testing (SIT) | Overdue Start | GREEN | -16.67 |  |  |  |  |  |
| 844 | 1.4.1.7.2.7.3.4 | Cycle 3 - PP's confirmation that test data is ready for SIT Functional | milestone | 0d | 2024-08-19 | 2024-08-19 | 843 |  |  | 2024-08-19 | 2024-08-19 | 0d |  |  | 17d | 0d |  |  | SI Test Data |  | 5.14 | Richard Puddephatt | Systems Integration Testing (SIT) | Green | AMBER | 11.71 | MHHS-ART140 MHHS-ART169 | 2/8 - added as a T3 milestone. Awaiting approval at TMAG | T3-TE-0081 | SITAG | T3 |
| 845 | 1.4.1.7.2.7.4 | **Regression Test data (SIT A)** |  | 45d | 2024-08-26 | 2024-10-25 |  |  |  | 2024-08-26 | 2024-10-25 | 45d |  |  | 17d |  |  | -0 | N/A | N/A | 5.4 | N/A | Systems Integration Testing (SIT) |  |  |  |  |  |  |  |  |
| 846 | 1.4.1.7.2.7.4.1 | Prepare, Generate and Allocate Test Data |  | 23d | 2024-08-26 | 2024-09-25 | 844FS+4d |  |  | 2024-08-26 | 2024-09-25 | 23d |  |  | 17d | 0d |  |  | SI Test Data |  | 5.14 | Richard Puddephatt | Systems Integration Testing (SIT) | Green | GREEN | 18.33 |  |  |  |  |  |
| 847 | 1.4.1.7.2.7.4.2 | Transmit Data Sets to PPs |  | 2d | 2024-09-26 | 2024-09-27 | 846 |  |  | 2024-09-23 | 2024-10-04 | 10d |  |  | 17d | 0d |  |  | SI Test Data |  | 5.14 | Richard Puddephatt | Systems Integration Testing (SIT) | Green | GREEN | 49.33 |  |  |  |  |  |
| 848 | 1.4.1.7.2.7.4.3 | PP's Iterative load and data integrity check |  | 20d | 2024-09-30 | 2024-10-25 | 847 |  |  | 2024-10-21 | 2024-10-25 | 5d |  |  | 17d | 0d |  |  | PP |  | 5.14 | Richard Puddephatt | Systems Integration Testing (SIT) | Green | GREEN | 53.33 |  |  |  |  |  |
| 849 | 1.4.1.7.2.7.4.4 | Regression - PP's confirmation that test data is ready for SIT Functional | milestone | 0d | 2024-10-25 | 2024-10-25 | 848 |  |  | 2024-10-25 | 2024-10-25 | 0d |  |  | 17d | 5d |  |  | SI Test Data |  | 5.14 | Richard Puddephatt | Systems Integration Testing (SIT) | Green | AMBER | 78.71 | MHHS-ART140 MHHS-ART169 | 2/8 - added as a T3 milestone. Awaiting approval at TMAG | T3-TE-0082 | SITAG | T3 |

Notes:
- 834: 21/2/24 - Date change approved at SITAG on 21/2/24. 5/3 - Red because 20% of PPs differed the data load to 6/3. These PPs have an action plan to complete this.
- 839: 4/6: Date missed because there are 3 separate data loads for each PP to complete. This is proving time consuming but is expected to complete by 14/6
- 844: 6/8/24: Date at risk due to programme scenario re-planning.
- 849: 6/8/24: Date at risk due to programme scenario re-planning.

| ID | WBS | Task | Type | Duration | Start | Finish | Predecessors | Complete | Baseline start | Baseline finish | Baseline duration | Baseline 1 start | Baseline 1 finish | Constraint | Baseline cost | Responsible | Involved | Update Version | MHHS Resource Name | MHHS Programme Phase | Sched Status | RAG | Milestone ID | Text29 | Tier | Artefact ID | Task Status |
| --- | --- | --- | --- | --- | --- | --- | --- | --- | --- | --- | --- | --- | --- | --- | --- | --- | --- | --- | --- | --- | --- | --- | --- | --- | --- | --- | --- |
| 850 | 1.4.1.7.2.8 | **SIT Functional Test Readiness Report** |  | 44d | 2024-01-01 A | 2024-02-29 A |  | 100% | 2024-01-01 | 2024-02-29 | 44d | 2024-01-01 | 2024-02-23 |  | -0 | N/A | N/A | 5.0 | N/A | Systems Integration Testing (SIT) |  |  |  |  |  |  |  |
| 851 | 1.4.1.7.2.8.1 | **PP SIT Functional Test Readiness Report** |  | 44d | 2024-01-01 A | 2024-02-29 A |  | 100% | 2024-01-01 | 2024-02-29 | 44d | 2024-01-01 | 2024-02-09 |  | -0 | N/A | N/A | 5.0 | N/A | Systems Integration Testing (SIT) |  |  |  |  |  |  |  |
| 852 | 1.4.1.7.2.8.1.1 | Develop draft Test Readiness Report and submit to Programme for assurance |  | 21d | 2024-01-01 A | 2024-01-29 A |  | 100% | 2024-01-01 | 2024-01-29 | 20d | 2024-01-01 | 2024-01-29 | start no earlier than 2024-01-01 |  | PP | SI Test | 5.0 | Lee Cox | Systems Integration Testing (SIT) | Complete | COMPLETE |  |  |  |  |  |
| 853 | 1.4.1.7.2.8.1.2 | Placing Reliance Stage 2 Review |  | 34d | 2024-01-15 A | 2024-02-29 A | 852SS+10d | 100% | 2024-01-15 | 2024-02-29 | 34d |  |  |  |  | SI Test | PP | 5.12 | Lee Cox | Systems Integration Testing (SIT) | Complete | COMPLETE |  |  |  |  |  |
| 854 | 1.4.1.7.2.8.1.3 | Finalise Test Readiness Report and submit to Programme for assurance |  | 9d | 2024-01-30 A | 2024-02-09 A | 852 | 100% | 2024-01-29 | 2024-02-09 | 10d | 2024-01-29 | 2024-02-09 |  |  | PP | SI Test | 5.0 | Lee Cox | Systems Integration Testing (SIT) | Complete | COMPLETE |  |  |  |  |  |
| 855 | 1.4.1.7.2.8.2 | **SI SIT Functional Test Readiness Report** |  | 40d | 2024-01-01 A | 2024-02-23 A |  | 100% | 2024-01-01 | 2024-02-23 | 40d | 2024-01-01 | 2024-02-23 |  |  | N/A | N/A | 5.0 | N/A | Systems Integration Testing (SIT) |  |  |  |  |  |  |  |
| 856 | 1.4.1.7.2.8.2.1 | Assure Test Participants' Test Readiness Reports |  | 35d | 2024-01-01 A | 2024-02-16 A | 852SS, 854FF+5d | 100% | 2024-01-01 | 2024-02-16 | 35d | 2024-01-01 | 2024-02-16 |  |  | SI Test | PP,IPA | 5.0 | Lee Cox | Systems Integration Testing (SIT) | Complete | COMPLETE |  |  |  |  |  |
| 857 | 1.4.1.7.2.8.2.2 | Develop Overarching SIT Functional Test Readiness Report |  | 20d | 2024-01-22 A | 2024-02-16 A | 856FF | 100% | 2024-01-22 | 2024-02-16 | 20d | 2024-01-22 | 2024-02-16 |  |  | SI Test |  | 5.0 | Lee Cox | Systems Integration Testing (SIT) | Complete | COMPLETE |  |  |  |  |  |
| 858 | 1.4.1.7.2.8.2.3 | Artefact review (via TMAG) and updates |  | 5d | 2024-02-19 A | 2024-02-23 A | 857 | 100% | 2024-02-19 | 2024-02-23 | 5d | 2024-02-19 | 2024-02-23 |  |  | SI Test | PP,IPA | 5.0 | Lee Cox | Systems Integration Testing (SIT) | Complete | COMPLETE |  |  |  |  |  |
| 859 | 1.4.1.7.2.9 | SIT Functional Testing Preparation Complete | milestone | 0d | 2024-03-01 A | 2024-03-01 A | 858FF+5d, 794, 313, 853, 802, 809, 834 | 100% | 2024-03-01 | 2024-03-01 | 0d | 2024-03-01 | 2024-03-01 |  |  | SI Test | PP,IPA | 5.0 | Lee Cox | Systems Integration Testing (SIT) | Complete | COMPLETE | T2-TE-0550 | SITAG | T2 |  |  |
| 860 | 1.4.1.7.3 | **SIT Migration Testing Preparation** |  | 435d | 2022-10-31 A | 2024-06-28 A |  | 100% | 2022-10-31 | 2024-06-07 | 420d | 2022-11-16 | 2024-06-03 |  | -0 | N/A | N/A | 5.21 | N/A | Systems Integration Testing (SIT) |  |  |  |  |  |  |  |
| 861 | 1.4.1.7.3.1 | **Test Approach & Plan** |  | 75d | 2023-09-07 A | 2023-12-20 A |  | 100% | 2023-09-07 | 2023-12-20 | 75d | 2023-09-07 | 2023-12-20 |  | -0 | N/A | N/A | 5.0 | N/A | Systems Integration Testing (SIT) |  |  |  |  |  |  |  |
| 862 | 1.4.1.7.3.1.1 | Develop document with SITWG |  | 32d | 2023-09-07 A | 2023-10-20 A | 1905 | 100% | 2023-09-07 | 2023-10-11 | 25d | 2023-09-07 | 2023-10-11 | finish no earlier than 2023-10-11 |  | SI Test |  | 5.0 | Lee Cox | Systems Integration Testing (SIT) | Complete | COMPLETE |  |  |  |  |  |
| 863 | 1.4.1.7.3.1.2 | Draft document review with Code Bodies |  | 8d | 2023-10-23 A | 2023-11-01 A | 862 | 100% | 2023-10-12 | 2023-10-25 | 10d | 2023-10-12 | 2023-10-25 |  |  | SI Test | Code Bodies | 5.0 | Lee Cox | Systems Integration Testing (SIT) | Complete | COMPLETE |  |  |  |  |  |
| 864 | 1.4.1.7.3.1.3 | Industry Consultation |  | 10d | 2023-11-02 A | 2023-11-15 A | 863 | 100% | 2023-11-02 | 2023-11-15 | 10d |  |  |  |  | PP |  | 5.1 | Lee Cox | Systems Integration Testing (SIT) | Complete | COMPLETE |  |  |  |  |  |
| 865 | 1.4.1.7.3.1.4 | Artefact review (via TMAG) and updates |  | 25d | 2023-11-16 A | 2023-12-20 A | 864 | 100% | 2023-11-09 | 2023-12-20 | 30d | 2023-10-26 | 2023-12-20 |  |  | SI Test | PP,IPA,Code Bodies | 5.0 | Lee Cox | Systems Integration Testing (SIT) | Complete | COMPLETE |  |  |  |  |  |
| 866 | 1.4.1.7.3.1.5 | SIT Migration Testing Test Approach & Plan approved | milestone | 0d | 2023-12-20 A | 2023-12-20 A | 865 | 100% | 2023-12-20 | 2023-12-20 | 1d | 2023-12-20 | 2023-12-20 | finish no earlier than 2023-12-20 |  | SI Test | PP | 5.14 | Lee Cox | Systems Integration Testing (SIT) | Complete | COMPLETE | T3-TE-0018 | SITAG | T3 | MHHS-ART073 |  |
| 867 | 1.4.1.7.3.2 | **Test Data Approach & Plan** |  | 35d | 2023-11-02 A | 2023-12-20 A |  | 100% | 2023-11-02 | 2023-12-20 | 35d | 2023-10-26 | 2023-12-20 |  | -0 | N/A | N/A | 5.0 | N/A | Systems Integration Testing (SIT) |  |  |  |  |  |  |  |
| 868 | 1.4.1.7.3.2.1 | Industry Consultation |  | 10d | 2023-11-02 A | 2023-11-15 A | 864SS | 100% | 2023-11-02 | 2023-11-15 | 10d |  |  |  |  | PP |  | 5.1 | PP | Systems Integration Testing (SIT) | Complete | COMPLETE |  |  |  |  |  |
| 869 | 1.4.1.7.3.2.2 | Artefact review (via TMAG) and updates |  | 25d | 2023-11-16 A | 2023-12-20 A | 868 | 100% | 2023-11-09 | 2023-12-20 | 30d | 2023-10-26 | 2023-12-20 |  |  | SI Test Data |  | 5.0 | Richard Puddephatt | Systems Integration Testing (SIT) | Complete | COMPLETE |  |  |  |  |  |
| 870 | 1.4.1.7.3.2.3 | SIT Migration Test Data Test Approach & Plan approved | milestone | 0d | 2023-12-20 A | 2023-12-20 A | 869 | 100% | 2023-12-20 | 2023-12-20 | 0d | 2023-12-20 | 2023-12-20 |  |  | SI Test Data | PP,IPA | 5.14 | Richard Puddephatt | Systems Integration Testing (SIT) | Complete | COMPLETE |  |  |  |  |  |
| 871 | 1.4.1.7.3.3 | **Test scenarios & Test Cases** |  | 85d | 2023-12-21 A | 2024-04-17 A |  | 100% | 2023-12-21 | 2024-03-20 | 65d | 2023-07-24 | 2024-01-17 |  | -0 | N/A | N/A | 5.16 | N/A | Systems Integration Testing (SIT) |  |  |  |  |  |  |  |
| 872 | 1.4.1.7.3.3.1 | **Theme 1** |  | 65d | 2023-12-21 A | 2024-03-20 A |  | 100% | 2023-12-21 | 2024-03-20 | 65d |  |  |  | -0 | N/A | N/A | 5.16 | N/A | Systems Integration Testing (SIT) |  |  |  |  |  |  | -448.67 |
| 873 | 1.4.1.7.3.3.1.1 | Develop Test Scenarios & Test Cases |  | 25d | 2023-12-21 A | 2024-01-24 A | 866 | 100% | 2023-12-21 | 2024-01-24 | 25d |  |  |  |  | SI Test | SI Test, PP | 5.16 | Lee Cox |  | Complete | COMPLETE |  |  |  |  |  |
| 874 | 1.4.1.7.3.3.1.2 | Industry Review Workshop |  | 1d | 2024-01-25 A | 2024-01-25 A | 873 | 100% | 2024-01-25 | 2024-01-25 | 1d |  |  |  |  | SI Test, PP | SI Test, PP | 5.16 | Lee Cox |  | Complete | COMPLETE |  |  |  |  |  |
| 875 | 1.4.1.7.3.3.1.3 | Industry Consultation Review |  | 6d | 2024-02-05 A | 2024-02-12 A | 874FS+6d | 100% | 2024-02-05 | 2024-02-12 | 6d |  |  |  |  | SI Test, PP | SI Test, PP | 5.16 | Lee Cox |  | Complete | COMPLETE |  |  |  |  |  |
| 876 | 1.4.1.7.3.3.1.4 | Review with SIT Working Group |  | 5d | 2024-02-29 A | 2024-03-06 A | 875FS+12d | 100% | 2024-02-29 | 2024-03-06 | 5d |  |  |  |  | SI Test, PP | SI Test, PP | 5.19 | Lee Cox |  | Complete | COMPLETE |  |  |  |  |  |
| 877 | 1.4.1.7.3.3.1.5 | SIT Migration Test scenarios & Test Cases Approved - Theme 1 | milestone | 0d | 2024-03-20 A | 2024-03-20 A | 876FS+10d | 100% | 2024-03-20 | 2024-03-20 | 0d |  |  |  |  | SI Test | SI Test, PP | 5.21 | Lee Cox | Systems Integration Testing (SIT) | Complete | COMPLETE | T3-TE-0110 | SITAG |  |  |  |

Notes:
- 859: 28/11 - At risk because of challenges with CCP and PP readiness & dependent on successful Secondary Routing Testing. Approved at 1/3 eSITAG
- 866: 24/10 - Amber because consultation window delayed by 5 days. 20/12 - Approved to complete at TMAG on 20/12
- 870: 20/12 - approved at TMAG on 20/12
- 877: 23/1 - New milestones added because of new themed delivery approach. To go to Feb SITAG for approval

| ID | WBS | Task | Type | Duration | Start | Finish | Predecessors | Complete | Baseline start | Baseline finish | Baseline duration | Baseline 1 start | Baseline 1 finish | Constraint | Baseline cost | Responsible | Involved | Task Status | Update Version | MHHS Resource Name | MHHS Programme Phase | Sched Status | RAG | Milestone ID | Text29 | Tier |
| --- | --- | --- | --- | --- | --- | --- | --- | --- | --- | --- | --- | --- | --- | --- | --- | --- | --- | --- | --- | --- | --- | --- | --- | --- | --- | --- |
| 878 | 1.4.1.7.3.3.2 | **Theme 2** |  | 85d | 2023-12-21 A | 2024-04-17 A |  | 100% | 2023-12-21 | 2024-04-17 | 85d |  |  |  | -0 | N/A | N/A | -448.67 | 5.16 | N/A | Systems Integration Testing (SIT) |  |  |  |  |  |
| 879 | 1.4.1.7.3.3.2.1 | Develop Test Scenarios & Test Cases |  | 40d | 2023-12-21 A | 2024-02-14 A | 866 | 100% | 2023-12-21 | 2024-02-14 | 40d |  |  |  |  | SI Test | SI Test, PP |  | 5.16 | Lee Cox |  | Complete | COMPLETE |  |  |  |
| 880 | 1.4.1.7.3.3.2.2 | Industry Review Workshop |  | 1d | 2024-02-15 A | 2024-02-15 A | 879 | 100% | 2024-02-15 | 2024-02-15 | 1d |  |  |  |  | SI Test, PP | SI Test, PP |  | 5.16 | Lee Cox |  | Complete | COMPLETE |  |  |  |
| 881 | 1.4.1.7.3.3.2.3 | Industry Consultation Review |  | 6d | 2024-02-26 A | 2024-03-04 A | 880FS+6d | 100% | 2024-02-26 | 2024-03-04 | 6d |  |  |  |  | SI Test, PP | SI Test, PP |  | 5.19 | Lee Cox |  | Complete | COMPLETE |  |  |  |
| 882 | 1.4.1.7.3.3.2.4 | Review with SIT Working Group |  | 5d | 2024-03-28 A | 2024-04-03 A | 881FS+17d | 100% | 2024-03-28 | 2024-04-03 | 5d |  |  |  |  | SI Test, PP | SI Test, PP |  | 5.16 | Lee Cox |  | Complete | COMPLETE |  |  |  |
| 883 | 1.4.1.7.3.3.2.5 | SIT Migration Test scenarios & Test Cases Approved - Theme 2 | milestone | 0d | 2024-04-17 A | 2024-04-17 A | 882FS+10d | 100% | 2024-04-17 | 2024-04-17 | 0d |  |  |  |  | SI Test | SI Test, PP |  | 5.22 | Lee Cox | Systems Integration Testing (SIT) | Complete | COMPLETE | T3-TE-0111 | SITAG |  |
| 884 | 1.4.1.7.3.3.3 | **Theme 3** |  | 85d | 2023-12-21 A | 2024-04-17 A |  | 100% | 2023-12-21 | 2024-04-17 | 85d |  |  |  | -0 | N/A | N/A | -448.67 | 5.16 | N/A | Systems Integration Testing (SIT) |  |  |  |  |  |
| 885 | 1.4.1.7.3.3.3.1 | Develop Test Scenarios & Test Cases |  | 55d | 2023-12-21 A | 2024-03-06 A | 866 | 100% | 2023-12-21 | 2024-03-06 | 55d |  |  |  |  | SI Test | SI Test, PP |  | 5.19 | Lee Cox |  | Complete | COMPLETE |  |  |  |
| 886 | 1.4.1.7.3.3.3.2 | Industry Review Workshop |  | 1d | 2024-03-07 A | 2024-03-07 A | 885 | 100% | 2024-03-07 | 2024-03-07 | 1d |  |  |  |  | SI Test, PP | SI Test, PP |  | 5.16 | Lee Cox |  | Complete | COMPLETE |  |  |  |
| 887 | 1.4.1.7.3.3.3.3 | Industry Consultation Review |  | 6d | 2024-03-13 A | 2024-03-20 A | 886FS+3d | 100% | 2024-03-13 | 2024-03-20 | 6d |  |  |  |  | SI Test, PP | SI Test, PP |  | 5.16 | Lee Cox |  | Complete | COMPLETE |  |  |  |
| 888 | 1.4.1.7.3.3.3.4 | Review with SIT Working Group |  | 5d | 2024-03-28 A | 2024-04-03 A | 887FS+5d | 100% | 2024-03-28 | 2024-04-03 | 5d |  |  |  |  | SI Test, PP | SI Test, PP |  | 5.16 | Lee Cox |  | Complete | COMPLETE |  |  |  |
| 889 | 1.4.1.7.3.3.3.5 | SIT Migration Test scenarios & Test Cases Approved - Theme 3 | milestone | 0d | 2024-04-17 A | 2024-04-17 A | 888FS+10d | 100% | 2024-04-17 | 2024-04-17 | 0d |  |  |  |  | SI Test | SI Test, PP |  | 5.22 | Lee Cox | Systems Integration Testing (SIT) | Complete | COMPLETE | T3-TE-0112 | SITAG |  |
| 890 | 1.4.1.7.3.4 | **Environments (SIT B)** |  | 435d | 2022-10-31 A | 2024-06-28 A |  | 100% | 2022-10-31 | 2024-06-07 | 420d | 2022-11-16 | 2024-05-13 |  | -0 | N/A | N/A |  | 5.0 | N/A | Systems Integration Testing (SIT) |  |  |  |  |  |
| 891 | 1.4.1.7.3.4.1 | **PP Environments (SIT B)** |  | 41d | 2024-05-03 A | 2024-06-28 A |  | 100% | 2024-05-03 | 2024-06-07 | 26d | 2022-11-16 | 2024-05-13 |  | -0 | N/A | N/A |  | 5.0 | N/A | Systems Integration Testing (SIT) |  |  |  |  |  |
| 892 | 1.4.1.7.3.4.1.1 | PP Environments available | milestone | 0d | 2024-05-03 A | 2024-05-03 A | 466 | 100% | 2024-05-03 | 2024-05-03 | 0d | 2022-11-16 | 2024-04-01 | start no earlier than 2024-05-03 |  | PP | SI Test |  | 5.21 | Simon Berry | Systems Integration Testing (SIT) | Complete | COMPLETE |  |  |  |
| 893 | 1.4.1.7.3.4.1.2 | PP Onboarding / Smoke test |  | 35d | 2024-05-13 A | 2024-06-28 A | 892FS+6d | 100% | 2024-05-13 | 2024-06-07 | 20d | 2022-11-16 | 2024-04-01 |  |  | PP | SI Test |  | 5.21 | Simon Berry | Systems Integration Testing (SIT) | Complete | COMPLETE |  |  |  |
| 894 | 1.4.1.7.3.4.1.3 | DTN Connectivity Proving Complete |  | 5d | 2024-06-10 A | 2024-06-14 A | 892FS+26d | 100% | 2024-05-31 | 2024-05-31 | 0d | 2024-04-15 | 2024-04-26 |  |  | PP | SI Test |  | 5.21 | Simon Berry | Systems Integration Testing (SIT) | Complete | COMPLETE |  |  |  |
| 895 | 1.4.1.7.3.4.1.4 | PP Code Deployment | milestone | 0d | 2024-06-14 A | 2024-06-14 A | 894 | 100% | 2024-06-03 | 2024-06-03 | 0d | 2024-04-29 | 2024-05-13 |  |  | PP | SI Test |  | 5.21 | Simon Berry | Systems Integration Testing (SIT) | Complete | COMPLETE |  |  |  |
| 896 | 1.4.1.7.3.4.2 | **SI Environments (SIT B)** |  | 425d | 2022-10-31 A | 2024-06-14 A |  | 100% | 2022-10-31 | 2024-06-07 | 420d | 2022-11-16 | 2024-05-10 |  | -0 | N/A | N/A |  | 5.0 | N/A | Systems Integration Testing (SIT) |  |  |  |  |  |
| 897 | 1.4.1.7.3.4.2.1 | Coordinate SIT Participants' SIT B environment preparation |  | 420d | 2022-10-31 A | 2024-06-07 A |  | 100% | 2022-10-31 | 2024-06-07 | 420d | 2022-11-16 | 2024-04-01 |  |  | SI Test | PP |  | 5.21 | Simon Berry | Systems Integration Testing (SIT) | Complete | COMPLETE |  |  |  |
| 898 | 1.4.1.7.3.4.2.2 | Assure PPs' self-declaration of environment preparation complete (incl. security certificates and security compliance) | milestone | 0d | 2024-06-07 A | 2024-06-07 A | 897 | 100% | 2024-06-07 | 2024-06-07 | 0d | 2022-11-16 | 2024-03-29 |  |  | SI Test | PP |  | 5.21 | Simon Berry | Systems Integration Testing (SIT) | Complete | COMPLETE |  |  |  |
| 899 | 1.4.1.7.3.4.2.3 | SIT Participants' SIT B environments ready to start connectivity proving (incl. certificates and security compliance) | milestone | 0d | 2024-06-05 A | 2024-06-05 A | 892FS+24d | 100% | 2024-05-03 | 2024-05-03 | 0d | 2024-04-01 | 2024-04-01 |  |  | SI Test | PP,IPA |  | 5.26 | Simon Berry | Systems Integration Testing (SIT) | Complete | COMPLETE | T3-TE-0033 | SITAG | T3 |
| 900 | 1.4.1.7.3.4.2.4 | Coordinate SIT Participants' SIT B environment connectivity proving |  | 2d | 2024-06-06 A | 2024-06-07 A | 899 | 100% | 2024-05-14 | 2024-06-07 | 19d | 2024-04-01 | 2024-04-26 |  |  | SI Test | PP |  | 5.21 | Simon Berry | Systems Integration Testing (SIT) | Complete | COMPLETE |  |  |  |
| 901 | 1.4.1.7.3.4.2.5 | Coordinate deployment of MHHS solution code to SIT Participants' SIT B environments | milestone | 0d | 2024-06-14 A | 2024-06-14 A | 895 | 100% | 2024-06-04 | 2024-06-07 | 4d | 2024-04-15 | 2024-04-26 |  |  | SI Test | PP |  | 5.21 | Simon Berry | Systems Integration Testing (SIT) | Complete | COMPLETE |  |  |  |

Notes:
- 883: 23/1 - New milestones added because of new themed delivery approach
- 889: 23/1 - New milestones added because of new themed delivery approach
- 899: 3/6: SI coordinated smoke test will run from 5th - 7th June

| ID | WBS | Task | Type | Duration | Start | Finish | Predecessors | Complete | Remaining | Baseline start | Baseline finish | Baseline duration | Baseline 1 start | Baseline 1 finish | Total slack | Free slack | Constraint | Baseline cost | Responsible | Involved | Update Version | MHHS Resource Name | MHHS Programme Phase | Sched Status | RAG | Milestone ID | Text29 | Tier | Artefact ID | Guidance | Task Status |
| --- | --- | --- | --- | --- | --- | --- | --- | --- | --- | --- | --- | --- | --- | --- | --- | --- | --- | --- | --- | --- | --- | --- | --- | --- | --- | --- | --- | --- | --- | --- | --- |
| 902 | 1.4.1.7.3.5 | **SIT Migration Test Readiness Report** |  | 44d | 2024-04-02 A | 2024-05-31 A |  | 100% |  | 2024-04-02 | 2024-05-31 | 44d | 2024-04-02 | 2024-05-27 |  |  |  | -0 | N/A | N/A | 5.0 | N/A | Systems Integration Testing (SIT) |  |  |  |  |  |  |  |  |
| 903 | 1.4.1.7.3.5.1 | **PP SIT Migration Test Readiness Report** |  | 44d | 2024-04-02 A | 2024-05-31 A |  | 100% |  | 2024-04-02 | 2024-05-31 | 44d | 2024-04-02 | 2024-05-13 |  |  |  | -0 | N/A | N/A | 5.0 | N/A | Systems Integration Testing (SIT) |  |  |  |  |  |  |  |  |
| 904 | 1.4.1.7.3.5.1.1 | Develop draft Test Readiness Report and submit to Programme for assurance |  | 20d | 2024-04-02 A | 2024-04-29 A |  | 100% |  | 2024-04-02 | 2024-04-30 | 20d | 2024-04-02 | 2024-04-30 |  |  | start no earlier than 2024-04-02 |  | PP | SI Test | 5.0 | Lee Cox | Systems Integration Testing (SIT) | Complete | COMPLETE |  |  |  |  |  |  |
| 905 | 1.4.1.7.3.5.1.2 | Placing Reliance Stage 2 Review |  | 35d | 2024-04-15 A | 2024-05-31 A | 904SS+9d | 100% |  | 2024-04-15 | 2024-05-31 | 35d |  |  |  |  |  |  | SI Test | PP | 5.12 | Lee Cox | Systems Integration Testing (SIT) | Complete | COMPLETE |  |  |  |  |  |  |
| 906 | 1.4.1.7.3.5.1.3 | Finalise Test Readiness Report and submit to Programme for assurance |  | 10d | 2024-04-30 A | 2024-05-13 A | 904 | 100% |  | 2024-04-30 | 2024-05-13 | 10d | 2024-04-30 | 2024-05-13 |  |  |  |  | PP | SI Test | 5.0 | Lee Cox | Systems Integration Testing (SIT) | Complete | COMPLETE |  |  |  |  |  |  |
| 907 | 1.4.1.7.3.5.2 | **SI SIT Migration Test Readiness Report** |  | 40d | 2024-04-02 A | 2024-05-27 A |  | 100% |  | 2024-04-02 | 2024-05-27 | 40d | 2024-04-02 | 2024-05-27 |  |  |  |  | N/A | N/A | 5.0 | N/A | Systems Integration Testing (SIT) |  |  |  |  |  |  |  |  |
| 908 | 1.4.1.7.3.5.2.1 | Assure Test Participants' Test Readiness Reports |  | 35d | 2024-04-02 A | 2024-05-20 A | 904SS, 906FF+5d | 100% |  | 2024-04-02 | 2024-05-20 | 35d | 2024-04-02 | 2024-05-20 |  |  |  |  | SI Test | PP,IPA | 5.0 | Lee Cox | Systems Integration Testing (SIT) | Complete | COMPLETE |  |  |  |  |  |  |
| 909 | 1.4.1.7.3.5.2.2 | Develop Overarching SIT Migration Test Readiness Report |  | 20d | 2024-04-23 A | 2024-05-20 A | 908FF | 100% |  | 2024-04-23 | 2024-05-20 | 20d | 2024-04-23 | 2024-05-20 |  |  |  |  | SI Test |  | 5.0 | Lee Cox | Systems Integration Testing (SIT) | Complete | COMPLETE |  |  |  |  |  |  |
| 910 | 1.4.1.7.3.5.2.3 | Artefact review (via SITAG) and updates |  | 5d | 2024-05-21 A | 2024-05-27 A | 909 | 100% |  | 2024-05-21 | 2024-05-27 | 5d | 2024-05-21 | 2024-05-27 |  |  |  |  | SI Test | PP,IPA | 5.0 | Lee Cox | Systems Integration Testing (SIT) | Complete | COMPLETE |  |  |  |  |  |  |
| 911 | 1.4.1.7.3.6 | SIT Migration Testing Preparation Complete | milestone | 0d | 2024-06-03 A | 2024-06-03 A | 910FF+5d, 866, 330, 905, 877, 883, 889 | 100% |  | 2024-06-03 | 2024-06-03 | 0d | 2024-06-03 | 2024-06-03 |  |  |  |  | SI Test | PP,IPA | 5.0 | Lee Cox | Systems Integration Testing (SIT) | Complete | COMPLETE | T2-TE-0650 | SITAG | T2 |  |  |  |
| 912 | 1.4.1.7.4 | **SIT Non-Functional Preparation** |  | 193d | 2023-11-30 A | 2024-08-27 |  | 89% | 21.13d | 2023-11-30 | 2024-08-27 | 193d | 2023-07-03 | 2024-08-26 | 719d |  |  | -0 | N/A | N/A | 5.0 | N/A | Systems Integration Testing (SIT) |  |  |  |  |  |  |  |  |
| 913 | 1.4.1.7.4.1 | **Test Approach & Plan** |  | 120d | 2023-11-30 A | 2024-05-15 A |  | 100% |  | 2023-11-30 | 2024-05-15 | 120d | 2023-11-30 | 2024-03-20 |  |  |  | -0 | N/A | N/A | 5.0 | N/A | Systems Integration Testing (SIT) |  |  |  |  |  |  |  |  |
| 914 | 1.4.1.7.4.1.1 | Develop document with SITWG |  | 67d | 2023-11-30 A | 2024-03-01 A |  | 100% |  | 2023-11-30 | 2024-03-01 | 67d | 2023-11-30 | 2024-01-10 |  |  | must start on 2023-11-30 |  | SI Test |  | 5.0 | Lee Cox | Systems Integration Testing (SIT) | Complete | COMPLETE |  |  |  |  |  |  |
| 915 | 1.4.1.7.4.1.2 | Draft document review with Code Bodies |  | 10d | 2024-03-04 A | 2024-03-15 A | 914 | 100% |  | 2024-03-04 | 2024-03-15 | 10d | 2024-01-11 | 2024-01-24 |  |  |  |  | SI Test | Code Bodies | 5.0 | Lee Cox | Systems Integration Testing (SIT) | Complete | COMPLETE |  |  |  |  |  |  |
| 916 | 1.4.1.7.4.1.3 | Industry Consultation |  | 10d | 2024-03-18 A | 2024-03-29 A | 915 | 100% |  | 2024-03-18 | 2024-03-29 | 10d |  |  |  |  |  |  | PP |  | 5.1 | Lee Cox | Systems Integration Testing (SIT) | Complete | COMPLETE |  |  |  |  |  |  |
| 917 | 1.4.1.7.4.1.4 | Industry Assurance Review |  | 5d | 2024-04-11 A | 2024-04-17 A | 916FS+8d | 100% |  | 2024-04-11 | 2024-04-17 | 5d |  |  |  |  |  |  |  |  | 5.16 | Lee Cox |  | Complete | COMPLETE |  |  |  |  |  |  |
| 918 | 1.4.1.7.4.1.5 | SIT Non-Functional Testing Test Approach & Plan approved | milestone | 0d | 2024-05-15 A | 2024-05-15 A | 917FS+20d | 100% |  | 2024-05-15 | 2024-05-15 | 0d | 2024-03-20 | 2024-03-20 |  |  |  |  | SI Test | PP | 5.30 | Roger Robar | Systems Integration Testing (SIT) | Complete | COMPLETE | T3-TE-0026 | SITAG | T3 | MHHS-ART073 | 30/7/24: Approved at esitag on 26/7/24 |  |
| 919 | 1.4.1.7.4.2 | **Test Data Approach & Plan** |  | 41d | 2024-03-20 A | 2024-05-15 A |  | 100% |  | 2024-03-20 | 2024-05-15 | 41d | 2024-01-25 | 2024-03-20 |  |  |  | -0 | N/A | N/A | 5.0 | N/A | Systems Integration Testing (SIT) |  |  |  |  |  |  |  |  |
| 920 | 1.4.1.7.4.2.1 | Industry Consultation |  | 14d | 2024-03-20 A | 2024-04-08 A | 916SS+2d | 100% |  | 2024-03-20 | 2024-04-08 | 14d |  |  |  |  |  |  | PP |  | 5.1 | Richard Puddephatt | Systems Integration Testing (SIT) | Complete | COMPLETE |  |  |  |  |  |  |
| 921 | 1.4.1.7.4.2.2 | Artefact review (via SITAG) and updates |  | 27d | 2024-04-09 A | 2024-05-15 A | 920 | 100% |  | 2024-04-09 | 2024-05-15 | 27d | 2024-01-25 | 2024-03-13 |  |  |  |  | SI Test |  | 5.0 | Richard Puddephatt | Systems Integration Testing (SIT) | Complete | COMPLETE |  |  |  |  |  |  |
| 922 | 1.4.1.7.4.2.3 | SIT Non-Functional Testing Test Data Approach & Plan approved | milestone | 0d | 2024-05-15 A | 2024-05-15 A | 918FF, 921 | 100% |  | 2024-05-15 | 2024-05-15 | 0d | 2024-03-20 | 2024-03-20 |  |  |  |  | SI Test | PP,IPA | 5.24 | Richard Puddephatt | Systems Integration Testing (SIT) | Complete | COMPLETE | T3-TE-0113 | SITAG |  |  |  |  |
| 923 | 1.4.1.7.4.3 | **Test scenarios & Test Cases** |  | 123d | 2024-03-04 A | 2024-08-21 |  | 97% | 3.48d | 2024-03-04 | 2024-08-21 | 123d | 2023-07-24 | 2024-01-17 | -9d | 0d |  | -0 | N/A | N/A | 5.21 | N/A | Systems Integration Testing (SIT) |  |  |  |  |  |  |  |  |
| 924 | 1.4.1.7.4.3.1 | **Theme 1** |  | 78d | 2024-03-04 A | 2024-06-19 A |  | 100% |  | 2024-03-04 | 2024-06-19 | 78d |  |  |  |  |  | -0 | N/A | N/A | 5.21 | N/A | Systems Integration Testing (SIT) |  |  |  |  |  |  |  | -448.67 |
| 925 | 1.4.1.7.4.3.1.1 | Develop Test Scenarios & Test Cases |  | 33d | 2024-03-04 A | 2024-04-17 A | 914 | 100% |  | 2024-03-04 | 2024-04-17 | 33d |  |  |  |  |  |  | SI Test | SI Test, PP | 5.21 | Lee Cox |  | Complete | COMPLETE |  |  |  |  |  |  |
| 926 | 1.4.1.7.4.3.1.2 | Industry Review Workshop |  | 1d | 2024-04-18 A | 2024-04-18 A | 925 | 100% |  | 2024-04-18 | 2024-04-18 | 1d |  |  |  |  |  |  | SI Test, PP | SI Test, PP | 5.21 | Lee Cox |  | Complete | COMPLETE |  |  |  |  |  |  |
| 927 | 1.4.1.7.4.3.1.3 | Industry Consultation Review |  | 7d | 2024-05-02 A | 2024-05-10 A | 926FS+9d | 100% |  | 2024-05-02 | 2024-05-10 | 7d |  |  |  |  |  |  | SI Test, PP | SI Test, PP | 5.21 | Lee Cox |  | Complete | COMPLETE |  |  |  |  |  |  |
| 928 | 1.4.1.7.4.3.1.4 | Review with NFT Working Group |  | 5d | 2024-05-31 A | 2024-06-06 A | 927FS+14d | 100% |  | 2024-05-31 | 2024-06-06 | 5d |  |  |  |  |  |  | SI Test, PP | SI Test, PP | 5.21 | Lee Cox |  | Complete | COMPLETE |  |  |  |  |  |  |
| 929 | 1.4.1.7.4.3.1.5 | SIT NFT Scenarios & Test Cases Approved - Theme 1 | milestone | 0d | 2024-06-19 A | 2024-06-19 A | 928FS+9d | 100% |  | 2024-06-19 | 2024-06-19 | 0d |  |  |  |  |  |  | SI Test | SI Test, PP | 5.30 | Roger Robar | Systems Integration Testing (SIT) | Complete | COMPLETE | T3-TE-0114 | SITAG |  |  | 30/7/24: Approved at esitag on 26/7/24 |  |

Notes:
- 911: 28/5: Amber because subject to SITAG agreement on work-off items. 4/6 eSITAG approved milestone completion subject to work-off items
- 918: Deferred from May SITAG approval, pending further confirmation and agreement of DIP-Helix Phase 1 testing.~ Start of SIT Non-Functional Testing at risk. Phase / Notes (2): 1 approach to be concluded and re-issued for SITAG approval. Forecast SITAG TBC
- 922: 13/2 - To go to Feb SITAG as a new milestone. 21/2/24 - Approved at SITAG on 21/2/24 as a new milestone. 3/4 At risk because of tight delivery schedule (added as amber to align with Lee's status)
- 929: Deferred from June SITAG approval, pending further confirmation and agreement of DIP-Helix Phase 1 testing. Start of SIT Non-Functional Testing at risk. Phase 1 approach to be concluded and re-issued for SITAG approval. Forecast SITAG TBC

| ID | WBS | Task | Type | Duration | Start | Finish | Predecessors | Complete | Remaining | Baseline start | Baseline finish | Baseline duration | Baseline 1 start | Baseline 1 finish | Total slack | Free slack | Constraint | Baseline cost | Responsible | Involved | Task Status | Update Version | MHHS Resource Name | MHHS Programme Phase | Sched Status | RAG | Milestone ID | Text29 | Guidance | Action | Tier |
| --- | --- | --- | --- | --- | --- | --- | --- | --- | --- | --- | --- | --- | --- | --- | --- | --- | --- | --- | --- | --- | --- | --- | --- | --- | --- | --- | --- | --- | --- | --- | --- |
| 930 | 1.4.1.7.4.3.2 | **Theme 2** |  | 98d | 2024-03-04 A | 2024-07-17 A |  | 100% |  | 2024-03-04 | 2024-07-17 | 98d |  |  |  |  |  |  | N/A | N/A | -448.67 | 5.21 | N/A | Systems Integration Testing (SIT) |  |  |  |  |  |  |  |
| 931 | 1.4.1.7.4.3.2.1 | Develop Test Scenarios & Test Cases |  | 53d | 2024-03-04 A | 2024-05-15 A | 914 | 100% |  | 2024-03-04 | 2024-05-15 | 53d |  |  |  |  |  |  | SI Test | SI Test, PP |  | 5.21 | Lee Cox |  | Complete | COMPLETE |  |  |  |  |  |
| 932 | 1.4.1.7.4.3.2.2 | Industry Review Workshop |  | 1d | 2024-05-16 A | 2024-05-16 A | 931 | 100% |  | 2024-05-16 | 2024-05-16 | 1d |  |  |  |  |  |  | SI Test, PP | SI Test, PP |  | 5.21 | Lee Cox |  | Complete | COMPLETE |  |  |  |  |  |
| 933 | 1.4.1.7.4.3.2.3 | Industry Consultation Review |  | 7d | 2024-05-20 A | 2024-05-28 A | 932FS+1d | 100% |  | 2024-05-20 | 2024-05-28 | 7d |  |  |  |  |  |  | SI Test, PP | SI Test, PP |  | 5.21 | Lee Cox |  | Complete | COMPLETE |  |  |  |  |  |
| 934 | 1.4.1.7.4.3.2.4 | Review with NFT Working Group |  | 5d | 2024-06-28 A | 2024-07-04 A | 933FS+22d | 100% |  | 2024-06-28 | 2024-07-04 | 5d |  |  |  |  |  |  | SI Test, PP | SI Test, PP |  | 5.21 | Lee Cox |  | Complete | COMPLETE |  |  |  |  |  |
| 935 | 1.4.1.7.4.3.2.5 | SIT NFT Scenarios & Test Cases Approved - Theme 2 | milestone | 0d | 2024-07-17 A | 2024-07-17 A | 934FS+9d | 100% |  | 2024-07-17 | 2024-07-17 | 0d |  |  |  |  |  |  | SI Test | SI Test, PP |  | 5.22 | Lee Cox | Systems Integration Testing (SIT) | Complete | COMPLETE | T3-TE-0115 | SITAG |  |  |  |
| 936 | 1.4.1.7.4.3.3 | **Theme 3** |  | 123d | 2024-03-04 A | 2024-08-21 |  | 94% | 7.38d | 2024-03-04 | 2024-08-21 | 123d |  |  | -9d | 0d |  | -0 | N/A | N/A | -448.67 | 5.21 | N/A | Systems Integration Testing (SIT) |  |  |  |  |  |  |  |
| 937 | 1.4.1.7.4.3.3.1 | Develop Test Scenarios & Test Cases |  | 63d | 2024-03-04 A | 2024-05-29 A | 914 | 100% |  | 2024-03-04 | 2024-05-29 | 63d |  |  |  |  |  |  | SI Test | SI Test, PP |  | 5.21 | Lee Cox |  | Complete | COMPLETE |  |  |  |  |  |
| 938 | 1.4.1.7.4.3.3.2 | Industry Review Workshop |  | 1d | 2024-05-30 A | 2024-05-30 A | 937 | 100% |  | 2024-05-30 | 2024-05-30 | 1d |  |  |  |  |  |  | SI Test, PP | SI Test, PP |  | 5.21 | Lee Cox |  | Complete | COMPLETE |  |  |  |  |  |
| 939 | 1.4.1.7.4.3.3.3 | Industry Consultation Review |  | 6d | 2024-06-10 A | 2024-06-17 A | 938FS+6d | 100% |  | 2024-06-10 | 2024-06-17 | 6d |  |  |  |  |  |  | SI Test, PP | SI Test, PP |  | 5.21 | Lee Cox |  | Complete | COMPLETE |  |  |  |  |  |
| 940 | 1.4.1.7.4.3.3.4 | Review with NFT Working Group |  | 30d | 2024-06-28 A | 2024-08-08 | 939FS+8d | 80% | 6d | 2024-06-28 | 2024-08-08 | 30d |  |  | -42d | 0d |  |  | SI Test, PP | SI Test, PP |  | 5.21 | Roger Robar |  | Green | GREEN |  |  |  |  |  |
| 941 | 1.4.1.7.4.3.3.5 | SIT NFT Scenarios & Test Cases Approved - Theme 3 | milestone | 0d | 2024-08-21 | 2024-08-21 | 940FS+9d |  |  | 2024-08-21 | 2024-08-21 | 0d |  |  | -42d | 0d |  |  | SI Test | SI Test, PP | 13.71 | 5.30 | Roger Robar | Systems Integration Testing (SIT) | Green | AMBER | T3-TE-0116 | SITAG | 31/7/24: baseline date change approved at esitag on 26/7/24 |  |  |
| 942 | 1.4.1.7.4.4 | **Environments (SIT B)** |  | 0d | 2024-08-27 | 2024-08-27 |  |  |  | 2024-08-27 | 2024-08-27 | 0d | 2024-07-30 | 2024-08-05 | 719d |  |  | -0 | N/A | N/A |  | 5.0 | N/A | Systems Integration Testing (SIT) |  |  |  |  |  |  |  |
| 943 | 1.4.1.7.4.4.1 | **PP Environments (SIT B)** |  | 0d | 2024-08-27 | 2024-08-27 |  |  |  | 2024-08-27 | 2024-08-27 | 0d | 2024-07-30 | 2024-08-05 | 719d |  |  | -0 | N/A | N/A |  | 5.0 | N/A | Systems Integration Testing (SIT) |  |  |  |  |  |  |  |
| 944 | 1.4.1.7.4.4.1.1 | Deployment of MHHS solution code to SIT B environments | milestone | 0d | 2024-08-27 | 2024-08-27 |  |  |  | 2024-08-27 | 2024-08-27 | 0d | 2024-07-30 | 2024-08-05 | 719d | 0d | start no earlier than 2024-08-27 |  | PP | SI Test | 19.33 | 5.21 | Simon Berry | Systems Integration Testing (SIT) | Green | GREEN |  |  |  | 26/3/24: Lee said change to SB and align to IR7 |  |
| 945 | 1.4.1.7.4.4.2 | **SI Environments (SIT B)** |  | 0d | 2024-08-27 | 2024-08-27 |  |  |  | 2024-08-27 | 2024-08-27 | 0d | 2024-07-30 | 2024-08-05 | 719d |  |  | -0 | N/A | N/A |  | 5.0 | N/A | Systems Integration Testing (SIT) |  |  |  |  |  |  |  |
| 946 | 1.4.1.7.4.4.2.1 | Coordinate deployment of MHHS solution code to SIT Participants' SIT B environments | milestone | 0d | 2024-08-27 | 2024-08-27 | 944SS |  |  | 2024-08-27 | 2024-08-27 | 0d | 2024-07-30 | 2024-08-05 | 719d |  |  |  | SI Test | PP | 19.33 | 5.21 | Simon Berry | Systems Integration Testing (SIT) | Green | GREEN |  |  |  |  |  |
| 947 | 1.4.1.7.4.5 | **SIT Non-Functional Test Readiness Report** |  | 44d | 2024-06-25 A | 2024-08-23 |  | 65% | 15.57d | 2024-06-25 | 2024-08-23 | 44d | 2024-06-25 | 2024-08-19 | 6d |  |  | -0 | N/A | N/A |  | 5.0 | N/A | Systems Integration Testing (SIT) |  |  |  |  |  |  |  |
| 948 | 1.4.1.7.4.5.1 | **PP SIT Non-Functional Test Readiness Report** |  | 44d | 2024-06-25 A | 2024-08-23 |  | 79% | 9.43d | 2024-06-25 | 2024-08-23 | 44d | 2024-06-25 | 2024-08-05 | 6d |  |  | -0 | N/A | N/A |  | 5.0 | N/A | Systems Integration Testing (SIT) |  |  |  |  |  |  |  |
| 949 | 1.4.1.7.4.5.1.1 | Develop draft Test Readiness Report and submit to Programme for assurance |  | 20d | 2024-06-25 A | 2024-07-22 A |  | 100% |  | 2024-06-25 | 2024-07-22 | 20d | 2024-06-25 | 2024-07-22 |  |  | start no earlier than 2024-06-25 |  | PP | SI Test |  | 5.0 | Roger Robar | Systems Integration Testing (SIT) | Complete | COMPLETE |  |  |  |  |  |
| 950 | 1.4.1.7.4.5.1.2 | Placing Reliance Stage 2 Review |  | 40d | 2024-07-01 A | 2024-08-23 | 949SS+4d | 70% | 12d | 2024-07-01 | 2024-08-23 | 40d |  |  | 6d | 1d |  |  | SI Test | PP |  | 5.12 | Roger Robar | Systems Integration Testing (SIT) | Green | GREEN |  |  |  |  |  |
| 951 | 1.4.1.7.4.5.1.3 | Finalise Test Readiness Report and submit to Programme for assurance |  | 10d | 2024-07-23 A | 2024-08-05 | 949 | 70% | 3d | 2024-07-23 | 2024-08-05 | 10d | 2024-07-23 | 2024-08-05 | 5d | 0d |  |  | PP | SI Test |  | 5.0 | Roger Robar | Systems Integration Testing (SIT) | Overdue | RED |  |  |  |  |  |
| 952 | 1.4.1.7.4.5.2 | **SI SIT Non-Functional Test Readiness Report** |  | 40d | 2024-06-25 A | 2024-08-19 |  | 48% | 20.67d | 2024-06-25 | 2024-08-19 | 40d | 2024-06-25 | 2024-08-19 | 5d |  |  |  | N/A | N/A |  | 5.0 | N/A | Systems Integration Testing (SIT) |  |  |  |  |  |  |  |
| 953 | 1.4.1.7.4.5.2.1 | Assure Test Participants' Test Readiness Reports |  | 35d | 2024-06-25 A | 2024-08-12 | 949SS, 951FF+5d | 63% | 13d | 2024-06-25 | 2024-08-12 | 35d | 2024-06-25 | 2024-08-12 | 5d | 0d |  |  | SI Test | PP,IPA |  | 5.0 | Roger Robar | Systems Integration Testing (SIT) | Green | GREEN |  |  |  |  |  |
| 954 | 1.4.1.7.4.5.2.2 | Develop Overarching SIT Non-Functional Test Readiness Report |  | 20d | 2024-07-16 A | 2024-08-12 | 953FF | 35% | 13d | 2024-07-16 | 2024-08-12 | 20d | 2024-07-16 | 2024-08-12 | 5d | 0d |  |  | SI Test |  |  | 5.0 | Roger Robar | Systems Integration Testing (SIT) | Green | GREEN |  |  |  |  |  |
| 955 | 1.4.1.7.4.5.2.3 | Artefact review (via SITAG) and updates |  | 5d | 2024-08-13 | 2024-08-19 | 954 |  |  | 2024-08-13 | 2024-08-19 | 5d | 2024-08-13 | 2024-08-19 | 5d | 0d |  |  | SI Test | PP,IPA | 5.33 | 5.0 | Roger Robar | Systems Integration Testing (SIT) | Green | GREEN |  |  |  |  |  |
| 956 | 1.4.1.7.4.6 | SIT Non-Functional Testing Preparation Complete | milestone | 0d | 2024-08-26 | 2024-08-26 | 955FF+5d, 794, 347, 950, 929, 935, 941 |  |  | 2024-08-26 | 2024-08-26 | 0d | 2024-08-26 | 2024-08-26 | 5d | 0d |  |  | SI Test | PP,IPA | 18.71 | 5.0 | Roger Robar | Systems Integration Testing (SIT) | Green | AMBER | T2-TE-0700 | SITAG |  |  | T2 |

Notes:
- 935: Date missed because of the deferment of the SIT Non-Functional Test Approach and Plan. This increases the risk to the start of SIT Non-Functional Testing
- 941: 6/8/24: Date at risk due to lower than expected test velocity. Start of NFT could be delayed. Programme-wide scenario re-planning underway
- 944: 25/3: SB - Date aligns to IR8 code delivery for SIT B
- 946: 25/3: SB - Date aligns to IR8 code delivery for SIT B
- 956: 6/8/24: Date at risk due to lower than expected test velocity. Start of NFT could be delayed. Programme-wide scenario re-planning underway

| ID | WBS | Task | Type | Duration | Start | Finish | Predecessors | Complete | Remaining | Baseline start | Baseline finish | Baseline duration | Baseline 1 start | Baseline 1 finish | Total slack | Free slack | Constraint | Baseline cost | Responsible | Involved | Update Version | MHHS Resource Name | MHHS Programme Phase | Sched Status | RAG | Artefact ID | Milestone ID | Text29 | Tier | Task Status | Guidance |
| --- | --- | --- | --- | --- | --- | --- | --- | --- | --- | --- | --- | --- | --- | --- | --- | --- | --- | --- | --- | --- | --- | --- | --- | --- | --- | --- | --- | --- | --- | --- | --- |
| 957 | 1.4.1.7.5 | **SIT Operational Preparation** |  | 170d | 2024-02-01 A | 2024-09-25 |  | 92% | 13.29d | 2024-02-01 | 2025-03-03 | 283d | 2023-08-03 | 2025-03-10 | 697d |  |  | -0 | N/A | N/A | 5.0 | N/A | Systems Integration Testing (SIT) |  |  |  |  |  |  |  |  |
| 958 | 1.4.1.7.5.1 | **Test Approach & Plan** |  | 75d | 2024-02-01 A | 2024-05-15 A |  | 100% |  | 2024-02-01 | 2024-05-15 | 75d | 2024-02-01 | 2024-05-15 |  |  |  | -0 | N/A | N/A | 5.0 | N/A | Systems Integration Testing (SIT) |  |  |  |  |  |  |  |  |
| 959 | 1.4.1.7.5.1.1 | Develop document with SITWG |  | 25d | 2024-02-01 A | 2024-03-06 A |  | 100% |  | 2024-02-01 | 2024-03-06 | 25d | 2024-02-01 | 2024-03-06 |  |  | must start on 2024-02-01 |  | SI Test |  | 5.0 | Lee Cox | Systems Integration Testing (SIT) | Complete | COMPLETE |  |  |  |  |  |  |
| 960 | 1.4.1.7.5.1.2 | Draft document review with Code Bodies |  | 4d | 2024-03-21 A | 2024-03-26 A | 959FS+10d | 100% |  | 2024-03-07 | 2024-03-20 | 10d | 2024-03-07 | 2024-03-20 |  |  |  |  | SI Test | Code Bodies | 5.0 | Lee Cox | Systems Integration Testing (SIT) | Complete | COMPLETE |  |  |  |  |  |  |
| 961 | 1.4.1.7.5.1.3 | Industry Consultation |  | 10d | 2024-03-27 A | 2024-04-09 A | 960 | 100% |  | 2024-03-27 | 2024-04-09 | 10d |  |  |  |  |  |  | PP |  | 5.1 | Lee Cox | Systems Integration Testing (SIT) | Complete | COMPLETE |  |  |  |  |  |  |
| 962 | 1.4.1.7.5.1.4 | Artefact review (via SITAG) and updates |  | 26d | 2024-04-10 A | 2024-05-15 A | 961 | 100% |  | 2024-04-04 | 2024-05-15 | 30d | 2024-03-21 | 2024-05-15 |  |  |  |  | SI Test | PP,IPA,Code Bodies | 5.0 | Lee Cox | Systems Integration Testing (SIT) | Complete | COMPLETE |  |  |  |  |  |  |
| 963 | 1.4.1.7.5.1.5 | SIT Operational Testing Test Approach & Plan approved | milestone | 0d | 2024-05-15 A | 2024-05-15 A | 962 | 100% |  | 2024-05-15 | 2024-05-15 | 0d | 2024-05-15 | 2024-05-15 |  |  |  |  | SI Test | PP | 5.24 | Lee Cox | Systems Integration Testing (SIT) | Complete | COMPLETE | MHHS-ART073 | T3-TE-0029 | SITAG | T3 |  |  |
| 964 | 1.4.1.7.5.2 | **Test Data Approach & Plan** |  | 36d | 2024-03-27 A | 2024-05-15 A |  | 100% |  | 2024-03-27 | 2024-05-15 | 36d | 2024-03-21 | 2024-05-15 |  |  |  | -0 | N/A | N/A | 5.0 | N/A | Systems Integration Testing (SIT) |  |  |  |  |  |  |  |  |
| 965 | 1.4.1.7.5.2.1 | Industry Consultation |  | 10d | 2024-03-27 A | 2024-04-09 A | 961SS | 100% |  | 2024-03-27 | 2024-04-09 | 10d |  |  |  |  |  |  | PP |  | 5.1 | Richard Puddephatt | Systems Integration Testing (SIT) | Complete | COMPLETE |  |  |  |  |  |  |
| 966 | 1.4.1.7.5.2.2 | Artefact review (via SITAG) and updates |  | 26d | 2024-04-10 A | 2024-05-15 A | 965 | 100% |  | 2024-04-10 | 2024-05-15 | 26d | 2024-03-21 | 2024-05-15 |  |  |  |  | SI Test |  | 5.0 | Richard Puddephatt | Systems Integration Testing (SIT) | Complete | COMPLETE |  |  |  |  |  |  |
| 967 | 1.4.1.7.5.2.3 | SIT Operational Testing Test Data Approach & Plan approved | milestone | 0d | 2024-05-15 A | 2024-05-15 A | 966 | 100% |  | 2024-05-15 | 2024-05-15 | 0d | 2024-05-15 | 2024-05-15 |  |  |  |  | SI Test | PP,IPA | 5.0 | Richard Puddephatt | Systems Integration Testing (SIT) | Complete | COMPLETE |  |  |  |  |  |  |
| 968 | 1.4.1.7.5.3 | **Test scenarios & Test Cases** |  | 116d | 2024-04-10 A | 2024-09-18 |  | 96% | 4.53d | 2024-04-10 | 2024-09-18 | 116d | 2023-07-24 | 2024-01-17 | -20d | 0d |  | -0 | N/A | N/A | 5.21 | N/A | Systems Integration Testing (SIT) |  |  |  |  |  |  |  |  |
| 969 | 1.4.1.7.5.3.1 | **Theme 1** |  | 96d | 2024-04-10 A | 2024-08-21 |  | 99% | 0d | 2024-04-10 | 2024-08-21 | 96d |  |  | -35d | 0d |  | -0 | N/A | N/A | 5.21 | N/A | Systems Integration Testing (SIT) |  |  |  |  |  |  | -448.67 |  |
| 970 | 1.4.1.7.5.3.1.1 | Develop Test Scenarios & Test Cases |  | 16d | 2024-04-10 A | 2024-05-01 A | 961 | 100% |  | 2024-04-10 | 2024-05-01 | 16d |  |  |  |  |  |  | SI Test | SI Test, PP | 5.21 | Lee Cox |  | Complete | COMPLETE |  |  |  |  |  |  |
| 971 | 1.4.1.7.5.3.1.2 | Industry Review Workshop |  | 1d | 2024-05-02 A | 2024-05-02 A | 970 | 100% |  | 2024-05-02 | 2024-05-02 | 1d |  |  |  |  |  |  | SI Test, PP | SI Test, PP | 5.21 | Lee Cox |  | Complete | COMPLETE |  |  |  |  |  |  |
| 972 | 1.4.1.7.5.3.1.3 | Industry Consultation Review |  | 6d | 2024-05-28 A | 2024-06-04 A | 971FS+17d | 100% |  | 2024-05-28 | 2024-06-04 | 6d |  |  |  |  |  |  | SI Test, PP | SI Test, PP | 5.21 | Lee Cox |  | Complete | COMPLETE |  |  |  |  |  |  |
| 973 | 1.4.1.7.5.3.1.4 | Review with SIT Working Group |  | 5d | 2024-06-27 A | 2024-07-03 A | 972FS+16d | 100% |  | 2024-06-27 | 2024-07-03 | 5d |  |  |  |  |  |  | SI Test, PP | SI Test, PP | 5.21 | Lee Cox |  | Complete | COMPLETE |  |  |  |  |  |  |
| 974 | 1.4.1.7.5.3.1.5 | SIT Operational Scenarios & Test Cases Approved - Theme 1 | milestone | 0d | 2024-08-21 | 2024-08-21 | 973FS+35d |  |  | 2024-08-21 | 2024-08-21 | 0d |  |  | -62d | 0d |  |  | SI Test | SI Test, PP | 5.30 | Roger Robar | Systems Integration Testing (SIT) | Green | AMBER |  | T3-TE-0117 | SITAG |  | 13.71 | 31/7/24: baseline date change approved at esitag on 26/7/24 |
| 975 | 1.4.1.7.5.3.2 | **Theme 2** |  | 71d | 2024-04-10 A | 2024-07-17 A |  | 100% |  | 2024-04-10 | 2024-07-17 | 71d |  |  |  |  |  |  | N/A | N/A | 5.21 | N/A | Systems Integration Testing (SIT) |  |  |  |  |  |  | -448.67 |  |
| 976 | 1.4.1.7.5.3.2.1 | Develop Test Scenarios & Test Cases |  | 31d | 2024-04-10 A | 2024-05-22 A | 961 | 100% |  | 2024-04-10 | 2024-05-22 | 31d |  |  |  |  |  |  | SI Test | SI Test, PP | 5.21 | Lee Cox |  | Complete | COMPLETE |  |  |  |  |  |  |
| 977 | 1.4.1.7.5.3.2.2 | Industry Review Workshop |  | 1d | 2024-05-23 A | 2024-05-23 A | 976 | 100% |  | 2024-05-23 | 2024-05-23 | 1d |  |  |  |  |  |  | SI Test, PP | SI Test, PP | 5.21 | Lee Cox |  | Complete | COMPLETE |  |  |  |  |  |  |
| 978 | 1.4.1.7.5.3.2.3 | Industry Consultation Review |  | 6d | 2024-06-04 A | 2024-06-11 A | 977FS+7d | 100% |  | 2024-06-04 | 2024-06-11 | 6d |  |  |  |  |  |  | SI Test, PP | SI Test, PP | 5.21 | Lee Cox |  | Complete | COMPLETE |  |  |  |  |  |  |
| 979 | 1.4.1.7.5.3.2.4 | Review with SIT Working Group |  | 5d | 2024-06-27 A | 2024-07-03 A | 978FS+11d | 100% |  | 2024-06-27 | 2024-07-03 | 5d |  |  |  |  |  |  | SI Test, PP | SI Test, PP | 5.21 | Lee Cox |  | Complete | COMPLETE |  |  |  |  |  |  |
| 980 | 1.4.1.7.5.3.2.5 | SIT Operational Scenarios & Test Cases Approved - Theme 2 | milestone | 0d | 2024-07-17 A | 2024-07-17 A | 979FS+10d | 100% |  | 2024-07-17 | 2024-07-17 | 0d |  |  |  |  |  |  | SI Test | SI Test, PP | 5.29 | Lee Cox | Systems Integration Testing (SIT) | Complete | COMPLETE |  | T3-TE-0118 | SITAG |  |  |  |

Notes:
- 963: 26/3 - At risk because of tight delivery schedule
- 974: 6/8/24: Date at risk due to lower than expected test velocity. Start of Operational could be delayed. Programme-wide scenario re-planning underway
- 980: 23/1 - New milestone added because of Operational themed delivery approach. To go to April SITAG for approval. 17/4: Approved as new milestone at SITAG on 17/4/24

| ID | WBS | Task | Type | Duration | Start | Finish | Predecessors | Complete | Remaining | Baseline start | Baseline finish | Baseline duration | Baseline 1 start | Baseline 1 finish | Total slack | Free slack | Constraint | Baseline cost | Responsible | Involved | Task Status | Update Version | MHHS Resource Name | MHHS Programme Phase | Sched Status | RAG | Guidance | Milestone ID | Text29 | Tier | Artefact ID | Text3 |
| --- | --- | --- | --- | --- | --- | --- | --- | --- | --- | --- | --- | --- | --- | --- | --- | --- | --- | --- | --- | --- | --- | --- | --- | --- | --- | --- | --- | --- | --- | --- | --- | --- |
| 981 | 1.4.1.7.5.3.3 | **Theme 3** |  | 116d | 2024-04-10 A | 2024-09-18 |  | 91% | 10.18d | 2024-04-10 | 2024-09-18 | 116d |  |  | -20d | 0d |  | -0 | N/A | N/A | -448.67 | 5.21 | N/A | Systems Integration Testing (SIT) |  |  |  |  |  |  |  |  |
| 982 | 1.4.1.7.5.3.3.1 | Develop Test Scenarios & Test Cases |  | 46d | 2024-04-10 A | 2024-06-12 A | 961 | 100% |  | 2024-04-10 | 2024-06-12 | 46d |  |  |  |  |  |  | SI Test | SI Test, PP |  | 5.21 | Lee Cox |  | Complete | COMPLETE |  |  |  |  |  |  |
| 983 | 1.4.1.7.5.3.3.2 | Industry Review Workshop |  | 1d | 2024-06-13 A | 2024-06-13 A | 982 | 100% |  | 2024-06-13 | 2024-06-13 | 1d |  |  |  |  |  |  | SI Test, PP | SI Test, PP |  | 5.21 | Lee Cox |  | Complete | COMPLETE |  |  |  |  |  |  |
| 984 | 1.4.1.7.5.3.3.3 | Industry Consultation Review |  | 5d | 2024-07-15 A | 2024-07-19 A | 983FS+21d | 100% |  | 2024-07-15 | 2024-07-19 | 5d |  |  |  |  |  |  | SI Test, PP | SI Test, PP |  | 5.21 | Lee Cox |  | Complete | COMPLETE |  |  |  |  |  |  |
| 985 | 1.4.1.7.5.3.3.4 | Review with SIT Working Group |  | 5d | 2024-07-25 | 2024-07-31 | 984FS+3d |  |  | 2024-07-25 | 2024-07-31 | 5d |  |  | -20d | 0d |  |  | SI Test, PP | SI Test, PP | -13.67 | 5.21 | Roger Robar |  | Overdue Start | RED |  |  |  |  |  |  |
| 986 | 1.4.1.7.5.3.3.5 | SIT Operational Scenarios & Test Cases Approved - Theme 3 | milestone | 0d | 2024-09-18 | 2024-09-18 | 985FS+35d |  |  | 2024-09-18 | 2024-09-18 | 0d |  |  | -20d | 0d |  |  | SI Test | SI Test, PP | 41.71 | 5.30 | Roger Robar | Systems Integration Testing (SIT) | Green | AMBER | 31/7/24: baseline date change approved at esitag on 26/7/24 | T3-TE-0119 | SITAG |  |  |  |
| 987 | 1.4.1.7.5.4 | **Environments (SIT B)** |  | 0d | 2024-08-27 | 2024-08-27 |  |  |  | 2024-08-27 | 2024-08-27 | 0d | 2024-09-03 | 2024-09-09 | 719d |  |  | -0 | N/A | N/A |  | 5.0 | N/A | Systems Integration Testing (SIT) |  |  |  |  |  |  |  |  |
| 988 | 1.4.1.7.5.4.1 | **PP Environments (SIT B)** |  | 0d | 2024-08-27 | 2024-08-27 |  |  |  | 2024-08-27 | 2024-08-27 | 0d | 2024-09-03 | 2024-09-09 | 719d |  |  | -0 | N/A | N/A |  | 5.0 | N/A | Systems Integration Testing (SIT) |  |  |  |  |  |  |  |  |
| 989 | 1.4.1.7.5.4.1.1 | Deployment of MHHS solution code to SIT B environments | milestone | 0d | 2024-08-27 | 2024-08-27 |  |  |  | 2024-08-27 | 2024-08-27 | 0d | 2024-09-03 | 2024-09-09 | 719d | 0d | start no earlier than 2024-08-27 |  | PP | SI Test | 19.33 | 5.21 | Simon Berry | Systems Integration Testing (SIT) | Green | GREEN |  |  |  |  |  |  |
| 990 | 1.4.1.7.5.4.2 | **SI Environments (SIT B)** |  | 0d | 2024-08-27 | 2024-08-27 |  |  |  | 2024-08-27 | 2024-08-27 | 0d | 2024-09-03 | 2024-09-09 | 719d |  |  | -0 | N/A | N/A |  | 5.0 | N/A | Systems Integration Testing (SIT) |  |  |  |  |  |  |  |  |
| 991 | 1.4.1.7.5.4.2.1 | Coordinate deployment of MHHS solution code to SIT Participants' SIT B environments | milestone | 0d | 2024-08-27 | 2024-08-27 | 989SS |  |  | 2024-08-27 | 2024-08-27 | 0d | 2024-09-03 | 2024-09-09 | 719d |  |  |  | SI Test | PP | 19.33 | 5.21 | Simon Berry | Systems Integration Testing (SIT) | Green | GREEN |  |  |  |  |  |  |
| 992 | 1.4.1.7.5.5 | **SIT Operational Test Readiness Report** |  | 19d | 2024-08-30 | 2024-09-25 |  |  |  | 2024-08-05 | 2025-03-03 | 151d | 2025-01-07 | 2025-03-03 | -3d | 0d |  | -0 | N/A | N/A |  | 5.0 | N/A | Systems Integration Testing (SIT) |  |  |  |  |  |  |  |  |
| 993 | 1.4.1.7.5.5.1 | **PP SIT Operational Test Readiness Report** |  | 0d | 2024-08-30 | 2024-08-30 |  |  |  | 2024-08-05 | 2025-02-03 | 131d | 2025-01-07 | 2025-02-17 | -3d | 0d |  | -0 | N/A | N/A |  | 5.0 | N/A | Systems Integration Testing (SIT) |  |  |  |  |  |  |  |  |
| 994 | 1.4.1.7.5.5.1.1 | Test Readiness Report submitted to Programme for assurance | milestone | 0d | 2024-08-30 | 2024-08-30 |  |  |  | 2025-01-07 | 2025-02-03 | 20d | 2025-01-07 | 2025-02-03 | -3d | 0d | start no earlier than 2024-08-30 |  | PP | SI Test | 22.33 | 5.0 | Roger Robar | Systems Integration Testing (SIT) | Green | GREEN |  |  |  |  |  |  |
| 995 | 1.4.1.7.5.5.2 | **SI SIT Operational Test Readiness Report** |  | 19d | 2024-08-30 | 2024-09-25 |  |  |  | 2025-01-07 | 2025-03-03 | 40d | 2025-01-07 | 2025-03-03 | -3d | 0d |  |  | N/A | N/A |  | 5.0 | N/A | Systems Integration Testing (SIT) |  |  |  |  |  |  |  |  |
| 996 | 1.4.1.7.5.5.2.1 | Assure Test Participants' Test Readiness Reports |  | 5d | 2024-08-30 | 2024-09-05 | 994 |  |  | 2025-01-07 | 2025-02-24 | 35d | 2025-01-07 | 2025-02-24 | -3d | 0d |  |  | SI Test | PP,IPA | 22.33 | 5.0 | Roger Robar | Systems Integration Testing (SIT) | Green | GREEN |  |  |  |  |  |  |
| 997 | 1.4.1.7.5.5.2.2 | Develop Overarching SIT Operational Test Readiness Report |  | 4d | 2024-09-13 | 2024-09-18 | 996SS+10d |  |  | 2025-01-28 | 2025-02-24 | 20d | 2025-01-28 | 2025-02-24 | -3d | 0d |  |  | SI Test |  | 36.33 | 5.0 | Roger Robar | Systems Integration Testing (SIT) | Green | GREEN |  |  |  |  |  |  |
| 998 | 1.4.1.7.5.5.2.3 | Artefact review (via SITAG) and updates |  | 5d | 2024-09-19 | 2024-09-25 | 997 |  |  | 2025-02-25 | 2025-03-03 | 5d | 2025-02-25 | 2025-03-03 | -3d | 0d |  |  | SI Test | PP,IPA | 42.33 | 5.0 | Roger Robar | Systems Integration Testing (SIT) | Green | GREEN |  |  |  |  |  |  |
| 999 | 1.4.1.7.5.6 | SIT Operational Testing Preparation Complete | milestone | 0d | 2024-09-25 | 2024-09-25 | 998, 364, 974, 980, 986 |  |  | 2024-09-25 | 2024-09-25 | 0d | 2025-03-10 | 2025-03-10 | -3d | 0d |  |  | SI Test | PP,IPA | 48.71 | 5.10 | Roger Robar | Systems Integration Testing (SIT) | Green | AMBER |  | T2-TE-0750 | SITAG | T2 |  |  |
| 1000 | 1.4.2 | **SIT Execution** |  | 390d | 2023-10-30 A | 2025-04-25 |  | 22% | 303.38d | 2023-10-30 | 2025-04-25 | 390d | 2023-10-30 | 2025-04-25 | 545d |  |  | -0 | N/A | N/A |  | 5.0 | N/A | Systems Integration Testing (SIT) |  |  |  |  |  |  |  |  |
| 1001 | 1.4.2.1 | System Integration Testing Start (M9) | milestone | 0d | 2023-10-30 A | 2023-10-30 A | 633FS+5d, 524, 547 | 100% |  | 2023-10-30 | 2023-10-30 | 0d | 2023-10-30 | 2023-10-30 |  |  | must start on 2023-10-30 |  | CPT | PMO |  | 5.11 | Lee Cox | Systems Integration Testing (SIT) | Complete | COMPLETE |  | T1-TE-1000 | PSG | T1 | MHHS-ART071 |  |
| 1002 | 1.4.2.2 | **SIT Component Integration Testing** |  | 96d | 2023-10-30 A | 2024-03-11 A |  | 100% |  | 2023-10-30 | 2024-03-08 | 95d | 2023-10-30 | 2024-03-08 |  |  |  |  | N/A | N/A |  | 5.0 | N/A | Systems Integration Testing (SIT) |  |  |  |  |  |  |  | D24A - Industry Integration Test Completion Report |
| 1003 | 1.4.2.2.1 | SIT Component Integration Testing Start | milestone | 0d | 2023-10-30 A | 2023-10-30 A | 1001 | 100% |  | 2023-10-30 | 2023-10-30 | 0d | 2023-10-30 | 2023-10-30 |  |  |  |  | SI Test | PP |  | 5.11 | Lee Cox | Systems Integration Testing (SIT) | Complete | COMPLETE |  |  |  |  |  |  |
| 1004 | 1.4.2.2.2 | Component Integration Testing Interval 1 Start | milestone | 0d | 2023-10-30 A | 2023-10-30 A | 633SS+1d, 554, 558, 562, 115 | 100% |  | 2023-10-30 | 2023-10-30 | 0d | 2023-10-30 | 2023-10-30 |  |  |  |  | SI Test | PP |  | 5.11 | Lee Cox | Systems Integration Testing (SIT) | Complete | COMPLETE |  | T3-TE-0060 | SITAG | T3 | MHHS-ART071 |  |
| 1005 | 1.4.2.2.3 | Component Integration Testing Interval 2 Start | milestone | 0d | 2023-11-13 A | 2023-11-13 A | 660SS+5d, 554, 562, 558, 115 | 100% |  | 2023-11-13 | 2023-11-13 | 0d | 2023-11-13 | 2023-11-13 |  |  |  |  | SI Test | PP |  | 5.12 | Lee Cox | Systems Integration Testing (SIT) | Complete | COMPLETE |  | T3-TE-0061 | SITAG | T3 |  |  |
| 1006 | 1.4.2.2.4 | Component Integration Testing Interval 3 Start | milestone | 0d | 2023-11-27 A | 2023-11-27 A | 692SS+5d, 554, 558, 562, 115 | 100% |  | 2023-11-27 | 2023-11-27 | 0d | 2023-11-27 | 2023-11-27 |  |  |  |  | SI Test | PP |  | 5.0 | Lee Cox | Systems Integration Testing (SIT) | Complete | COMPLETE |  | T3-TE-0062 | SITAG | T3 |  |  |
| 1007 | 1.4.2.2.5 | Component Integration Testing Interval 4 Start | milestone | 0d | 2023-12-11 A | 2023-12-11 A | 724SS+5d, 554, 558, 562, 115 | 100% |  | 2023-12-11 | 2023-12-11 | 0d | 2023-12-11 | 2023-12-11 |  |  |  |  | SI Test | PP |  | 5.0 | Lee Cox | Systems Integration Testing (SIT) | Complete | COMPLETE |  | T3-TE-0063 | SITAG | T3 |  |  |
| 1008 | 1.4.2.2.6 | Component Integration Testing Interval 5 Start | milestone | 0d | 2024-01-15 A | 2024-01-15 A | 756SS+5d, 554, 558, 562, 115 | 100% |  | 2024-01-15 | 2024-01-15 | 0d | 2024-01-15 | 2024-01-15 |  |  |  |  | SI Test | PP |  | 5.0 | Lee Cox | Systems Integration Testing (SIT) | Complete | COMPLETE |  | T3-TE-0064 |  | T3 |  |  |
| 1009 | 1.4.2.2.7 | Component Integration Testing Interval 6 Start | milestone | 0d | 2024-01-29 A | 2024-01-29 A | 554, 558, 562, 788, 115, 600 | 100% |  | 2024-01-29 | 2024-01-29 | 0d | 2024-01-29 | 2024-01-29 |  |  | must start on 2024-01-29 |  | SI Test | PP |  | 5.0 | Lee Cox | Systems Integration Testing (SIT) | Complete | COMPLETE |  | T3-TE-0065 | SITAG | T3 |  |  |
| 1010 | 1.4.2.2.8 | SIT Component Integration Testing Execution |  | 85d | 2023-10-30 A | 2024-02-23 A | 1004SS | 100% |  | 2023-10-30 | 2024-02-23 | 85d | 2023-10-30 | 2024-02-23 |  |  | must start on 2023-10-30 |  | SI Test | PP |  | 5.0 | Lee Cox | Systems Integration Testing (SIT) | Complete | COMPLETE |  |  |  |  |  | D24A - Industry Integration Test Completion Report |
| 1011 | 1.4.2.2.9 | SIT Component Integration Testing End (incl. confirmation that PPs have submitted their Test Completion Reports to Programme for assurance) | milestone | 0d | 2024-02-23 A | 2024-02-23 A | 1010FF | 100% |  | 2024-02-23 | 2024-02-23 | 0d | 2024-02-23 | 2024-02-23 |  |  |  |  | SI Test | PP |  | 5.19 | Lee Cox | Systems Integration Testing (SIT) | Complete | COMPLETE |  | T3-TE-0032 | SITAG | T3 | MHHS-ART074 |  |
| 1012 | 1.4.2.2.10 | Assurance of PPs Test Completion Reports |  | 30d | 2024-01-22 A | 2024-03-01 A | 1011FF+5d | 100% |  | 2024-01-22 | 2024-03-01 | 30d | 2024-01-22 | 2024-03-01 |  |  |  |  | SI Test | PP |  | 5.19 | Lee Cox | Systems Integration Testing (SIT) | Complete | COMPLETE |  |  |  |  |  |  |

Notes:
- 986: 6/8/24: Date at risk due to lower than expected test velocity. Start of Operational could be delayed. Programme-wide scenario re-planning underway
- 999: 6/8/24: Date at risk due to lower than expected test velocity. Start of Operational could be delayed. Programme-wide scenario re-planning underway
- 1001: On track, however there are a number of associated risks that are being mitigated by the Programme
- 1004: On track, however there are a number of associated risks that are being mitigated by the Programme
- 1007: 13/12 - Complete noting a work-off plan and revised CIT Approach being taken to Dec TMAG
- 1008: 2/1//24 - Approved at 20/12 TMAG based on CIT Gov approach change
- 1009: 2/1//24 - Approved at 20/12 TMAG based on CIT Gov approach change
- 1011: All PPs are expected to complete their CIT by the target date on 09-Feb

| ID | WBS | Task | Type | Duration | Start | Finish | Predecessors | Complete | Remaining | Baseline start | Baseline finish | Baseline duration | Baseline 1 start | Baseline 1 finish | Total slack | Free slack | Baseline cost | Responsible | Involved | Update Version | MHHS Resource Name | MHHS Programme Phase | Sched Status | RAG | Artefact ID | Milestone ID | Text29 | Tier | Text3 | Task Status |
| --- | --- | --- | --- | --- | --- | --- | --- | --- | --- | --- | --- | --- | --- | --- | --- | --- | --- | --- | --- | --- | --- | --- | --- | --- | --- | --- | --- | --- | --- | --- |
| 1013 | 1.4.2.2.11 | **SIT CI Test Completion Report** |  | 18d | 2024-02-07 A | 2024-03-01 A |  | 100% |  | 2024-02-07 | 2024-03-01 | 18d | 2024-02-07 | 2024-03-01 |  |  |  | N/A | N/A | 5.0 | N/A | Systems Integration Testing (SIT) |  |  |  |  |  |  |  |  |
| 1014 | 1.4.2.2.11.1 | Develop document |  | 13d | 2024-02-07 A | 2024-02-23 A | 1011FF | 100% |  | 2024-02-07 | 2024-02-23 | 13d | 2024-02-07 | 2024-02-23 |  |  |  | SI Test |  | 5.19 | Lee Cox | Systems Integration Testing (SIT) | Complete | COMPLETE |  |  |  |  |  |  |
| 1015 | 1.4.2.2.11.2 | Review & agree document |  | 5d | 2024-02-26 A | 2024-03-01 A | 1014, 1012FF | 100% |  | 2024-02-26 | 2024-03-01 | 5d | 2024-02-26 | 2024-03-01 |  |  |  | SI Test | PP,IPA | 5.19 | Lee Cox | Systems Integration Testing (SIT) | Complete | COMPLETE |  |  |  |  |  |  |
| 1016 | 1.4.2.2.12 | SIT Component Integration Testing Test Completion Report Approved | milestone | 0d | 2024-03-11 A | 2024-03-11 A | 1015FS+6d | 100% |  | 2024-03-08 | 2024-03-08 | 0d | 2024-03-08 | 2024-03-08 |  |  |  | SI Test | PP | 5.18 | Lee Cox | Systems Integration Testing (SIT) | Complete | COMPLETE | MHHS-ART074 | T2-TE-0600 | SITAG | T2 |  |  |
| 1017 | 1.4.2.3 | **SIT - Minimum Viable Cohort (MVC)** |  | 240d | 2024-03-11 A | 2025-02-07 |  | 18% | 197.48d | 2024-03-11 | 2025-02-07 | 240d | 2024-03-11 | 2025-02-07 | 600d |  | -0 | N/A | N/A | 5.0 | N/A | Systems Integration Testing (SIT) |  |  |  |  |  |  |  |  |
| 1018 | 1.4.2.3.1 | **SIT Functional Testing (MVC)** |  | 225d | 2024-03-11 A | 2025-01-17 |  | 37% | 142.23d | 2024-03-11 | 2025-01-17 | 225d | 2024-03-11 | 2025-01-17 | 615d |  |  | N/A | N/A | 5.0 | N/A | Systems Integration Testing (SIT) |  |  |  |  |  |  |  |  |
| 1019 | 1.4.2.3.1.1 | SIT Functional Testing Start | milestone | 0d | 2024-03-11 A | 2024-03-11 A | 1016, 859FS+5d, 794, 802, 803, 804, 811 | 100% |  | 2024-03-11 | 2024-03-11 | 0d | 2024-03-11 | 2024-03-11 |  |  |  | SI Test | PP | 5.0 | Lee Cox | Systems Integration Testing (SIT) | Complete | COMPLETE | MHHS-ART073 | T3-TE-0034 | SITAG | T3 |  |  |
| 1020 | 1.4.2.3.1.2 | **SIT Functional Testing Execution (Minimum Viable Cohort)** |  | 225d | 2024-03-11 A | 2025-01-17 |  | 37% | 142.23d | 2024-03-11 | 2025-01-17 | 225d | 2024-03-11 | 2025-01-17 | 615d |  |  | N/A | N/A | 5.0 | N/A | Systems Integration Testing (SIT) |  |  |  |  |  |  | D24C - E2E Test Completion Report | M10 |
| 1021 | 1.4.2.3.1.2.1 | **Cycle 1 (Full Cycle)** |  | 70d | 2024-03-11 A | 2024-06-14 A |  | 100% |  | 2024-03-11 | 2024-07-12 | 90d | 2024-03-11 | 2024-07-12 |  |  |  | N/A | N/A | 5.0 | N/A | Systems Integration Testing (SIT) |  |  |  |  |  |  |  |  |
| 1022 | 1.4.2.3.1.2.1.1 | Test Execution |  | 55d | 2024-03-11 A | 2024-05-24 A | 1019SS-1d, 834 | 100% |  | 2024-03-11 | 2024-06-28 | 80d | 2024-03-11 | 2024-06-28 |  |  |  | PP | SI Test | 5.0 | Lee Cox | Systems Integration Testing (SIT) | Complete | COMPLETE |  |  |  |  |  |  |
| 1023 | 1.4.2.3.1.2.1.2 | Defect resolution, assurance, review, data & environments maintenance |  | 15d | 2024-05-27 A | 2024-06-14 A | 1022 | 100% |  | 2024-07-01 | 2024-07-12 | 10d | 2024-07-01 | 2024-07-12 |  |  |  | SI Test | PP | 5.0 | Lee Cox | Systems Integration Testing (SIT) | Complete | COMPLETE |  |  |  |  |  |  |
| 1024 | 1.4.2.3.1.2.2 | **Cycle 2 (Defect retests and targeted regression testing)** |  | 55d | 2024-06-17 A | 2024-08-30 |  | 60% | 22d | 2024-07-15 | 2024-09-20 | 50d | 2024-07-15 | 2024-09-20 | 12d |  |  | N/A | N/A | 5.0 | N/A | Systems Integration Testing (SIT) |  |  |  |  |  |  |  |  |
| 1025 | 1.4.2.3.1.2.2.1 | Test Execution |  | 45d | 2024-06-17 A | 2024-08-16 | 1023, 839 | 73% | 12d | 2024-07-15 | 2024-09-06 | 40d | 2024-07-15 | 2024-09-06 | 11d | 0d |  | PP | SI Test | 5.0 | Roger Robar | Systems Integration Testing (SIT) | Green | GREEN |  |  |  |  |  |  |
| 1026 | 1.4.2.3.1.2.2.2 | Defect resolution, assurance, review, data & environments maintenance |  | 10d | 2024-08-19 | 2024-08-30 | 1025 |  |  | 2024-09-09 | 2024-09-20 | 10d | 2024-09-09 | 2024-09-20 | 12d | 0d |  | SI Test | PP | 5.0 | Roger Robar | Systems Integration Testing (SIT) | Green | GREEN |  |  |  |  |  | 11.33 |
| 1027 | 1.4.2.3.1.2.3 | **SIT Functional Testing back-up progress risk-assessment** |  | 20d | 2024-09-02 | 2024-09-27 |  |  |  | 2024-09-23 | 2024-10-18 | 20d | 2024-09-23 | 2024-10-18 | 695d |  |  | N/A | N/A | 5.0 | N/A | Systems Integration Testing (SIT) |  |  |  |  |  |  |  |  |
| 1028 | 1.4.2.3.1.2.3.1 | Back-up risk-assessment of SIT Functional progress to assess whether Qualification Execution can start early |  | 15d | 2024-09-02 | 2024-09-20 | 1026 |  |  | 2024-09-23 | 2024-10-11 | 15d | 2024-09-23 | 2024-10-11 | 695d | 0d |  | SI Test | Code Bodies,PP,IPA | 5.0 | Nicola Farley,Lee Cox | Systems Integration Testing (SIT) | Green | GREEN |  |  |  |  |  | 25.33 |
| 1029 | 1.4.2.3.1.2.3.2 | Back-up SITAG decision on early Qualification Testing Execution start | milestone | 0d | 2024-09-27 | 2024-09-27 | 1028FS+5d |  |  | 2024-10-18 | 2024-10-18 | 0d | 2024-10-18 | 2024-10-18 | 695d |  |  | SI Test | Code Bodies,PP,IPA | 5.0 | Nicola Farley,Lee Cox | Systems Integration Testing (SIT) | Green | GREEN |  | T3-TE-0041 | QAG | T3 |  | 50.71 |
| 1030 | 1.4.2.3.1.2.4 | **Cycle 3 (Defect retests and targeted regression testing)** |  | 45d | 2024-09-02 | 2024-11-01 |  |  |  | 2024-09-23 | 2024-11-01 | 30d | 2024-09-23 | 2024-11-01 | 12d |  |  | N/A | N/A | 5.0 | N/A | Systems Integration Testing (SIT) |  |  |  |  |  |  |  |  |
| 1031 | 1.4.2.3.1.2.4.1 | Test Execution |  | 35d | 2024-09-02 | 2024-10-18 | 1026, 844 |  |  | 2024-09-23 | 2024-10-18 | 20d | 2024-09-23 | 2024-10-18 | 12d | 0d |  | PP | SI Test | 5.0 | Roger Robar | Systems Integration Testing (SIT) | Green | GREEN |  |  |  |  |  | 25.33 |
| 1032 | 1.4.2.3.1.2.4.2 | Defect resolution, assurance, review, data & environments maintenance |  | 10d | 2024-10-21 | 2024-11-01 | 1031 |  |  | 2024-10-21 | 2024-11-01 | 10d | 2024-10-21 | 2024-11-01 | 12d | 0d |  | SI Test | PP | 5.0 | Roger Robar | Systems Integration Testing (SIT) | Green | GREEN |  |  |  |  |  | 74.33 |
| 1033 | 1.4.2.3.1.2.5 | Core Systems Code Freeze | milestone | 0d | 2024-11-01 | 2024-11-01 | 1032FF |  |  | 2024-11-01 | 2024-11-01 | 0d | 2024-11-01 | 2024-11-01 | 669d | 69d |  | SI Test | PP | 5.0 | Roger Robar | Systems Integration Testing (SIT) | Green | AMBER |  | T3-TE-0045 | SITAG | T3 |  | 85.71 |
| 1034 | 1.4.2.3.1.2.6 | Regression Testing (code freeze) |  | 45d | 2024-11-04 | 2025-01-03 | 1032, 849 |  |  | 2024-11-04 | 2025-01-03 | 45d | 2024-11-04 | 2025-01-03 | 12d | 0d |  | PP | SI Test | 5.0 | Roger Robar | Systems Integration Testing (SIT) | Green | GREEN |  |  |  |  |  | 88.33 |
| 1035 | 1.4.2.3.1.2.7 | SIT Functional Testing End (Minimum Viable Cohort) (incl. confirmation that PPs have submitted their Test Completion Reports to Programme for assurance) | milestone | 0d | 2025-01-03 | 2025-01-03 | 1034FF |  |  | 2025-01-03 | 2025-01-03 | 0d | 2025-01-03 | 2025-01-03 | 12d | 0d |  | SI Test | PP | 5.0 | Roger Robar | Systems Integration Testing (SIT) | Green | AMBER | MHHS-ART072 | T3-TE-0046 | SITAG | T3 |  | 148.71 |
| 1036 | 1.4.2.3.1.2.8 | Assurance of PPs Test Completion Reports |  | 30d | 2024-12-02 | 2025-01-10 | 1035FF+5d |  |  | 2024-12-02 | 2025-01-10 | 30d | 2024-12-02 | 2025-01-10 | 12d | 0d |  | SI Test | PP | 5.0 | Roger Robar | Systems Integration Testing (SIT) | Green | GREEN |  |  |  |  |  | 116.33 |

Notes:
- 1016: 20/2 - Date changed to align with SITAG meeting. On track for approval 11/3
- 1019: 28/11 - At risk because of challenges with CCP and PP readiness & dependent on successful Secondary Routing Testing
- 1028: Action: 5/12 - LC said change name from his to nicola and check dates based on new start date for non sit ldso testing
- 1029: Action: 5/12 - LC said change name from his to nicola and check dates based on new start date for non sit ldso testing
- 1033: 6/8/24: Date at risk due to lower than expected test velocity. Completion of Functional could be delayed. Programme-wide scenario re-planning underway
- 1035: 6/8/24: Date at risk due to lower than expected test velocity. Completion of Functional could be delayed. Programme-wide scenario re-planning underway

| ID | WBS | Task | Type | Duration | Start | Finish | Predecessors | Complete | Remaining | Baseline start | Baseline finish | Baseline duration | Baseline 1 start | Baseline 1 finish | Total slack | Free slack | Baseline cost | Responsible | Involved | Update Version | MHHS Resource Name | MHHS Programme Phase | Task Status | Sched Status | RAG | Artefact ID | Milestone ID | Text29 | Tier | Text3 |
| --- | --- | --- | --- | --- | --- | --- | --- | --- | --- | --- | --- | --- | --- | --- | --- | --- | --- | --- | --- | --- | --- | --- | --- | --- | --- | --- | --- | --- | --- | --- |
| 1037 | 1.4.2.3.1.2.9 | **SIT Functional Test Completion Report (Minimum Viable Cohort)** |  | 20d | 2024-12-16 | 2025-01-10 |  |  |  | 2024-12-16 | 2025-01-10 | 20d | 2024-12-16 | 2025-01-10 | 12d |  |  | N/A | N/A | 5.0 | N/A | Systems Integration Testing (SIT) |  |  |  |  |  |  |  |  |
| 1038 | 1.4.2.3.1.2.9.1 | Develop document |  | 15d | 2024-12-16 | 2025-01-03 | 1035FF |  |  | 2024-12-16 | 2025-01-03 | 15d | 2024-12-16 | 2025-01-03 | 12d | 0d |  | SI Test |  | 5.0 | Roger Robar | Systems Integration Testing (SIT) | 130.33 | Green | GREEN |  |  |  |  |  |
| 1039 | 1.4.2.3.1.2.9.2 | Review & agree document |  | 5d | 2025-01-06 | 2025-01-10 | 1038, 1036FF |  |  | 2025-01-06 | 2025-01-10 | 5d | 2025-01-06 | 2025-01-10 | 12d | 0d |  | SI Test | PP,IPA | 5.0 | Roger Robar | Systems Integration Testing (SIT) | 151.33 | Green | GREEN |  |  |  |  |  |
| 1040 | 1.4.2.3.1.2.10 | SIT Functional Testing Test Completion Report (Minimum Viable Cohort) Approved | milestone | 0d | 2025-01-17 | 2025-01-17 | 1039FF+5d |  |  | 2025-01-17 | 2025-01-17 | 0d | 2025-01-17 | 2025-01-17 | 12d | 11d |  | SI Test | PP | 5.0 | Roger Robar | Systems Integration Testing (SIT) | 162.71 | Green | AMBER | MHHS-ART072 | T2-TE-0850 | SITAG | T2 |  |
| 1041 | 1.4.2.3.2 | **SIT Migration Testing (MVC)** |  | 152d | 2024-06-17 A | 2025-01-15 |  | 16% | 126.93d | 2024-06-10 | 2025-01-10 | 155d | 2024-06-10 | 2024-10-18 | 14d |  | -0 | N/A | N/A | 5.0 | N/A | Systems Integration Testing (SIT) |  |  |  |  |  |  |  |  |
| 1042 | 1.4.2.3.2.1 | SIT Migration Testing Start | milestone | 0d | 2024-06-17 A | 2024-06-17 A | 911FS+10d, 866, 870, 877, 883, 889 | 100% |  | 2024-06-10 | 2024-06-10 | 0d | 2024-06-10 | 2024-06-10 |  |  |  | SI Test | PP | 5.27 | Lee Cox | Systems Integration Testing (SIT) |  | Complete | COMPLETE | MHHS-ART076 | T3-TE-0038 | SITAG | T3 |  |
| 1043 | 1.4.2.3.2.2 | SIT Migration Testing Execution (Minimum Viable Cohort) |  | 89d | 2024-06-18 A | 2024-10-18 | 1042SS | 36% | 57d | 2024-06-10 | 2024-10-04 | 85d | 2024-06-10 | 2024-10-04 | 14d | 0d |  | SI Test | PP | 5.0 | Roger Robar | Systems Integration Testing (SIT) |  | Red | RED |  |  |  |  | D24E - Migration Test Completion Report |
| 1044 | 1.4.2.3.2.3 | Defect resolution, assurance, review, data & environments maintenance |  | 10d | 2024-10-21 | 2024-11-01 | 1043 |  |  | 2024-10-21 | 2024-11-01 | 10d | 2024-10-21 | 2024-11-01 | 14d | 0d |  | SI Test | PP | 5.27 | Roger Robar | Systems Integration Testing (SIT) | 74.33 | Green | GREEN |  |  |  |  |  |
| 1045 | 1.4.2.3.2.4 | Regression Testing (code freeze) |  | 45d | 2024-11-04 | 2025-01-03 | 1044 |  |  | 2024-11-04 | 2025-01-03 | 45d |  |  | 14d | 0d |  |  |  | 5.27 |  |  | 88.33 | Green | GREEN |  |  |  |  |  |
| 1046 | 1.4.2.3.2.5 | SIT Migration Testing End (Minimum Viable Cohort) (incl. confirmation that PPs have submitted their Test Completion Reports to Programme for assurance) | milestone | 0d | 2025-01-03 | 2025-01-03 | 1043FF, 1045 |  |  | 2025-01-03 | 2025-01-03 | 0d | 2024-10-04 | 2024-10-04 | 14d | 0d |  | SI Test | PP | 5.29 | Roger Robar | Systems Integration Testing (SIT) | 148.71 | Green | AMBER | MHHS-ART076 | T3-TE-0043 | SITAG | T3 |  |
| 1047 | 1.4.2.3.2.6 | Assurance of PPs Test Completion Reports |  | 30d | 2024-12-02 | 2025-01-10 | 1046FF+5d |  |  | 2024-12-02 | 2025-01-10 | 30d | 2024-09-02 | 2024-10-11 | 14d | 0d |  | SI Test | PP | 5.0 | Roger Robar | Systems Integration Testing (SIT) | 116.33 | Green | GREEN |  |  |  |  |  |
| 1048 | 1.4.2.3.2.7 | **SIT Migration Testing Test Completion Report (Minimum Viable Cohort)** |  | 20d | 2024-12-16 | 2025-01-10 |  |  |  | 2024-09-16 | 2024-10-11 | 20d | 2024-09-16 | 2024-10-11 | 14d |  |  | N/A | N/A | 5.0 | N/A | Systems Integration Testing (SIT) |  |  |  |  |  |  |  |  |
| 1049 | 1.4.2.3.2.7.1 | Develop document |  | 15d | 2024-12-16 | 2025-01-03 | 1046FF |  |  | 2024-09-16 | 2024-10-04 | 15d | 2024-09-16 | 2024-10-04 | 14d | 0d |  | SI Test |  | 5.0 | Roger Robar | Systems Integration Testing (SIT) | 130.33 | Red | RED |  |  |  |  |  |
| 1050 | 1.4.2.3.2.7.2 | Review & agree document |  | 5d | 2025-01-06 | 2025-01-10 | 1049, 1047FF |  |  | 2024-10-07 | 2024-10-11 | 5d | 2024-10-07 | 2024-10-11 | 14d | 0d |  | SI Test | PP,IPA | 5.0 | Roger Robar | Systems Integration Testing (SIT) | 151.33 | Red | RED |  |  |  |  |  |
| 1051 | 1.4.2.3.2.8 | SIT Migration Testing Test Completion Report (Minimum Viable Cohort) Approved | milestone | 0d | 2025-01-15 | 2025-01-15 | 1050FF+3d |  |  | 2024-10-18 | 2024-10-18 | 0d | 2024-10-18 | 2024-10-18 | 14d |  |  | SI Test | PP | 5.28 | Roger Robar | Systems Integration Testing (SIT) | 160.71 | Red | RED | MHHS-ART076 | T2-TE-0800 | SITAG | T2 |  |
| 1052 | 1.4.2.3.3 | **SIT Non-Functional Testing (MVC)** |  | 99d | 2024-09-02 | 2025-01-17 |  |  |  | 2024-09-02 | 2025-01-17 | 100d | 2024-09-02 | 2025-01-17 | 5d |  |  | N/A | N/A | 5.0 | N/A | Systems Integration Testing (SIT) |  |  |  |  |  |  |  |  |
| 1053 | 1.4.2.3.3.1 | SIT Non-Functional Testing Start | milestone | 0d | 2024-09-02 | 2024-09-02 | 956FS+5d, 1025FS+5d, 918, 922, 929, 935, 941 |  |  | 2024-09-02 | 2024-09-02 | 0d | 2024-09-02 | 2024-09-02 | 5d | 0d |  | SI Test | PP | 5.0 | Roger Robar | Systems Integration Testing (SIT) | 25.71 | yellow | AMBER | MHHS-ART079 | T3-TE-0040 | SITAG | T3 |  |
| 1054 | 1.4.2.3.3.2 | SIT Non-Functional Testing Execution (Minimum Viable Cohort) |  | 89d | 2024-09-03 | 2025-01-03 | 1053SS |  |  | 2024-09-02 | 2025-01-03 | 90d | 2024-09-02 | 2025-01-03 | 12d | 0d |  | SI Test | PP | 5.0 | Roger Robar | Systems Integration Testing (SIT) | 26.33 | Green | GREEN |  |  |  |  | D24D - NF Test Completion Report |
| 1055 | 1.4.2.3.3.3 | SIT Non-Functional Testing End (Minimum Viable Cohort) (incl. confirmation that PPs have submitted their Test Completion Reports to Programme for assurance) | milestone | 0d | 2025-01-03 | 2025-01-03 | 1054FF |  |  | 2025-01-03 | 2025-01-03 | 0d | 2025-01-03 | 2025-01-03 | 12d | 0d |  | SI Test | PP | 5.0 | Roger Robar | Systems Integration Testing (SIT) | 148.71 | Green | AMBER | MHHS-ART079 | T3-TE-0047 | SITAG | T3 |  |
| 1056 | 1.4.2.3.3.4 | Assurance of PPs Test Completion Reports |  | 30d | 2024-12-02 | 2025-01-10 | 1055FF+5d |  |  | 2024-12-02 | 2025-01-10 | 30d | 2024-12-02 | 2025-01-10 | 12d | 0d |  | SI Test | PP | 5.0 | Roger Robar | Systems Integration Testing (SIT) | 116.33 | Green | GREEN |  |  |  |  |  |
| 1057 | 1.4.2.3.3.5 | **SIT Non-Functional Testing Test Completion Report (Minimum Viable Cohort)** |  | 20d | 2024-12-16 | 2025-01-10 |  |  |  | 2024-12-16 | 2025-01-10 | 20d | 2024-12-16 | 2025-01-10 | 12d |  |  | N/A | N/A | 5.0 | N/A | Systems Integration Testing (SIT) |  |  |  |  |  |  |  |  |
| 1058 | 1.4.2.3.3.5.1 | Develop document |  | 15d | 2024-12-16 | 2025-01-03 | 1055FF |  |  | 2024-12-16 | 2025-01-03 | 15d | 2024-12-16 | 2025-01-03 | 12d | 0d |  | SI Test |  | 5.0 | Roger Robar | Systems Integration Testing (SIT) | 130.33 | Green | GREEN |  |  |  |  |  |
| 1059 | 1.4.2.3.3.5.2 | Review & agree document |  | 5d | 2025-01-06 | 2025-01-10 | 1058, 1056FF |  |  | 2025-01-06 | 2025-01-10 | 5d | 2025-01-06 | 2025-01-10 | 12d | 0d |  | SI Test | PP,IPA | 5.0 | Roger Robar | Systems Integration Testing (SIT) | 151.33 | Green | GREEN |  |  |  |  |  |
| 1060 | 1.4.2.3.3.6 | SIT Non-Functional Testing Test Completion Report (Minimum Viable Cohort) Approved | milestone | 0d | 2025-01-17 | 2025-01-17 | 1059FF+5d |  |  | 2025-01-17 | 2025-01-17 | 0d | 2025-01-17 | 2025-01-17 | 12d |  |  | SI Test | PP | 5.0 | Roger Robar | Systems Integration Testing (SIT) | 162.71 | Green | AMBER | MHHS-ART079 | T2-TE-0900 | SITAG | T2 |  |

Notes:
- 1040: 6/8/24: Date at risk due to lower than expected test velocity. Completion of Functional could be delayed. Programme-wide scenario re-planning underway
- 1042: 21/5: at risk because dependant on prioritised SIT F CoA tests. Subject to approval at eSITAG on 10/6. 11/6: Missed date because MPRS data and code not ready. Decision deferred to 17/6
- 1046: 6/8/24: Date at risk due to lower than expected test velocity. Completion of Migration could be delayed. Programme-wide scenario re-planning underway / Guidance: 17/7/24: Date changed approved at SITAG on 17/7/24 from 4/10/24 to 3/1/25
- 1051: Date change because the plan did not consider SIT Migration regression testing. SIT Migration Test Completion Report date was incorrect. Revise plan to align to Jan 25 SITAG approval
- 1053: 6/8/24: Date at risk due to lower than expected test velocity. Start of SIT-Non Functional (MVC) could be delayed. Programme-wide scenario re-planning underway
- 1055: 6/8/24: Date at risk due to lower than expected test velocity. Start of SIT-Non Functional (MVC) could be delayed. Programme-wide scenario re-planning underway
- 1060: 6/8/24: Date at risk due to lower than expected test velocity. Start of SIT-Non Functional (MVC) could be delayed. Programme-wide scenario re-planning underway

| ID | WBS | Task | Type | Duration | Start | Finish | Predecessors | Complete | Remaining | Baseline start | Baseline finish | Baseline duration | Baseline 1 start | Baseline 1 finish | Total slack | Free slack | Baseline cost | Responsible | Involved | Update Version | MHHS Resource Name | MHHS Programme Phase | Artefact ID | Task Status | Sched Status | RAG | Milestone ID | Text29 | Tier | Text3 |
| --- | --- | --- | --- | --- | --- | --- | --- | --- | --- | --- | --- | --- | --- | --- | --- | --- | --- | --- | --- | --- | --- | --- | --- | --- | --- | --- | --- | --- | --- | --- |
| 1061 | 1.4.2.3.4 | **SIT Operational Testing (MVC)** |  | 89d | 2024-10-07 | 2025-02-07 |  |  |  | 2024-10-07 | 2025-02-07 | 90d | 2024-10-07 | 2025-02-07 | -3d | 0d |  | N/A | N/A | 5.0 | N/A | Systems Integration Testing (SIT) |  |  |  |  |  |  |  |  |
| 1062 | 1.4.2.3.4.1 | SIT Operational Testing Start | milestone | 0d | 2024-10-07 | 2024-10-07 | 999FS+8d, 963, 967, 974, 980, 986 |  |  | 2024-10-07 | 2024-10-07 | 0d | 2024-10-07 | 2024-10-07 | -3d | 0d |  | SI Test | PP | 5.0 | Roger Robar | Systems Integration Testing (SIT) | MHHS-ART073 MHHS-ART143 | 60.71 | yellow | AMBER | T3-TE-0042 | SITAG | T3 |  |
| 1063 | 1.4.2.3.4.2 | SIT Operational Testing Execution (Minimum Viable Cohort) |  | 79d | 2024-10-08 | 2025-01-24 | 1062SS |  |  | 2024-10-07 | 2025-01-24 | 80d | 2024-10-07 | 2025-01-24 | -3d | 0d |  | SI Test | PP | 5.0 | Roger Robar | Systems Integration Testing (SIT) |  | 61.33 | Green | AMBER |  |  |  | D24D - NF Test Completion Report |
| 1064 | 1.4.2.3.4.3 | SIT Operational Testing End (Minimum Viable Cohort) (incl. confirmation that PPs have submitted their Test Completion Reports to Programme for assurance) | milestone | 0d | 2025-01-24 | 2025-01-24 | 1063FF |  |  | 2025-01-24 | 2025-01-24 | 0d | 2025-01-24 | 2025-01-24 | -3d | 0d |  | SI Test | PP | 5.0 | Roger Robar | Systems Integration Testing (SIT) | MHHS-ART081 | 169.71 | Green | AMBER | T3-TE-0050 | SITAG | T3 |  |
| 1065 | 1.4.2.3.4.4 | Assurance of PPs Test Completion Reports |  | 30d | 2024-12-23 | 2025-01-31 | 1064FF+5d |  |  | 2024-12-23 | 2025-01-31 | 30d | 2024-12-23 | 2025-01-31 | -3d | 0d |  | SI Test | PP | 5.0 | Roger Robar | Systems Integration Testing (SIT) |  | 137.33 | Green | GREEN |  |  |  |  |
| 1066 | 1.4.2.3.4.5 | **SIT Operational Testing Test Completion Report (Minimum Viable Cohort)** |  | 20d | 2025-01-06 | 2025-01-31 |  |  |  | 2025-01-06 | 2025-01-31 | 20d | 2025-01-06 | 2025-01-31 | -3d | 0d |  | N/A | N/A | 5.0 | N/A | Systems Integration Testing (SIT) |  |  |  |  |  |  |  |  |
| 1067 | 1.4.2.3.4.5.1 | Develop document |  | 15d | 2025-01-06 | 2025-01-24 | 1064FF |  |  | 2025-01-06 | 2025-01-24 | 15d | 2025-01-06 | 2025-01-24 | -3d | 0d |  | SI Test |  | 5.0 | Roger Robar | Systems Integration Testing (SIT) |  | 151.33 | Green | GREEN |  |  |  |  |
| 1068 | 1.4.2.3.4.5.2 | Review & agree document |  | 5d | 2025-01-27 | 2025-01-31 | 1067, 1065FF |  |  | 2025-01-27 | 2025-01-31 | 5d | 2025-01-27 | 2025-01-31 | -3d | 0d |  | SI Test | PP,IPA | 5.0 | Roger Robar | Systems Integration Testing (SIT) |  | 172.33 | Green | GREEN |  |  |  |  |
| 1069 | 1.4.2.3.4.6 | SIT Operational Testing Test Completion Report (Minimum Viable Cohort) Approved | milestone | 0d | 2025-02-07 | 2025-02-07 | 1068FF+5d |  |  | 2025-02-07 | 2025-02-07 | 0d | 2025-02-07 | 2025-02-07 | -3d | 0d |  | SI Test | PP | 5.0 | Roger Robar | Systems Integration Testing (SIT) | MHHS-ART081 | 183.71 | Green | AMBER | T2-TE-0950 | SITAG | T2 |  |
| 1070 | 1.4.2.3.5 | **SIT MVC Test Exit Report** |  | 20d | 2025-01-06 | 2025-01-31 |  |  |  | 2025-01-06 | 2025-01-31 | 20d | 2025-01-06 | 2025-01-31 | -3d | 0d |  | N/A | N/A | 5.0 | N/A | Systems Integration Testing (SIT) |  |  |  |  |  |  |  |  |
| 1071 | 1.4.2.3.5.1 | Develop document |  | 15d | 2025-01-06 | 2025-01-24 | 1067FF |  |  | 2025-01-06 | 2025-01-24 | 15d | 2025-01-06 | 2025-01-24 | -3d | 0d |  | SI Test |  | 5.0 | Roger Robar | Systems Integration Testing (SIT) |  | 151.33 | Green | GREEN |  |  |  |  |
| 1072 | 1.4.2.3.5.2 | Review & agree document |  | 5d | 2025-01-27 | 2025-01-31 | 1071 |  |  | 2025-01-27 | 2025-01-31 | 5d | 2025-01-27 | 2025-01-31 | -3d | 0d |  | SI Test | PP,IPA | 5.0 | Roger Robar | Systems Integration Testing (SIT) |  | 172.33 | Green | GREEN |  |  |  |  |
| 1073 | 1.4.2.3.6 | SIT Minimum Viable Cohort Complete (SIT Minimum Viable Cohort Test Exit Report Approved) | milestone | 0d | 2025-02-07 | 2025-02-07 | 1072FS+5d, 1016, 1040, 1051, 1060, 1069 |  |  | 2025-02-07 | 2025-02-07 | 0d | 2025-02-07 | 2025-02-07 | -3d | 0d |  | CPT | PP,IPA | 5.0 | Roger Robar | Systems Integration Testing (SIT) | MHHS-ART081 | 183.71 | yellow | AMBER | T1-TE-2000 | PSG | T1 |  |
| 1074 | 1.4.2.4 | **SIT - Other Participants** |  | 295d | 2024-03-11 A | 2025-04-25 |  | 14% | 252.25d | 2024-03-11 | 2025-04-25 | 295d | 2024-03-11 | 2025-04-25 | 5d |  | -0 | N/A | N/A | 5.0 | N/A | Systems Integration Testing (SIT) |  | M10,M11 |  |  |  |  |  | D24D - NF Test Completion Report |
| 1075 | 1.4.2.4.1 | **SIT Functional Testing (Other Participants)** |  | 295d | 2024-03-11 A | 2025-04-25 |  | 34% | 195.38d | 2024-03-11 | 2025-04-25 | 295d | 2024-03-11 | 2025-04-25 | 5d |  |  | N/A | N/A | 5.0 | N/A | Systems Integration Testing (SIT) |  |  |  |  |  |  |  |  |
| 1076 | 1.4.2.4.1.1 | **SIT Functional Testing Execution (Other Participants)** |  | 280d | 2024-03-11 A | 2025-04-04 |  | 37% | 177d | 2024-03-11 | 2025-04-04 | 280d | 2024-03-11 | 2025-04-04 | 5d |  |  | N/A | N/A | 5.0 | N/A | Systems Integration Testing (SIT) |  | M10 |  |  |  |  |  | D24C - E2E Test Completion Report |
| 1077 | 1.4.2.4.1.1.1 | **Cycle 1 (Full Cycle)** |  | 70d | 2024-03-11 A | 2024-06-14 A |  | 100% |  | 2024-03-11 | 2024-07-12 | 90d | 2024-03-11 | 2024-07-12 |  |  |  | N/A | N/A | 5.0 | N/A | Systems Integration Testing (SIT) |  |  |  |  |  |  |  |  |
| 1078 | 1.4.2.4.1.1.1.1 | Test Execution |  | 55d | 2024-03-11 A | 2024-05-24 A | 1022SS, 128 | 100% |  | 2024-03-11 | 2024-06-28 | 80d | 2024-03-11 | 2024-06-28 |  |  |  | PP | SI Test | 5.0 | Lee Cox | Systems Integration Testing (SIT) |  |  | Complete | COMPLETE |  |  |  |  |
| 1079 | 1.4.2.4.1.1.1.2 | Defect resolution, assurance, review, data & environments maintenance |  | 15d | 2024-05-27 A | 2024-06-14 A | 1078 | 100% |  | 2024-07-01 | 2024-07-12 | 10d | 2024-07-01 | 2024-07-12 |  |  |  | SI Test | PP | 5.0 | Lee Cox | Systems Integration Testing (SIT) |  |  | Complete | COMPLETE |  |  |  |  |
| 1080 | 1.4.2.4.1.1.2 | **Cycle 2 (Defect retests and targeted regression testing)** |  | 55d | 2024-06-17 A | 2024-08-30 |  | 60% | 22d | 2024-07-15 | 2024-09-20 | 50d | 2024-07-15 | 2024-09-20 | 5d |  |  | N/A | N/A | 5.0 | N/A | Systems Integration Testing (SIT) |  |  |  |  |  |  |  |  |
| 1081 | 1.4.2.4.1.1.2.1 | Test Execution |  | 45d | 2024-06-17 A | 2024-08-16 | 1079, 132, 136 | 73% | 12d | 2024-07-15 | 2024-09-06 | 40d | 2024-07-15 | 2024-09-06 | 5d | 0d |  | PP | SI Test | 5.0 | Roger Robar | Systems Integration Testing (SIT) |  |  | Green | GREEN |  |  |  |  |
| 1082 | 1.4.2.4.1.1.2.2 | Defect resolution, assurance, review, data & environments maintenance |  | 10d | 2024-08-19 | 2024-08-30 | 1081 |  |  | 2024-09-09 | 2024-09-20 | 10d | 2024-09-09 | 2024-09-20 | 5d | 0d |  | SI Test | PP | 5.0 | Roger Robar | Systems Integration Testing (SIT) |  | 11.33 | Green | GREEN |  |  |  |  |
| 1083 | 1.4.2.4.1.1.3 | **Cycle 3 (Defect retests and targeted regression testing)** |  | 45d | 2024-09-02 | 2024-11-01 |  |  |  | 2024-09-23 | 2024-11-01 | 30d | 2024-09-23 | 2024-11-01 | 5d |  |  | N/A | N/A | 5.0 | N/A | Systems Integration Testing (SIT) |  |  |  |  |  |  |  |  |
| 1084 | 1.4.2.4.1.1.3.1 | Test Execution |  | 35d | 2024-09-02 | 2024-10-18 | 1082, 140 |  |  | 2024-09-23 | 2024-10-18 | 20d | 2024-09-23 | 2024-10-18 | 5d | 0d |  | PP | SI Test | 5.0 | Roger Robar | Systems Integration Testing (SIT) |  | 25.33 | Green | GREEN |  |  |  |  |
| 1085 | 1.4.2.4.1.1.3.2 | Defect resolution, assurance, review, data & environments maintenance |  | 10d | 2024-10-21 | 2024-11-01 | 1084 |  |  | 2024-10-21 | 2024-11-01 | 10d | 2024-10-21 | 2024-11-01 | 5d | 0d |  | SI Test | PP | 5.0 | Roger Robar | Systems Integration Testing (SIT) |  | 74.33 | Green | GREEN |  |  |  |  |
| 1086 | 1.4.2.4.1.1.4 | Regression Testing (code freeze) |  | 45d | 2024-11-04 | 2025-01-03 | 1085 |  |  | 2024-11-04 | 2025-01-03 | 45d | 2024-11-04 | 2025-01-03 | 5d | 0d |  | PP | SI Test | 5.0 | Roger Robar | Systems Integration Testing (SIT) |  | 88.33 | Green | GREEN |  |  |  |  |
| 1087 | 1.4.2.4.1.1.5 | SIT Other PPs continued support |  | 65d | 2025-01-06 | 2025-04-04 | 1086 |  |  | 2025-01-06 | 2025-04-04 | 65d | 2025-01-06 | 2025-04-04 | 5d | 0d |  | PP | SI Test | 5.0 | Roger Robar | Systems Integration Testing (SIT) |  | 151.33 | Green | GREEN |  |  |  |  |
| 1088 | 1.4.2.4.1.2 | SIT Functional Testing End (Other Participants) (incl. confirmation that PPs have submitted their Test Completion Reports to Programme for assurance) | milestone | 0d | 2025-04-04 | 2025-04-04 | 1087FF |  |  | 2025-04-04 | 2025-04-04 | 0d | 2025-04-04 | 2025-04-04 | 5d | 0d |  | SI Test | PP | 5.0 | Roger Robar | Systems Integration Testing (SIT) | MHHS-ART072 | 239.71 | Green | AMBER | T3-TE-0052 | SITAG | T3 |  |
| 1089 | 1.4.2.4.1.3 | Assurance of PPs Test Completion Reports |  | 5d | 2025-04-14 | 2025-04-18 | 1088FS+5d |  |  | 2025-04-14 | 2025-04-18 | 5d | 2025-04-14 | 2025-04-18 | 5d | 0d |  | SI Test | PP | 5.0 | Roger Robar | Systems Integration Testing (SIT) |  | 249.33 | Green | GREEN |  |  |  |  |

Notes:
- 1062: 6/8/24: Date at risk due to lower than expected test velocity. Start of SIT Operational (MVC) could be delayed. Programme-wide scenario re-planning underway
- 1064: 6/8/24: Date at risk due to lower than expected test velocity. Start of SIT Operational (MVC) could be delayed. Programme-wide scenario re-planning underway
- 1069: 6/8/24: Date at risk due to lower than expected test velocity. Start of SIT Operational (MVC) could be delayed. Programme-wide scenario re-planning underway
- 1073: 6/8/24: Date at risk due to lower than expected test velocity. Start of SIT Operational (MVC) could be delayed. Programme-wide scenario re-planning underway
- 1088: 6/8/24: Date at risk due to lower than expected test velocity. Completion of SIT Functional Testing (Other Participants) could be delayed. Programme-wide scenario re-planning underway

| ID | WBS | Task | Type | Duration | Start | Finish | Predecessors | Complete | Remaining | Baseline start | Baseline finish | Baseline duration | Baseline 1 start | Baseline 1 finish | Total slack | Free slack | Responsible | Involved | Update Version | MHHS Resource Name | MHHS Programme Phase | Task Status | Sched Status | RAG | Artefact ID | Milestone ID | Text29 | Tier | Text3 |
| --- | --- | --- | --- | --- | --- | --- | --- | --- | --- | --- | --- | --- | --- | --- | --- | --- | --- | --- | --- | --- | --- | --- | --- | --- | --- | --- | --- | --- | --- |
| 1090 | 1.4.2.4.1.4 | **SIT Functional Testing Test Completion Report (Other Participants)** |  | 25d | 2025-03-17 | 2025-04-18 |  |  |  | 2025-03-17 | 2025-04-18 | 25d | 2025-03-17 | 2025-04-18 | 5d |  | N/A | N/A | 5.0 | N/A | Systems Integration Testing (SIT) |  |  |  |  |  |  |  |  |
| 1091 | 1.4.2.4.1.4.1 | Develop document |  | 15d | 2025-03-17 | 2025-04-04 | 1088FF |  |  | 2025-03-17 | 2025-04-04 | 15d | 2025-03-17 | 2025-04-04 | 10d | 5d | SI Test |  | 5.0 | Roger Robar | Systems Integration Testing (SIT) | 221.33 | Green | GREEN |  |  |  |  |  |
| 1092 | 1.4.2.4.1.4.2 | Review & agree document |  | 5d | 2025-04-14 | 2025-04-18 | 1091, 1089FF |  |  | 2025-04-14 | 2025-04-18 | 5d | 2025-04-14 | 2025-04-18 | 5d | 0d | SI Test | PP,IPA | 5.0 | Roger Robar | Systems Integration Testing (SIT) | 249.33 | Green | GREEN |  |  |  |  |  |
| 1093 | 1.4.2.4.1.5 | SIT Functional Testing Test Completion Report (Other Participants) Approved | milestone | 0d | 2025-04-25 | 2025-04-25 | 1092FF+5d |  |  | 2025-04-25 | 2025-04-25 | 0d | 2025-04-25 | 2025-04-25 | 5d | 0d | SI Test | PP | 5.0 | Roger Robar | Systems Integration Testing (SIT) | 260.71 | Green | AMBER | MHHS-ART072 | T3-TE-0055 | SITAG | T3 |  |
| 1094 | 1.4.2.4.2 | **SIT Migration Testing (Other Participants)** |  | 224d | 2024-06-18 A | 2025-04-25 |  | 12% | 198.15d | 2024-06-10 | 2025-04-25 | 230d | 2024-06-10 | 2025-04-25 | 5d |  | N/A | N/A | 5.0 | N/A | Systems Integration Testing (SIT) |  |  |  |  |  |  |  |  |
| 1095 | 1.4.2.4.2.1 | SIT Migration Testing Execution (Other Participants) |  | 209d | 2024-06-18 A | 2025-04-04 | 1042SS | 13% | 182d | 2024-06-10 | 2025-04-04 | 215d | 2024-06-10 | 2025-04-04 | 5d | 0d | SI Test | PP | 5.0 | Roger Robar | Systems Integration Testing (SIT) |  | Green | GREEN |  |  |  |  | D24E - Migration Test Completion Report |
| 1096 | 1.4.2.4.2.2 | SIT Migration Testing End (Other Participants) (incl. confirmation that PPs have submitted their Test Completion Reports to Programme for assurance) | milestone | 0d | 2025-04-04 | 2025-04-04 | 1095FF |  |  | 2025-04-04 | 2025-04-04 | 0d | 2025-04-04 | 2025-04-04 | 5d | 0d | SI Test | PP | 5.0 | Roger Robar | Systems Integration Testing (SIT) | 239.71 | Green | AMBER | MHHS-ART076 | T3-TE-0051 | SITAG | T3 |  |
| 1097 | 1.4.2.4.2.3 | Assurance of PPs Test Completion Reports |  | 5d | 2025-04-14 | 2025-04-18 | 1096FS+5d |  |  | 2025-04-14 | 2025-04-18 | 5d | 2025-04-14 | 2025-04-18 | 5d | 0d | SI Test | PP | 5.0 | Roger Robar | Systems Integration Testing (SIT) | 249.33 | Green | GREEN |  |  |  |  |  |
| 1098 | 1.4.2.4.2.4 | **SIT Migration Testing Test Completion Report (Other Participants)** |  | 25d | 2025-03-17 | 2025-04-18 |  |  |  | 2025-03-17 | 2025-04-18 | 25d | 2025-03-17 | 2025-04-18 | 5d |  | N/A | N/A | 5.0 | N/A | Systems Integration Testing (SIT) |  |  |  |  |  |  |  |  |
| 1099 | 1.4.2.4.2.4.1 | Develop document |  | 15d | 2025-03-17 | 2025-04-04 | 1096FF |  |  | 2025-03-17 | 2025-04-04 | 15d | 2025-03-17 | 2025-04-04 | 10d | 5d | SI Test |  | 5.0 | Roger Robar | Systems Integration Testing (SIT) | 221.33 | Green | GREEN |  |  |  |  |  |
| 1100 | 1.4.2.4.2.4.2 | Review & agree document |  | 5d | 2025-04-14 | 2025-04-18 | 1099, 1097FF |  |  | 2025-04-14 | 2025-04-18 | 5d | 2025-04-14 | 2025-04-18 | 5d | 0d | SI Test | PP,IPA | 5.0 | Roger Robar | Systems Integration Testing (SIT) | 249.33 | Green | GREEN |  |  |  |  |  |
| 1101 | 1.4.2.4.2.5 | SIT Migration Testing Test Completion Report (Other Participants) Approved | milestone | 0d | 2025-04-25 | 2025-04-25 | 1100FF+5d |  |  | 2025-04-25 | 2025-04-25 | 0d | 2025-04-25 | 2025-04-25 | 5d | 0d | SI Test | PP | 5.0 | Roger Robar | Systems Integration Testing (SIT) | 260.71 | Green | AMBER | MHHS-ART076 | T3-TE-0056 | SITAG | T3 |  |
| 1102 | 1.4.2.4.3 | **SIT Non-Functional Testing (Other Participants)** |  | 169d | 2024-09-03 | 2025-04-25 |  |  |  | 2024-09-02 | 2025-04-25 | 170d | 2024-09-02 | 2025-04-25 | 5d |  | N/A | N/A | 5.0 | N/A | Systems Integration Testing (SIT) |  |  |  |  |  |  |  |  |
| 1103 | 1.4.2.4.3.1 | SIT Non-Functional Testing Execution (Other Participants) |  | 154d | 2024-09-03 | 2025-04-04 | 1053SS |  |  | 2024-09-02 | 2025-04-04 | 155d | 2024-09-02 | 2025-04-04 | 5d | 0d | SI Test | PP | 5.0 | Roger Robar | Systems Integration Testing (SIT) | 26.33 | Green | GREEN |  |  |  |  | D24D - NF Test Completion Report |
| 1104 | 1.4.2.4.3.2 | SIT Non-Functional Testing End (Other Participants) (incl. confirmation that PPs have submitted their Test Completion Reports to Programme for assurance) | milestone | 0d | 2025-04-04 | 2025-04-04 | 1103FF |  |  | 2025-04-04 | 2025-04-04 | 0d | 2025-04-04 | 2025-04-04 | 5d | 0d | SI Test | PP | 5.0 | Roger Robar | Systems Integration Testing (SIT) | 239.71 | Green | AMBER | MHHS-ART079 | T3-TE-0053 | SITAG | T3 |  |
| 1105 | 1.4.2.4.3.3 | Assurance of PPs Test Completion Reports |  | 5d | 2025-04-14 | 2025-04-18 | 1104FS+5d |  |  | 2025-04-14 | 2025-04-18 | 5d | 2025-04-14 | 2025-04-18 | 5d | 0d | SI Test | PP | 5.0 | Roger Robar | Systems Integration Testing (SIT) | 249.33 | Green | GREEN |  |  |  |  |  |
| 1106 | 1.4.2.4.3.4 | **SIT Non-Functional Testing Test Completion Report (Other Participants)** |  | 25d | 2025-03-17 | 2025-04-18 |  |  |  | 2025-03-17 | 2025-04-18 | 25d | 2025-03-17 | 2025-04-18 | 5d |  | N/A | N/A | 5.0 | N/A | Systems Integration Testing (SIT) |  |  |  |  |  |  |  |  |
| 1107 | 1.4.2.4.3.4.1 | Develop document |  | 15d | 2025-03-17 | 2025-04-04 | 1104FF |  |  | 2025-03-17 | 2025-04-04 | 15d | 2025-03-17 | 2025-04-04 | 10d | 5d | SI Test |  | 5.0 | Roger Robar | Systems Integration Testing (SIT) | 221.33 | Green | GREEN |  |  |  |  |  |
| 1108 | 1.4.2.4.3.4.2 | Review & agree document |  | 5d | 2025-04-14 | 2025-04-18 | 1107, 1105FF |  |  | 2025-04-14 | 2025-04-18 | 5d | 2025-04-14 | 2025-04-18 | 5d | 0d | SI Test | PP,IPA | 5.0 | Roger Robar | Systems Integration Testing (SIT) | 249.33 | Green | GREEN |  |  |  |  |  |
| 1109 | 1.4.2.4.3.5 | SIT Non-Functional Testing Test Completion Report (Other Participants) Approved | milestone | 0d | 2025-04-25 | 2025-04-25 | 1108FF+5d |  |  | 2025-04-25 | 2025-04-25 | 0d | 2025-04-25 | 2025-04-25 | 5d | 0d | SI Test | PP | 5.0 | Roger Robar | Systems Integration Testing (SIT) | 260.71 | Green | AMBER | MHHS-ART079 | T3-TE-0057 | SITAG | T3 |  |
| 1110 | 1.4.2.4.4 | **SIT Operational Testing (Other Participants)** |  | 144d | 2024-10-08 | 2025-04-25 |  |  |  | 2024-10-07 | 2025-04-25 | 145d | 2024-10-07 | 2025-04-25 | 5d |  | N/A | N/A | 5.0 | N/A | Systems Integration Testing (SIT) |  |  |  |  |  |  |  |  |
| 1111 | 1.4.2.4.4.1 | SIT Operational Testing Execution (Other Participants) |  | 129d | 2024-10-08 | 2025-04-04 | 1062SS |  |  | 2024-10-07 | 2025-04-04 | 130d | 2024-10-07 | 2025-04-04 | 5d | 0d | SI Test | PP | 5.0 | Roger Robar | Systems Integration Testing (SIT) | 61.33 | Green | GREEN |  |  |  |  | D24D - NF Test Completion Report |
| 1112 | 1.4.2.4.4.2 | SIT Operational Testing End (Other Participants) (incl. confirmation that PPs have submitted their Test Completion Reports to Programme for assurance) | milestone | 0d | 2025-04-04 | 2025-04-04 | 1111FF |  |  | 2025-04-04 | 2025-04-04 | 0d | 2025-04-04 | 2025-04-04 | 5d | 0d | SI Test | PP | 5.0 | Roger Robar | Systems Integration Testing (SIT) | 239.71 | Green | AMBER | MHHS-ART081 | T3-TE-0054 | SITAG | T3 |  |
| 1113 | 1.4.2.4.4.3 | Assurance of PPs Test Completion Reports |  | 10d | 2025-04-07 | 2025-04-18 | 1112 |  |  | 2025-04-14 | 2025-04-18 | 5d | 2025-04-14 | 2025-04-18 | 5d | 0d | SI Test | PP | 5.0 | Roger Robar | Systems Integration Testing (SIT) | 242.33 | Green | GREEN |  |  |  |  |  |

Notes:
- 1093: 6/8/24: Date at risk due to lower than expected test velocity. Completion of SIT Functional Testing (Other Participants) could be delayed. Programme-wide scenario re-planning underway
- 1096: 6/8/24: Date at risk due to lower than expected test velocity. Completion of SIT Migration Testing (Other Participants) could be delayed. Programme-wide scenario re-planning underway
- 1101: 6/8/24: Date at risk due to lower than expected test velocity. Completion of SIT Migration Testing (Other Participants) could be delayed. Programme-wide scenario re-planning underway
- 1104: 6/8/24: Date at risk due to lower than expected test velocity. Start of SIT Non-functional Testing (Other Participants) could be delayed. Programme-wide scenario re-planning underway
- 1109: 6/8/24: Date at risk due to lower than expected test velocity. Start of SIT Non-functional Testing (Other Participants) could be delayed. Programme-wide scenario re-planning underway
- 1112: 6/8/24: Date at risk due to lower than expected test velocity. Start of SIT Operational Testing (Other Participants) could be delayed. Programme-wide scenario re-planning underway

| ID | WBS | Task | Type | Duration | Start | Finish | Predecessors | Complete | Remaining | Baseline start | Baseline finish | Baseline duration | Baseline 1 start | Baseline 1 finish | Total slack | Free slack | Constraint | Baseline cost | Responsible | Involved | Update Version | MHHS Resource Name | MHHS Programme Phase | Task Status | Sched Status | RAG | Artefact ID | Action | Milestone ID | Text29 | Tier |
| --- | --- | --- | --- | --- | --- | --- | --- | --- | --- | --- | --- | --- | --- | --- | --- | --- | --- | --- | --- | --- | --- | --- | --- | --- | --- | --- | --- | --- | --- | --- | --- |
| 1114 | 1.4.2.4.4.4 | **SIT Operational Testing Test Completion Report (Other Participants)** |  | 25d | 2025-03-17 | 2025-04-18 |  |  |  | 2025-03-17 | 2025-04-18 | 25d | 2025-03-17 | 2025-04-18 | 5d |  |  |  | N/A | N/A | 5.0 | N/A | Systems Integration Testing (SIT) |  |  |  |  |  |  |  |  |
| 1115 | 1.4.2.4.4.4.1 | Develop document |  | 15d | 2025-03-17 | 2025-04-04 | 1112FF |  |  | 2025-03-17 | 2025-04-04 | 15d | 2025-03-17 | 2025-04-04 | 10d | 0d |  |  | SI Test |  | 5.0 | Roger Robar | Systems Integration Testing (SIT) | 221.33 | Green | GREEN |  |  |  |  |  |
| 1116 | 1.4.2.4.4.4.2 | Review & agree document |  | 5d | 2025-04-14 | 2025-04-18 | 1115, 1113FF |  |  | 2025-04-14 | 2025-04-18 | 5d | 2025-04-14 | 2025-04-18 | 5d | 0d |  |  | SI Test | PP,IPA | 5.0 | Roger Robar | Systems Integration Testing (SIT) | 249.33 | Green | GREEN |  |  |  |  |  |
| 1117 | 1.4.2.4.4.5 | SIT Operational Testing Test Completion Report (Other Participants) Approved | milestone | 0d | 2025-04-25 | 2025-04-25 | 1116FF+5d |  |  | 2025-04-25 | 2025-04-25 | 0d | 2025-04-25 | 2025-04-25 | 5d | 0d |  |  | SI Test | PP | 5.0 | Roger Robar | Systems Integration Testing (SIT) | 260.71 | Green | AMBER | MHHS-ART081 | 4/6 - sort out link. Remove fixed date from line 1119 | T3-TE-0058 | SITAG | T3 |
| 1118 | 1.4.2.4.5 | **SIT Other Participants Test Exit Report** |  | 20d | 2025-03-17 | 2025-04-11 |  |  |  | 2025-03-17 | 2025-04-11 | 20d | 2025-03-17 | 2025-04-11 | 11d |  |  |  | N/A | N/A | 5.0 | N/A | Systems Integration Testing (SIT) |  |  |  |  |  |  |  |  |
| 1119 | 1.4.2.4.5.1 | Develop document |  | 15d | 2025-03-17 | 2025-04-04 | 1115FF |  |  | 2025-03-17 | 2025-04-04 | 15d | 2025-03-17 | 2025-04-04 | 11d | 0d |  |  | SI Test |  | 5.0 | Roger Robar | Systems Integration Testing (SIT) | 221.33 | Green | GREEN |  |  |  |  |  |
| 1120 | 1.4.2.4.5.2 | Review & agree document |  | 5d | 2025-04-07 | 2025-04-11 | 1119 |  |  | 2025-04-07 | 2025-04-11 | 5d | 2025-04-07 | 2025-04-11 | 11d | 6d |  |  | SI Test | PP,IPA | 5.0 | Roger Robar | Systems Integration Testing (SIT) | 242.33 | Green | GREEN |  |  |  |  |  |
| 1121 | 1.4.2.4.6 | SIT - Other Participants Complete | milestone | 0d | 2025-04-25 | 2025-04-25 | 1120FS+4d, 1093, 1101, 1109, 1117 |  |  | 2025-04-25 | 2025-04-25 | 0d | 2025-04-21 | 2025-04-21 | 5d | 4d |  |  | SI Test | PP | 5.27 | Roger Robar | Systems Integration Testing (SIT) | 260.71 | Green | AMBER | MHHS-ART081 |  | T3-TE-0059 | SITAG | T3 |
| 1122 | 1.4.3 | **UIT Environment Preparation** |  | 700d | 2022-10-31 A | 2025-07-04 |  | 44% | 393.8d | 2022-10-31 | 2025-06-06 | 680d | 2022-10-31 | 2025-06-06 | 495d |  |  | -0 | N/A | N/A | 5.0 | N/A | Systems Integration Testing (SIT) |  |  |  |  |  |  |  |  |
| 1123 | 1.4.3.1 | **Test Artefact Development** |  | 361d | 2023-03-01 A | 2024-07-18 |  |  | 361d | 2023-03-01 | 2024-07-18 | 361d | 2023-03-01 | 2023-08-04 | 747d |  |  | -0 | N/A | N/A | 5.0 | N/A | Systems Integration Testing (SIT) |  |  |  |  |  |  |  |  |
| 1124 | 1.4.3.1.1 | **E2E Sandbox Guidance** |  | 361d | 2023-03-01 A | 2024-07-18 |  |  | 361d | 2023-03-01 | 2024-07-18 | 361d | 2023-03-01 | 2023-08-04 | 747d |  |  | -0 | N/A | N/A | 5.0 | N/A | Systems Integration Testing (SIT) |  |  |  |  |  |  |  |  |
| 1125 | 1.4.3.1.1.1 | Develop document |  | 83d | 2023-03-01 | 2023-06-23 |  |  |  | 2023-03-01 | 2023-06-23 | 83d | 2023-03-01 | 2023-06-23 | 995d | 0d | start no earlier than 2023-03-01 |  | SI Test |  | 5.0 | Stuart Scott | Systems Integration Testing (SIT) | -525.67 | Overdue Start | RED |  |  |  |  |  |
| 1126 | 1.4.3.1.1.2 | Artefact review (via SITAG) and updates |  | 25d | 2023-06-26 | 2023-07-28 | 1125 |  |  | 2023-06-26 | 2023-07-28 | 25d | 2023-06-26 | 2023-07-28 | 1000d |  |  |  | SI Test | PP,IPA | 5.0 | Stuart Scott | Systems Integration Testing (SIT) | -408.67 | Overdue Start | RED |  |  |  |  |  |
| 1127 | 1.4.3.1.1.3 | E2E Sandbox Guidance approved | milestone | 0d | 2024-07-18 A | 2024-07-18 A | 1126FF+5d | 100% |  | 2024-07-18 | 2024-07-18 | 0d | 2023-08-04 | 2023-08-04 |  |  | start no earlier than 2024-07-18 |  | SI Test | PP | 5.29 | Stuart Scott | Systems Integration Testing (SIT) |  | Complete | COMPLETE | MHHS-ART154 |  | T3-TE-0067 | QAG | T3 |
| 1128 | 1.4.3.1.2 | **E2E Sandbox Test Data Approach & Plan** |  | 93d | 2023-03-29 | 2023-08-04 |  |  |  | 2023-03-29 | 2023-08-04 | 93d | 2023-03-29 | 2023-08-04 | 995d |  |  |  | N/A | N/A | 5.0 | N/A | Systems Integration Testing (SIT) |  |  |  |  |  |  |  |  |
| 1129 | 1.4.3.1.2.1 | Develop document |  | 68d | 2023-03-29 | 2023-06-30 | 1125SS+20d |  |  | 2023-03-29 | 2023-06-30 | 68d | 2023-03-29 | 2023-06-30 | 995d | 0d |  |  | SI Test |  | 5.0 | Stuart Scott | Systems Integration Testing (SIT) | -497.67 | Overdue Start | RED |  |  |  |  |  |
| 1130 | 1.4.3.1.2.2 | Review, update & agree document internally |  | 25d | 2023-07-03 | 2023-08-04 | 1129 |  |  | 2023-07-03 | 2023-08-04 | 25d | 2023-07-03 | 2023-08-04 | 995d |  |  |  | SI Test | PP,IPA | 5.0 | Stuart Scott | Systems Integration Testing (SIT) | -401.67 | Overdue Start | RED |  |  |  |  |  |
| 1131 | 1.4.3.2 | **UIT Stub Specification and Delivery** |  | 190d | 2023-12-04 A | 2024-08-23 |  | 88% | 22d | 2023-12-04 | 2024-08-23 | 190d | 2023-10-27 | 2024-08-23 | 694d |  |  | -0 | N/A | N/A | 5.0 | N/A | Systems Integration Testing (SIT) |  |  |  |  |  |  |  |  |
| 1132 | 1.4.3.2.1 | **Qualification Test Stubs** |  | 190d | 2023-12-04 A | 2024-08-23 |  | 88% | 22d | 2023-12-04 | 2024-08-23 | 190d | 2023-10-27 | 2024-08-23 | 694d |  |  | -0 | N/A | N/A | 5.16 | N/A | Systems Integration Testing (SIT) |  |  |  |  |  |  |  |  |
| 1133 | 1.4.3.2.1.1 | Specify |  | 44d | 2023-12-04 A | 2024-02-01 A | 470FS+13d | 100% |  | 2023-12-04 | 2024-02-01 | 44d | 2023-10-27 | 2023-12-29 |  |  |  |  | SI DevOps | Qualification,SRO | 5.0 | Matthew Bray | Systems Integration Testing (SIT) |  | Complete | COMPLETE |  |  |  |  |  |
| 1134 | 1.4.3.2.1.2 | Build & Test |  | 141d | 2024-02-02 A | 2024-08-16 | 1133 | 88% | 17d | 2024-02-02 | 2024-08-16 | 141d | 2023-12-29 | 2024-05-24 | 694d | 0d |  |  | SI DevOps | Qualification,SRO | 5.23 | Matthew Bray | Systems Integration Testing (SIT) |  | Green | GREEN |  |  |  |  |  |
| 1135 | 1.4.3.2.1.3 | Prepare for release |  | 5d | 2024-08-19 | 2024-08-23 | 1134 |  |  | 2024-08-19 | 2024-08-23 | 5d | 2024-07-29 | 2024-08-23 | 694d | 0d |  |  | SI DevOps | Qualification,SRO | 5.0 | Matthew Bray | Systems Integration Testing (SIT) | 11.33 | Green | GREEN |  |  |  |  |  |
| 1136 | 1.4.3.2.1.4 | Non-SIT LDSO Test Harness Released | milestone | 0d | 2024-08-23 | 2024-08-23 | 1135 |  |  | 2024-08-23 | 2024-08-23 | 0d | 2024-08-23 | 2024-08-23 | 694d | 0d |  |  | SI DevOps | Qualification,SRO | 5.27 | Matthew Bray | Systems Integration Testing (SIT) | 15.71 | Green | RED | MHHS-ART080 |  | T3-TE-0035 | QAG | T3 |
| 1137 | 1.4.3.3 | **Environments (UIT)** |  | 700d | 2022-10-31 A | 2025-07-04 |  | 44% | 389.54d | 2022-10-31 | 2025-06-06 | 680d | 2022-10-31 | 2025-06-06 | 495d |  |  | -0 | N/A | N/A | 5.0 | N/A | Systems Integration Testing (SIT) |  |  |  |  |  |  |  |  |
| 1138 | 1.4.3.3.1 | **Central Party (Avenade) Environments (UIT)** |  | 488d | 2022-11-16 A | 2024-09-27 |  | 97% | 14.82d | 2022-11-16 | 2024-10-04 | 493d | 2022-11-16 | 2024-10-04 | 695d |  |  | -0 | N/A | N/A | 5.28 | N/A | Systems Integration Testing (SIT) |  |  |  |  |  |  |  |  |
| 1139 | 1.4.3.3.1.1 | Central Party (Avendae) environment preparation (incl. security certificates and security compliance) |  | 447d | 2022-11-16 A | 2024-08-01 A | 466 | 100% |  | 2022-11-16 | 2024-08-23 | 463d | 2022-11-16 | 2024-08-23 |  |  |  |  | PP | SI Test | 5.28 | Simon Berry | Systems Integration Testing (SIT) |  | Complete | COMPLETE |  |  |  |  |  |
| 1140 | 1.4.3.3.1.2 | Submit self-declaration of environment preparation complete (incl. security certificates and security compliance) to Programme for assurance |  | 447d | 2022-11-16 A | 2024-08-01 A | 1139SS | 100% |  | 2022-11-16 | 2024-08-23 | 463d | 2022-11-16 | 2024-08-23 |  |  |  |  | PP | SI Test | 5.28 | Simon Berry | Systems Integration Testing (SIT) |  | Complete | COMPLETE |  |  |  |  |  |
| 1141 | 1.4.3.3.1.3 | Central Party (Avenade) UIT environment connectivity proving |  | 25d | 2024-08-26 | 2024-09-27 | 1153 |  |  | 2024-08-26 | 2024-09-27 | 25d | 2024-08-27 | 2024-09-20 | 694d | 0d |  |  | PP | SI Test | 5.28 | Simon Berry | Systems Integration Testing (SIT) | 18.33 | Green | GREEN |  |  |  |  |  |
| 1142 | 1.4.3.3.1.4 | Deployment of MHHS solution code to UIT environments |  | 2d | 2024-07-29 | 2024-07-30 |  |  |  | 2024-09-09 | 2024-09-20 | 10d | 2024-09-09 | 2024-09-20 | 737d | 0d | start no earlier than 2024-07-29 |  | PP | SI Test | 5.28 | Simon Berry | Systems Integration Testing (SIT) | -9.67 | Overdue Start | GREEN |  |  |  |  |  |
| 1143 | 1.4.3.3.1.5 | Central Party (Avenade) UIT environment Regression Testing |  | 1d | 2024-07-31 | 2024-07-31 | 1142 |  |  | 2024-09-23 | 2024-10-04 | 10d | 2024-09-23 | 2024-10-04 | 737d |  |  |  | PP | SI Test | 5.28 | Simon Berry | Systems Integration Testing (SIT) | -7.67 | Overdue Start | GREEN |  |  |  |  |  |

Notes:
- 1117: 6/8/24: Date at risk due to lower than expected test velocity. Start of SIT Operational Testing (Other Participants) could be delayed. Programme-wide scenario re-planning underway
- 1121: 6/8/24: Date at risk due to lower than expected test velocity. Completion of SIT- Other Particiapnts Test Exit report could be delayed. Programme-wide scenario re-planning underway
- 1127: 26/6: Baseline date change approved at QAG on 20/6/24. 11/7/24: Date change approved at QAG on 20/6/24 from 4/08/24 to 18/7/24
- 1134: 30/4: Removed previous testing phases as were no longer relevant and extended task to push out to align with existing dates
- 1136: 5/8/24: Date will be missed because Sims & Ems are blocked from completing connectivity and regression testing activities due to message functionality being disabled in the current UIT environment version (IR7.3), only being available from 2/9. LDP / Notes (2): 5/8/24: working towards getting the milestone date changed to later in September, and seeking approval from QAG on 22/8.
- 1138: 8/7/24: Updated to reflect Avende are the only PP

| ID | WBS | Task | Type | Duration | Start | Finish | Predecessors | Complete | Remaining | Baseline start | Baseline finish | Baseline duration | Baseline 1 start | Baseline 1 finish | Total slack | Free slack | Constraint | Responsible | Involved | Update Version | MHHS Resource Name | MHHS Programme Phase | Task Status | Sched Status | RAG | Milestone ID | Text29 | Tier | Artefact ID |
| --- | --- | --- | --- | --- | --- | --- | --- | --- | --- | --- | --- | --- | --- | --- | --- | --- | --- | --- | --- | --- | --- | --- | --- | --- | --- | --- | --- | --- | --- |
| 1144 | 1.4.3.3.2 | **E2E Sandbox Participants (UIT)** |  | 680d | 2022-10-31 | 2025-06-06 |  |  |  | 2022-10-31 | 2025-06-06 | 680d | 2022-10-31 | 2025-06-06 | 0d |  |  | N/A | N/A | 5.0 | N/A | Systems Integration Testing (SIT) |  |  |  |  |  |  |  |
| 1145 | 1.4.3.3.2.1 | E2E Sandbox Participants environment preparation (incl. security certificates and security compliance) |  | 660d | 2022-10-31 | 2025-05-09 |  |  |  | 2022-10-31 | 2025-05-09 | 660d | 2022-10-31 | 2025-05-09 | 0d |  | must finish on 2025-05-09 | PP | SI Test | 5.0 | Simon Berry | Systems Integration Testing (SIT) | -646.67 | Overdue Start | GREEN |  |  |  |  |
| 1146 | 1.4.3.3.2.2 | Submit self-declaration of environment preparation complete (incl. security certificates and security compliance) to Programme for assurance |  | 660d | 2022-10-31 | 2025-05-09 |  |  |  | 2022-10-31 | 2025-05-09 | 660d | 2022-10-31 | 2025-05-09 | 515d | 0d |  | PP | SI Test | 5.0 | Simon Berry | Systems Integration Testing (SIT) | -646.67 | Overdue Start | GREEN |  |  |  |  |
| 1147 | 1.4.3.3.2.3 | E2E Sandbox Participants UIT environment connectivity proving |  | 20d | 2025-05-12 | 2025-06-06 | 1146 |  |  | 2025-05-12 | 2025-06-06 | 20d | 2025-05-12 | 2025-06-06 | 515d | 0d |  | PP | SI Test | 5.0 | Simon Berry | Systems Integration Testing (SIT) | 277.33 | Green | GREEN |  |  |  |  |
| 1148 | 1.4.3.3.2.4 | Deployment of MHHS solution code to UIT environments |  | 10d | 2025-05-26 | 2025-06-06 | 1147FF |  |  | 2025-05-26 | 2025-06-06 | 10d | 2025-05-26 | 2025-06-06 | 515d |  |  | PP | SI Test | 5.0 | Simon Berry | Systems Integration Testing (SIT) | 291.33 | Green | GREEN |  |  |  |  |
| 1149 | 1.4.3.3.2.5 | Coordinate E2E Sandbox Participants' UIT environment preparation (for E2E Sandbox Testing Start) |  | 463d | 2022-10-31 | 2024-08-07 | 1145SS |  |  | 2022-10-31 | 2024-08-07 | 463d | 2022-10-31 | 2024-08-07 | 732d |  |  | SI Test | PP | 5.0 | Simon Berry | Systems Integration Testing (SIT) | -646.67 | Overdue Start | RED |  |  |  |  |
| 1150 | 1.4.3.3.3 | **SI Environments (UIT)** |  | 688d | 2022-11-16 A | 2025-07-04 |  | 69% | 215.33d | 2022-10-31 | 2025-06-06 | 680d | 2022-10-31 | 2025-06-06 | 495d |  |  | N/A | N/A | 5.0 | N/A | Systems Integration Testing (SIT) |  |  |  |  |  |  |  |
| 1151 | 1.4.3.3.3.1 | Coordinate Central Parties' UIT environment preparation |  | 447d | 2022-11-16 A | 2024-08-01 A | 1139SS | 100% |  | 2022-11-16 | 2024-08-23 | 463d | 2022-11-16 | 2024-08-23 |  |  |  | SI Test | PP | 5.0 | Simon Berry | Systems Integration Testing (SIT) |  | Complete | COMPLETE |  |  |  |  |
| 1152 | 1.4.3.3.3.2 | Assure Central Parties' self-declaration of environment preparation complete (incl. security certificates and security compliance) |  | 463d | 2022-11-16 A | 2024-08-23 | 1140SS | 97% | 12d | 2022-11-16 | 2024-08-23 | 463d | 2022-11-16 | 2024-08-23 | 720d |  |  | SI Test | PP | 5.0 | Simon Berry | Systems Integration Testing (SIT) |  | Green | GREEN |  |  |  |  |
| 1153 | 1.4.3.3.3.3 | Central Parties' UIT environments ready to start connectivity proving (incl. certificates and security compliance) | milestone | 0d | 2024-08-23 | 2024-08-23 | 1136 |  |  | 2024-08-23 | 2024-08-23 | 0d | 2024-08-23 | 2024-08-23 | 694d | 0d |  | SI Test | PP | 5.0 | Simon Berry | Systems Integration Testing (SIT) | 15.71 | Green | GREEN | T3-TE-0044 | QAG | T3 |  |
| 1154 | 1.4.3.3.3.4 | Coordinate Central Parties' UIT environment connectivity proving |  | 26d | 2024-08-26 | 2024-09-30 | 1141SS |  |  | 2025-05-12 | 2025-06-05 | 19d | 2025-05-12 | 2025-06-05 | 694d |  |  | SI Test | PP | 5.0 | Simon Berry | Systems Integration Testing (SIT) | 18.33 | Green | GREEN |  |  |  |  |
| 1155 | 1.4.3.3.3.5 | Coordinate deployment of MHHS solution code to Central Parties' UIT environments |  | 2d | 2024-07-29 A | 2024-07-30 A | 1142SS | 100% |  | 2025-05-26 | 2025-06-06 | 10d | 2025-05-26 | 2025-06-06 |  |  |  | SI Test | PP | 5.0 | Simon Berry | Systems Integration Testing (SIT) |  | Complete | COMPLETE |  |  |  |  |
| 1156 | 1.4.3.3.3.6 | Coordinate Central Parties' UIT environment Regression Testing |  | 1d | 2024-07-31 | 2024-07-31 | 1155 |  |  | 2024-09-23 | 2024-10-04 | 10d | 2024-09-23 | 2024-10-04 | 737d |  |  | SI Test | PP | 5.0 | Simon Berry | Systems Integration Testing (SIT) | -7.67 | Overdue Start | GREEN |  |  |  |  |
| 1157 | 1.4.3.3.3.7 | **Environments (Non-SIT LDSO)** |  | 43d | 2024-08-01 | 2024-09-30 |  |  |  | 2024-08-06 | 2025-01-13 | 115d | 2024-08-06 | 2025-01-13 | 694d |  |  | N/A | N/A | 5.28 | N/A | Qualification |  |  |  |  |  |  |  |
| 1158 | 1.4.3.3.3.7.1 | Coordinate Qualification Participants' environment preparation |  | 17d | 2024-08-01 | 2024-08-23 |  |  |  | 2024-08-06 | 2024-10-28 | 60d | 2024-08-06 | 2024-10-28 | 720d |  | start no earlier than 2024-08-01 | SI Test | Code Bodies, PP | 5.28 | Simon Berry | Qualification | -6.67 | Overdue Start | GREEN |  |  |  |  |
| 1159 | 1.4.3.3.3.7.2 | Coordinate deployment of MHHS solution code to Qualification Participants' UIT environments |  | 17d | 2024-08-01 | 2024-08-23 |  |  |  | 2024-10-15 | 2024-10-28 | 10d | 2024-10-15 | 2024-10-28 | 694d | 0d | start no earlier than 2024-08-01 | SI Test | Code Bodies, PP | 5.28 | Simon Berry | Qualification | -6.67 | Overdue Start | GREEN |  |  |  |  |
| 1160 | 1.4.3.3.3.7.3 | Qualification Testing Tranche 1 Participants' UIT environments ready to start connectivity proving (incl. certificates and security compliance) | milestone | 0d | 2024-08-26 | 2024-08-26 | 1159FS+1d |  |  | 2024-11-04 | 2024-11-04 | 0d | 2024-11-04 | 2024-11-04 | 694d | 0d |  | SI Test | Code Bodies, PP, IPA | 5.28 | Simon Berry | Qualification | 18.71 | Green | GREEN | T3-QU-0017 | QAG | T3 | MHHS-ART073 |
| 1161 | 1.4.3.3.3.7.4 | **Coordinate Qualification Participants' connectivity proving (Non-SIT LDSO)** |  | 25d | 2024-08-27 | 2024-09-30 |  |  |  | 2024-11-05 | 2025-01-13 | 50d | 2024-11-05 | 2025-01-13 | 694d |  |  | N/A | N/A | 5.0 | N/A | Qualification |  |  |  |  |  |  |  |
| 1162 | 1.4.3.3.3.7.4.1 | Assurance of Qualification Participants' connectivity proving |  | 25d | 2024-08-27 | 2024-09-30 | 1160 |  |  | 2024-11-05 | 2025-01-13 | 50d | 2024-11-05 | 2025-01-13 | 694d |  |  | SI Test | Code Bodies, PP | 5.0 |  | Qualification | 19.33 | Green | GREEN |  |  |  |  |
| 1163 | 1.4.3.3.3.8 | **Environments (S&A) Wave 1** |  | 41d | 2024-08-01 | 2024-09-26 |  |  |  | 2024-08-06 | 2025-01-13 | 115d | 2024-08-06 | 2025-01-13 |  |  |  | N/A | N/A | 5.28 | N/A | Qualification |  |  |  |  |  |  |  |
| 1164 | 1.4.3.3.3.8.1 | Coordinate Qualification Participants' environment preparation |  | 20d | 2024-09-02 | 2024-09-27 |  |  |  | 2024-08-06 | 2024-10-28 | 60d | 2024-08-06 | 2024-10-28 | 695d |  | start no earlier than 2024-09-02 | SI Test | Code Bodies, PP | 5.28 | Simon Berry | Qualification | 25.33 | Green | GREEN |  |  |  |  |
| 1165 | 1.4.3.3.3.8.2 | Coordinate deployment of MHHS solution code to Qualification Participants' UIT environments |  | 10d | 2024-10-21 | 2024-11-01 |  |  |  | 2024-10-15 | 2024-10-28 | 10d | 2024-10-15 | 2024-10-28 | 625d | 0d | start no earlier than 2024-10-21 | SI Test | Code Bodies, PP | 5.28 | Simon Berry | Qualification | 74.33 | yellow | RED |  |  |  |  |
| 1166 | 1.4.3.3.3.8.3 | Qualification Testing Wave 1 Participants' UIT environments ready to start connectivity proving (incl. certificates and security compliance) |  | 19d | 2024-11-05 | 2024-11-29 | 1165FS+1d |  |  | 2024-11-04 | 2024-11-04 | 0d | 2024-11-04 | 2024-11-04 | 625d | 0d |  | SI Test | Code Bodies, PP, IPA | 5.28 | Simon Berry | Qualification | 89.33 | Red | RED | New? | QAG | T3 | MHHS-ART073 |
| 1167 | 1.4.3.3.3.8.4 | **Coordinate Qualification Participants' connectivity proving (S&A)** |  | 25d | 2024-12-02 | 2025-01-03 |  |  |  | 2024-11-05 | 2025-01-13 | 50d | 2024-11-05 | 2025-01-13 | 625d |  |  | N/A | N/A | 5.0 | N/A | Qualification |  |  |  |  |  |  |  |
| 1168 | 1.4.3.3.3.8.4.1 | Assurance of Qualification Participants' connectivity proving |  | 25d | 2024-12-02 | 2025-01-03 | 1166 |  |  | 2024-11-05 | 2025-01-13 | 50d | 2024-11-05 | 2025-01-13 | 625d |  |  | SI Test | Code Bodies, PP | 5.0 |  | Qualification | 116.33 | Green | GREEN |  |  |  |  |

Notes:
- 1157: 8/7/24: Updated to reflect the separation between non-sit and s and a and the 4 waves for s and a
- 1158: 8/7/24: Updated to reflect the separation between non-sit and s and a and the 4 waves for s and a
- 1159: 8/7/24: Updated to reflect the separation between non-sit and s and a and the 4 waves for s and a
- 1160: 8/7/24: Updated to reflect the separation between non-sit and s and a and the 4 waves for s and a
- 1163: 8/7/24: Updated to reflect the separation between non-sit and s and a and the 4 waves for s and a
- 1164: 8/7/24: Updated to reflect the separation between non-sit and s and a and the 4 waves for s and a
- 1165: 8/7/24: Updated to reflect the separation between non-sit and s and a and the 4 waves for s and a
- 1166: 8/7/24: Updated to reflect the separation between non-sit and s and a and the 4 waves for s and a

| ID | WBS | Task | Type | Duration | Start | Finish | Predecessors | Baseline start | Baseline finish | Baseline duration | Baseline 1 start | Baseline 1 finish | Total slack | Free slack | Constraint | Baseline cost | Responsible | Involved | Update Version | MHHS Resource Name | MHHS Programme Phase | Task Status | Sched Status | RAG | Artefact ID | Milestone ID | Text29 | Tier |
| --- | --- | --- | --- | --- | --- | --- | --- | --- | --- | --- | --- | --- | --- | --- | --- | --- | --- | --- | --- | --- | --- | --- | --- | --- | --- | --- | --- | --- |
| 1169 | 1.4.3.3.3.9 | **Environments (S&A) Wave 2** |  | 139d | 2024-08-27 | 2025-03-07 |  | 2024-08-06 | 2025-01-13 | 115d | 2024-08-06 | 2025-01-13 | 0d |  |  |  | N/A | N/A | 5.28 | N/A | Qualification |  |  |  |  |  |  |  |
| 1170 | 1.4.3.3.3.9.1 | Coordinate Qualification Participants' environment preparation |  | 20d | 2024-11-18 | 2024-12-13 |  | 2024-08-06 | 2024-10-28 | 60d | 2024-08-06 | 2024-10-28 | 640d |  | start no earlier than 2024-11-18 |  | SI Test | Code Bodies, PP | 5.28 | Simon Berry | Qualification | 102.33 | Red | RED |  |  |  |  |
| 1171 | 1.4.3.3.3.9.2 | Coordinate deployment of MHHS solution code to Qualification Participants' UIT environments |  | 20d | 2024-12-16 | 2025-01-10 |  | 2024-10-15 | 2024-10-28 | 10d | 2024-10-15 | 2024-10-28 | 580d | 0d | start no earlier than 2024-12-16 |  | SI Test | Code Bodies, PP | 5.28 | Simon Berry | Qualification | 130.33 | Red | RED |  |  |  |  |
| 1172 | 1.4.3.3.3.9.3 | Qualification Testing Wave 2 Participants' UIT environments ready to start connectivity proving (incl. certificates and security compliance) |  | 15d | 2025-01-13 | 2025-01-31 | 1171 | 2024-11-04 | 2024-11-04 | 0d | 2024-11-04 | 2024-11-04 | 580d | 0d |  |  | SI Test | Code Bodies, PP, IPA | 5.28 | Simon Berry | Qualification | 158.33 | Red | RED | MHHS-ART073 | New? | QAG | T3 |
| 1173 | 1.4.3.3.3.9.4 | **Coordinate Qualification Participants' connectivity proving (S&A)** |  | 25d | 2024-08-27 | 2024-09-30 |  | 2024-11-05 | 2025-01-13 | 50d | 2024-11-05 | 2025-01-13 |  |  |  |  | N/A | N/A | 5.0 | N/A | Qualification |  |  |  |  |  |  |  |
| 1174 | 1.4.3.3.3.9.4.1 | Assurance of Qualification Participants' connectivity proving |  | 25d | 2025-02-03 | 2025-03-07 | 1172 | 2024-11-05 | 2025-01-13 | 50d | 2024-11-05 | 2025-01-13 | 580d |  |  |  | SI Test | Code Bodies, PP | 5.0 |  | Qualification | 179.33 | Red | RED |  |  |  |  |
| 1175 | 1.4.3.3.3.10 | **Environments (S&A) Wave 3** |  | 80d | 2025-03-17 | 2025-07-04 |  | 2024-08-06 | 2025-01-13 | 115d | 2024-08-06 | 2025-01-13 | 495d |  |  |  | N/A | N/A | 5.28 | N/A | Qualification |  |  |  |  |  |  |  |
| 1176 | 1.4.3.3.3.10.1 | Coordinate Qualification Participants' environment preparation |  | 30d | 2025-03-17 | 2025-04-25 |  | 2024-08-06 | 2024-10-28 | 60d | 2024-08-06 | 2024-10-28 | 545d |  | start no earlier than 2025-03-17 |  | SI Test | Code Bodies, PP | 5.28 | Simon Berry | Qualification | 221.33 | Red | RED |  |  |  |  |
| 1177 | 1.4.3.3.3.10.2 | Coordinate deployment of MHHS solution code to Qualification Participants' UIT environments |  | 10d | 2025-04-28 | 2025-05-09 |  | 2024-10-15 | 2024-10-28 | 10d | 2024-10-15 | 2024-10-28 | 495d | 0d | start no earlier than 2025-04-28 |  | SI Test | Code Bodies, PP | 5.28 | Simon Berry | Qualification | 263.33 | Red | RED |  |  |  |  |
| 1178 | 1.4.3.3.3.10.3 | Qualification Testing Wave 3 Participants' UIT environments ready to start connectivity proving (incl. certificates and security compliance) |  | 14d | 2025-05-13 | 2025-05-30 | 1177FS+1d | 2024-11-04 | 2024-11-04 | 0d | 2024-11-04 | 2024-11-04 | 495d | 0d |  |  | SI Test | Code Bodies, PP, IPA | 5.28 | Simon Berry | Qualification | 278.33 | Red | RED | MHHS-ART073 | New? | QAG | T3 |
| 1179 | 1.4.3.3.3.10.4 | **Coordinate Qualification Participants' connectivity proving (S&A)** |  | 25d | 2025-06-02 | 2025-07-04 |  | 2024-11-05 | 2025-01-13 | 50d | 2024-11-05 | 2025-01-13 | 495d |  |  |  | N/A | N/A | 5.0 | N/A | Qualification |  |  |  |  |  |  |  |
| 1180 | 1.4.3.3.3.10.4.1 | Assurance of Qualification Participants' connectivity proving |  | 25d | 2025-06-02 | 2025-07-04 | 1178 | 2024-11-05 | 2025-01-13 | 50d | 2024-11-05 | 2025-01-13 | 495d |  |  |  | SI Test | Code Bodies, PP | 5.0 |  | Qualification | 298.33 | Red | RED |  |  |  |  |
| 1181 | 1.4.3.3.3.11 | **Environments (S&A) Wave 4** |  | 80d | 2025-03-17 | 2025-07-04 |  | 2024-08-06 | 2025-01-13 | 115d | 2024-08-06 | 2025-01-13 | 55d |  |  |  | N/A | N/A | 5.28 | N/A | Qualification |  |  |  |  |  |  |  |
| 1182 | 1.4.3.3.3.11.1 | Coordinate Qualification Participants' environment preparation |  | 30d | 2025-03-17 | 2025-04-25 |  | 2024-08-06 | 2024-10-28 | 60d | 2024-08-06 | 2024-10-28 | 545d |  | finish no earlier than 2025-04-25 |  | SI Test | Code Bodies, PP | 5.28 | Simon Berry | Qualification | 221.33 | Red | RED |  |  |  |  |
| 1183 | 1.4.3.3.3.11.2 | Coordinate deployment of MHHS solution code to Qualification Participants' UIT environments |  | 10d | 2025-04-28 | 2025-05-09 |  | 2024-10-15 | 2024-10-28 | 10d | 2024-10-15 | 2024-10-28 | 495d | 0d | finish no earlier than 2025-05-09 |  | SI Test | Code Bodies, PP | 5.28 | Simon Berry | Qualification | 263.33 | Red | RED |  |  |  |  |
| 1184 | 1.4.3.3.3.11.3 | Qualification Testing Wave 4 Participants' UIT environments ready to start connectivity proving (incl. certificates and security compliance) |  | 14d | 2025-05-13 | 2025-05-30 | 1183FS+1d | 2024-11-04 | 2024-11-04 | 0d | 2024-11-04 | 2024-11-04 | 495d | 0d | finish no earlier than 2025-05-30 |  | SI Test | Code Bodies, PP, IPA | 5.28 | Simon Berry | Qualification | 278.33 | Red | RED | MHHS-ART073 | New? | QAG | T3 |
| 1185 | 1.4.3.3.3.11.4 | **Coordinate Qualification Participants' connectivity proving (S&A)** |  | 25d | 2025-06-02 | 2025-07-04 |  | 2024-11-05 | 2025-01-13 | 50d | 2024-11-05 | 2025-01-13 |  |  |  |  | N/A | N/A | 5.0 | N/A | Qualification |  |  |  |  |  |  |  |
| 1186 | 1.4.3.3.3.11.4.1 | Assurance of Qualification Participants' connectivity proving |  | 25d | 2025-06-02 | 2025-07-04 | 1184 | 2024-11-05 | 2025-01-13 | 50d | 2024-11-05 | 2025-01-13 | 495d |  | start no earlier than 2025-06-02 |  | SI Test | Code Bodies, PP | 5.0 |  | Qualification | 298.33 | Red | RED |  |  |  |  |
| 1187 | 1.4.3.4 | **Test Data** |  | 30d | 2024-08-26 | 2024-10-04 |  | 2024-08-26 | 2024-10-04 | 30d | 2024-08-26 | 2024-10-04 | 670d |  |  | -0 | N/A | N/A | 5.0 | N/A | Systems Integration Testing (SIT) |  |  |  |  |  |  |  |
| 1188 | 1.4.3.4.1 | **Central Parties (for E2E Sandbox & Qualification)** |  | 30d | 2024-08-26 | 2024-10-04 |  | 2024-08-26 | 2024-10-04 | 30d | 2024-08-26 | 2024-10-04 | 670d |  |  |  | N/A | N/A | 5.0 | N/A | Systems Integration Testing (SIT) |  |  |  |  |  |  |  |
| 1189 | 1.4.3.4.1.1 | Central Parties' UIT environment test data loading & verification (& data cleansing, if required) |  | 30d | 2024-08-26 | 2024-10-04 |  | 2024-08-26 | 2024-10-04 | 30d | 2024-08-26 | 2024-10-04 | 670d | 0d | start no earlier than 2024-08-26 |  | PP | SI Test | 5.0 | Richard Puddephatt | Systems Integration Testing (SIT) | 18.33 | Green | GREEN |  |  |  |  |
| 1190 | 1.4.3.4.1.2 | Submit self-declaration to Programme to confirm loading & verification of test data |  | 30d | 2024-08-26 | 2024-10-04 | 1189SS | 2024-08-26 | 2024-10-04 | 30d | 2024-08-26 | 2024-10-04 | 670d | 0d |  |  | PP | SI Test | 5.0 | Richard Puddephatt | Systems Integration Testing (SIT) | 18.33 | Green | GREEN |  |  |  |  |
| 1191 | 1.4.3.4.2 | **E2E Sandbox Participants** |  | 30d | 2024-08-26 | 2024-10-04 |  | 2024-08-26 | 2024-10-04 | 30d | 2024-08-26 | 2024-10-04 | 690d |  |  | -0 | N/A | N/A | 5.0 | N/A | Systems Integration Testing (SIT) |  |  |  |  |  |  |  |
| 1192 | 1.4.3.4.2.1 | E2E Sandbox Test Data Approach and Plan Approved | milestone | 0d | 2024-09-19 | 2024-09-19 |  | 2024-09-19 | 2024-09-19 | 0d |  |  | 702d |  | start no earlier than 2024-09-19 |  | Sandbox (Qualification Governance) | Sandbox (Qualification Governance), Code Bodies, SRO | 5.28 | Stuart Scott |  | 42.33 | Green | GREEN |  | T3-QU-0124 | QAG |  |
| 1193 | 1.4.3.4.2.2 | UIT environment test data loading and verification (and data cleansing, if required) (for E2E Sandbox Testing Start) |  | 30d | 2024-08-26 | 2024-10-04 | 1189FF | 2024-08-26 | 2024-10-04 | 30d | 2024-08-26 | 2024-10-04 | 690d | 0d |  |  | PP | SI Test | 5.0 | Richard Puddephatt | Systems Integration Testing (SIT) | 18.33 | Green | GREEN |  |  |  |  |

Notes:
- 1169: 8/7/24: Updated to reflect the separation between non-sit and s and a and the 4 waves for s and a
- 1170: 8/7/24: Updated to reflect the separation between non-sit and s and a and the 4 waves for s and a
- 1171: 8/7/24: Updated to reflect the separation between non-sit and s and a and the 4 waves for s and a
- 1172: 8/7/24: Updated to reflect the separation between non-sit and s and a and the 4 waves for s and a
- 1175: 8/7/24: Updated to reflect the separation between non-sit and s and a and the 4 waves for s and a
- 1176: 8/7/24: Updated to reflect the separation between non-sit and s and a and the 4 waves for s and a
- 1177: 8/7/24: Updated to reflect the separation between non-sit and s and a and the 4 waves for s and a
- 1178: 8/7/24: Updated to reflect the separation between non-sit and s and a and the 4 waves for s and a
- 1181: 8/7/24: Updated to reflect the separation between non-sit and s and a and the 4 waves for s and a
- 1182: 8/7/24: Updated to reflect the separation between non-sit and s and a and the 4 waves for s and a
- 1183: 8/7/24: Updated to reflect the separation between non-sit and s and a and the 4 waves for s and a
- 1184: 8/7/24: Updated to reflect the separation between non-sit and s and a and the 4 waves for s and a
- 1189: 1/5: changed from Simon berry to richard puddephatt. Link was 1143(5579) doesnt work now as the date has changed
- 1190: 1/5: changed from Simon berry to richard puddephatt
- 1192: 11/7/24: New Milestone approved at QAG on 20/6/24
- 1193: 1/5: changed from Simon berry to richard puddephatt

| ID | WBS | Task | Type | Duration | Start | Finish | Predecessors | Complete | Remaining | Baseline start | Baseline finish | Baseline duration | Baseline 1 start | Baseline 1 finish | Total slack | Free slack | Constraint | Baseline cost | Responsible | Involved | Update Version | MHHS Resource Name | MHHS Programme Phase | Task Status | Sched Status | RAG | Artefact ID | Milestone ID | Text29 | Tier |
| --- | --- | --- | --- | --- | --- | --- | --- | --- | --- | --- | --- | --- | --- | --- | --- | --- | --- | --- | --- | --- | --- | --- | --- | --- | --- | --- | --- | --- | --- | --- |
| 1194 | 1.4.3.4.3 | **SI Test Data** |  | 30d | 2024-08-26 | 2024-10-04 |  |  |  | 2024-08-26 | 2024-10-04 | 30d | 2024-08-26 | 2024-10-04 | 690d |  |  |  | N/A | N/A | 5.0 | N/A | Systems Integration Testing (SIT) |  |  |  |  |  |  |  |
| 1195 | 1.4.3.4.3.1 | Coordinate Central Parties' UIT environment test data loading and verification (and data cleansing, if required) |  | 30d | 2024-08-26 | 2024-10-04 | 1189SS |  |  | 2024-08-26 | 2024-10-04 | 30d | 2024-08-26 | 2024-10-04 | 690d |  |  |  | SI Test | PP | 5.0 | Richard Puddephatt | Systems Integration Testing (SIT) | 18.33 | Green | GREEN |  |  |  |  |
| 1196 | 1.4.3.4.3.2 | Assure evidence of Central Parties' UIT environment test data load and verification |  | 30d | 2024-08-26 | 2024-10-04 | 1190SS |  |  | 2024-08-26 | 2024-10-04 | 30d | 2024-08-26 | 2024-10-04 | 690d |  |  |  | SI Test | PP | 5.0 | Richard Puddephatt | Systems Integration Testing (SIT) | 18.33 | Green | GREEN |  |  |  |  |
| 1197 | 1.4.3.4.3.3 | Coordinate E2E Sandbox Participants' UIT environment test data loading and verification (and data cleansing, if required) (for E2E Sandbox Testing Start) |  | 30d | 2024-08-26 | 2024-10-04 | 1193SS |  |  | 2024-08-26 | 2024-10-04 | 30d | 2024-08-26 | 2024-10-04 | 690d |  |  |  | SI Test | PP | 5.0 | Richard Puddephatt | Systems Integration Testing (SIT) | 18.33 | Green | GREEN |  |  |  |  |
| 1198 | 1.4.3.5 | **Other Preparation** |  | 496d | 2022-10-31 A | 2024-09-23 |  | 59% | 201.3d | 2022-11-16 | 2024-09-23 | 484d | 2022-11-16 | 2024-09-23 | 699d |  |  |  | N/A | N/A | 5.0 | N/A | Systems Integration Testing (SIT) |  |  |  |  |  |  |  |
| 1199 | 1.4.3.5.1 | **SI Other Preparation** |  | 66d | 2022-10-31 | 2023-01-30 |  |  |  | 2024-05-02 | 2024-08-01 | 66d | 2024-05-02 | 2024-08-01 | 1129d |  |  |  | N/A | N/A | 5.0 | N/A | Systems Integration Testing (SIT) |  |  |  |  |  |  |  |
| 1200 | 1.4.3.5.1.1 | Onboarding of UIT E2E Sandbox Participants to Test Management Tool for E2E Sandbox Testing Start (onboarding of participants will be ongoing hereafter) |  | 66d | 2022-10-31 | 2023-01-30 |  |  |  | 2024-05-02 | 2024-08-01 | 66d | 2024-05-02 | 2024-08-01 | 1129d | 393d |  |  | SI Test | PP | 5.0 | Stuart Scott | Systems Integration Testing (SIT) | -646.67 | Overdue Start | RED |  |  |  |  |
| 1201 | 1.4.3.5.2 | **Other Preparation (for Central Parties & E2E Sandbox Participants)** |  | 484d | 2022-11-16 A | 2024-09-23 |  | 67% | 161.92d | 2022-11-16 | 2024-09-23 | 484d | 2022-11-16 | 2024-09-23 | 699d |  |  |  | N/A | N/A | 5.0 | N/A | Systems Integration Testing (SIT) |  |  |  |  |  |  |  |
| 1202 | 1.4.3.5.2.1 | Test Management Tool onboarding for E2E Sandbox Testing Start (onboarding will be ongoing hereafter) |  | 66d | 2024-05-02 | 2024-08-01 | 1200SS |  |  | 2024-05-02 | 2024-08-01 | 66d | 2024-05-02 | 2024-08-01 | 736d |  | start no earlier than 2024-05-02 |  | PP | SI Test | 5.0 | Stuart Scott | Systems Integration Testing (SIT) | -97.67 | Overdue Start | RED |  |  |  |  |
| 1203 | 1.4.3.5.2.2 | Other Preparation (incl. test execution planning) |  | 484d | 2022-11-16 A | 2024-09-23 | 1139SS, 1145SS | 76% | 118d | 2022-11-16 | 2024-09-23 | 484d | 2022-11-16 | 2024-09-23 | 699d |  |  |  | PP | SI Test | 5.0 | Stuart Scott | Systems Integration Testing (SIT) |  | Green | GREEN |  |  |  |  |
| 1204 | 1.4.3.6 | **UIT E2E Sandbox Test Readiness Report** |  | 114d | 2024-08-26 | 2025-01-31 |  |  |  | 2024-08-26 | 2025-01-31 | 114d | 2024-08-26 | 2024-10-25 | 601d |  |  | -0 | N/A | N/A | 5.0 | N/A | Systems Integration Testing (SIT) |  |  |  |  |  |  |  |
| 1205 | 1.4.3.6.1 | **Central Parties E2E Sandbox Test Readiness Report** |  | 30d | 2024-08-26 | 2024-10-04 |  |  |  | 2024-08-26 | 2024-10-04 | 30d | 2024-08-26 | 2024-10-04 | 670d |  |  |  | N/A | N/A | 5.0 | N/A | Systems Integration Testing (SIT) |  |  |  |  |  |  |  |
| 1206 | 1.4.3.6.1.1 | Develop draft Test Readiness Report and submit to Programme for assurance |  | 20d | 2024-08-26 | 2024-09-20 | 1190FF-10d |  |  | 2024-08-26 | 2024-09-20 | 20d | 2024-08-26 | 2024-09-20 | 670d | 0d |  |  | PP | SI Test | 5.0 | Stuart Scott | Systems Integration Testing (SIT) | 18.33 | Green | GREEN |  |  |  |  |
| 1207 | 1.4.3.6.1.2 | Finalise Test Readiness Report and submit to Programme for assurance |  | 10d | 2024-09-23 | 2024-10-04 | 1190FF |  |  | 2024-09-23 | 2024-10-04 | 10d | 2024-09-23 | 2024-10-04 | 670d | 0d |  |  | PP | SI Test | 5.0 | Stuart Scott | Systems Integration Testing (SIT) | 46.33 | Green | GREEN |  |  |  |  |
| 1208 | 1.4.3.6.2 | **SI E2E Sandbox Test Readiness Report** |  | 40d | 2024-08-26 | 2024-10-18 |  |  |  | 2024-08-26 | 2024-10-18 | 40d | 2024-08-26 | 2024-10-18 | 670d |  |  |  | N/A | N/A | 5.0 | N/A | Systems Integration Testing (SIT) |  |  |  |  |  |  |  |
| 1209 | 1.4.3.6.2.1 | Assure Central Parties' E2E Sandbox Test Readiness Reports |  | 35d | 2024-08-26 | 2024-10-11 | 1206SS, 1207FF+5d |  |  | 2024-08-26 | 2024-10-11 | 35d | 2024-08-26 | 2024-10-11 | 670d | 0d |  |  | SI Test | PP | 5.0 | Stuart Scott | Systems Integration Testing (SIT) | 18.33 | Green | GREEN |  |  |  |  |
| 1210 | 1.4.3.6.2.2 | Develop Overarching E2E Sandbox Test Readiness Report |  | 20d | 2024-09-16 | 2024-10-11 | 1209FF |  |  | 2024-09-16 | 2024-10-11 | 20d | 2024-09-16 | 2024-10-11 | 670d | 0d |  |  | SI Test |  | 5.0 | Stuart Scott | Systems Integration Testing (SIT) | 39.33 | Green | GREEN |  |  |  |  |
| 1211 | 1.4.3.6.2.3 | Artefact review (via SITAG) and updates |  | 5d | 2024-10-14 | 2024-10-18 | 1210 |  |  | 2024-10-14 | 2024-10-18 | 5d | 2024-10-14 | 2024-10-18 | 670d | 69d |  |  | SI Test | PP,IPA | 5.0 | Stuart Scott | Systems Integration Testing (SIT) | 67.33 | Green | GREEN |  |  |  |  |
| 1212 | 1.4.3.6.3 | UIT E2E Sandbox Preparation Complete | milestone | 0d | 2025-01-31 | 2025-01-31 | 1211FS+5d |  |  | 2025-01-31 | 2025-01-31 | 0d | 2024-10-25 | 2024-10-25 | 601d | 1d | start no earlier than 2025-01-31 |  | SI Test | PP | 5.28 | Stuart Scott | Systems Integration Testing (SIT) | 176.33 | Green | GREEN | MHHS-ART154 MHHS-ART147 | T3-TE-0048 | QAG | T3 |
| 1213 | 1.4.4 | **SIT PPs E2E Sandbox Testing Execution** |  | 316d | 2025-02-07 | 2026-04-24 |  |  |  | 2024-11-04 | 2026-01-19 | 316d | 2024-11-04 | 2026-01-19 | 285d |  |  | -0 | N/A | N/A | 5.0 | N/A | Systems Integration Testing (SIT) |  |  |  |  |  |  |  |
| 1214 | 1.4.4.1 | SIT PPs E2E Sandbox Testing Start | milestone | 0d | 2025-02-10 | 2025-02-10 | 1033FS+1d, 1212FS+5d |  |  | 2025-02-10 | 2025-02-10 | 0d | 2024-11-04 | 2024-11-04 | 600d | 0d | start no earlier than 2025-02-10 |  | SI Test | PP | 5.28 | Stuart Scott | Systems Integration Testing (SIT) | 186.33 | Green | GREEN | MHHS-ART018 MHHS-ART154 MHHS-ART147 | T3-TE-0049 | QAG | T3 |
| 1215 | 1.4.4.2 | SIT PPs E2E Sandbox Testing Execution |  | 316d | 2025-02-07 | 2026-04-24 | 1214SS-1d |  |  | 2024-11-04 | 2026-01-19 | 316d | 2024-11-04 | 2026-01-19 | 285d |  | start no earlier than 2024-11-04 |  | PP | SI Test | 5.0 | Stuart Scott | Systems Integration Testing (SIT) | 183.33 | Red | RED |  |  |  |  |
| 1216 | 1.4.5 | **External Programme Dependency Management** |  | 174d | 2022-10-31 A | 2023-06-30 A |  | 100% |  | 2022-10-31 | 2023-06-30 | 174d | 2022-10-31 | 2023-06-30 |  |  |  |  | N/A | N/A | 5.0 | N/A | Systems Integration Testing (SIT) |  |  |  |  |  |  |  |
| 1217 | 1.4.5.1 | **BSC CP1558** |  | 173d | 2022-10-31 A | 2023-06-29 A |  | 100% |  | 2022-10-31 | 2023-06-29 | 173d | 2022-10-31 | 2023-06-29 |  |  |  |  | N/A | N/A | 5.0 | N/A | Systems Integration Testing (SIT) |  |  |  |  |  |  |  |
| 1218 | 1.4.5.1.1 | Monitor progress to implementation date |  | 173d | 2022-10-31 A | 2023-06-28 A |  | 100% |  | 2022-10-31 | 2023-06-28 | 173d | 2022-10-31 | 2023-06-28 |  |  |  |  | CPT | Code Bodies | 5.0 | Andrew Margan | Systems Integration Testing (SIT) |  | Complete | COMPLETE |  |  |  |  |
| 1219 | 1.4.5.1.2 | BSC CP1558 Implementation Date | milestone | 0d | 2023-06-29 A | 2023-06-29 A | 1218 | 100% |  | 2023-06-29 | 2023-06-29 | 0d | 2023-06-29 | 2023-06-29 |  |  | must start on 2023-06-29 |  | Code Bodies |  | 5.0 | Andrew Margan | Systems Integration Testing (SIT) |  | Complete | COMPLETE |  |  |  |  |

Notes:
- 1212: 11/7/24: Date change approved at QAG on 20/6/24 from 25/10/24 to 31/1/25
- 1214: 11/7/24: Date change approved at QAG on 20/6/24 from 4/11/24 to 10/2/25

| ID | WBS | Task | Type | Duration | Start | Finish | Predecessors | Complete | Remaining | Baseline start | Baseline finish | Baseline duration | Baseline 1 start | Baseline 1 finish | Total slack | Free slack | Constraint | Baseline cost | Responsible | Involved | Update Version | MHHS Resource Name | MHHS Programme Phase | Sched Status | RAG | Task Status | Milestone ID | Text29 | Tier |
| --- | --- | --- | --- | --- | --- | --- | --- | --- | --- | --- | --- | --- | --- | --- | --- | --- | --- | --- | --- | --- | --- | --- | --- | --- | --- | --- | --- | --- | --- |
| 1220 | 1.4.5.2 | **REC CP R0032** |  | 174d | 2022-10-31 A | 2023-06-30 A |  | 100% |  | 2022-10-31 | 2023-06-30 | 174d | 2022-10-31 | 2023-06-30 |  |  |  |  | N/A | N/A | 5.0 | N/A | Systems Integration Testing (SIT) |  |  |  |  |  |  |
| 1221 | 1.4.5.2.1 | Monitor progress to implementation date |  | 174d | 2022-10-31 A | 2023-06-29 A |  | 100% |  | 2022-10-31 | 2023-06-29 | 174d | 2022-10-31 | 2023-06-29 |  |  |  |  | CPT | Code Bodies | 5.0 | Andrew Margan | Systems Integration Testing (SIT) | Complete | COMPLETE |  |  |  |  |
| 1222 | 1.4.5.2.2 | REC CP R0032 Implementation Date | milestone | 0d | 2023-06-30 A | 2023-06-30 A | 1221 | 100% |  | 2023-06-30 | 2023-06-30 | 0d | 2023-06-30 | 2023-06-30 |  |  | must start on 2023-06-30 |  | Code Bodies |  | 5.0 | Andrew Margan | Systems Integration Testing (SIT) | Complete | COMPLETE |  |  |  |  |
| 1223 | 1.4.5.3 | **REC CP R0044** |  | 173d | 2022-10-31 A | 2023-06-29 A |  | 100% |  | 2022-10-31 | 2023-06-29 | 173d | 2022-10-31 | 2023-06-29 |  |  |  |  | N/A | N/A | 5.0 | N/A | Systems Integration Testing (SIT) |  |  |  |  |  |  |
| 1224 | 1.4.5.3.1 | Monitor progress to implementation date |  | 173d | 2022-10-31 A | 2023-06-28 A |  | 100% |  | 2022-10-31 | 2023-06-28 | 173d | 2022-10-31 | 2023-06-28 |  |  |  |  | CPT | Code Bodies | 5.0 | Andrew Margan | Systems Integration Testing (SIT) | Complete | COMPLETE |  |  |  |  |
| 1225 | 1.4.5.3.2 | REC CP R0044 Implementation Date | milestone | 0d | 2023-06-29 A | 2023-06-29 A | 1224 | 100% |  | 2023-06-29 | 2023-06-29 | 0d | 2023-06-29 | 2023-06-29 |  |  | must start on 2023-06-29 |  | Code Bodies |  | 5.0 | Andrew Margan | Systems Integration Testing (SIT) | Complete | COMPLETE |  |  |  |  |
| 1226 | 1.5 | **NON SIT LDSO QUALIFICATION** |  | 339d | 2023-11-07 A | 2025-02-21 |  | 74% | 87.55d | 2023-11-07 | 2025-02-28 | 343d | 2024-01-29 | 2024-07-05 | -3d | 0d |  | -0 | N/A | N/A |  | N/A | Systems Integration Testing (SIT) |  |  |  |  |  |  |
| 1227 | 1.5.1 | **Approach Planning** |  | 208d | 2023-11-07 A | 2024-08-22 |  | 96% | 7.47d | 2023-11-07 | 2024-08-22 | 208d |  |  | 25d |  |  | -0 | N/A | N/A | 5.24 | N/A |  |  |  | -386.67 |  |  |  |
| 1228 | 1.5.1.1 | Develop Draft Testing Approach & Plan |  | 61d | 2023-11-07 A | 2024-01-30 A |  | 100% |  | 2023-11-07 | 2024-01-30 | 61d |  |  |  |  | start no earlier than 2023-11-07 |  | Non-SIT LDSO | Non-SIT LDSO | 5.24 | Ben Wickins |  | Complete | COMPLETE |  |  |  |  |
| 1229 | 1.5.1.2 | Draft Testing Approach & Plan Issued to LDSO for Review |  | 1d | 2024-01-31 A | 2024-01-31 A | 1228 | 100% |  | 2024-01-31 | 2024-01-31 | 1d |  |  |  |  |  |  | Non-SIT LDSO | Non-SIT LDSO | 5.24 | Ben Wickins |  | Complete | COMPLETE |  |  |  |  |
| 1230 | 1.5.1.3 | LDSO Review Complete |  | 10d | 2024-02-01 A | 2024-02-14 A | 1229 | 100% |  | 2024-02-01 | 2024-02-14 | 10d |  |  |  |  |  |  | LDSOs | Non-SIT LDSO | 5.24 | Ben Wickins |  | Complete | COMPLETE |  |  |  |  |
| 1231 | 1.5.1.4 | Update Following LDSO Review |  | 14d | 2024-02-15 A | 2024-03-05 A | 1230 | 100% |  | 2024-02-15 | 2024-03-05 | 14d |  |  |  |  |  |  | Non-SIT LDSO | Non-SIT LDSO, Code Bodies | 5.24 | Ben Wickins |  | Complete | COMPLETE |  |  |  |  |
| 1232 | 1.5.1.5 | QWG Review of Approach & Plan |  | 1d | 2024-03-12 A | 2024-03-12 A | 1231FS+4d | 100% |  | 2024-03-12 | 2024-03-12 | 1d |  |  |  |  |  |  | Non-SIT LDSO, PP | Non-SIT LDSO, Code Bodies | 5.24 | Ben Wickins |  | Complete | COMPLETE |  |  |  |  |
| 1233 | 1.5.1.6 | QAG Approval for Approach & Plan | milestone | 0d | 2024-03-21 A | 2024-03-21 A | 1232FS+7d | 100% |  | 2024-03-21 | 2024-03-21 | 0d |  |  |  |  |  |  | Code Bodies | Non-SIT LDSO,Code Bodies | 5.24 | Ben Wickins |  | Complete | COMPLETE |  |  |  |  |
| 1234 | 1.5.1.7 | Confirmation of Participants for Non-SIT LDSO Qualification Testing | milestone | 0d | 2024-03-21 A | 2024-03-21 A | 1233 | 100% |  | 2024-03-21 | 2024-03-21 | 0d | 2024-01-29 | 2024-01-29 |  |  |  |  | Non-SIT LDSO | SI Test, PP, IPA | 5.24 | Ben Wickins | Systems Integration Testing (SIT) | Complete | COMPLETE |  | T3-QU-0011 | QAG (Non-SIT LDSO) | T3 |
| 1235 | 1.5.1.8 | Update to Annex 1 for internal review (NF, Not Operational) |  | 15d | 2024-03-18 A | 2024-04-05 A | 915 | 100% |  | 2024-03-18 | 2024-04-05 | 15d |  |  |  |  |  |  | Non-SIT LDSO | PP, Code Bodies | 5.24 | Ben Wickins |  | Complete | COMPLETE |  |  |  |  |
| 1236 | 1.5.1.9 | Non-Functional, Operational & Migration Approaches Socialised with Code Bodies & LDSO & Feedback Actioned |  | 86d | 2024-04-08 A | 2024-08-05 A | 1235 | 100% |  | 2024-04-08 | 2024-08-05 | 86d |  |  |  |  |  |  | Non-SIT LDSO | PP, Code Bodies | 5.27 | Ben Wickins |  | Complete | COMPLETE |  |  |  |  |
| 1237 | 1.5.1.10 | QWG Review Operational, Non-Functional & Migration Annexes of Approach & Plan |  | 1d | 2024-08-13 | 2024-08-13 | 1236FS+5d |  |  | 2024-08-13 | 2024-08-13 | 1d |  |  | 25d | 0d |  |  | Non-SIT LDSO, PP | Non-SIT LDSO, PP, Code Bodies | 5.27 | Ben Wickins |  | Green | GREEN | 5.33 |  |  |  |
| 1238 | 1.5.1.11 | Update Following QWG Review |  | 6d | 2024-08-14 | 2024-08-21 | 1237 |  |  | 2024-08-14 | 2024-08-21 | 6d |  |  | 25d | 0d |  |  | Non-SIT LDSO, PP | Non-SIT LDSO, Code Bodies | 5.27 | Ben Wickins |  | Green | GREEN | 6.33 |  |  |  |
| 1239 | 1.5.1.12 | QAG Approval for Operational, Non-Functional & Migration Annexes of Approach & Plan | milestone | 0d | 2024-08-22 | 2024-08-22 | 1238FS+1d, 1234, 918 |  |  | 2024-08-22 | 2024-08-22 | 0d |  |  | 25d | 0d |  |  | Code Bodies | Non-SIT LDSO, Code Bodies | 5.29 | Ben Wickins |  | Green | GREEN | 14.71 | T3-QU-0110 | QAG (Non-SIT LDSO) |  |
| 1240 | 1.5.2 | **Functional Test Cases & Scenarios** |  | 58d | 2024-01-30 A | 2024-04-18 A |  | 100% |  | 2024-01-30 | 2024-04-18 | 58d |  |  |  |  |  | -0 | N/A | N/A | 5.24 | N/A |  |  |  | -385.67 |  |  |  |
| 1241 | 1.5.2.1 | **Functional Test Cases & Scenarios Batch 1** |  | 8d | 2024-01-30 A | 2024-02-08 A |  | 100% |  | 2024-01-30 | 2024-02-08 | 8d |  |  |  |  |  | -0 | N/A | N/A | 5.24 | N/A |  |  |  |  |  |  |  |
| 1242 | 1.5.2.1.1 | Walkthrough Test Cases & Scenarios Batch 1 with Code Bodies |  | 1d | 2024-01-30 A | 2024-01-30 A | 1228SS+60d | 100% |  | 2024-01-30 | 2024-01-30 | 1d |  |  |  |  |  |  | Non-SIT LDSO | Non-SIT LDSO, Code Bodies | 5.24 | Ben Wickins |  | Complete | COMPLETE |  |  |  |  |
| 1243 | 1.5.2.1.2 | Walkthrough Test Cases & Scenarios Batch 1 with LDSO |  | 1d | 2024-02-01 A | 2024-02-01 A | 1242 | 100% |  | 2024-02-01 | 2024-02-01 | 1d |  |  |  |  |  |  | LDSO, Non-SIT LDSO | LDSO, Non-SIT LDSO | 5.24 | Ben Wickins |  | Complete | COMPLETE |  |  |  |  |
| 1244 | 1.5.2.1.3 | Action Feedback on Test Cases & Scenarios Batch 1 |  | 5d | 2024-02-02 A | 2024-02-08 A | 1243 | 100% |  | 2024-02-02 | 2024-02-08 | 5d |  |  |  |  |  |  | Non-SIT LDSO | Non-SIT LDSO, LDSO , Code Bodies | 5.24 | Ben Wickins |  | Complete | COMPLETE |  |  |  |  |

Notes:
- 1234: Have confirmed LDSOs going through SIT. We should receive notifications on non-SIT through January. Milestone holds to baseline. 13/5: date on cr47 was 18/4 but completed before CR approved
- 1235: Includes time to update Approach & Plan with updates / Guidance: 26/3: Linked to the development of SIT non functional plan
- 1239: Date missed because the Non-Functional Test Materials are not available for the July QAG and therefore to maintain our approach of approving plans in parallel with materials, the date has moved to the August QAG. There is no impact on the deliverability / Guidance: 18/7/24: Date change from 18/7/24 to 22/8/24 approved at QAG on 18/7/24 / Notes (2): of the overall project. Project to engage with Code Bodies and industry in sufficient time to review all required materials. To go to July QAG for baseline date change

| ID | WBS | Task | Type | Duration | Start | Finish | Predecessors | Complete | Remaining | Baseline start | Baseline finish | Baseline duration | Baseline 1 start | Baseline 1 finish | Total slack | Free slack | Baseline cost | Responsible | Involved | Update Version | MHHS Resource Name | Sched Status | RAG | Milestone ID | Text29 | MHHS Programme Phase | Task Status | Tier |
| --- | --- | --- | --- | --- | --- | --- | --- | --- | --- | --- | --- | --- | --- | --- | --- | --- | --- | --- | --- | --- | --- | --- | --- | --- | --- | --- | --- | --- |
| 1245 | 1.5.2.2 | **Functional Test Cases & Scenarios Batch 2** |  | 14d | 2024-02-20 A | 2024-03-08 A |  | 100% |  | 2024-02-20 | 2024-03-08 | 14d |  |  |  |  | -0 | N/A | N/A | 5.24 | N/A |  |  |  |  |  |  |  |
| 1246 | 1.5.2.2.1 | Walkthrough Test Cases & Scenarios Batch 2 with Code Bodies |  | 1d | 2024-02-20 A | 2024-02-20 A | 1228SS+75d | 100% |  | 2024-02-20 | 2024-02-20 | 1d |  |  |  |  |  | Non-SIT LDSO | Non-SIT LDSO, Code Bodies | 5.24 | Ben Wickins | Complete | COMPLETE |  |  |  |  |  |
| 1247 | 1.5.2.2.2 | Walkthrough Test Cases & Scenarios Batch 2 with LDSO |  | 1d | 2024-03-01 A | 2024-03-01 A | 1246FS+7d | 100% |  | 2024-03-01 | 2024-03-01 | 1d |  |  |  |  |  | LDSO, Non-SIT LDSO | LDSO, Non-SIT LDSO | 5.24 | Ben Wickins | Complete | COMPLETE |  |  |  |  |  |
| 1248 | 1.5.2.2.3 | Action Feedback on Test Cases & Scenarios Batch 2 |  | 5d | 2024-03-04 A | 2024-03-08 A | 1247 | 100% |  | 2024-03-04 | 2024-03-08 | 5d |  |  |  |  |  | Non-SIT LDSO | Non-SIT LDSO, LDSO , Code Bodies | 5.24 | Ben Wickins | Complete | COMPLETE |  |  |  |  |  |
| 1249 | 1.5.2.3 | **Functional Test Cases & Scenarios Batch 3** |  | 13d | 2024-03-20 A | 2024-04-05 A |  | 100% |  | 2024-03-20 | 2024-04-05 | 13d |  |  |  |  | -0 | N/A | N/A | 5.24 | N/A |  |  |  |  |  |  |  |
| 1250 | 1.5.2.3.1 | Walkthrough Test Cases & Scenarios Batch 3 with Code Bodies |  | 1d | 2024-03-20 A | 2024-03-20 A | 1228SS+96d | 100% |  | 2024-03-20 | 2024-03-20 | 1d |  |  |  |  |  | Non-SIT LDSO | Non-SIT LDSO, Code Bodies | 5.24 | Ben Wickins | Complete | COMPLETE |  |  |  |  |  |
| 1251 | 1.5.2.3.2 | Walkthrough Test Cases & Scenarios Batch 3 with LDSO |  | 1d | 2024-03-28 A | 2024-03-28 A | 1250FS+5d | 100% |  | 2024-03-28 | 2024-03-28 | 1d |  |  |  |  |  | LDSO, Non-SIT LDSO | LDSO, Non-SIT LDSO | 5.24 | Ben Wickins | Complete | COMPLETE |  |  |  |  |  |
| 1252 | 1.5.2.3.3 | Action Feedback on Test Cases & Scenarios Batch 3 |  | 6d | 2024-03-29 A | 2024-04-05 A | 1251 | 100% |  | 2024-03-29 | 2024-04-05 | 6d |  |  |  |  |  | Non-SIT LDSO | Non-SIT LDSO, LDSO , Code Bodies | 5.24 | Ben Wickins | Complete | COMPLETE |  |  |  |  |  |
| 1253 | 1.5.2.4 | Test Cases & Scenarios Batch 1-3 Discussion at QWG |  | 1d | 2024-04-09 A | 2024-04-09 A | 1244, 1248, 1252FS+1d | 100% |  | 2024-04-09 | 2024-04-09 | 1d |  |  |  |  |  | Non-SIT LDSO, PP | Non-SIT LDSO, Code Bodies | 5.24 | Ben Wickins | Complete | COMPLETE |  |  |  |  |  |
| 1254 | 1.5.2.5 | Action QWG Feedback on Test Cases & Scenarios Batch 1-3 |  | 2d | 2024-04-10 A | 2024-04-11 A | 1253 | 100% |  | 2024-04-10 | 2024-04-11 | 2d |  |  |  |  |  | Non-SIT LDSO | Non-SIT LDSO, Code Bodies | 5.24 | Ben Wickins | Complete | COMPLETE |  |  |  |  |  |
| 1255 | 1.5.2.6 | Batch 1-3 Non-SIT LDSO QT Functional Test Scenarios and Test Cases approved | milestone | 0d | 2024-04-18 A | 2024-04-18 A | 1254FS+5d | 100% |  | 2024-04-18 | 2024-04-18 | 0d |  |  |  |  |  | Code Bodies | Non-SIT LDSO, Code Bodies | 5.24 | Ben Wickins | Complete | COMPLETE | T3-QU-0069 | QAG (Non-SIT LDSO) |  |  |  |
| 1256 | 1.5.3 | **Test Execution Schedule** |  | 90d | 2024-04-19 A | 2024-08-22 |  | 99% | 0d | 2024-04-19 | 2024-08-22 | 90d | 2024-01-29 | 2024-04-26 | 25d |  | -0 | N/A | N/A | 5.24 | N/A |  |  |  |  | Systems Integration Testing (SIT) |  |  |
| 1257 | 1.5.3.1 | Draft Test Delivery Schedule for Functional and Operational Testing |  | 20d | 2024-04-19 A | 2024-05-16 A | 1255 | 100% |  | 2024-04-19 | 2024-05-16 | 20d | 2024-01-29 | 2024-03-22 |  |  |  | Non-SIT LDSO | SI Test, PP, Non-SIT LDSO | 5.24 | Ben Wickins | Complete | COMPLETE |  |  | Systems Integration Testing (SIT) |  |  |
| 1258 | 1.5.3.2 | Socialise Test Delivery Schedule with Code Bodies & LDSO for Review & Action Feedback |  | 37d | 2024-05-17 A | 2024-07-08 A | 1257 | 100% |  | 2024-05-17 | 2024-07-08 | 37d |  |  |  |  |  | Non-SIT LDSO | LDSO, Code Bodies, Non-SIT LDSO | 5.24 | Ben Wickins | Complete | COMPLETE |  |  |  |  |  |
| 1259 | 1.5.3.3 | Agree Test Execution Timetable Format at QWG, Including Anonymisation Requirements |  | 1d | 2024-07-09 A | 2024-07-09 A | 1258 | 100% |  | 2024-07-09 | 2024-07-09 | 1d | 2024-03-25 | 2024-04-19 |  |  |  | Non-SIT LDSO, PP | Non-SIT LDSO, Code Bodies | 5.24 | Ben Wickins | Complete | COMPLETE |  |  | Systems Integration Testing (SIT) |  |  |
| 1260 | 1.5.3.4 | Action QWG Feedback |  | 3d | 2024-07-10 A | 2024-07-12 A | 1259 | 100% |  | 2024-07-10 | 2024-07-12 | 3d |  |  |  |  |  | Non-SIT LDSO, PP | Non-SIT LDSO, Code Bodies | 5.24 | Ben Wickins | Complete | COMPLETE |  |  |  |  |  |
| 1261 | 1.5.3.5 | Agree Test Execution Timetable Format at QAG, Including Anonymisation Requirements | milestone | 0d | 2024-07-18 A | 2024-07-18 A | 1260FS+4d | 100% |  | 2024-07-18 | 2024-07-18 | 0d |  |  |  |  |  | Code Bodies | Non-SIT LDSO, Code Bodies | 5.29 | Ben Wickins | Complete | COMPLETE | T3-QU-0111 | QAG (Non-SIT LDSO) |  |  |  |
| 1262 | 1.5.3.6 | Qualification Testing for Non-SIT LDSOs (Functional, Migration, NFT, Operational) Test Execution Schedule Complete | milestone | 0d | 2024-08-22 | 2024-08-22 | 1239 |  |  | 2024-08-22 | 2024-08-22 | 0d | 2024-04-26 | 2024-04-26 | 25d |  |  | Non-SIT LDSO | Non-SIT LDSO, Code Bodies, PP | 5.29 | Ben Wickins | Green | RED | T3-QU-0008 | QAG (Non-SIT LDSO) | Systems Integration Testing (SIT) | 14.71 | T3 |
| 1263 | 1.5.4 | **Functional, Non-Functional, Operational & Migration Test Scenarios & Cases** |  | 110d | 2024-03-22 A | 2024-08-22 |  | 90% | 10.61d | 2024-03-22 | 2024-08-22 | 110d |  |  | 25d |  | -0 | N/A | N/A | 5.24 | N/A |  |  |  |  |  |  |  |
| 1264 | 1.5.4.1 | Test Scenarios & Cases - Functional - Drafted, Reviewed |  | 14d | 2024-04-01 A | 2024-04-18 A | 1233 | 100% |  | 2024-04-01 | 2024-04-18 | 14d |  |  |  |  |  | Non-SIT LDSO | Non-SIT LDSO, LDSO, Code Bodies | 5.24 | Ben Wickins | Complete | COMPLETE |  |  |  |  |  |
| 1265 | 1.5.4.2 | Test Scenarios & Cases- Functional - Approved at QAG | milestone | 0d | 2024-04-18 A | 2024-04-18 A | 1264 | 100% |  | 2024-04-18 | 2024-04-18 | 0d |  |  |  |  |  | Non-SIT LDSO | Non-SIT LDSO, LDSO, Code Bodies | 5.24 | Ben Wickins | Complete | COMPLETE | T3-QU-0070 | QAG (Non-SIT LDSO) |  |  |  |
| 1266 | 1.5.4.3 | Test Scenarios & Cases - Non-Functional - Drafted, Reviewed |  | 110d | 2024-03-22 A | 2024-08-22 | 1233, 935FF | 90% | 11d | 2024-03-22 | 2024-08-22 | 110d |  |  | 25d | 0d |  | Non-SIT LDSO | Non-SIT LDSO, LDSO, Code Bodies | 5.24 | Ben Wickins | Green | GREEN |  |  |  |  |  |
| 1267 | 1.5.4.4 | Test Scenarios & Cases - Non-Functional - Approved at QAG | milestone | 0d | 2024-08-22 | 2024-08-22 | 1266 |  |  | 2024-08-22 | 2024-08-22 | 0d |  |  | 25d |  |  | Non-SIT LDSO | Non-SIT LDSO, LDSO, Code Bodies | 5.29 | Ben Wickins | Green | GREEN | T3-QU-0071 | QAG (Non-SIT LDSO) |  | 14.71 |  |
| 1268 | 1.5.4.5 | Test Scenarios & Cases - Migration - Drafted, Reviewed |  | 45d | 2024-03-22 A | 2024-05-23 A | 1233 | 100% |  | 2024-03-22 | 2024-05-23 | 45d |  |  |  |  |  | Non-SIT LDSO | Non-SIT LDSO, LDSO, Code Bodies | 5.24 | Ben Wickins | Complete | COMPLETE |  |  |  |  |  |
| 1269 | 1.5.4.6 | Test Scenarios & Cases - Migration - Approved at QAG | milestone | 0d | 2024-05-23 A | 2024-05-23 A | 1268 | 100% |  | 2024-05-23 | 2024-05-23 | 0d |  |  |  |  |  | Non-SIT LDSO | Non-SIT LDSO, LDSO, Code Bodies | 5.24 | Ben Wickins | Complete | COMPLETE | T3-QU-0072 | QAG (Non-SIT LDSO) |  |  |  |
| 1270 | 1.5.4.7 | Test Scenarios & Cases - Operational - Drafted, Reviewed |  | 59d | 2024-06-03 A | 2024-08-22 | 1233FS+51d | 81% | 11d | 2024-06-03 | 2024-08-22 | 59d |  |  | 24d | 0d |  | Non-SIT LDSO | Non-SIT LDSO, LDSO, Code Bodies | 5.24 | Ben Wickins | Green | GREEN |  |  |  |  |  |
| 1271 | 1.5.4.8 | Test Scenarios & Cases - Operational - Approved at QAG | milestone | 0d | 2024-08-22 | 2024-08-22 | 1270, 935FF |  |  | 2024-08-22 | 2024-08-22 | 0d |  |  | 24d | 0d |  | Non-SIT LDSO | Non-SIT LDSO, LDSO, Code Bodies | 5.29 | Ben Wickins | Green | GREEN | T3-QU-0073 | QAG (Non-SIT LDSO) |  | 14.71 |  |

Notes:
- 1255: 13/5: New milestone approved as part of cr47.
- 1262: 5/8/24: Date will not be met because of re-planning activity around SIT Cycle 2 Maintenance window. Maintain dialog with Programme scenario planing from SIT. / Guidance: 18/7/24: Date change from 15/8/24 to 22/8/24 approved at QAG on 18/7/24
- 1265: 13/5: New milestone approved as part of cr47.
- 1267: Date missed because Non-Functional Test Materials are not available for the July QAG. There is no impact the QT window and it will be approved at the August QAG. To go to July QAG for baseline date change / Guidance: 18/7/24: Date change from 18/7/24 to 22/8/24 approved at QAG on 18/7/24
- 1271: Date missed because Operational Test Materials are not available for the July QAG. There is no impact the QT window and it will be approved at the August QAG. To go to July QAG for baseline date change / Guidance: 18/7/24: Date change from 18/7/24 to 22/8/24 approved at QAG on 18/7/24

| ID | WBS | Task | Type | Duration | Start | Finish | Predecessors | Complete | Remaining | Baseline start | Baseline finish | Baseline duration | Total slack | Free slack | Deadline | Baseline cost | Responsible | Involved | Task Status | Update Version | MHHS Resource Name | Sched Status | RAG | Milestone ID | Text29 |
| --- | --- | --- | --- | --- | --- | --- | --- | --- | --- | --- | --- | --- | --- | --- | --- | --- | --- | --- | --- | --- | --- | --- | --- | --- | --- |
| 1272 | 1.5.5 | **Test Data** |  | 241d | 2024-01-22 A | 2024-12-23 |  | 61% | 94.1d | 2024-01-22 | 2024-12-23 | 241d | 41d |  |  | -0 | N/A | N/A | -385.67 | 5.24 | N/A |  |  |  |  |
| 1273 | 1.5.5.1 | Test Data Plan Drafted & Reviewed |  | 89d | 2024-01-22 A | 2024-05-23 A | 1228 | 100% |  | 2024-01-22 | 2024-05-23 | 89d |  |  |  |  | Code Bodies | Non-SIT LDSO, Code Bodies |  | 5.24 | Ben Wickins | Complete | COMPLETE |  |  |
| 1274 | 1.5.5.2 | Non-SIT LDSO QT Test Data Plan Approved by QAG | milestone | 0d | 2024-05-23 A | 2024-05-23 A | 1273 | 100% |  | 2024-05-16 | 2024-05-16 | 0d |  |  |  |  | Code Bodies | Non-SIT LDSO, Code Bodies |  | 5.24 | Ben Wickins | Complete | COMPLETE | T3-QU-0074 | QAG (Non-SIT LDSO) |
| 1275 | 1.5.5.3 | Develop Test Data Matrices |  | 10d | 2024-05-24 A | 2024-06-06 A | 1274 | 100% |  | 2024-05-24 | 2024-06-06 | 10d |  |  |  |  | Non-SIT LDSO | Non-SIT LDSO |  | 5.24 | Ben Wickins | Complete | COMPLETE |  |  |
| 1276 | 1.5.5.4 | Test Data Cut |  | 17d | 2024-05-24 A | 2024-06-17 A | 1274 | 100% |  | 2024-05-24 | 2024-06-17 | 17d |  |  |  |  | PP, Non-SIT LDSO | PP, Non-SIT LDSO |  | 5.24 | Ben Wickins | Complete | COMPLETE |  |  |
| 1277 | 1.5.5.5 | Test Data Cut Complete | milestone | 0d | 2024-06-17 A | 2024-06-17 A | 1276, 1275 | 100% |  | 2024-06-17 | 2024-06-17 | 0d |  |  |  |  | PP, Non-SIT LDSO | PP, Non-SIT LDSO |  | 5.27 | Ben Wickins | Complete | COMPLETE | T3-QU-0112 | QAG (Non-SIT LDSO) |
| 1278 | 1.5.5.6 | Test Data Reviewed by the Programme |  | 39d | 2024-06-18 A | 2024-08-09 | 1277 | 95% | 2d | 2024-06-18 | 2024-08-09 | 39d | 41d | 0d |  |  | Non-SIT LDSO | PP, Non-SIT LDSO |  | 5.24 | Ben Wickins | Green | GREEN |  |  |
| 1279 | 1.5.5.7 | Test Data Loaded |  | 17d | 2024-08-12 | 2024-09-03 | 1278 |  |  | 2024-08-12 | 2024-09-03 | 17d | 41d | 0d |  |  | Non-SIT LDSO | PP, Non-SIT LDSO | 4.33 | 5.24 | Ben Wickins | Green | GREEN |  |  |
| 1280 | 1.5.5.8 | Test Data Signed Off | milestone | 0d | 2024-09-03 | 2024-09-03 | 1279 |  |  | 2024-09-03 | 2024-09-03 | 0d | 41d | 0d |  |  | Non-SIT LDSO | PP, Non-SIT LDSO | 26.71 | 5.25 | Ben Wickins | Green | AMBER | T3-QU-0113 | QAG (Non-SIT LDSO) |
| 1281 | 1.5.5.9 | Test Execution Data Support |  | 79d | 2024-09-04 | 2024-12-23 | 1280 |  |  | 2024-09-04 | 2024-12-23 | 79d | 41d | 24d |  |  | Non-SIT LDSO | Non-SIT LDSO | 27.33 | 5.24 | Ben Wickins | Green | GREEN |  |  |
| 1282 | 1.5.6 | **Tooling** |  | 148d | 2024-01-31 A | 2024-08-23 |  | 96% | 5.25d | 2024-01-31 | 2024-08-23 | 148d | 24d |  |  | -0 | N/A | N/A | -385.67 | 5.24 | N/A |  |  |  |  |
| 1283 | 1.5.6.1 | Design Approach & Set-Up ADO Tool for Test & Defect Management Tool |  | 53d | 2024-01-31 A | 2024-04-12 A | 1228 | 100% |  | 2024-01-31 | 2024-04-12 | 53d |  |  |  |  | Non-SIT LDSO | Non-SIT LDSO, SI Test |  | 5.24 | Ben Wickins | Complete | COMPLETE |  |  |
| 1284 | 1.5.6.2 | Develop Training Requirements & Materials Inc. Day in the Life |  | 87d | 2024-04-15 A | 2024-08-13 | 1283 | 95% | 4d | 2024-04-15 | 2024-08-13 | 87d | 31d | 7d |  |  | Non-SIT LDSO | Non-SIT LDSO, SI Test |  | 5.24 | Ben Wickins | Green | GREEN |  |  |
| 1285 | 1.5.6.3 | ADO Launch complete |  | 1d | 2024-08-23 | 2024-08-23 | 1284, 1265, 1269, 1271 |  |  | 2024-08-23 | 2024-08-23 | 1d | 24d |  |  |  | Non-SIT LDSO | Non-SIT LDSO | 15.33 | 5.24 | Ben Wickins | Green | GREEN |  |  |
| 1286 | 1.5.7 | **Pre-Integration Testing** |  | 174d | 2024-01-31 A | 2024-09-30 |  | 84% | 28.45d | 2024-01-31 | 2024-09-30 | 174d | 0d |  |  | -0 | N/A | N/A | -385.67 | 5.24 | N/A |  |  |  |  |
| 1287 | 1.5.7.1 | PIT Guidance & Templates & Approach & Plans Developed |  | 106d | 2024-02-05 A | 2024-07-01 A | 1228FS+3d | 100% |  | 2024-02-05 | 2024-07-01 | 106d |  |  |  |  | Non-SIT LDSO | Non-SIT LDSO, LDSO |  | 5.27 | Ben Wickins | Complete | COMPLETE |  |  |
| 1288 | 1.5.7.2 | PIT Test Approach & Plan Deadline for Submission for Non-SIT LDSO​ QT | milestone | 0d | 2024-07-01 A | 2024-07-01 A | 1287 | 100% |  | 2024-07-01 | 2024-07-01 | 0d |  |  |  |  | Non-SIT LDSO | Non-SIT LDSO, LDSO |  | 5.28 | Ben Wickins | Complete | COMPLETE | T3-QU-0075 | QAG (Non-SIT LDSO) |
| 1289 | 1.5.7.3 | Develop and agree PIT Test Scenarios |  | 20d | 2024-07-02 A | 2024-07-29 A | 1288 | 100% |  | 2024-06-17 | 2024-07-29 | 31d |  |  |  |  | Non-SIT LDSO | Non-SIT LDSO, Code Bodies, LDSO |  | 5.24 | Ben Wickins | Complete | COMPLETE |  |  |
| 1290 | 1.5.7.4 | PIT Execution |  | 45d | 2024-07-30 A | 2024-09-30 | 1289 | 16% | 38d | 2024-07-30 | 2024-09-30 | 45d | -2d | 0d |  |  | Non-SIT LDSO | Non-SIT LDSO, LDSO |  | 5.24 | Ben Wickins | Green | GREEN |  |  |
| 1291 | 1.5.7.5 | Non-SIT LDSO Participants have submitted PIT Test Completion Report & evidence for QT Entry​ | milestone | 0d | 2024-09-30 | 2024-09-30 | 1290 |  |  | 2024-09-30 | 2024-09-30 | 0d | -2d | 0d |  |  | Non-SIT LDSO | Non-SIT LDSO, LDSO | 53.71 | 5.24 | Ben Wickins | Green | GREEN | T3-QU-0076 | QAG (Non-SIT LDSO) |
| 1292 | 1.5.7.6 | **Placing Reliance - Code Body & LDSO Functional and Migration** |  | 147d | 2024-01-31 A | 2024-08-22 |  | 93% | 11d | 2024-01-31 | 2024-08-22 | 147d | 25d |  |  | -0 | N/A | N/A | -100.67 | 5.24 | N/A |  |  |  |  |
| 1293 | 1.5.7.6.1 | Placing Reliance Submitted & Reviewed |  | 21d | 2024-01-31 A | 2024-02-28 A | 1228 | 100% |  | 2024-01-31 | 2024-02-28 | 21d |  |  | 2024-01-05 |  | LDSO, Non-SIT LDSO | LDSO, Non-SIT LDSO |  | 5.24 | Ben Wickins | Complete | COMPLETE |  |  |
| 1294 | 1.5.7.6.2 | Define & Agree QT Testing for Each LDSO |  | 22d | 2024-02-29 A | 2024-03-29 A | 1293 | 100% |  | 2024-02-29 | 2024-03-29 | 22d |  |  |  |  | Non-SIT LDSO | LDSO, Non-SIT LDSO |  | 5.24 | Ben Wickins | Complete | COMPLETE |  |  |
| 1295 | 1.5.7.6.3 | Develop Test Scope & Reliance Submissions |  | 20d | 2024-04-01 A | 2024-04-26 A | 1294 | 100% |  | 2024-04-01 | 2024-04-26 | 20d |  |  |  |  | Non-SIT LDSO | LDSO, Non-SIT LDSO, Code Bodies |  | 5.24 | Ben Wickins | Complete | COMPLETE |  |  |
| 1296 | 1.5.7.6.4 | Review and Consultation |  | 84d | 2024-04-29 A | 2024-08-22 | 1295, 1239FF | 87% | 11d | 2024-04-29 | 2024-08-22 | 84d | 25d | 0d |  |  | Non-SIT LDSO | LDSO, Non-SIT LDSO |  | 5.27 | Ben Wickins | Green | GREEN |  |  |

Notes:
- 1274: 13/5: New milestone approved as part of cr47. 13/5: Date change to line up with QAG
- 1277: 28/5 LDSO will complete test data cut between 3rd and 17th June
- 1280: To complete testing in accordance with test scenarios, LDSOs are required to fill gaps in their test data, potentially with synthetic data. Some LDSOs stated that they won't be able to incorporate synthetic data into their test data (Risk no: TBC). / Notes (2): LDSOs will not be able to meet the standards of M10 and achieve Qualification. Through QWG and the LQTSG we have proposed and are discussing solutions with the LDSOs, with a view to achieving full test coverage for all
- 1288: 13/5: New milestone approved as part of cr47. 11/6: Missed date because additional time requested by PPs. 24/6: Approved at QAG on 20/6
- 1291: 13/5: New milestone approved as part of cr47.

| ID | WBS | Task | Type | Duration | Start | Finish | Predecessors | Complete | Remaining | Baseline start | Baseline finish | Baseline duration | Baseline 1 start | Baseline 1 finish | Total slack | Free slack | Constraint | Baseline cost | Responsible | Involved | Task Status | Update Version | MHHS Resource Name | Sched Status | RAG | Milestone ID | Text29 | MHHS Programme Phase | Action | Tier |
| --- | --- | --- | --- | --- | --- | --- | --- | --- | --- | --- | --- | --- | --- | --- | --- | --- | --- | --- | --- | --- | --- | --- | --- | --- | --- | --- | --- | --- | --- | --- |
| 1297 | 1.5.7.7 | **Placing Reliance - Code Body & LDSO Non Functional and Operational** |  | 49d | 2024-06-17 A | 2024-08-22 |  | 78% | 11d | 2024-06-17 | 2024-08-22 | 49d |  |  | 25d |  |  | -0 | N/A | N/A | -100.67 | 5.25 | N/A |  |  |  |  |  |  |  |
| 1298 | 1.5.7.7.1 | Placing Reliance Submitted & Reviewed |  | 32d | 2024-06-17 A | 2024-07-30 A | 1237FF-10d | 100% |  | 2024-06-17 | 2024-07-30 | 32d |  |  |  |  |  |  | LDSO, Non-SIT LDSO | LDSO, Non-SIT LDSO |  | 5.27 | Ben Wickins | Complete | COMPLETE |  |  |  |  |  |
| 1299 | 1.5.7.7.2 | Review and Consultation |  | 17d | 2024-07-31 A | 2024-08-22 | 1298 | 35% | 11d | 2024-07-31 | 2024-08-22 | 17d |  |  | 25d | 0d |  |  | Non-SIT LDSO | LDSO, Non-SIT LDSO |  | 5.27 | Ben Wickins | Green | GREEN |  |  |  |  |  |
| 1300 | 1.5.7.7.3 | PP Test Scope Presented at QAG | milestone | 0d | 2024-08-22 | 2024-08-22 | 1299, 1296 |  |  | 2024-08-22 | 2024-08-22 | 0d |  |  | 25d |  |  |  | Non-SIT LDSO | LDSO, Non-SIT LDSO | 14.71 | 5.29 | Ben Wickins | Green | GREEN | T3-QU-0077 | QAG (Non-SIT LDSO) |  |  |  |
| 1301 | 1.5.8 | **LDSO Test Readiness Reporting** |  | 118d | 2024-04-19 A | 2024-10-01 |  | 62% | 45.15d | 2024-04-19 | 2024-10-01 | 118d |  |  | -3d | 0d |  | -0 | N/A | N/A |  | 5.24 | N/A |  |  |  |  |  |  |  |
| 1302 | 1.5.8.1 | Interim Test Readiness Report & Plan Developed & Reviewed |  | 71d | 2024-04-19 A | 2024-07-26 A | 1255 | 100% |  | 2024-04-19 | 2024-07-26 | 71d |  |  |  |  |  |  | Non-SIT LDSO, LDSO | Non-SIT LDSO, LDSO |  | 5.24 | Ben Wickins | Complete | COMPLETE |  |  |  |  |  |
| 1303 | 1.5.8.2 | Test Plan Submission to MHHS Programme For Review | milestone | 0d | 2024-07-26 A | 2024-07-26 A | 1302 | 100% |  | 2024-07-26 | 2024-07-26 | 0d |  |  |  |  |  |  | LDSO | Non-SIT LDSO, LDSO |  | 5.30 | Ben Wickins | Complete | COMPLETE | T3-QU-0114 | QAG (Non-SIT LDSO) |  |  |  |
| 1304 | 1.5.8.3 | Final Test Readiness Report Developed & Submitted |  | 44d | 2024-07-29 | 2024-09-26 | 1303 |  |  | 2024-07-29 | 2024-09-26 | 44d |  |  | -3d | 0d |  |  | Non-SIT LDSO | Non-SIT LDSO, LDSO | -9.67 | 5.24 | Ben Wickins | Overdue Start | GREEN |  |  |  |  |  |
| 1305 | 1.5.8.4 | Non-SIT LDSO QT Test Execution Starts | milestone | 0d | 2024-10-01 | 2024-10-01 | 1304FS+3d, 1285, 1312, 1319, 1320, 1262, 1300 |  |  | 2024-10-01 | 2024-10-01 | 0d |  |  | -3d | 0d |  |  | Non-SIT LDSO | Non-SIT LDSO, LDSO, Code Bodies | 54.71 | 5.25 | Ben Wickins | Green | AMBER | T3-QU-0115 | QAG (Non-SIT LDSO) |  |  |  |
| 1306 | 1.5.9 | **Test Environment** |  | 111d | 2024-04-17 A | 2024-09-18 |  | 65% | 38.85d | 2024-04-17 | 2024-09-18 | 111d | 2024-01-29 | 2024-07-05 | 5d |  |  | -0 | N/A | N/A |  | 5.24 | N/A |  |  |  |  | Systems Integration Testing (SIT) |  |  |
| 1307 | 1.5.9.1 | Define Test Harness Requirements and Sign-Off with SRO |  | 13d | 2024-04-17 A | 2024-05-03 A | 471 | 100% |  | 2024-04-17 | 2024-05-03 | 13d |  |  |  |  |  |  | Non-SIT LDSO | Non-SIT LDSO,SRO,Sims and Ems |  | 5.24 | Ben Wickins | Complete | COMPLETE |  |  |  |  |  |
| 1308 | 1.5.9.2 | Central System (DIP Env & Helix Test Harness) Test Environment DBT |  | 104d | 2024-04-17 A | 2024-09-09 | 471 | 73% | 28d | 2024-04-17 | 2024-08-22 | 92d |  |  | 12d | 0d |  |  | LDSO | Non SIT-LDSO, LDSO |  | 5.24 | Ben Wickins | Red | RED |  |  |  |  |  |
| 1309 | 1.5.9.3 | Coordinate LDSO Env Preparation |  | 42d | 2024-07-12 A | 2024-09-09 | 1308FF | 33% | 28d | 2024-07-12 | 2024-08-22 | 30d |  |  | 12d | 7d |  |  | Non-SIT LDSO | Non-SIT LDSO |  | 5.24 | Ben Wickins | Red | RED |  |  |  |  |  |
| 1310 | 1.5.9.4 | DIP available for Onboarding |  | 1d | 2024-08-01 A | 2024-08-01 A |  | 100% |  | 2024-08-01 | 2024-08-01 | 1d |  |  |  |  | start no earlier than 2024-08-01 |  | Test Env | Test Env, Non-SIT LDSO |  | 5.24 | Ben Wickins | Complete | COMPLETE |  |  |  | 11/3: Ask Simon B for the link |  |
| 1311 | 1.5.9.5 | Qualification Testing for Non-SIT LDSOs Participants' environments) Ready to start DIP onboarding (incl. certificates and security compliance) | milestone | 0d | 2024-08-05 A | 2024-08-05 A | 1310FS+2d | 100% |  | 2024-08-05 | 2024-08-05 | 0d | 2024-04-26 | 2024-04-26 |  |  |  |  | Non-SIT LDSO | Code Bodies, PP, IPA |  | 5.30 | Ben Wickins | Complete | COMPLETE | T3-QU-0009 | QAG (Non-SIT LDSO) | Systems Integration Testing (SIT) |  | T3 |
| 1312 | 1.5.9.6 | LDSO Test Environments Connection Confirmed to UIT Environment | milestone | 0d | 2024-09-18 | 2024-09-18 | 1311FS+32d, 1309 |  |  | 2024-09-18 | 2024-09-18 | 0d |  |  | 5d |  |  |  | Non-SIT LDSO | Code Bodies, PP, IPA | 41.71 | 5.24 | Ben Wickins | Green | AMBER | T3-QU-0078 | QAG (Non-SIT LDSO) |  |  |  |
| 1313 | 1.5.10 | **Test Readiness** |  | 65d | 2024-07-02 A | 2024-09-30 |  | 41% | 38.41d | 2024-06-17 | 2024-09-30 | 76d |  |  | -2d | 0d |  | -0 | N/A | N/A |  | 5.24 | N/A |  |  |  |  |  |  |  |
| 1314 | 1.5.10.1 | Preparation for Interim Test Readiness Report |  | 19d | 2024-07-02 A | 2024-07-26 A | 1288 | 100% |  | 2024-06-17 | 2024-07-26 | 30d |  |  |  |  |  |  | LDSO | LDSO, Non-SIT LDSO |  | 5.24 | Ben Wickins | Complete | COMPLETE |  |  |  |  |  |
| 1315 | 1.5.10.2 | Interim Test Readiness Report Submission to MHHS Programme for Review | milestone | 0d | 2024-07-26 | 2024-07-26 | 1314 |  |  | 2024-07-26 | 2024-07-26 | 0d |  |  | 8d | 0d |  |  | LDSO | Non-SIT LDSO, LDSO | -12.29 | 5.25 | Ben Wickins | Overdue Start | RED | T3-QU-0116 | QAG (Non-SIT LDSO) |  |  |  |
| 1316 | 1.5.10.3 | LDSO Update Readiness Report & Final Assurance by Programme |  | 25d | 2024-07-29 A | 2024-08-30 | 1315 | 32% | 17d | 2024-07-29 | 2024-08-30 | 25d |  |  | -3d | 0d |  |  | Non-SIT LDSO, LDSO | Non-SIT LDSO, LDSO |  | 5.24 | Ben Wickins | Green | GREEN |  |  |  |  |  |
| 1317 | 1.5.10.4 | Final Test Readiness Report Submitted to MHHS Programme |  | 1d | 2024-09-02 | 2024-09-02 | 1316 |  |  | 2024-09-02 | 2024-09-02 | 1d |  |  | 5d |  |  |  | LDSO | Non-SIT LDSO, Code Bodies | 25.33 | 5.24 | Ben Wickins | Green | GREEN |  |  |  |  |  |
| 1318 | 1.5.10.5 | Final Programme Assurance of LDSO Test Readiness |  | 21d | 2024-09-02 | 2024-09-30 | 1316 |  |  | 2024-09-02 | 2024-09-30 | 21d |  |  | -3d | 0d |  |  | Non-SIT LDSO | Non-SIT LDSO, LDSO | 25.33 | 5.24 | Ben Wickins | Green | GREEN |  |  |  |  |  |
| 1319 | 1.5.10.6 | Qualification Testing for Non-SIT LDSOs (Functional, Migration, NFT, Operational) Programme Test Readiness confirmed | milestone | 0d | 2024-09-30 | 2024-09-30 | 1317FS+13d, 1291, 1265, 1267, 1269, 1307 |  |  | 2024-09-30 | 2024-09-30 | 0d | 2024-07-05 | 2024-07-05 | -2d | 0d |  |  | Non-SIT LDSO | SI Test, PP, Non-SIT LDSO | 53.71 | 5.24 | Ben Wickins | Green | GREEN | T3-QU-0007 | QAG (Non-SIT LDSO) | Systems Integration Testing (SIT) |  | T3 |
| 1320 | 1.5.10.7 | Qualification Testing for Non-SIT LDSOs (Functional, Migration, NFT, Operational) Test Readiness Confirmed (Final Test Readiness Review for LDSO) | milestone | 0d | 2024-09-30 | 2024-09-30 | 1316, 1318 |  |  | 2024-09-30 | 2024-09-30 | 0d | 2024-07-05 | 2024-07-05 | -3d | 0d |  |  | LDSO | SI Test, PP, LDSO | 53.71 | 5.24 | Ben Wickins | Green | GREEN | T2-QU-0550 | QAG (Non-SIT LDSO) | Systems Integration Testing (SIT) |  |  |

Notes:
- 1300: Date missed because of the update to Supplier and Agent Approach and Plan. Finalised Test Scope will be presented for approval as part of the assurance around the update to Annex 1. To go to July QAG for baseline date change / Guidance: 18/7/24: Date change from 18/7/24 to 22/8/24 approved at QAG on 18/7/24
- 1303: 9 of the expected 12 Interim Test Readiness Reports and are following up with those who are outstanding. These are not a direct requirement of onboarding but a gap analysis ahead of test start
- 1305: At risk because of DIP env availability for the test harness. (Issue no: I186). Issue will be avoided if start of QT window is delayed
- 1311: At risk because of DIP env availability for the test harness. (Issue no: I186)
- 1312: At risk because of DIP env availability for the test harness. (Issue no: I186). Issue will be avoided if start of QT window is delayed
- 1315: 9 of the expected 12 Interim Test Readiness Reports have been received and are following up with those who are outstanding. These are not a direct requirement of onboarding but a gap analysis ahead of test start
- 1319: 13/5: Date rebaselined as part of cr47
- 1320: 13/5: New milestone approved as part of cr47.

| ID | WBS | Task | Type | Duration | Start | Finish | Predecessors | Complete | Remaining | Baseline start | Baseline finish | Baseline duration | Baseline 1 start | Baseline 1 finish | Total slack | Free slack | Constraint | Baseline cost | Responsible | Involved | Task Status | Update Version | MHHS Resource Name | Sched Status | RAG | Notes (2) | Milestone ID | Text29 | MHHS Programme Phase |
| --- | --- | --- | --- | --- | --- | --- | --- | --- | --- | --- | --- | --- | --- | --- | --- | --- | --- | --- | --- | --- | --- | --- | --- | --- | --- | --- | --- | --- | --- |
| 1321 | 1.5.11 | **Test Window** |  | 59d | 2024-10-01 | 2024-12-20 |  |  |  | 2024-10-01 | 2024-12-20 | 59d |  |  | -3d | 0d |  | -0 | N/A | N/A | -527.67 | 5.24 | N/A |  |  |  |  |  |  |
| 1322 | 1.5.11.1 | All Non-SIT LDSOs Qualification Testing |  | 59d | 2024-10-01 | 2024-12-20 | 1320, 1312 |  |  | 2024-10-01 | 2024-12-20 | 59d |  |  | -3d | 0d |  |  | LDSO | Non-SIT LDSO,Code Bodies, LDSO | 54.33 | 5.24 | Ben Wickins | Green | AMBER | 5/8/24 avoided if start of QT window is delayed |  |  |  |
| 1323 | 1.5.12 | **Test Result Assurance** |  | 60d | 2024-11-04 | 2025-01-24 |  |  |  | 2024-11-04 | 2025-01-24 | 60d |  |  | -3d | 0d |  | -0 | N/A | N/A |  | 5.24 | N/A |  |  |  |  |  |  |
| 1324 | 1.5.12.1 | LDSOs Develop & Submit Test Report (QT Test Completion Report) |  | 19d | 2024-11-04 | 2024-11-28 | 1305FS+23d |  |  | 2024-11-04 | 2024-11-28 | 19d |  |  | -3d | 0d |  |  | LDSO | Non-SIT LDSO, LDSO | 88.33 | 5.24 | Ben Wickins | Green | GREEN |  |  |  |  |
| 1325 | 1.5.12.2 | Test Reports Reviewed By MHHS & Code Bodies & Finalised |  | 16d | 2024-11-29 | 2024-12-20 | 1324 |  |  | 2024-11-29 | 2024-12-20 | 16d |  |  | -3d | 0d |  |  | Non-SIT LDSO | Non-SIT LDSO, Code Bodies | 113.33 | 5.24 | Ben Wickins | Green | GREEN |  |  |  |  |
| 1326 | 1.5.12.3 | Non-SIT LDSOs submission deadline for their QT Test Completion Report to MHHS Programme | milestone | 0d | 2024-12-20 | 2024-12-20 | 1325, 1322 |  |  | 2024-12-20 | 2024-12-20 | 0d |  |  | -3d | 0d |  |  | Non-SIT LDSO | Non-SIT LDSO | 134.71 | 5.24 | Ben Wickins | Green | GREEN |  | T3-QU-0079 | QAG (Non-SIT LDSO) |  |
| 1327 | 1.5.12.4 | Qualification Testing for Non-SIT LDSOs (Functional, Migration, NFT, Operational) 1 End | milestone | 0d | 2025-01-24 | 2025-01-24 | 1326FS+25d, 1281 |  |  | 2025-01-24 | 2025-01-24 | 0d |  |  | 17d |  |  |  | Non-SIT LDSO | Non-SIT LDSO | 169.71 | 5.24 | Ben Wickins | Green | GREEN |  | T3-QU-0010 | QAG (Non-SIT LDSO) |  |
| 1328 | 1.5.13 | **Non-SIT LDSO Qualification Closure** |  | 45d | 2024-12-23 | 2025-02-21 |  |  |  | 2024-12-23 | 2025-02-28 | 49d |  |  | -3d | 0d |  | -0 | N/A | N/A |  | 5.24 | N/A |  |  |  |  |  |  |
| 1329 | 1.5.13.1 | Non-SIT LDSO Qualification Learned Captured |  | 15d | 2024-12-23 | 2025-01-10 | 1326 |  |  | 2024-12-23 | 2025-01-10 | 15d |  |  | -3d | 0d |  |  | Non-SIT LDSO | Non-SIT LDSO | 137.33 | 5.24 | Ben Wickins | Green | GREEN |  |  |  |  |
| 1330 | 1.5.13.2 | Non-SIT LDSO Qualification Closure Down |  | 5d | 2025-01-13 | 2025-01-17 | 1329 |  |  | 2025-01-13 | 2025-01-17 | 5d |  |  | -3d | 0d |  |  | Non-SIT LDSO | Non-SIT LDSO | 158.33 | 5.24 | Ben Wickins | Green | GREEN |  |  |  |  |
| 1331 | 1.5.13.3 | BSC PAB & REC Manager approval of Qualification for Non-SIT LDSOs (Start of Migration for Qualification Participants) | milestone | 0d | 2025-02-21 | 2025-02-21 | 1330FS+25d, 1327, 1420, 1421 |  |  | 2025-02-28 | 2025-02-28 | 0d |  |  | -3d | 0d |  |  | Non-SIT LDSO | Non-SIT LDSO | 197.71 | 5.24 | Ben Wickins | Green | GREEN |  | T2-QU-0500 | QAG (Non-SIT LDSO) |  |
| 1332 | 1.6 | **S & A QUALIFICATION** |  | 604d | 2023-11-07 A | 2026-02-27 |  | 33% | 405.9d | 2023-11-07 | 2026-02-27 | 603d | 2024-01-29 | 2024-07-05 | 325d |  |  | -0 | N/A | N/A | -461.67 |  | N/A |  |  |  |  |  | Systems Integration Testing (SIT) |
| 1333 | 1.6.1 | **MHHS Qualification - Qualification Deliverables** |  | 349d | 2023-11-07 A | 2025-03-07 |  | 85% | 52.62d | 2023-11-07 | 2025-03-07 | 349d |  |  | 2d |  |  | -0 | N/A | N/A | -131.67 | 5.24 | N/A |  |  |  |  |  |  |
| 1334 | 1.6.1.1 | **BSC & REC Assessment Criteria** |  | 213d | 2023-11-07 A | 2024-08-29 |  | 99% | 0d | 2023-11-07 | 2024-08-29 | 212d |  |  | 56d |  |  | -0 | N/A | N/A | -131.67 | 5.24 | N/A |  |  |  |  |  |  |
| 1335 | 1.6.1.1.1 | Draft BSC Assessment Criteria (Functional) |  | 21d | 2023-11-07 A | 2023-12-05 A |  | 100% |  | 2023-11-07 | 2023-12-05 | 21d |  |  |  |  | finish no earlier than 2023-12-05 |  | Code Bodies | Code Bodies |  | 5.24 | Laura Kennedy | Complete | COMPLETE |  |  |  |  |
| 1336 | 1.6.1.1.2 | BSC PAB Review |  | 1d | 2023-12-14 A | 2023-12-14 A |  | 100% |  | 2023-12-14 | 2023-12-14 | 1d |  |  |  |  | start no earlier than 2023-12-14 |  | Code Bodies | Code Bodies |  | 5.24 | Laura Kennedy | Complete | COMPLETE |  |  |  |  |
| 1337 | 1.6.1.1.3 | Update BSC Assessment Criteria (Functional, Non-Functional, Migration) |  | 30d | 2024-02-07 A | 2024-03-19 A |  | 100% |  | 2024-02-07 | 2024-03-19 | 30d |  |  |  |  | finish no earlier than 2024-03-19 |  | Code Bodies | Code Bodies |  | 5.24 | Laura Kennedy | Complete | COMPLETE |  |  |  |  |
| 1338 | 1.6.1.1.4 | REC & BSC PAB Approval |  | 3d | 2024-03-26 A | 2024-03-28 A |  | 100% |  | 2024-03-26 | 2024-03-28 | 3d |  |  |  |  | start no earlier than 2024-03-28 |  | Code Bodies | Code Bodies |  | 5.24 | Laura Kennedy | Complete | COMPLETE |  |  |  |  |
| 1339 | 1.6.1.1.5 | Update BSC Assessment Criteria (Functional, Non-Functional, Migration, Operational) |  | 20d | 2024-07-24 A | 2024-08-20 A | 983FS+28d | 100% |  | 2024-07-24 | 2024-08-20 | 20d |  |  |  |  |  |  | Code Bodies | Code Bodies |  | 5.24 | Laura Kennedy | Complete | COMPLETE |  |  |  |  |
| 1340 | 1.6.1.1.6 | Assessment Criteria (Functional, Non-Functional, Migration, Operational) Approved by REC PAB and BSC PAB | milestone | 0d | 2024-08-29 | 2024-08-29 | 1339FS+7d |  |  | 2024-08-29 | 2024-08-29 | 0d |  |  | 56d | 6d |  |  | Code Bodies | Code Bodies | 21.71 | 5.25 | Laura Kennedy | yellow | GREEN |  | T3-QU-0080 | QAG |  |
| 1341 | 1.6.1.2 | **Qualification Approach and Plan** |  | 194d | 2023-12-04 A | 2024-08-29 |  | 97% | 5.75d | 2023-12-04 | 2024-08-29 | 194d |  |  | 88d |  |  | -0 | N/A | N/A | -131.67 | 5.24 | N/A |  |  |  |  |  |  |
| 1342 | 1.6.1.2.1 | **Qualification Approach and Plan v2** |  | 84d | 2023-12-04 A | 2024-03-28 A |  | 100% |  | 2023-12-04 | 2024-03-28 | 84d |  |  |  |  |  | -0 | N/A | N/A | -131.67 | 5.24 | N/A |  |  |  |  |  |  |
| 1343 | 1.6.1.2.1.1 | Draft Qualification Approach and Plan v2 |  | 30d | 2023-12-04 A | 2024-01-12 A |  | 100% |  | 2023-12-04 | 2024-01-12 | 30d |  |  |  |  | finish no earlier than 2024-01-12 |  | Code Bodies | Code Bodies |  | 5.24 | Laura Kennedy | Complete | COMPLETE |  |  |  |  |
| 1344 | 1.6.1.2.1.2 | Internal Review (Code Bodies and MHHSP) for Qualification Approach and Plan V2 |  | 10d | 2024-01-15 A | 2024-01-26 A | 1343 | 100% |  | 2024-01-15 | 2024-01-26 | 10d |  |  |  |  | finish no earlier than 2024-01-26 |  | Code Bodies, SI Team, SRO | Code Bodies, SI Team, SRO |  | 5.24 | Laura Kennedy | Complete | COMPLETE |  |  |  |  |
| 1345 | 1.6.1.2.1.3 | Industry consultation for Qualification Approach and Plan v2 |  | 11d | 2024-01-31 A | 2024-02-14 A | 1344 | 100% |  | 2024-01-31 | 2024-02-14 | 11d |  |  |  |  | start no earlier than 2024-01-31 |  | Participants | Participants |  | 5.24 | Laura Kennedy | Complete | COMPLETE |  |  |  |  |
| 1346 | 1.6.1.2.1.4 | Update Qualification Approach and Plan v2 post industry consultation |  | 10d | 2024-02-15 A | 2024-02-28 A | 1345 | 100% |  | 2024-02-15 | 2024-02-28 | 10d |  |  |  |  |  |  | Code Bodies | Code Bodies |  | 5.24 | Laura Kennedy | Complete | COMPLETE |  |  |  |  |
| 1347 | 1.6.1.2.1.5 | QWG Endorsement of Qualification Approach and Plan v2 |  | 1d | 2024-03-12 A | 2024-03-12 A |  | 100% |  | 2024-03-12 | 2024-03-12 | 1d |  |  |  |  | start no earlier than 2024-03-12 |  | Code Bodies | Code Bodies |  | 5.24 | Laura Kennedy | Complete | COMPLETE |  |  |  |  |
| 1348 | 1.6.1.2.1.6 | QAG Approval of Qualification Approach and Plan v2 |  | 1d | 2024-03-21 A | 2024-03-21 A |  | 100% |  | 2024-03-21 | 2024-03-21 | 1d |  |  |  |  | start no earlier than 2024-03-21 |  | Code Bodies | Code Bodies |  | 5.24 | Laura Kennedy | Complete | COMPLETE |  |  |  |  |
| 1349 | 1.6.1.2.1.7 | BSC and REC PAB Approval of Qualification Approach and Plan v2 |  | 3d | 2024-03-26 A | 2024-03-28 A |  | 100% |  | 2024-03-26 | 2024-03-28 | 3d |  |  |  |  | finish no earlier than 2024-03-28 |  | Code Bodies | Code Bodies |  | 5.24 | Laura Kennedy | Complete | COMPLETE |  |  |  |  |
| 1350 | 1.6.1.2.1.8 | Functional Testing elements of Qualification Approach & Plan v2 approvement by REC PAB and BSC PAB | milestone | 0d | 2024-03-28 A | 2024-03-28 A | 1349 | 100% |  | 2024-03-28 | 2024-03-28 | 0d |  |  |  |  |  |  | Code Bodies | Code Bodies |  | 5.24 | Laura Kennedy | Complete | COMPLETE |  | T3-QU-0063 | QAG |  |
| 1351 | 1.6.1.2.1.9 | Migration Testing elements of Qualification Approach & Plan v2 appoved by REC PAB and BSC PAB | milestone | 0d | 2024-03-28 A | 2024-03-28 A | 1349 | 100% |  | 2024-03-28 | 2024-03-28 | 0d |  |  |  |  |  |  | Code Bodies | Code Bodies |  | 5.24 | Laura Kennedy | Complete | COMPLETE |  | T3-QU-0064 | QAG |  |

Notes:
- 1322: 5/8/24: Date will not be met because of re-planning activity around SIT Cycle 2 Maintenance window. Maintain dialog with Programme scenario planing from SIT. At risk because of DIP env availability for the test harness. (Issue no: I186). Issue will be
- 1326: 13/5: New milestone approved as part of cr47.
- 1327: 13/5: No change as part of cr47
- 1331: 13/5: name changed as part of cr47.

| ID | WBS | Task | Type | Duration | Start | Finish | Predecessors | Complete | Remaining | Baseline start | Baseline finish | Baseline duration | Total slack | Free slack | Constraint | Baseline cost | Responsible | Involved | Task Status | Update Version | MHHS Resource Name | Sched Status | RAG | Milestone ID | Text29 |
| --- | --- | --- | --- | --- | --- | --- | --- | --- | --- | --- | --- | --- | --- | --- | --- | --- | --- | --- | --- | --- | --- | --- | --- | --- | --- |
| 1352 | 1.6.1.2.2 | **Qualification Approach and Plan v3** |  | 84d | 2024-05-06 A | 2024-08-29 |  | 94% | 4.87d | 2024-05-06 | 2024-08-29 | 84d | 88d |  |  | -0 | N/A | N/A | -133.67 | 5.24 | N/A |  |  |  |  |
| 1353 | 1.6.1.2.2.1 | Draft Qualification Approach and Plan v3 |  | 35d | 2024-05-06 A | 2024-06-21 A | 918 | 100% |  | 2024-05-06 | 2024-06-21 | 35d |  |  | finish no earlier than 2024-05-17 |  | Code Bodies | Code Bodies |  | 5.27 | Laura Kennedy | Complete | COMPLETE |  |  |
| 1354 | 1.6.1.2.2.2 | Internal Review (Code Bodies and MHHSP) of Qualification Approach and Plan v3 |  | 10d | 2024-06-24 A | 2024-07-05 A | 1353 | 100% |  | 2024-06-24 | 2024-07-05 | 10d |  |  |  |  | Code Bodies, SI Team, SRO | Code Bodies, SI Team, SRO |  | 5.27 | Laura Kennedy | Complete | COMPLETE |  |  |
| 1355 | 1.6.1.2.2.3 | Industry consultation for Qualification Approach and Plan v3 |  | 10d | 2024-07-08 A | 2024-07-19 A | 1354 | 100% |  | 2024-07-08 | 2024-07-19 | 10d |  |  |  |  | Participants | Participants |  | 5.27 | Laura Kennedy | Complete | COMPLETE |  |  |
| 1356 | 1.6.1.2.2.4 | Update Qualification Approach and Plan v3 Post-Consultation |  | 10d | 2024-07-22 A | 2024-08-02 A | 1355 | 100% |  | 2024-07-22 | 2024-08-02 | 10d |  |  |  |  | Code Bodies | Code Bodies |  | 5.27 | Laura Kennedy | Complete | COMPLETE |  |  |
| 1357 | 1.6.1.2.2.5 | QWG Endorsement of Qualification Approach and Plan v3 |  | 1d | 2024-08-13 | 2024-08-13 | 1356FS+6d |  |  | 2024-08-13 | 2024-08-13 | 1d | 88d | 0d |  |  | Code Bodies | Code Bodies | 5.33 | 5.27 | Laura Kennedy | Green | GREEN |  |  |
| 1358 | 1.6.1.2.2.6 | QAG Approval of Qualification Approach and Plan v3 | milestone | 0d | 2024-08-22 | 2024-08-22 | 1357FS+7d |  |  | 2024-08-22 | 2024-08-22 | 0d | 88d | 0d |  |  | Code Bodies | Code Bodies | 14.71 | 5.27 | Laura Kennedy | Green | GREEN | T3-QU-0081 | QAG |
| 1359 | 1.6.1.2.2.7 | BSC and REC PAB Approval of Qualification Approach and Plan v3 |  | 3d | 2024-08-27 | 2024-08-29 | 1358FS+2d |  |  | 2024-08-27 | 2024-08-29 | 3d | 88d | 0d |  |  | Code Bodies | Code Bodies | 19.33 | 5.27 | Laura Kennedy | Green | GREEN |  |  |
| 1360 | 1.6.1.2.2.8 | Non-Functional Testing elements of Qualification Approach and Plan v3 approved by REC PAB and BSC PAB | milestone | 0d | 2024-08-29 | 2024-08-29 | 1359 |  |  | 2024-08-29 | 2024-08-29 | 0d | 88d | 8d |  |  | Code Bodies | Code Bodies | 21.71 | 5.27 | Laura Kennedy | Green | GREEN | T3-QU-0065 | QAG |
| 1361 | 1.6.1.3 | **Qualification Assessment Document** |  | 316d | 2023-12-22 A | 2025-03-07 |  | 76% | 75.48d | 2023-12-22 | 2025-03-07 | 316d | 2d |  |  | -0 | N/A | N/A | -131.67 | 5.24 | N/A |  |  |  |  |
| 1362 | 1.6.1.3.1 | **Qualification Assessment Document v1** |  | 70d | 2023-12-22 A | 2024-03-28 A |  | 100% |  | 2023-12-22 | 2024-03-28 | 70d |  |  |  | -0 | N/A | N/A | -131.67 | 5.24 | N/A |  |  |  |  |
| 1363 | 1.6.1.3.1.1 | Draft Qualification Assessment Document v1 |  | 30d | 2023-12-22 A | 2024-02-01 A |  | 100% |  | 2023-12-22 | 2024-02-01 | 30d |  |  | finish no earlier than 2024-02-01 |  | Code Bodies | Code Bodies |  | 5.24 | Laura Kennedy | Complete | COMPLETE |  |  |
| 1364 | 1.6.1.3.1.2 | Internal Review (Code Bodies and MHHSP) of Qualification Assessment Document v1 |  | 10d | 2024-02-01 A | 2024-02-14 A |  | 100% |  | 2024-02-01 | 2024-02-14 | 10d |  |  | finish no earlier than 2024-02-14 |  | Code Bodies, SI Team, SRO | Code Bodies, SI Team, SRO |  | 5.24 | Laura Kennedy | Complete | COMPLETE |  |  |
| 1365 | 1.6.1.3.1.3 | Industry consultation for Qualification Assessment Document v1 |  | 11d | 2024-02-16 A | 2024-03-01 A |  | 100% |  | 2024-02-16 | 2024-03-01 | 11d |  |  | start no earlier than 2024-02-16 |  | Participants | Participants |  | 5.24 | Laura Kennedy | Complete | COMPLETE |  |  |
| 1366 | 1.6.1.3.1.4 | Update Post-Consultation for Qualification Assessment Document v1 |  | 10d | 2024-03-04 A | 2024-03-15 A | 1365 | 100% |  | 2024-03-04 | 2024-03-15 | 10d |  |  |  |  | Code Bodies | Code Bodies |  | 5.24 | Laura Kennedy | Complete | COMPLETE |  |  |
| 1367 | 1.6.1.3.1.5 | BSC and REC PAB Approval of Qualification Assessment Document v1 |  | 3d | 2024-03-26 A | 2024-03-28 A |  | 100% |  | 2024-03-26 | 2024-03-28 | 3d |  |  | start no earlier than 2024-03-26 |  | Code Bodies | Code Bodies |  | 5.24 | Laura Kennedy | Complete | COMPLETE |  |  |
| 1368 | 1.6.1.3.1.6 | Qualification Assessment Document v1 approved by REC PAB and BSC PAB | milestone | 0d | 2024-03-28 A | 2024-03-28 A | 1367 | 100% |  | 2024-03-28 | 2024-03-28 | 0d |  |  |  |  | Code Bodies | Code Bodies |  | 5.24 | Laura Kennedy | Complete | COMPLETE | T3-QU-0066 | QAG |
| 1369 | 1.6.1.3.2 | **Qualification Assessment Document v2** |  | 110d | 2024-03-29 A | 2024-08-29 |  | 94% | 6.96d | 2024-03-29 | 2024-08-29 | 110d | 62d |  |  | -0 | N/A | N/A | -131.67 | 5.24 | N/A |  |  |  |  |
| 1370 | 1.6.1.3.2.1 | Draft Qualification Assessment Document V1.1 |  | 26d | 2024-03-29 A | 2024-05-03 A | 1368 | 100% |  | 2024-03-29 | 2024-05-03 | 26d |  |  |  |  |  |  |  | 5.24 | Laura Kennedy | Complete | COMPLETE |  |  |
| 1371 | 1.6.1.3.2.2 | Industry Consultation for Qualification Assessment Document V1.1 |  | 12d | 2024-05-06 A | 2024-05-21 A | 1370 | 100% |  | 2024-05-06 | 2024-05-21 | 12d |  |  |  |  |  |  |  | 5.24 | Laura Kennedy | Complete | COMPLETE |  |  |
| 1372 | 1.6.1.3.2.3 | Draft Qualification Assessment Document v2 |  | 6d | 2024-06-14 A | 2024-06-21 A | 977, 983, 1371 | 100% |  | 2024-06-14 | 2024-06-21 | 6d |  |  |  |  | Code Bodies | Code Bodies |  | 5.24 | Laura Kennedy | Complete | COMPLETE |  |  |
| 1373 | 1.6.1.3.2.4 | Internal Review (Code Bodies and MHHSP) of Qualification Assessment Document v2 |  | 10d | 2024-06-24 A | 2024-07-05 A | 1372 | 100% |  | 2024-06-24 | 2024-07-05 | 10d |  |  |  |  | Code Bodies, SI Team, SRO | Code Bodies, SI Team, SRO |  | 5.24 | Laura Kennedy | Complete | COMPLETE |  |  |
| 1374 | 1.6.1.3.2.5 | Industry consultation for Qualification Assessment Document v2 |  | 10d | 2024-07-08 A | 2024-07-19 A | 1373 | 100% |  | 2024-07-08 | 2024-07-19 | 10d |  |  |  |  | Participants | Participants |  | 5.24 | Laura Kennedy | Complete | COMPLETE |  |  |
| 1375 | 1.6.1.3.2.6 | Update Post-Consultation for Qualification Assessment Document v2 |  | 10d | 2024-07-22 A | 2024-08-02 A | 1374 | 100% |  | 2024-07-22 | 2024-08-02 | 10d |  |  |  |  | Code Bodies | Code Bodies |  | 5.24 | Laura Kennedy | Complete | COMPLETE |  |  |
| 1376 | 1.6.1.3.2.7 | QWG Endorsement of Qualification Assessment Document v2 |  | 1d | 2024-08-13 | 2024-08-13 | 1375FS+6d |  |  | 2024-08-13 | 2024-08-13 | 1d | 62d | 0d |  |  | Code Bodies | Code Bodies | 5.33 | 5.24 | Laura Kennedy | Green | GREEN |  |  |
| 1377 | 1.6.1.3.2.8 | QAG Endorsement of Qualification Assessment Document v2 |  | 1d | 2024-08-22 | 2024-08-22 | 1376FS+6d |  |  | 2024-08-22 | 2024-08-22 | 1d | 62d | 0d |  |  | Code Bodies | Code Bodies | 14.33 | 5.25 | Laura Kennedy | Green | GREEN | T3-QU-0083 | QAG |
| 1378 | 1.6.1.3.2.9 | BSC and REC PAB Approval of Qualification Assessment Document v2 |  | 3d | 2024-08-27 | 2024-08-29 | 1377FS+2d |  |  | 2024-08-27 | 2024-08-29 | 3d | 62d | 0d |  |  | Code Bodies | Code Bodies | 19.33 | 5.24 | Laura Kennedy | Green | GREEN |  |  |
| 1379 | 1.6.1.3.2.10 | Qualification Assessment Document v2 approved by REC PAB and BSC PAB | milestone | 0d | 2024-08-29 | 2024-08-29 | 1378 |  |  | 2024-08-29 | 2024-08-29 | 0d | 62d | 0d |  |  | Code Bodies | Code Bodies | 21.71 | 5.24 | Laura Kennedy | Green | GREEN | T3-QU-0067 | QAG |

Notes:
- 1358: 28/5: Late because of delay to approval of SIT Non Functional approach. Re-planned to align to v4. To go to June QAG for baseline date change. 24/6: Approved at QAG on 20/6
- 1360: 28/5: Late because of delay to approval of SIT Non Functional approach. Re-planned to align to v4. 24/6: Approved at QAG on 20/6

| ID | WBS | Task | Type | Duration | Start | Finish | Predecessors | Complete | Remaining | Baseline start | Baseline finish | Baseline duration | Baseline 1 start | Baseline 1 finish | Total slack | Free slack | Constraint | Baseline cost | Responsible | Involved | Task Status | Update Version | MHHS Resource Name | Sched Status | RAG | Milestone ID | Text29 | MHHS Programme Phase |
| --- | --- | --- | --- | --- | --- | --- | --- | --- | --- | --- | --- | --- | --- | --- | --- | --- | --- | --- | --- | --- | --- | --- | --- | --- | --- | --- | --- | --- |
| 1380 | 1.6.1.3.3 | **Qualification Assessment Document Portal** |  | 285d | 2024-02-05 A | 2025-03-07 |  | 59% | 116.67d | 2024-02-05 | 2025-03-07 | 285d |  |  | 2d |  |  | -0 | N/A | N/A | -131.67 | 5.24 | N/A |  |  |  |  |  |
| 1381 | 1.6.1.3.3.1 | Design Completion |  | 30d | 2024-02-05 A | 2024-03-15 A |  | 100% |  | 2024-02-05 | 2024-03-15 | 30d |  |  |  |  | finish no earlier than 2024-03-15 |  | QAD Portal Dev Team | QAD Portal Dev Team |  | 5.24 | Laura Kennedy | Complete | COMPLETE |  |  |  |
| 1382 | 1.6.1.3.3.2 | Qualification Assessment Document Portal Build |  | 30d | 2024-03-18 A | 2024-04-26 A | 1381 | 100% |  | 2024-03-18 | 2024-04-26 | 30d |  |  |  |  |  |  | QAD Portal Dev Team | QAD Portal Dev Team |  | 5.24 | Laura Kennedy | Complete | COMPLETE |  |  |  |
| 1383 | 1.6.1.3.3.3 | Qualification Assessment Document Internal Testing |  | 20d | 2024-04-29 A | 2024-05-24 A | 1382 | 100% |  | 2024-04-29 | 2024-05-24 | 20d |  |  |  |  |  |  | QAD Portal Dev Team. Code Bodies | QAD Portal Dev Team. Code Bodies |  | 5.24 | Laura Kennedy | Complete | COMPLETE |  |  |  |
| 1384 | 1.6.1.3.3.4 | Qualification Assessment Document Portal Training and Onboarding Material Creation |  | 20d | 2024-05-27 A | 2024-06-21 A | 1383 | 100% |  | 2024-05-27 | 2024-06-21 | 20d |  |  |  |  |  |  | QAD Portal Dev Team | QAD Portal Dev Team |  | 5.24 | Laura Kennedy | Complete | COMPLETE |  |  |  |
| 1385 | 1.6.1.3.3.5 | Qualification Assessment Document Portal Webinar (Date TBC) |  | 1d | 2024-06-18 A | 2024-06-18 A |  | 100% |  | 2024-06-11 | 2024-06-11 | 1d |  |  |  |  | start no earlier than 2024-06-18 |  | QAD Portal Dev Team | QAD Portal Dev Team |  | 5.24 | Laura Kennedy | Complete | COMPLETE |  |  |  |
| 1386 | 1.6.1.3.3.6 | SIT Participant QAD Application Creation in Portal |  | 10d | 2024-08-12 | 2024-08-23 | 1384FS+35d |  |  | 2024-08-12 | 2024-08-23 | 10d |  |  | 1d | 0d |  |  | Code Bodies | Code Bodies | 4.33 | 5.24 | Laura Kennedy | Green | GREEN |  |  |  |
| 1387 | 1.6.1.3.3.7 | Non-SIT LDSO Participant QAD Application Creation in Portal |  | 10d | 2024-08-12 | 2024-08-23 | 1384FS+35d |  |  | 2024-08-12 | 2024-08-23 | 10d |  |  | 7d | 0d |  |  | Code Bodies | Code Bodies | 4.33 | 5.24 | Laura Kennedy | Green | GREEN |  |  |  |
| 1388 | 1.6.1.3.3.8 | QT Wave 1 Participant QAD Application Creation in Portal |  | 10d | 2024-09-23 | 2024-10-04 | 1384FS+65d |  |  | 2024-09-23 | 2024-10-04 | 10d |  |  | 1d | 0d |  |  | Code Bodies | Code Bodies | 46.33 | 5.24 | Laura Kennedy | Green | GREEN |  |  |  |
| 1389 | 1.6.1.3.3.9 | QT Wave 2 Participant QAD Application Creation in Portal |  | 10d | 2024-10-28 | 2024-11-08 | 1384FS+90d |  |  | 2024-10-28 | 2024-11-08 | 10d |  |  | 1d | 0d |  |  | Code Bodies | Code Bodies | 81.33 | 5.27 | Laura Kennedy | Green | GREEN |  |  |  |
| 1390 | 1.6.1.3.3.10 | QT Wave 3 Participant QAD Application Creation in Portal |  | 10d | 2024-12-30 | 2025-01-10 | 1384FS+135d |  |  | 2024-12-30 | 2025-01-10 | 10d |  |  | 2d | 0d |  |  | Code Bodies | Code Bodies | 144.33 | 5.27 | Laura Kennedy | Green | GREEN |  |  |  |
| 1391 | 1.6.1.3.3.11 | QT Wave 4 Participant QAD Application Creation in Portal |  | 10d | 2025-02-24 | 2025-03-07 | 1384FS+175d |  |  | 2025-02-24 | 2025-03-07 | 10d |  |  | 2d | 0d |  |  | Code Bodies | Code Bodies | 200.33 | 5.27 | Laura Kennedy | Green | GREEN |  |  |  |
| 1392 | 1.6.1.3.3.12 | Update to Qualification Assessment Document Portal post QAD V2 |  | 10d | 2024-08-30 | 2024-09-12 | 1379 |  |  | 2024-08-30 | 2024-09-12 | 10d |  |  | 62d | 0d |  |  | QAD Portal Dev Team | QAD Portal Dev Team | 22.33 | 5.24 | Laura Kennedy | Green | GREEN |  |  |  |
| 1393 | 1.6.1.3.3.13 | Update to Qualification Assessment Document Portal post QAD V2 Complete | milestone | 0d | 2024-09-12 | 2024-09-12 | 1392 |  |  | 2024-09-12 | 2024-09-12 | 0d |  |  | 62d | 56d |  |  | QAD Portal Dev Team | QAD Portal Dev Team | 35.71 | 5.25 | Laura Kennedy | Green | GREEN | T3-QU-0084 | QAG |  |
| 1394 | 1.6.2 | **MHHS Qualification - SIT Participants** |  | 194d | 2024-09-02 | 2025-05-30 |  |  |  | 2024-09-02 | 2025-05-30 | 194d | 2024-01-29 | 2024-07-05 | 1d |  |  | -0 | N/A | N/A | -133.67 | 5.24 | N/A |  |  |  |  | Systems Integration Testing (SIT) |
| 1395 | 1.6.2.1 | Initial QAD Submission Window opens | milestone | 0d | 2024-09-02 | 2024-09-02 | 1386FS+6d |  |  | 2024-09-02 | 2024-09-02 | 0d |  |  | 1d | 0d |  |  | Participants | Participants | 25.71 | 5.24 | Laura Kennedy | yellow | GREEN |  |  |  |
| 1396 | 1.6.2.2 | SIT Participants submit Initial QAD |  | 28d | 2024-09-03 | 2024-10-10 | 1395 |  |  | 2024-09-02 | 2024-10-10 | 29d |  |  | 1d | 0d |  |  | Participants | Participants | 26.33 | 5.24 | Laura Kennedy | Green | GREEN |  |  |  |
| 1397 | 1.6.2.3 | Code Bodies review Initial QAD |  | 36d | 2024-10-11 | 2024-11-29 | 1396 |  |  | 2024-10-11 | 2024-11-29 | 36d |  |  | 1d | 0d |  |  | Code Bodies | Code Bodies | 64.33 | 5.24 | Laura Kennedy | Green | GREEN |  |  |  |
| 1398 | 1.6.2.4 | Completion of Code Bodies review of Initial QAD | milestone | 0d | 2024-11-29 | 2024-11-29 | 1397 |  |  | 2024-11-29 | 2024-11-29 | 0d |  |  | 1d | 0d |  |  | Code Bodies | Code Bodies | 113.71 | 5.24 | Laura Kennedy | Green | GREEN |  |  |  |
| 1399 | 1.6.2.5 | **MHHS Qualification - SIT MVC Participants** |  | 65d | 2024-11-29 | 2025-02-28 |  |  |  | 2024-11-29 | 2025-02-28 | 64d |  |  | 1d |  |  |  | N/A | N/A | -154.67 | 5.24 | N/A |  |  |  |  |  |
| 1400 | 1.6.2.5.1 | Final QAD Submission Window (MVC) opens | milestone | 0d | 2024-11-29 | 2024-11-29 | 1397, 1393, 1398 |  |  | 2024-11-29 | 2024-11-29 | 0d |  |  | 6d | 0d |  |  | Participants | Participants | 113.71 | 5.24 | Laura Kennedy | Green | GREEN |  |  |  |
| 1401 | 1.6.2.5.2 | SIT MVC Participants submit Final QAD |  | 26d | 2024-12-02 | 2025-01-06 | 1400 |  |  | 2024-12-02 | 2025-01-06 | 26d |  |  | 6d | 0d |  |  | Participants | Participants | 116.33 | 5.24 | Laura Kennedy | Green | GREEN |  |  |  |
| 1402 | 1.6.2.5.3 | Completion of Code Bodies review of Final QAD (MVC) |  | 19d | 2025-01-07 | 2025-01-31 | 1401, 1064FF |  |  | 2025-01-07 | 2025-01-31 | 19d |  |  | 6d | 5d |  |  | Code Bodies | Code Bodies | 152.33 | 5.24 | Laura Kennedy | Green | GREEN |  |  |  |
| 1403 | 1.6.2.5.4 | QAD Sign Off Deadline (MVC) | milestone | 0d | 2025-02-07 | 2025-02-07 | 1073, 1402 |  |  | 2025-02-07 | 2025-02-07 | 1d |  |  | 1d | 0d |  |  | Participants | Participants | 183.71 | 5.24 | Laura Kennedy | Green | GREEN |  |  |  |
| 1404 | 1.6.2.5.5 | REC Code Manager / BSC PAB Approval of Qualification (MVC) | milestone | 0d | 2025-02-28 | 2025-02-28 | 1403FS+15d |  |  | 2025-02-28 | 2025-02-28 | 0d |  |  | 1d | 0d |  |  | Code Bodies | Code Bodies | 204.71 | 5.25 | Laura Kennedy | yellow | AMBER | T3-QU-0085 | QAG |  |

Notes:
- 1404: 6/8/24: Date at risk from scenario planning activity

| ID | WBS | Task | Type | Duration | Start | Finish | Predecessors | Complete | Remaining | Baseline start | Baseline finish | Baseline duration | Total slack | Free slack | Constraint | Baseline cost | Responsible | Involved | Task Status | Update Version | MHHS Resource Name | Sched Status | RAG | Milestone ID | Text29 |
| --- | --- | --- | --- | --- | --- | --- | --- | --- | --- | --- | --- | --- | --- | --- | --- | --- | --- | --- | --- | --- | --- | --- | --- | --- | --- |
| 1405 | 1.6.2.6 | **MHHS Qualification - SIT Non-MVC Participants** |  | 129d | 2024-12-02 | 2025-05-30 |  |  |  | 2024-12-02 | 2025-05-30 | 129d | 1d |  |  |  | N/A | N/A | -154.67 | 5.24 | N/A |  |  |  |  |
| 1406 | 1.6.2.6.1 | Final QAD Submission Window (Non-MVC) opens | milestone | 0d | 2024-12-02 | 2024-12-02 | 1398FS+1d |  |  | 2024-12-02 | 2024-12-02 | 0d | 1d | 0d |  |  | Participants | Participants | 116.71 | 5.24 | Laura Kennedy | yellow | GREEN |  |  |
| 1407 | 1.6.2.6.2 | SIT Non-MVC Participants submit Final QAD |  | 85d | 2024-12-03 | 2025-03-31 | 1406SS |  |  | 2024-12-02 | 2025-03-31 | 86d | 1d | 0d |  |  | Participants | Participants | 117.33 | 5.24 | Laura Kennedy | Green | GREEN |  |  |
| 1408 | 1.6.2.6.3 | Completion of Code Bodies review of Final QAD (Non-MVC) |  | 19d | 2025-04-01 | 2025-04-25 | 1407 |  |  | 2025-04-01 | 2025-04-25 | 19d | 1d | 0d |  |  | Code Bodies | Code Bodies | 236.33 | 5.24 | Laura Kennedy | Green | GREEN |  |  |
| 1409 | 1.6.2.6.4 | QAD Sign Off Deadline (Non-MVC) |  | 1d | 2025-05-02 | 2025-05-02 | 1408FS+4d, 1121 |  |  | 2025-05-02 | 2025-05-02 | 1d | 1d | 0d |  |  | Participants | Participants | 267.33 | 5.24 | Laura Kennedy | Green | GREEN |  |  |
| 1410 | 1.6.2.6.5 | REC Code Manager / BSC PAB Approval of Qualification (Non-MVC) | milestone | 0d | 2025-05-30 | 2025-05-30 | 1409FS+20d |  |  | 2025-05-30 | 2025-05-30 | 0d | 1d | 0d |  |  | Code Bodies | Code Bodies | 295.71 | 5.25 | Laura Kennedy | yellow | AMBER | T3-QU-0086 | QAG |
| 1411 | 1.6.3 | **MHHS Qualification - Non-SIT LDSO** |  | 114d | 2024-09-02 | 2025-02-07 |  |  |  | 2024-09-02 | 2025-02-07 | 115d | 7d |  |  | -0 | N/A | N/A | -133.67 | 5.24 | N/A |  |  |  |  |
| 1412 | 1.6.3.1 | Initial QAD Submission window opens | milestone | 0d | 2024-09-02 | 2024-09-02 | 1387FS+6d |  |  | 2024-09-02 | 2024-09-02 | 0d | 7d | 0d |  |  | Participants | Participants | 25.71 | 5.24 | Laura Kennedy | yellow | GREEN |  |  |
| 1413 | 1.6.3.2 | Non-SIT LDSO Participants submit initial QAD |  | 28d | 2024-09-03 | 2024-10-10 | 1412 |  |  | 2024-09-02 | 2024-10-10 | 29d | 7d | 0d |  |  | Participants | Participants | 26.33 | 5.24 | Laura Kennedy | Green | GREEN |  |  |
| 1414 | 1.6.3.3 | Non-SIT LDSO QT Participants have submitted their initial QAD | milestone | 0d | 2024-10-10 | 2024-10-10 | 1413 |  |  | 2024-10-10 | 2024-10-10 | 0d | 7d | 0d |  |  | Participants | Participants | 63.71 | 5.25 | Laura Kennedy | Green | GREEN | T3-QU-0087 | QAG |
| 1415 | 1.6.3.4 | Code Bodies review of Non-SIT LDSO participants Initial QAD |  | 36d | 2024-10-11 | 2024-11-29 | 1414 |  |  | 2024-10-11 | 2024-11-29 | 36d | 7d | 0d |  |  | Code Bodies | Code Bodies | 64.33 | 5.24 | Laura Kennedy | Green | GREEN |  |  |
| 1416 | 1.6.3.5 | Completion of Code Bodies review of Initial QAD | milestone | 0d | 2024-11-29 | 2024-11-29 | 1415 |  |  | 2024-11-29 | 2024-11-29 | 0d | 7d | 0d |  |  | Code Bodies | Code Bodies | 113.71 | 5.24 | Laura Kennedy | Green | GREEN |  |  |
| 1417 | 1.6.3.6 | Final QAD Submission window opens | milestone | 0d | 2024-12-02 | 2024-12-02 | 1416FS+1d |  |  | 2024-12-02 | 2024-12-02 | 0d | 7d | 0d |  |  | Participants | Participants | 116.71 | 5.24 | Laura Kennedy | yellow | GREEN |  |  |
| 1418 | 1.6.3.7 | Non-SIT LDSO Participants submit Final QAD |  | 25d | 2024-12-03 | 2025-01-06 | 1324SS, 1417SS |  |  | 2024-12-02 | 2025-01-06 | 26d | 7d | 0d |  |  | Participants | Participants | 117.33 | 5.24 | Laura Kennedy | Green | GREEN |  |  |
| 1419 | 1.6.3.8 | Non-SIT LDSO QT Participants have submitted their final QAD | milestone | 0d | 2025-01-06 | 2025-01-06 | 1418 |  |  | 2025-01-06 | 2025-01-06 | 0d | 7d | 0d |  |  | Participants | Participants | 151.71 | 5.25 | Laura Kennedy | Green | AMBER | T3-QU-0088 | QAG |
| 1420 | 1.6.3.9 | Completion of Code Bodies review of the Final QAD |  | 19d | 2025-01-07 | 2025-01-31 | 1419 |  |  | 2025-01-07 | 2025-01-31 | 19d | 7d | 0d |  |  | Code Bodies | Code Bodies | 152.33 | 5.24 | Laura Kennedy | Green | GREEN |  |  |
| 1421 | 1.6.3.10 | QAD Sign Off Deadline | milestone | 0d | 2025-02-07 | 2025-02-07 | 1420FS+5d |  |  | 2025-02-07 | 2025-02-07 | 1d | 7d |  |  |  | Participants | Participants | 183.71 | 5.24 | Laura Kennedy | Green | GREEN |  |  |
| 1422 | 1.6.4 | **MHHS Qualification - Qualification Waves** |  | 575d | 2023-12-18 A | 2026-02-27 |  | 28% | 412.93d | 2023-12-18 | 2026-02-27 | 574d | 325d |  |  | -0 | N/A | N/A | -131.67 | 5.24 | N/A |  |  |  |  |
| 1423 | 1.6.4.1 | **Qualification Wave Prep** |  | 424d | 2023-12-18 A | 2025-07-31 |  | 53% | 200.54d | 2023-12-18 | 2025-07-31 | 424d | 476d |  |  | -0 | N/A | N/A | -131.67 | 5.24 | N/A |  |  |  |  |
| 1424 | 1.6.4.1.1 | **Non-SIT Supplier and Agent Test Approach and Plan** |  | 119d | 2023-12-18 A | 2024-05-30 A |  | 100% |  | 2023-12-18 | 2024-05-30 | 118d |  |  |  | -0 | N/A | N/A | -133.67 | 5.24 | N/A |  |  |  |  |
| 1425 | 1.6.4.1.1.1 | Draft Non-SIT S&A Test Approach and Plan |  | 50d | 2023-12-18 A | 2024-02-23 A |  | 100% |  | 2023-12-18 | 2024-02-23 | 50d |  |  | finish no earlier than 2024-02-23 |  | Non-SIT S&A QT Test Team | Non-SIT S&A QT Test Team |  | 5.24 | Laura Kennedy | Complete | COMPLETE |  |  |
| 1426 | 1.6.4.1.1.2 | Internal Review of Non-SIT S&A Test Approach and Plan (Code Bodies and MHHSP) |  | 10d | 2024-02-26 A | 2024-03-08 A | 1425 | 100% |  | 2024-02-26 | 2024-03-08 | 10d |  |  |  |  | Code Bodies, SI Team, SRO | Code Bodies, SI Team, SRO |  | 5.24 | Laura Kennedy | Complete | COMPLETE |  |  |
| 1427 | 1.6.4.1.1.3 | Issue Non-SIT S&A Test Approach and Plan for Consultation |  | 15d | 2024-03-18 A | 2024-04-05 A | 1426 | 100% |  | 2024-03-18 | 2024-04-05 | 15d |  |  | start no earlier than 2024-03-18 |  | Participants | Participants |  | 5.24 | Laura Kennedy | Complete | COMPLETE |  |  |
| 1428 | 1.6.4.1.1.4 | Update Non-SIT S&A Test Approach and Plan Post-Consultation |  | 10d | 2024-04-08 A | 2024-04-19 A | 1427 | 100% |  | 2024-04-08 | 2024-04-19 | 10d |  |  |  |  | Non-SIT S&A QT Test Team | Non-SIT S&A QT Test Team |  | 5.24 | Laura Kennedy | Complete | COMPLETE |  |  |
| 1429 | 1.6.4.1.1.5 | QWG Endorsement of Non-SIT S&A Test Approach and Plan |  | 1d | 2024-05-14 A | 2024-05-14 A |  | 100% |  | 2024-05-14 | 2024-05-14 | 1d |  |  | finish no earlier than 2024-05-14 |  | Non-SIT S&A QT Test Team | Non-SIT S&A QT Test Team |  | 5.24 | Laura Kennedy | Complete | COMPLETE |  |  |
| 1430 | 1.6.4.1.1.6 | QAG Approval of Non-SIT S&A Test Approach and Plan | milestone | 0d | 2024-05-23 A | 2024-05-23 A | 1429FS+7d | 100% |  | 2024-05-23 | 2024-05-23 | 0d |  |  |  |  | Non-SIT S&A QT Test Team | Non-SIT S&A QT Test Team |  | 5.25 | Laura Kennedy | Complete | COMPLETE | T3-QU-0089 | QAG |
| 1431 | 1.6.4.1.1.7 | BSC & REC PAB Approval of Non-SIT S&A Test Approach and Plan | milestone | 0d | 2024-05-30 A | 2024-05-30 A | 1430FS+5d | 100% |  | 2024-05-30 | 2024-05-30 | 0d |  |  |  |  | Code Bodies | Code Bodies |  | 5.25 | Laura Kennedy | Complete | COMPLETE | T3-QU-0090 | QAG |

Notes:
- 1410: 6/8/24: Date at risk from scenario planning activity
- 1414: 14/5: Was in non-sit ldso CR 47
- 1419: 6/8/24: Date at risk from scenario planning activity

| ID | WBS | Task | Type | Duration | Start | Finish | Predecessors | Complete | Baseline start | Baseline finish | Baseline duration | Total slack | Free slack | Constraint | Baseline cost | Responsible | Involved | Task Status | Update Version | MHHS Resource Name | Sched Status | RAG | Milestone ID | Text29 |
| --- | --- | --- | --- | --- | --- | --- | --- | --- | --- | --- | --- | --- | --- | --- | --- | --- | --- | --- | --- | --- | --- | --- | --- | --- |
| 1432 | 1.6.4.1.2 | **QT Test Data Approach and Plan** |  | 64d | 2024-04-19 A | 2024-07-18 A |  | 100% | 2024-04-19 | 2024-07-18 | 64d |  |  |  | -0 | N/A | N/A | -133.67 | 5.24 | N/A |  |  |  |  |
| 1433 | 1.6.4.1.2.1 | QT Test Data Approach agreed as part of the Non-SIT Supplier and Agent Test Approach and Plan | milestone | 0d | 2024-04-19 A | 2024-04-19 A | 1428 | 100% | 2024-04-19 | 2024-04-19 | 0d |  |  |  |  | Non-SIT S&A QT Test Team, Participants | Non-SIT S&A QT Test Team, Participants |  | 5.24 | Laura Kennedy | Complete | COMPLETE |  |  |
| 1434 | 1.6.4.1.2.2 | Draft Test Data Approach and Plan for QT |  | 10d | 2024-05-06 A | 2024-05-17 A | 1433 | 100% | 2024-05-06 | 2024-05-17 | 10d |  |  |  |  | Non-SIT S&A QT Test Team | Non-SIT S&A QT Test Team |  | 5.24 | Laura Kennedy | Complete | COMPLETE |  |  |
| 1435 | 1.6.4.1.2.3 | Internal Review (Code Bodies and MHHSP) of QT Test Data Approach and Plan |  | 15d | 2024-05-20 A | 2024-06-07 A | 1434 | 100% | 2024-05-20 | 2024-05-31 | 10d |  |  |  |  | Code Bodies, SI Team, SRO | Code Bodies, SI Team, SRO |  | 5.24 | Laura Kennedy | Complete | COMPLETE |  |  |
| 1436 | 1.6.4.1.2.4 | Issue QT Test Data Approach and Plan for Industry Consultation |  | 10d | 2024-06-10 A | 2024-06-21 A | 1435 | 100% | 2024-06-03 | 2024-06-14 | 10d |  |  |  |  | Participants | Participants |  | 5.24 | Laura Kennedy | Complete | COMPLETE |  |  |
| 1437 | 1.6.4.1.2.5 | Update QT Test Approach and Plan Post Industry Consultation |  | 5d | 2024-06-24 A | 2024-06-28 A | 1436 | 100% | 2024-06-17 | 2024-06-28 | 10d |  |  |  |  | Non-SIT S&A QT Team | Non-SIT S&A QT Team |  | 5.24 | Laura Kennedy | Complete | COMPLETE |  |  |
| 1438 | 1.6.4.1.2.6 | QWG Endorsement of Test Data Approach and Plan |  | 1d | 2024-07-09 A | 2024-07-09 A | 1437FS+6d | 100% | 2024-07-09 | 2024-07-09 | 1d |  |  |  |  | Non-SIT S&A QT Test Team | Non-SIT S&A QT Test Team |  | 5.24 | Laura Kennedy | Complete | COMPLETE |  |  |
| 1439 | 1.6.4.1.2.7 | QAG Approval of QT Test Data Approach and Plan | milestone | 0d | 2024-07-18 A | 2024-07-18 A | 1438FS+7d | 100% | 2024-07-18 | 2024-07-18 | 0d |  |  |  |  | Non-SIT S&A QT Test Team | Non-SIT S&A QT Test Team |  | 5.29 | Laura Kennedy | Complete | COMPLETE | T3-QU-0091 | QAG |
| 1440 | 1.6.4.1.3 | **QT Functional Test Scenarios and Test Cases** |  | 59d | 2024-03-04 A | 2024-05-23 A |  | 100% | 2024-03-04 | 2024-05-23 | 59d |  |  |  | -0 | N/A | N/A | -133.67 | 5.24 | N/A |  |  |  |  |
| 1441 | 1.6.4.1.3.1 | Draft Test Scenarios and Test Case list - Batch 1 |  | 10d | 2024-03-04 A | 2024-03-15 A |  | 100% | 2024-03-04 | 2024-03-15 | 10d |  |  | finish no earlier than 2024-03-15 |  | Non-SIT S&A QT Test Team, Code Bodies | Non-SIT S&A QT Test Team, Code Bodies |  | 5.24 | Laura Kennedy | Complete | COMPLETE |  |  |
| 1442 | 1.6.4.1.3.2 | Issue Batch 1 for Consultation |  | 15d | 2024-03-18 A | 2024-04-05 A | 1441 | 100% | 2024-03-18 | 2024-04-05 | 15d |  |  | start no earlier than 2024-03-18 |  | Participants | Participants |  | 5.24 | Laura Kennedy | Complete | COMPLETE |  |  |
| 1443 | 1.6.4.1.3.3 | Gap analysis against QT Requirements |  | 8d | 2024-03-18 A | 2024-03-27 A | 1441 | 100% | 2024-03-18 | 2024-03-27 | 8d |  |  |  |  | Non-SIT S&A QT Test Team | Non-SIT S&A QT Test Team |  | 5.24 | Laura Kennedy | Complete | COMPLETE |  |  |
| 1444 | 1.6.4.1.3.4 | Update Test Scenarios and Test Case list - Batch 2 |  | 6d | 2024-03-28 A | 2024-04-04 A | 1443 | 100% | 2024-03-28 | 2024-04-04 | 6d |  |  |  |  | Non-SIT S&A QT Test Team, Code Bodies | Non-SIT S&A QT Test Team, Code Bodies |  | 5.24 | Laura Kennedy | Complete | COMPLETE |  |  |
| 1445 | 1.6.4.1.3.5 | Issue Batch 2 for consultation |  | 10d | 2024-04-05 A | 2024-04-18 A | 1444 | 100% | 2024-04-05 | 2024-04-18 | 10d |  |  |  |  | Participants | Participants |  | 5.24 | Laura Kennedy | Complete | COMPLETE |  |  |
| 1446 | 1.6.4.1.3.6 | Update Batch 2 post consultation |  | 10d | 2024-04-19 A | 2024-05-02 A | 1445 | 100% | 2024-04-19 | 2024-05-02 | 10d |  |  |  |  | Non-SIT S&A QT Test Team, Code Bodies | Non-SIT S&A QT Test Team, Code Bodies |  | 5.24 | Laura Kennedy | Complete | COMPLETE |  |  |
| 1447 | 1.6.4.1.3.7 | QWG Endorsement of Batch 1 and 2 |  | 1d | 2024-05-14 A | 2024-05-14 A |  | 100% | 2024-05-14 | 2024-05-14 | 1d |  |  | finish no earlier than 2024-05-14 |  | Non-SIT S&A QT Test Team | Non-SIT S&A QT Test Team, Code Bodies, Participants |  | 5.24 | Laura Kennedy | Complete | COMPLETE |  |  |
| 1448 | 1.6.4.1.3.8 | QAG Approval of QT Functional Test Scenarios and Test Cases Batches 1 and 2 | milestone | 0d | 2024-05-23 A | 2024-05-23 A | 1447FS+7d | 100% | 2024-05-23 | 2024-05-23 | 0d |  |  |  |  | Non-SIT S&A QT Test Team | Non-SIT S&A QT Test Team, Code Bodies, Participants |  | 5.25 | Laura Kennedy | Complete | COMPLETE | T3-QU-0092 | QAG |
| 1449 | 1.6.4.1.4 | **QT Migration Test Scenarios and Test Cases** |  | 54d | 2024-05-06 A | 2024-07-18 A |  | 100% | 2024-05-06 | 2024-07-18 | 54d |  |  |  |  | N/A | N/A |  | 5.25 | N/A |  |  |  |  |
| 1450 | 1.6.4.1.4.1 | Draft Test Scenarios and Test Case list - Batch 1 |  | 20d | 2024-05-06 A | 2024-05-31 A | 889FS+12d | 100% | 2024-05-06 | 2024-05-31 | 20d |  |  |  |  | Non-SIT S&A QT Test Team, Code Bodies | Non-SIT S&A QT Test Team, Code Bodies |  | 5.25 | Laura Kennedy | Complete | COMPLETE |  |  |
| 1451 | 1.6.4.1.4.2 | Issue Batch 1 for Consultation |  | 10d | 2024-06-03 A | 2024-06-14 A | 1450 | 100% | 2024-06-03 | 2024-06-14 | 10d |  |  |  |  | Participants | Participants |  | 5.25 | Laura Kennedy | Complete | COMPLETE |  |  |
| 1452 | 1.6.4.1.4.3 | Update Batch 1 Post Consultation |  | 10d | 2024-06-17 A | 2024-06-28 A | 1451 | 100% | 2024-06-17 | 2024-06-28 | 10d |  |  |  |  | Non-SIT S&A QT Test Team | Non-SIT S&A QT Test Team |  | 5.25 | Laura Kennedy | Complete | COMPLETE |  |  |
| 1453 | 1.6.4.1.4.4 | QWG Endorsement of Batch 1 | milestone | 0d | 2024-07-09 A | 2024-07-09 A | 1452FS+7d | 100% | 2024-07-09 | 2024-07-09 | 0d |  |  |  |  | Non-SIT S&A QT Test Team | Non-SIT S&A QT Test Team, Code Bodies, Participants |  | 5.25 | Laura Kennedy | Complete | COMPLETE |  |  |
| 1454 | 1.6.4.1.4.5 | QAG Approval of QT Migration Test Scenarios and Test Cases Batches 1 | milestone | 0d | 2024-07-18 A | 2024-07-18 A | 1453FS+7d | 100% | 2024-07-18 | 2024-07-18 | 0d |  |  |  |  | Non-SIT S&A QT Test Team | Non-SIT S&A QT Test Team, Code Bodies, Participants |  | 5.29 | Laura Kennedy | Complete | COMPLETE | T3-QU-0119 | QAG |
| 1455 | 1.6.4.1.5 | **QT Non-Functional Test Scenarios and Test Cases** |  | 61d | 2024-06-27 | 2024-09-19 |  |  | 2024-07-22 | 2024-09-19 | 43d | 0d |  |  |  | N/A | N/A |  | 5.25 | N/A |  |  |  |  |
| 1456 | 1.6.4.1.5.1 | Draft Test Scenarios and Test Case list - Batch 2 |  | 27d | 2024-06-27 | 2024-08-02 | 941FS+2d, 935FS+2d |  | 2024-07-22 | 2024-08-02 | 10d | -42d | 0d | must finish on 2024-08-02 |  | Non-SIT S&A QT Test Team, Code Bodies | Non-SIT S&A QT Test Team, Code Bodies | -41.67 | 5.25 | Laura Kennedy | Overdue Start | RED |  |  |
| 1457 | 1.6.4.1.5.2 | Issue Batch 2 for Consultation |  | 10d | 2024-08-05 | 2024-08-16 | 1456 |  | 2024-08-05 | 2024-08-16 | 10d | 80d | 0d |  |  | Participants | Participants | -2.67 | 5.25 | Laura Kennedy | Overdue Start | GREEN |  |  |
| 1458 | 1.6.4.1.5.3 | Update Batch 2 Post Consultation |  | 10d | 2024-08-19 | 2024-08-30 | 1457 |  | 2024-08-19 | 2024-08-30 | 10d | 80d | 0d |  |  | Non-SIT S&A QT Test Team | Non-SIT S&A QT Test Team | 11.33 | 5.25 | Laura Kennedy | Green | GREEN |  |  |
| 1459 | 1.6.4.1.5.4 | QWG Endorsement of Batch 2 | milestone | 0d | 2024-09-10 | 2024-09-10 | 1458FS+7d, 1360 |  | 2024-09-10 | 2024-09-10 | 0d | 80d | 0d |  |  | Non-SIT S&A QT Test Team | Non-SIT S&A QT Test Team, Code Bodies, Participants | 33.71 | 5.25 | Laura Kennedy | yellow | GREEN |  |  |
| 1460 | 1.6.4.1.5.5 | QAG Approval of QT Non-Functional Test Scenarios and Test Cases Batch 2 | milestone | 0d | 2024-09-19 | 2024-09-19 | 1459FS+7d |  | 2024-09-19 | 2024-09-19 | 0d | 80d | 30d |  |  | Non-SIT S&A QT Test Team | Non-SIT S&A QT Test Team, Code Bodies, Participants | 42.71 | 5.27 | Laura Kennedy | yellow | AMBER | T3-QU-0120 | QAG |

Notes:
- 1460: Delay in SIT Non-Functional/Operational Test Scenario Approval dates. QT Test Scenarios which reuse SIT Scenarios are unable to be approved until SIT Scenarios are approved. Review scope of SIT NF/Operational to understand whether all themes impact QT, / Notes (2): work with SIT team to increase parallelisation of activities where possible.

| ID | WBS | Task | Type | Duration | Start | Finish | Predecessors | Complete | Remaining | Baseline start | Baseline finish | Baseline duration | Total slack | Free slack | Constraint | Baseline cost | Responsible | Involved | Update Version | MHHS Resource Name | Task Status | Sched Status | RAG | Milestone ID | Text29 |
| --- | --- | --- | --- | --- | --- | --- | --- | --- | --- | --- | --- | --- | --- | --- | --- | --- | --- | --- | --- | --- | --- | --- | --- | --- | --- |
| 1461 | 1.6.4.1.6 | **QT Operational Test Scenarios and Test Cases** |  | 101d | 2024-05-30 | 2024-10-17 |  |  |  | 2024-07-22 | 2024-10-17 | 63d | 0d |  |  |  | N/A | N/A | 5.25 | N/A |  |  |  |  |  |
| 1462 | 1.6.4.1.6.1 | Draft QT Operational Test Cases - Batch 1 |  | 47d | 2024-05-30 | 2024-08-02 | 974FS+2d, 1439 |  |  | 2024-07-22 | 2024-08-02 | 10d | -62d | 0d | must finish on 2024-08-02 |  | Non-SIT S&A QT Test Team, Code Bodies | Non-SIT S&A QT Test Team, Code Bodies | 5.25 | Laura Kennedy | -69.67 | Overdue Start | RED |  |  |
| 1463 | 1.6.4.1.6.2 | Issue Batch 1 for Consultation |  | 10d | 2024-08-05 | 2024-08-16 | 1462 |  |  | 2024-08-05 | 2024-08-16 | 10d | 80d | 0d |  |  | Participants | Participants | 5.25 | Laura Kennedy | -2.67 | Overdue Start | GREEN |  |  |
| 1464 | 1.6.4.1.6.3 | Update Batch 1 Post Consultation |  | 10d | 2024-08-19 | 2024-08-30 | 1463 |  |  | 2024-08-19 | 2024-08-30 | 10d | 80d | 0d |  |  | Non-SIT S&A QT Test Team | Non-SIT S&A QT Test Team | 5.25 | Laura Kennedy | 11.33 | Green | GREEN |  |  |
| 1465 | 1.6.4.1.6.4 | QWG Endorsement of Batch 1 | milestone | 0d | 2024-09-10 | 2024-09-10 | 1464FS+7d |  |  | 2024-09-10 | 2024-09-10 | 0d | 80d | 0d |  |  | Non-SIT S&A QT Test Team | Non-SIT S&A QT Test Team, Code Bodies, Participants | 5.25 | Laura Kennedy | 33.71 | yellow | GREEN |  |  |
| 1466 | 1.6.4.1.6.5 | QAG Approval of QT Operational Test Scenarios and Test Cases Batch 1 | milestone | 0d | 2024-09-19 | 2024-09-19 | 1465FS+7d |  |  | 2024-09-19 | 2024-09-19 | 0d | 80d | 30d |  |  | Non-SIT S&A QT Test Team | Non-SIT S&A QT Test Team, Code Bodies, Participants | 5.27 | Laura Kennedy | 42.71 | yellow | AMBER | T3-QU-0121 | QAG |
| 1467 | 1.6.4.1.6.6 | Draft QT Operational Test Cases - Batch 2 |  | 10d | 2024-07-22 | 2024-08-02 | 980FS+2d |  |  | 2024-07-22 | 2024-08-02 | 10d | 80d | 0d |  |  | Non-SIT S&A QT Test Team, Code Bodies | Non-SIT S&A QT Test Team, Code Bodies | 5.25 | Laura Kennedy | -16.67 | Overdue Start | RED |  |  |
| 1468 | 1.6.4.1.6.7 | Issue Batch 2 for Consultation |  | 10d | 2024-08-05 | 2024-08-16 | 1467 |  |  | 2024-08-05 | 2024-08-16 | 10d | 80d | 0d |  |  | Participants | Participants | 5.25 | Laura Kennedy | -2.67 | Overdue Start | GREEN |  |  |
| 1469 | 1.6.4.1.6.8 | Update Batch 2 Post Consultation |  | 10d | 2024-08-19 | 2024-08-30 | 1468 |  |  | 2024-08-19 | 2024-08-30 | 10d | 80d | 0d |  |  | Non-SIT S&A QT Test Team | Non-SIT S&A QT Test Team | 5.25 | Laura Kennedy | 11.33 | Green | GREEN |  |  |
| 1470 | 1.6.4.1.6.9 | QWG Endorsement of Batch 2 | milestone | 0d | 2024-09-10 | 2024-09-10 | 1469FS+7d |  |  | 2024-09-10 | 2024-09-10 | 0d | 80d | 0d |  |  | Non-SIT S&A QT Test Team | Non-SIT S&A QT Test Team, Code Bodies, Participants | 5.25 | Laura Kennedy | 33.71 | yellow | GREEN |  |  |
| 1471 | 1.6.4.1.6.10 | QAG Approval of QT Operational Test Scenarios and Test Cases Batch 2 | milestone | 0d | 2024-09-19 | 2024-09-19 | 1470FS+7d |  |  | 2024-09-19 | 2024-09-19 | 0d | 80d | 30d |  |  | Non-SIT S&A QT Test Team | Non-SIT S&A QT Test Team, Code Bodies, Participants | 5.27 | Laura Kennedy | 42.71 | yellow | GREEN | T3-QU-0122 | QAG |
| 1472 | 1.6.4.1.6.11 | Draft QT Operational Test Cases - Batch 3 |  | 10d | 2024-08-26 | 2024-09-06 | 986FS+2d |  |  | 2024-08-26 | 2024-09-06 | 10d | -20d | 0d | must finish on 2024-09-06 |  | Non-SIT S&A QT Test Team, Code Bodies | Non-SIT S&A QT Test Team, Code Bodies | 5.25 | Laura Kennedy | 18.33 | Green | GREEN |  |  |
| 1473 | 1.6.4.1.6.12 | Issue Batch 3 for Consultation |  | 10d | 2024-09-09 | 2024-09-20 | 1472, 1340 |  |  | 2024-09-09 | 2024-09-20 | 10d | 50d | 0d |  |  | Participants | Participants | 5.25 | Laura Kennedy | 32.33 | Green | GREEN |  |  |
| 1474 | 1.6.4.1.6.13 | Update Batch 3 Post Consultation |  | 5d | 2024-09-23 | 2024-09-27 | 1473 |  |  | 2024-09-23 | 2024-09-27 | 5d | 50d | 0d |  |  | Non-SIT S&A QT Test Team | Non-SIT S&A QT Test Team | 5.25 | Laura Kennedy | 46.33 | Green | GREEN |  |  |
| 1475 | 1.6.4.1.6.14 | QWG Endorsement of Batch 3 | milestone | 0d | 2024-10-08 | 2024-10-08 | 1474FS+7d |  |  | 2024-10-08 | 2024-10-08 | 0d | 50d | 0d |  |  | Non-SIT S&A QT Test Team | Non-SIT S&A QT Test Team, Code Bodies, Participants | 5.25 | Laura Kennedy | 61.71 | yellow | GREEN |  |  |
| 1476 | 1.6.4.1.6.15 | QAG Approval of QT Operational Test Scenarios and Test Cases Batch 3 | milestone | 0d | 2024-10-17 | 2024-10-17 | 1475FS+7d |  |  | 2024-10-17 | 2024-10-17 | 0d | 50d | 0d |  |  | Non-SIT S&A QT Test Team | Non-SIT S&A QT Test Team, Code Bodies, Participants | 5.27 | Laura Kennedy | 70.71 | yellow | AMBER | T3-QU-0123 | QAG |
| 1477 | 1.6.4.1.7 | **Qualification Testing Framework (Test Stubs and Supporting UI)** |  | 394d | 2024-01-29 A | 2025-07-31 |  | 47% | 207.22d | 2024-01-29 | 2025-07-31 | 394d | 476d |  |  | -0 | N/A | N/A | 5.27 | N/A | -594.67 |  |  |  |  |
| 1478 | 1.6.4.1.7.1 | Proof of Concept for QTF Completion |  | 45d | 2024-01-29 A | 2024-03-29 A |  | 100% |  | 2024-01-29 | 2024-03-29 | 45d |  |  | start no earlier than 2024-01-22 |  | Non-SIT S&A QT Test Team | Non-SIT S&A QT Test Team | 5.27 | Laura Kennedy |  | Complete | COMPLETE |  |  |
| 1479 | 1.6.4.1.7.2 | Discovery and Mobilisation |  | 25d | 2024-04-01 A | 2024-05-03 A | 1478 | 100% |  | 2024-04-01 | 2024-05-03 | 25d |  |  |  |  | Non-SIT S&A QT Test Team | Non-SIT S&A QT Test Team | 5.27 | Laura Kennedy |  | Complete | COMPLETE |  |  |
| 1480 | 1.6.4.1.7.3 | **Agile DBT of Qualification Testing Framework** |  | 83d | 2024-04-24 A | 2024-08-16 |  | 96% | 3.05d | 2024-04-24 | 2024-08-16 | 83d | 725d |  |  | -0 | N/A | N/A | 5.27 | N/A |  |  |  |  |  |
| 1481 | 1.6.4.1.7.3.1 | **User Interface (UI)** |  | 48d | 2024-04-24 A | 2024-06-28 A |  | 100% |  | 2024-04-24 | 2024-06-28 | 48d |  |  |  |  | N/A | N/A | 5.27 | N/A | -594.67 |  |  |  |  |
| 1482 | 1.6.4.1.7.3.1.1 | UI Wireframe |  | 48d | 2024-04-24 A | 2024-06-28 A | 1428FS+2d | 100% |  | 2024-04-24 | 2024-06-28 | 48d |  |  |  |  | Non-SIT S&A QT Test Team | Non-SIT S&A QT Test Team | 5.27 | Laura Kennedy |  | Complete | COMPLETE |  |  |
| 1483 | 1.6.4.1.7.3.1.2 | UI Standards |  | 35d | 2024-05-13 A | 2024-06-28 A | 1482SS+13d | 100% |  | 2024-05-13 | 2024-06-28 | 35d |  |  |  |  | Non-SIT S&A QT Test Team | Non-SIT S&A QT Test Team | 5.27 | Laura Kennedy |  | Complete | COMPLETE |  |  |
| 1484 | 1.6.4.1.7.3.1.3 | Elexon Branding Sylesheet |  | 1d | 2024-05-17 A | 2024-05-20 A | 1479FS+10d | 100% |  | 2024-05-17 | 2024-05-20 | 1d |  |  |  |  | Non-SIT S&A QT Test Team | Non-SIT S&A QT Test Team | 5.27 | Laura Kennedy |  | Complete | COMPLETE |  |  |
| 1485 | 1.6.4.1.7.3.1.4 | Elexon Branding QTF Logo |  | 1d | 2024-05-31 A | 2024-06-03 A | 1479FS+20d | 100% |  | 2024-05-31 | 2024-06-03 | 1d |  |  |  |  | Non-SIT S&A QT Test Team | Non-SIT S&A QT Test Team | 5.27 | Laura Kennedy |  | Complete | COMPLETE |  |  |

Notes:
- 1461: Impact: QT Test Scenarios which reuse SIT Scenarios are unable to be approved until SIT Scenarios are approved.
- 1462: Action: Review scope of SIT NF/Operational to understand whether all themes impact QT, work with SIT team to increase parallelisation of activities where possible. / Action: 9/7/24: Potential delay as delay from the test side. Does it need to be linked to all 3 or just 1?
- 1466: Delay in SIT Non-Functional/Operational Test Scenario Approval dates. QT Test Scenarios which reuse SIT Scenarios are unable to be approved until SIT Scenarios are approved. Review scope of SIT NF/Operational to understand whether all themes impact QT, / Notes (2): work with SIT team to increase parallelisation of activities where possible.
- 1476: Delay in SIT Non-Functional/Operational Test Scenario Approval dates. QT Test Scenarios which reuse SIT Scenarios are unable to be approved until SIT Scenarios are approved. Review scope of SIT NF/Operational to understand whether all themes impact QT, / Notes (2): work with SIT team to increase parallelisation of activities where possible.

| ID | WBS | Task | Duration | Start | Finish | Predecessors | Complete | Remaining | Baseline start | Baseline finish | Baseline duration | Total slack | Free slack | Baseline cost | Responsible | Involved | Task Status | Update Version | MHHS Resource Name | Sched Status | RAG |
| --- | --- | --- | --- | --- | --- | --- | --- | --- | --- | --- | --- | --- | --- | --- | --- | --- | --- | --- | --- | --- | --- |
| 1486 | 1.6.4.1.7.3.2 | **Design, Build, Test** | 70d | 2024-05-13 A | 2024-08-16 |  | 95% | 3.47d | 2024-05-13 | 2024-08-16 | 70d | 725d |  |  | N/A | N/A | -594.67 | 5.27 | N/A |  |  |
| 1487 | 1.6.4.1.7.3.2.1 | Core UI Screens | 60d | 2024-05-13 A | 2024-08-02 A | 1483SS | 100% |  | 2024-05-13 | 2024-08-02 | 60d |  |  |  | Non-SIT S&A QT Test Team | Non-SIT S&A QT Test Team |  | 5.27 | Laura Kennedy | Complete | COMPLETE |
| 1488 | 1.6.4.1.7.3.2.2 | Tooling (Trigger Files / Template Generators) | 70d | 2024-05-13 A | 2024-08-16 | 1482SS+13d | 83% | 12d | 2024-05-13 | 2024-08-16 | 70d | 725d | 10d |  | Non-SIT S&A QT Test Team | Non-SIT S&A QT Test Team |  | 5.27 | Laura Kennedy | Green | GREEN |
| 1489 | 1.6.4.1.7.3.2.3 | Database Schema | 50d | 2024-05-13 A | 2024-07-19 A | 1482SS+13d | 100% |  | 2024-05-13 | 2024-07-19 | 50d |  |  |  | Non-SIT S&A QT Test Team | Non-SIT S&A QT Test Team |  | 5.27 | Laura Kennedy | Complete | COMPLETE |
| 1490 | 1.6.4.1.7.3.2.4 | Core API's | 60d | 2024-05-13 A | 2024-08-02 A | 1482SS+13d | 100% |  | 2024-05-13 | 2024-08-02 | 60d |  |  |  | Non-SIT S&A QT Test Team | Non-SIT S&A QT Test Team |  | 5.27 | Laura Kennedy | Complete | COMPLETE |
| 1491 | 1.6.4.1.7.3.2.5 | DIP (SIT-A) Onboarding for Development inc. Test Stubs | 1d | 2024-07-12 A | 2024-07-12 A | 1479FS+49d | 100% |  | 2024-07-12 | 2024-07-12 | 1d |  |  |  | Non-SIT S&A QT Test Team, Electralink | Non-SIT S&A QT Test Team, Electralink |  | 5.27 | Laura Kennedy | Complete | COMPLETE |
| 1492 | 1.6.4.1.7.3.2.6 | DTN Onboarding for Development inc. Test Stubs | 1d | 2024-07-15 A | 2024-07-15 A | 1491 | 100% |  | 2024-07-15 | 2024-07-15 | 1d |  |  |  | Non-SIT S&A QT Test Team, MHHSP, Avanade | Non-SIT S&A QT Test Team, MHHSP, Avanade |  | 5.27 | Laura Kennedy | Complete | COMPLETE |
| 1493 | 1.6.4.1.7.4 | QTF Test Cases DBT Refinement, Execution and Results Validation, Defect Management, Error Handling | 131d | 2024-05-02 | 2024-10-31 | 1454FF, 1460FF, 1466FF, 1471FF, 1476FF+10d |  |  | 2024-07-15 | 2024-10-31 | 79d | 50d | 0d |  | Non-SIT S&A QT Test Team | Non-SIT S&A QT Test Team | -97.67 | 5.27 | Laura Kennedy. | Overdue Start | GREEN |
| 1494 | 1.6.4.1.7.5 | **Environments** | 158d | 2024-04-15 A | 2024-11-20 |  | 49% | 79.82d | 2024-04-15 | 2024-11-20 | 158d | 657d |  | -0 | N/A | N/A | -594.67 | 5.27 | N/A |  |  |
| 1495 | 1.6.4.1.7.5.1 | **Azure Devops** | 120d | 2024-04-15 A | 2024-09-27 |  | 42% | 69.38d | 2024-04-15 | 2024-09-27 | 120d | 67d |  | -0 | N/A | N/A | -594.67 | 5.27 | N/A |  |  |
| 1496 | 1.6.4.1.7.5.1.1 | **QFT ADO Development Instance** | 15d | 2024-04-15 A | 2024-05-03 A |  | 100% |  | 2024-04-15 | 2024-05-03 | 15d |  |  |  | N/A | N/A | -594.67 | 5.27 | N/A |  |  |
| 1497 | 1.6.4.1.7.5.1.1.1 | Elexon Instance Setup for QTF Build | 5d | 2024-04-15 A | 2024-04-19 A | 1479SS+10d | 100% |  | 2024-04-15 | 2024-04-19 | 5d |  |  |  | Non-SIT S&A QT Test Team | Non-SIT S&A QT Test Team |  | 5.27 | Laura Kennedy | Complete | COMPLETE |
| 1498 | 1.6.4.1.7.5.1.1.2 | Configuration and User Access | 10d | 2024-04-22 A | 2024-05-03 A | 1497 | 100% |  | 2024-04-22 | 2024-05-03 | 10d |  |  |  | Non-SIT S&A QT Test Team | Non-SIT S&A QT Test Team |  | 5.27 | Laura Kennedy | Complete | COMPLETE |
| 1499 | 1.6.4.1.7.5.1.2 | **MHHSP ADO Instance** | 49d | 2024-07-23 A | 2024-09-27 |  | 24% | 37d | 2024-07-22 | 2024-09-27 | 50d | 67d |  |  | N/A | N/A | -594.67 | 5.27 | N/A | Complete |  |
| 1500 | 1.6.4.1.7.5.1.2.1 | MHHSP Instance Setup for QTF Production | 29d | 2024-07-23 A | 2024-08-30 | 1506SS+41d | 41% | 17d | 2024-07-22 | 2024-08-30 | 30d | 67d | 0d |  | MHHSP | MHHSP |  | 5.27 | Laura Kennedy | Green | GREEN |
| 1501 | 1.6.4.1.7.5.1.2.2 | Configuration and User Access | 20d | 2024-09-02 | 2024-09-27 | 1500, 1557 |  |  | 2024-09-02 | 2024-09-27 | 20d | 67d | 60d |  | Non-SIT S&A QT Test Team | Non-SIT S&A QT Test Team | 25.33 | 5.27 | Laura Kennedy | Green | GREEN |
| 1502 | 1.6.4.1.7.5.2 | **Temporary Development Environment** | 35d | 2024-04-15 A | 2024-05-31 A |  | 100% |  | 2024-04-15 | 2024-05-31 | 35d |  |  |  | N/A | N/A | -594.67 | 5.27 | N/A |  |  |
| 1503 | 1.6.4.1.7.5.2.1 | Design | 15d | 2024-04-15 A | 2024-05-03 A | 1479SS+10d | 100% |  | 2024-04-15 | 2024-05-03 | 15d |  |  |  | Non-SIT S&A QT Test Team | Non-SIT S&A QT Test Team |  | 5.27 | Laura Kennedy | Complete | COMPLETE |
| 1504 | 1.6.4.1.7.5.2.2 | Build and Deployment | 20d | 2024-05-06 A | 2024-05-31 A | 1498, 1503 | 100% |  | 2024-05-06 | 2024-05-31 | 20d |  |  |  | Non-SIT S&A QT Test Team | Non-SIT S&A QT Test Team |  | 5.27 | Laura Kennedy | Complete | COMPLETE |
| 1505 | 1.6.4.1.7.5.3 | **Dev, Test & Prod Environment Requirements + Design** | 105d | 2024-05-27 A | 2024-10-18 |  | 58% | 43.91d | 2024-05-27 | 2024-10-18 | 105d | 680d |  | -0 | N/A | N/A | -594.67 | 5.27 | N/A |  |  |
| 1506 | 1.6.4.1.7.5.3.1 | Design (including Security Review) | 70d | 2024-05-27 A | 2024-08-30 | 1479FS+15d | 76% | 17d | 2024-05-27 | 2024-08-30 | 70d | 715d | 0d |  | Non-SIT S&A QT Test Team | Non-SIT S&A QT Test Team |  | 5.27 | Laura Kennedy | Green | GREEN |
| 1507 | 1.6.4.1.7.5.3.2 | Hub Deployment | 20d | 2024-06-10 A | 2024-07-05 A | 1506SS+10d | 100% |  | 2024-06-10 | 2024-07-05 | 20d |  |  |  | Non-SIT S&A QT Test Team | Non-SIT S&A QT Test Team |  | 5.27 | Laura Kennedy | Complete | COMPLETE |
| 1508 | 1.6.4.1.7.5.3.3 | Development Envn. Deployment | 40d | 2024-07-08 A | 2024-08-30 | 1507 | 58% | 17d | 2024-07-08 | 2024-08-30 | 40d | 59d | 0d |  | Non-SIT S&A QT Test Team | Non-SIT S&A QT Test Team |  | 5.27 | Laura Kennedy | Green | GREEN |
| 1509 | 1.6.4.1.7.5.3.4 | Test Envn. Deployment | 10d | 2024-09-02 | 2024-09-13 | 1508 |  |  | 2024-09-02 | 2024-09-13 | 10d | 59d | 0d |  | Non-SIT S&A QT Test Team | Non-SIT S&A QT Test Team | 25.33 | 5.27 | Laura Kennedy | Green | GREEN |
| 1510 | 1.6.4.1.7.5.3.5 | Production Envn. Deployment | 25d | 2024-09-16 | 2024-10-18 | 1509 |  |  | 2024-09-16 | 2024-10-18 | 25d | 59d | 9d |  | Non-SIT S&A QT Test Team | Non-SIT S&A QT Test Team | 39.33 | 5.27 | Laura Kennedy | Green | GREEN |

| ID | WBS | Task | Duration | Start | Finish | Predecessors | Complete | Remaining | Baseline start | Baseline finish | Baseline duration | Total slack | Free slack | Constraint | Baseline cost | Responsible | Involved | Task Status | Update Version | Sched Status | MHHS Resource Name | RAG |
| --- | --- | --- | --- | --- | --- | --- | --- | --- | --- | --- | --- | --- | --- | --- | --- | --- | --- | --- | --- | --- | --- | --- |
| 1511 | 1.6.4.1.7.5.4 | **QTF Deployment into Production** | 14d | 2024-11-01 | 2024-11-20 |  |  |  | 2024-11-01 | 2024-11-20 | 14d | 50d |  |  |  | N/A | N/A | -594.67 | 5.27 | No BL | N/A |  |
| 1512 | 1.6.4.1.7.5.4.1 | App Deployment | 1d | 2024-11-01 | 2024-11-01 | 1493, 1510 |  |  | 2024-11-01 | 2024-11-01 | 1d | 50d | 0d |  |  | Non-SIT S&A QT Test Team | Non-SIT S&A QT Test Team | 85.33 | 5.27 | Green | Laura Kennedy | GREEN |
| 1513 | 1.6.4.1.7.5.4.2 | Smoke Test | 2d | 2024-11-01 | 2024-11-04 | 1512SS |  |  | 2024-11-01 | 2024-11-04 | 2d | 50d | 0d |  |  | Non-SIT S&A QT Test Team | Non-SIT S&A QT Test Team | 85.33 | 5.27 | Green | Laura Kennedy | GREEN |
| 1514 | 1.6.4.1.7.5.4.3 | PEN Test | 2d | 2024-11-05 | 2024-11-06 | 1513 |  |  | 2024-11-05 | 2024-11-06 | 2d | 50d | 0d |  |  | Non-SIT S&A QT Test Team | Non-SIT S&A QT Test Team | 89.33 | 5.27 | Green | Laura Kennedy | GREEN |
| 1515 | 1.6.4.1.7.5.4.4 | Regresssion Test | 10d | 2024-11-07 | 2024-11-20 | 1514 |  |  | 2024-11-07 | 2024-11-20 | 10d | 50d | 42d |  |  | Non-SIT S&A QT Test Team | Non-SIT S&A QT Test Team | 91.33 | 5.27 | Green | Laura Kennedy | GREEN |
| 1516 | 1.6.4.1.7.5.5 | **DIP Onboarding (UIT)** | 37d | 2024-08-05 | 2024-09-24 |  |  |  | 2024-08-05 | 2024-09-24 | 37d | 91d |  |  |  | N/A | N/A | -594.67 | 5.27 |  | N/A |  |
| 1517 | 1.6.4.1.7.5.5.1 | DIP available for Onboarding | 1d | 2024-08-05 | 2024-08-05 | 1503 |  |  | 2024-08-05 | 2024-08-05 | 1d | 91d | 0d | start no earlier than 2024-08-05 |  | MHHSP, Avanade | MHHSP, Avanade | -2.67 | 5.27 | Overdue Start | Laura Kennedy | RED |
| 1518 | 1.6.4.1.7.5.5.2 | Qualification Testing for Non-SIT S&A Participants' environments) Ready to start DIP onboarding (incl. certificates and security compliance) | 15d | 2024-08-06 | 2024-08-26 | 1517 |  |  | 2024-08-06 | 2024-08-26 | 15d | 91d | 0d |  |  | MHHSP, Avanade | MHHSP, Avanade | -1.67 | 5.27 | Overdue Start | Laura Kennedy | GREEN |
| 1519 | 1.6.4.1.7.5.5.3 | Non-SIT S&A QTF Environments Connection Confirmed to UIT Environment | 1d | 2024-08-27 | 2024-08-27 | 1518 |  |  | 2024-08-27 | 2024-08-27 | 1d | 91d | 0d |  |  | Non-SIT S&A QT Test Team | Non-SIT S&A QT Test Team | 19.33 | 5.27 | Green | Laura Kennedy | GREEN |
| 1520 | 1.6.4.1.7.5.5.4 | DIP UIT Test Stubs | 20d | 2024-08-28 | 2024-09-24 | 1519 |  |  | 2024-08-28 | 2024-09-24 | 20d | 91d | 83d |  |  | Non-SIT S&A QT Test Team | Non-SIT S&A QT Test Team, Avanade | 20.33 | 5.27 | Green |  | GREEN |
| 1521 | 1.6.4.1.7.5.6 | **DTN Onboarding** | 95d | 2024-05-20 A | 2024-09-27 |  | 47% | 50.21d | 2024-05-20 | 2024-09-27 | 95d | 88d |  |  | -0 | N/A | N/A | -594.67 | 5.27 |  | N/A |  |
| 1522 | 1.6.4.1.7.5.6.1 | DTN Request Raised for Onboarding | 25d | 2024-05-20 A | 2024-06-21 A | 1503FS+10d | 100% |  | 2024-05-20 | 2024-06-21 | 25d |  |  |  |  | Non-SIT S&A QT Test Team | Non-SIT S&A QT Test Team |  | 5.27 | Complete | Laura Kennedy | COMPLETE |
| 1523 | 1.6.4.1.7.5.6.2 | Setup, configuration of New Host and Test Flags | 5d | 2024-06-24 A | 2024-06-28 A | 1522 | 100% |  | 2024-06-24 | 2024-06-28 | 5d |  |  |  |  | Electralink | Electralink |  | 5.27 | Complete | Laura Kennedy | COMPLETE |
| 1524 | 1.6.4.1.7.5.6.3 | New VPN Connection | 30d | 2024-08-05 A | 2024-09-13 | 1523FS+25d | 10% | 27d | 2024-08-05 | 2024-09-13 | 30d | 88d | 0d |  |  | QT Test Team | QT Test Team |  | 5.30 | Green | Laura Kennedy | GREEN |
| 1525 | 1.6.4.1.7.5.6.4 | DTN Test Stubs | 10d | 2024-09-16 | 2024-09-27 | 1524 |  |  | 2024-09-16 | 2024-09-27 | 10d | 88d | 80d |  |  | Non-SIT S&A QT Test Team | Non-SIT S&A QT Test Team | 39.33 | 5.27 | Green | Laura Kennedy | GREEN |
| 1526 | 1.6.4.1.7.6 | **Test Data (MPANs, DIP Messages, Settlement, Consumption, Reference)** | 299d | 2024-06-10 A | 2025-07-31 |  | 14% | 257.5d | 2024-06-10 | 2025-07-31 | 299d | 476d |  |  | -0 | N/A | N/A | -385.67 | 5.27 |  | N/A |  |
| 1527 | 1.6.4.1.7.6.1 | Sample MPAN Data + Attributes from Suppliers | 15d | 2024-06-10 A | 2024-06-28 A | 1435 | 100% |  | 2024-06-10 | 2024-06-28 | 15d |  |  |  |  | Participants | Participants |  | 5.27 | Complete | Laura Kennedy | COMPLETE |
| 1528 | 1.6.4.1.7.6.2 | Test Data Templates and generator tools ready | 30d | 2024-06-24 A | 2024-08-02 | 1488SS+20d, 1527FF+25d | 93% | 2d | 2024-06-24 | 2024-08-02 | 30d | 735d |  |  |  | Non-SIT S&A QT Test Team | Non-SIT S&A QT Test Team |  | 5.27 | Overdue | Laura Kennedy | RED |
| 1529 | 1.6.4.1.7.6.3 | **Industry Standing Data (ISD)** | 33d | 2024-07-26 A | 2024-09-10 |  | 6% | 31.17d | 2024-07-26 | 2024-09-10 | 33d | 101d |  |  | -0 | N/A | N/A | -594.67 | 5.27 |  | N/A |  |
| 1530 | 1.6.4.1.7.6.3.1 | Dependant on Receiving ISD Agreed Source Data from Helix | 1d | 2024-07-26 A | 2024-07-26 A |  | 100% |  | 2024-07-26 | 2024-07-26 | 1d |  |  | start no earlier than 2024-07-26 |  | Helix | Helix |  | 5.27 | Complete | Laura Kennedy | COMPLETE |
| 1531 | 1.6.4.1.7.6.3.2 | First View of Migrated ISD Data | 1d | 2024-08-19 | 2024-08-19 | 1530 |  |  | 2024-08-19 | 2024-08-19 | 1d | 101d | 0d | start no earlier than 2024-08-19 |  |  |  | 11.33 | 5.28 | Green | Laura Kennedy | AMBER |
| 1532 | 1.6.4.1.7.6.3.3 | Final Cycle 3 Migrated ISD Data | 1d | 2024-08-20 | 2024-08-20 | 1531 |  |  | 2024-08-20 | 2024-08-20 | 1d | 101d | 0d |  |  |  |  | 12.33 | 5.28 | Green | Laura Kennedy | GREEN |
| 1533 | 1.6.4.1.7.6.3.4 | Create ISD Template inc. DIP ID | 5d | 2024-08-21 | 2024-08-27 | 1532 |  |  | 2024-08-21 | 2024-08-27 | 5d | 101d | 0d |  |  | Non-SIT S&A QT Test Team | Non-SIT S&A QT Test Team | 13.33 | 5.27 | Green | Laura Kennedy | GREEN |
| 1534 | 1.6.4.1.7.6.3.5 | Publish Qualification ISD | 10d | 2024-08-28 | 2024-09-10 | 1533 |  |  | 2024-08-28 | 2024-09-10 | 10d | 101d | 93d |  |  | Non-SIT S&A QT Test Team | Non-SIT S&A QT Test Team | 20.33 | 5.27 | Green | Laura Kennedy | GREEN |

Notes:
- 1517: Action: 3/7: Link into UIT ENV
- 1528: Action: 6/8/24: To be split into 2 tasks - jordan awaiting update. Successor?
- 1531: Action: 6/8/24: Will have to reflect the start of the new maintenence window

| ID | WBS | Task | Type | Duration | Start | Finish | Predecessors | Complete | Remaining | Baseline start | Baseline finish | Baseline duration | Total slack | Free slack | Responsible | Involved | Task Status | Update Version | MHHS Resource Name | Sched Status | RAG | Milestone ID | Text29 |
| --- | --- | --- | --- | --- | --- | --- | --- | --- | --- | --- | --- | --- | --- | --- | --- | --- | --- | --- | --- | --- | --- | --- | --- |
| 1535 | 1.6.4.1.7.6.4 | **Wave 1 Test Data** |  | 46d | 2024-11-29 | 2025-01-31 |  |  |  | 2024-11-29 | 2025-01-31 | 46d | 1d |  | N/A | N/A | -596.67 | 5.27 | N/A |  |  |  |  |
| 1536 | 1.6.4.1.7.6.4.1 | Test Data Request + Templates Completed |  | 16d | 2024-11-29 | 2024-12-20 | 1580 |  |  | 2024-11-29 | 2024-12-20 | 16d | 1d | 0d | Participants | Participants | 113.33 | 5.27 | Laura Kennedy | Green | GREEN |  |  |
| 1537 | 1.6.4.1.7.6.4.2 | Test Data Generated |  | 10d | 2024-12-23 | 2025-01-03 | 1536 |  |  | 2024-12-23 | 2025-01-03 | 10d | 1d | 0d | Non-SIT S&A QT Test Team | Non-SIT S&A QT Test Team | 137.33 | 5.27 | Laura Kennedy | Green | GREEN |  |  |
| 1538 | 1.6.4.1.7.6.4.3 | Test Data Loaded into QP Systems |  | 20d | 2025-01-06 | 2025-01-31 | 1537 |  |  | 2025-01-06 | 2025-01-31 | 20d | 1d | 0d | Participants | Participants | 151.33 | 5.27 | Laura Kennedy | Green | GREEN |  |  |
| 1539 | 1.6.4.1.7.6.4.4 | Test Data Loaded into QTF + ADO |  | 20d | 2025-01-06 | 2025-01-31 | 1537 |  |  | 2025-01-06 | 2025-01-31 | 20d | 1d | 0d | Non-SIT S&A QT Test Team | Non-SIT S&A QT Test Team | 151.33 | 5.27 | Laura Kennedy | Green | GREEN |  |  |
| 1540 | 1.6.4.1.7.6.5 | **Wave 2 Test Data** |  | 42d | 2025-01-31 | 2025-03-31 |  |  |  | 2025-01-31 | 2025-03-31 | 42d | 1d |  | N/A | N/A | -596.67 | 5.27 | N/A |  |  |  |  |
| 1541 | 1.6.4.1.7.6.5.1 | Test Data Request + Templates Completed |  | 16d | 2025-01-31 | 2025-02-21 | 1610 |  |  | 2025-01-31 | 2025-02-21 | 16d | 1d | 0d | Participants | Participants | 176.33 | 5.27 | Laura Kennedy | Green | GREEN |  |  |
| 1542 | 1.6.4.1.7.6.5.2 | Test Data Generated |  | 10d | 2025-02-24 | 2025-03-07 | 1541 |  |  | 2025-02-24 | 2025-03-07 | 10d | 1d | 0d | Non-SIT S&A QT Test Team | Non-SIT S&A QT Test Team | 200.33 | 5.27 | Laura Kennedy | Green | GREEN |  |  |
| 1543 | 1.6.4.1.7.6.5.3 | Test Data Loaded into QP Systems |  | 16d | 2025-03-10 | 2025-03-31 | 1542 |  |  | 2025-03-10 | 2025-03-31 | 16d | 1d | 0d | Participants | Participants | 214.33 | 5.27 | Laura Kennedy | Green | GREEN |  |  |
| 1544 | 1.6.4.1.7.6.5.4 | Test Data Loaded into QTF + ADO |  | 16d | 2025-03-10 | 2025-03-31 | 1542 |  |  | 2025-03-10 | 2025-03-31 | 16d | 1d | 0d | Non-SIT S&A QT Test Team | Non-SIT S&A QT Test Team | 214.33 | 5.27 | Laura Kennedy | Green | GREEN |  |  |
| 1545 | 1.6.4.1.7.6.6 | **Wave 3 Test Data** |  | 45d | 2025-03-31 | 2025-05-30 |  |  |  | 2025-03-31 | 2025-05-30 | 45d | 2d |  | N/A | N/A | -596.67 | 5.27 | N/A |  |  |  |  |
| 1546 | 1.6.4.1.7.6.6.1 | Test Data Request + Templates Completed |  | 15d | 2025-03-31 | 2025-04-18 | 1640 |  |  | 2025-03-31 | 2025-04-18 | 15d | 2d | 0d | Participants | Participants | 235.33 | 5.27 | Laura Kennedy | Green | GREEN |  |  |
| 1547 | 1.6.4.1.7.6.6.2 | Test Data Generated |  | 10d | 2025-04-21 | 2025-05-02 | 1546 |  |  | 2025-04-21 | 2025-05-02 | 10d | 2d | 0d | Non-SIT S&A QT Test Team | Non-SIT S&A QT Test Team | 256.33 | 5.27 | Laura Kennedy | Green | GREEN |  |  |
| 1548 | 1.6.4.1.7.6.6.3 | Test Data Loaded into QP Systems |  | 20d | 2025-05-05 | 2025-05-30 | 1547 |  |  | 2025-05-05 | 2025-05-30 | 20d | 2d | 0d | Participants | Participants | 270.33 | 5.27 | Laura Kennedy | Green | GREEN |  |  |
| 1549 | 1.6.4.1.7.6.6.4 | Test Data Loaded into QTF + ADO |  | 20d | 2025-05-05 | 2025-05-30 | 1547 |  |  | 2025-05-05 | 2025-05-30 | 20d | 2d | 0d | Non-SIT S&A QT Test Team | Non-SIT S&A QT Test Team | 270.33 | 5.27 | Laura Kennedy | Green | GREEN |  |  |
| 1550 | 1.6.4.1.7.6.7 | **Wave 4 Test Data** |  | 45d | 2025-05-30 | 2025-07-31 |  |  |  | 2025-05-30 | 2025-07-31 | 45d | 2d |  | N/A | N/A | -596.67 | 5.27 | N/A |  |  |  |  |
| 1551 | 1.6.4.1.7.6.7.1 | Test Data Request + Templates Completed |  | 15d | 2025-05-30 | 2025-06-19 | 1670 |  |  | 2025-05-30 | 2025-06-19 | 15d | 2d | 0d | Participants | Participants | 295.33 | 5.27 | Laura Kennedy | Green | GREEN |  |  |
| 1552 | 1.6.4.1.7.6.7.2 | Test Data Generated |  | 10d | 2025-06-20 | 2025-07-03 | 1551 |  |  | 2025-06-20 | 2025-07-03 | 10d | 2d | 0d | Non-SIT S&A QT Test Team | Non-SIT S&A QT Test Team | 316.33 | 5.27 | Laura Kennedy | Green | GREEN |  |  |
| 1553 | 1.6.4.1.7.6.7.3 | Test Data Loaded into QP Systems |  | 20d | 2025-07-04 | 2025-07-31 | 1552 |  |  | 2025-07-04 | 2025-07-31 | 20d | 2d | 0d | Participants | Participants | 330.33 | 5.27 | Laura Kennedy | Green | GREEN |  |  |
| 1554 | 1.6.4.1.7.6.7.4 | Test Data Loaded into QTF + ADO |  | 20d | 2025-07-04 | 2025-07-31 | 1552 |  |  | 2025-07-04 | 2025-07-31 | 20d | 2d | 0d | Non-SIT S&A QT Test Team | Non-SIT S&A QT Test Team | 330.33 | 5.27 | Laura Kennedy | Green | GREEN |  |  |
| 1555 | 1.6.4.1.7.7 | **Governance** |  | 130d | 2024-07-01 A | 2024-12-27 |  | 29% | 92.67d | 2024-07-01 | 2024-12-27 | 130d | 630d |  | N/A | N/A | -594.67 | 5.27 | N/A |  |  |  |  |
| 1556 | 1.6.4.1.7.7.1 | Onboarding Strategy and Develop Training Requirements & Materials Inc. Day in the Life |  | 65d | 2024-07-01 A | 2024-09-27 | 1482 | 43% | 37d | 2024-07-01 | 2024-09-27 | 65d | 695d | 0d | Non-SIT S&A QT Test Team | Non-SIT S&A QT Test Team |  | 5.27 | Laura Kennedy | Green | GREEN |  |  |
| 1557 | 1.6.4.1.7.7.2 | Design Approach & Set-Up ADO Tool for Test & Defect Management Tool |  | 45d | 2024-07-01 A | 2024-08-30 | 1556SS | 62% | 17d | 2024-07-01 | 2024-08-30 | 45d | 67d | 0d | Non-SIT S&A QT Test Team | Non-SIT S&A QT Test Team |  | 5.27 | Laura Kennedy | Green | GREEN |  |  |
| 1558 | 1.6.4.1.7.7.3 | Knowledge Transfer, Training, Demonstrations, Documentation, Governance |  | 85d | 2024-09-02 | 2024-12-27 | 1556SS+45d |  |  | 2024-09-02 | 2024-12-27 | 85d | 8d | 0d | Non-SIT S&A QT Test Team | Non-SIT S&A QT Test Team | 25.33 | 5.27 | Laura Kennedy | Green | GREEN |  |  |
| 1559 | 1.6.4.1.7.8 | Qualification Testing Framework (Test Stubs and Supporting UI) Complete | milestone | 0d | 2025-01-17 | 2025-01-17 | 1487, 1489, 1490, 1491, 1492, 1493, 1515, 1525, 1534, 1520, 1558FS+15d |  |  | 2025-01-17 | 2025-01-17 | 0d | 8d | 0d | Non-SIT S&A QT Test Team | Non-SIT S&A QT Test Team | 162.71 | 5.25 | Laura Kennedy | Green | GREEN | T3-QU-0093 | QAG |
| 1560 | 1.6.4.1.7.9 | Qualification Testing Wave Readiness Confirmed | milestone | 0d | 2025-01-23 | 2025-01-23 | 1559FS+4d, 1558 |  |  | 2025-01-23 | 2025-01-23 | 0d | 8d | 7d | Non-SIT S&A QT Test Team | Non-SIT S&A QT Test Team, Code Bodies | 168.71 | 5.25 | Laura Kennedy | Green | GREEN | T3-QU-0117 | QAG |

| ID | WBS | Task | Type | Duration | Start | Finish | Predecessors | Complete | Baseline start | Baseline finish | Baseline duration | Total slack | Free slack | Constraint | Baseline cost | Responsible | Involved | Task Status | Update Version | MHHS Resource Name | Sched Status | RAG | Milestone ID | Text29 |
| --- | --- | --- | --- | --- | --- | --- | --- | --- | --- | --- | --- | --- | --- | --- | --- | --- | --- | --- | --- | --- | --- | --- | --- | --- |
| 1561 | 1.6.4.1.8 | **Wave Allocation** |  | 129d | 2024-01-02 A | 2024-06-28 A |  | 100% | 2024-01-02 | 2024-06-28 | 128d |  |  |  | -0 | N/A | N/A | -133.67 | 5.24 | N/A |  |  |  |  |
| 1562 | 1.6.4.1.8.1 | Draft Pre-Qualification Submission (PQS) document |  | 20d | 2024-01-02 A | 2024-01-29 A |  | 100% | 2024-01-02 | 2024-01-29 | 20d |  |  | finish no earlier than 2024-01-26 |  | Code Bodies | Code Bodies |  | 5.24 | Laura Kennedy | Complete | COMPLETE |  |  |
| 1563 | 1.6.4.1.8.2 | Publish PQS document |  | 1d | 2024-01-31 A | 2024-01-31 A |  | 100% | 2024-01-31 | 2024-01-31 | 1d |  |  | start no earlier than 2024-01-31 |  | Code Bodies | Code Bodies |  | 5.24 | Laura Kennedy | Complete | COMPLETE |  |  |
| 1564 | 1.6.4.1.8.3 | PQS Submission window |  | 60d | 2024-02-05 A | 2024-04-26 A |  | 100% | 2024-02-05 | 2024-04-26 | 60d |  |  | start no earlier than 2024-02-05 |  | Participants | Participants |  | 5.24 | Laura Kennedy | Complete | COMPLETE |  |  |
| 1565 | 1.6.4.1.8.4 | Pre-Qualification Submission and PIT Test Plan Deadline for Submission​ | milestone | 0d | 2024-04-26 A | 2024-04-26 A | 1564 | 100% | 2024-04-26 | 2024-04-26 | 0d |  |  |  |  | Participants | Participants |  | 5.25 | Laura Kennedy | Complete | COMPLETE | T3-QU-0118 | QAG |
| 1566 | 1.6.4.1.8.5 | PQS Review by Code Bodies |  | 25d | 2024-04-29 A | 2024-05-31 A | 1564, 1565 | 100% | 2024-04-29 | 2024-05-31 | 25d |  |  |  |  | Code Bodies | Code Bodies |  | 5.24 | Laura Kennedy | Complete | COMPLETE |  |  |
| 1567 | 1.6.4.1.8.6 | Draft Wave Allocations |  | 15d | 2024-06-03 A | 2024-06-21 A | 1566 | 100% | 2024-06-03 | 2024-06-21 | 15d |  |  |  |  | Code Bodies | Code Bodies |  | 5.24 | Laura Kennedy | Complete | COMPLETE |  |  |
| 1568 | 1.6.4.1.8.7 | Confirmation of participant Qualification Wave allocation | milestone | 0d | 2024-06-28 A | 2024-06-28 A | 1567FS+5d | 100% | 2024-06-28 | 2024-06-28 | 0d |  |  |  |  | Code Bodies | Code Bodies |  | 5.28 | Laura Kennedy | Complete | COMPLETE | T3-QU-0012 | QAG |
| 1569 | 1.6.4.2 | **Qualification Wave 1** |  | 229d | 2024-10-14 | 2025-08-29 |  |  | 2024-10-14 | 2025-08-29 | 229d | 1d |  |  | -0 | N/A | N/A | -133.67 | 5.24 | N/A |  |  |  |  |
| 1570 | 1.6.4.2.1 | **Qualification Wave 1 QAD Prep** |  | 79d | 2024-10-14 | 2025-01-31 |  |  | 2024-10-14 | 2025-01-31 | 80d | 1d |  |  | -0 | N/A | N/A | -152.67 | 5.24 | N/A |  |  |  |  |
| 1571 | 1.6.4.2.1.1 | Initial QAD Submission window opens | milestone | 0d | 2024-10-14 | 2024-10-14 | 1568, 1388FS+6d |  | 2024-10-14 | 2024-10-14 | 0d | 1d | 0d |  |  | Participants | Participants | 67.71 | 5.24 | Laura Kennedy | yellow | GREEN |  |  |
| 1572 | 1.6.4.2.1.2 | Qualification Wave 1 Participants Submit Initial QAD |  | 49d | 2024-10-15 | 2024-12-20 | 1571 |  | 2024-10-14 | 2024-12-20 | 50d | 1d | 0d |  |  | Participants | Participants | 68.33 | 5.24 | Laura Kennedy | Green | GREEN |  |  |
| 1573 | 1.6.4.2.1.3 | Qualification Wave 1 Participants have submitted their initial QAD | milestone | 0d | 2024-12-20 | 2024-12-20 | 1572 |  | 2024-12-20 | 2024-12-20 | 0d | 1d | 0d |  |  | Participants | Participants | 134.71 | 5.25 | Laura Kennedy | Green | GREEN | T3-QU-0094 | QAG |
| 1574 | 1.6.4.2.1.4 | Code Bodies review of Wave 1 Participants Initial QAD |  | 30d | 2024-12-23 | 2025-01-31 | 1572, 1573 |  | 2024-12-23 | 2025-01-31 | 30d | 1d | 0d |  |  | Code Bodies | Code Bodies | 137.33 | 5.24 | Laura Kennedy | Green | GREEN |  |  |
| 1575 | 1.6.4.2.1.5 | Completion of Code Bodies review of Initial QAD | milestone | 0d | 2025-01-31 | 2025-01-31 | 1574 |  | 2025-01-31 | 2025-01-31 | 0d | 1d | 0d |  |  | Code Bodies | Code Bodies | 176.71 | 5.24 | Laura Kennedy | Green | GREEN |  |  |
| 1576 | 1.6.4.2.2 | **Qualification Wave 1 Test Prep** |  | 60d | 2024-11-01 | 2025-01-24 |  |  | 2024-11-01 | 2025-01-24 | 60d | 7d |  |  | -0 | N/A | N/A | -555.67 | 5.24 | N/A |  |  |  |  |
| 1577 | 1.6.4.2.2.1 | Confirmation from Qualification Wave 1 Participants that DIP onboarding has commenced | milestone | 0d | 2024-11-01 | 2024-11-01 |  |  | 2024-11-01 | 2024-11-01 | 0d | 26d | 0d | finish no earlier than 2024-11-01 |  | Participants | Participants | 85.71 | 5.24 | Laura Kennedy | Green | GREEN | T3-QU-0017 | QAG |
| 1578 | 1.6.4.2.2.2 | Qualification Wave 1 Participants DIP Onboarding Window |  | 35d | 2024-11-04 | 2024-12-20 | 1577 |  | 2024-11-04 | 2024-12-20 | 35d | 26d | 0d |  |  | Participants | Participants | 88.33 | 5.24 | Laura Kennedy | Green | GREEN |  |  |
| 1579 | 1.6.4.2.2.3 | Confirmation from Qualification Wave 1 Participants that DIP onboarding has completed | milestone | 0d | 2024-12-20 | 2024-12-20 | 1578 |  | 2024-12-20 | 2024-12-20 | 0d | 26d | 25d |  |  | Participants | Participants | 134.71 | 5.24 | Laura Kennedy | Green | GREEN |  |  |
| 1580 | 1.6.4.2.2.4 | Qualification Wave 1 Participants' to provide status of PIT completion and submit QT Test Plan | milestone | 0d | 2024-11-29 | 2024-11-29 |  |  | 2024-11-29 | 2024-11-29 | 0d | 1d | 0d | start no earlier than 2024-11-29 |  | Participants | Participants | 113.33 | 5.25 | Laura Kennedy | Green | GREEN | T3-QU-0095 | QAG |
| 1581 | 1.6.4.2.2.5 | Review of Participants' PIT Status and QT Test Plan |  | 15d | 2024-12-02 | 2024-12-20 | 1580FS+1d |  | 2024-12-02 | 2024-12-20 | 15d | 26d | 0d |  |  | Code Bodies, Non-SIT S&A QT Test Team | Code Bodies, Non-SIT S&A QT Test Team | 116.33 | 5.24 | Laura Kennedy | Green | GREEN |  |  |
| 1582 | 1.6.4.2.2.6 | Qualification Test Plans for Wave 1 Participants approved | milestone | 0d | 2024-12-20 | 2024-12-20 | 1581 |  | 2024-12-20 | 2024-12-20 | 0d | 26d | 25d |  |  | Non-SIT S&A QT Test Team | Non-SIT S&A QT Test Team | 134.71 | 5.24 | Laura Kennedy | Green | GREEN | T3-QU-0016 | QAG |
| 1583 | 1.6.4.2.2.7 | Qualification Wave 1 Participants have submitted PIT Test Completion Report and evidence for QT Entry | milestone | 0d | 2024-12-20 | 2024-12-20 |  |  | 2024-12-20 | 2024-12-20 | 0d | 1d | 0d | finish no earlier than 2024-12-20 |  | Participants | Participants | 134.71 | 5.25 | Laura Kennedy | Green | GREEN | T3-QU-0096 | QAG |
| 1584 | 1.6.4.2.2.8 | Review of Participants PIT Test Completion Report |  | 25d | 2024-12-23 | 2025-01-24 | 1583 |  | 2024-12-23 | 2025-01-24 | 25d | 1d | 0d |  |  | Code Bodies, Non-SIT S&A QT Test Team | Code Bodies, Non-SIT S&A QT Test Team | 137.33 | 5.24 | Laura Kennedy | Green | GREEN |  |  |
| 1585 | 1.6.4.2.2.9 | Onboarding to QTF & ADO |  | 25d | 2024-12-23 | 2025-01-24 | 1584SS, 1501 |  | 2024-12-23 | 2025-01-24 | 25d | 7d | 6d |  |  | Code Bodies, Non-SIT S&A QT Test Team | Code Bodies, Non-SIT S&A QT Test Team | 137.33 | 5.25 | Laura Kennedy | Green | GREEN |  |  |

| ID | WBS | Task | Type | Duration | Start | Finish | Predecessors | Baseline start | Baseline finish | Baseline duration | Total slack | Free slack | Constraint | Baseline cost | Responsible | Involved | Task Status | Update Version | MHHS Resource Name | Sched Status | RAG | Milestone ID | Text29 |
| --- | --- | --- | --- | --- | --- | --- | --- | --- | --- | --- | --- | --- | --- | --- | --- | --- | --- | --- | --- | --- | --- | --- | --- |
| 1586 | 1.6.4.2.3 | **Qualification Wave 1 QT Execution** |  | 100d | 2025-01-27 | 2025-06-13 |  | 2025-01-27 | 2025-06-13 | 100d | 1d |  |  | -0 | N/A | N/A | -152.67 | 5.24 | N/A |  |  |  |  |
| 1587 | 1.6.4.2.3.1 | Review Entry Criteria Evidence for each Wave 1 Participant |  | 5d | 2025-01-27 | 2025-01-31 | 1575FF, 1579, 1582, 1584 | 2025-01-27 | 2025-01-31 | 5d | 1d | 0d |  |  | Non-SIT S&A QT Test Team | Non-SIT S&A QT Test Team | 172.33 | 5.24 | Laura Kennedy | Green | GREEN |  |  |
| 1588 | 1.6.4.2.3.2 | Qualification Wave 1 Participant Test Readiness Confirmed | milestone | 0d | 2025-01-31 | 2025-01-31 | 1574, 1575, 1587, 1538, 1539 | 2025-01-31 | 2025-01-31 | 0d | 1d | 0d |  |  | Non-SIT S&A QT Test Team | Non-SIT S&A QT Test Team | 176.71 | 5.24 | Laura Kennedy | Green | GREEN | T3-QU-0027 | QAG |
| 1589 | 1.6.4.2.3.3 | Qualification Wave 1 QT Execution Start | milestone | 0d | 2025-02-03 | 2025-02-03 | 1588FS+1d, 1560, 1585, 1040 | 2025-02-03 | 2025-02-03 | 0d | 1d | 0d |  |  | Participants | Participants | 179.71 | 5.24 | Laura Kennedy | Green | AMBER | T3-QU-0028 | QAG |
| 1590 | 1.6.4.2.3.4 | Qualification Wave 1 QT Execution Window |  | 95d | 2025-02-03 | 2025-06-13 | 1589FS-1d | 2025-02-03 | 2025-06-13 | 95d | 6d | 0d |  |  | Participants | Participants | 179.33 | 5.24 | Laura Kennedy | Green | GREEN |  |  |
| 1591 | 1.6.4.2.3.5 | Qualification Wave 1 QT Projected Execution End | milestone | 0d | 2025-06-13 | 2025-06-13 | 1590 | 2025-06-13 | 2025-06-13 | 0d | 6d | 5d |  |  | Participants | Participants | 309.71 | 5.24 | Laura Kennedy | Green | GREEN | T3-QU-0054 | QAG |
| 1592 | 1.6.4.2.4 | **Qualification Wave 1 Exit** |  | 149d | 2025-02-03 | 2025-08-29 |  | 2025-02-03 | 2025-08-29 | 149d? | 1d |  |  | -0 | N/A | N/A | -152.67 | 5.24 | N/A |  |  |  |  |
| 1593 | 1.6.4.2.4.1 | Final QAD Submission window opens | milestone | 0d | 2025-02-03 | 2025-02-03 | 1589 | 2025-02-03 | 2025-02-03 | 0d | 1d | 0d |  |  | Participants | Participants | 179.71 | 5.24 | Laura Kennedy | yellow | GREEN |  |  |
| 1594 | 1.6.4.2.4.2 | Qualification Wave 1 Participants submit their Final QAD |  | 99d | 2025-02-04 | 2025-06-20 | 1593 | 2025-02-03 | 2025-06-20 | 100d | 1d | 0d |  |  | Participants | Participants | 180.33 | 5.24 | Laura Kennedy | Green | GREEN |  |  |
| 1595 | 1.6.4.2.4.3 | Qualification Wave 1 Participants have submitted their final QAD | milestone | 0d | 2025-06-20 | 2025-06-20 | 1594, 1591 | 2025-06-20 | 2025-06-20 | 0d | 1d | 0d |  |  | Participants | Participants | 316.71 | 5.25 | Laura Kennedy | Green | GREEN | T3-QU-0097 | QAG |
| 1596 | 1.6.4.2.4.4 | Completion of Code Bodies review of Final QAD |  | 20d | 2025-06-23 | 2025-07-18 | 1594, 1595 | 2025-06-23 | 2025-07-18 | 20d | 1d | 0d |  |  | Code Bodies | Code Bodies | 319.33 | 5.24 | Laura Kennedy | Green | GREEN |  |  |
| 1597 | 1.6.4.2.4.5 | QAD Sign Off deadline |  | 1d | 2025-07-31 | 2025-07-31 | 1596FS+8d | 2025-07-31 | 2025-07-31 | 1d | 1d | 0d |  |  | Participants | Participants | 357.33 | 5.24 | Laura Kennedy | Green | GREEN |  |  |
| 1598 | 1.6.4.2.4.6 | Qualification Wave 1 Participants Qualification approved by BSC PAB and REC Manager | milestone | 0d | 2025-08-29 | 2025-08-29 | 1597FS+21d | 2025-08-29 | 2025-08-29 | 0d | 1d | 0d |  |  | Code Bodies | Code Bodies | 386.71 | 5.24 | Laura Kennedy | yellow | GREEN | T2-QU-0150 | QAG |
| 1599 | 1.6.4.3 | **Qualification Wave 2** |  | 249d | 2024-11-18 | 2025-10-31 |  | 2024-11-18 | 2025-10-31 | 249d | 1d |  |  | -0 | N/A | N/A | -133.67 | 5.24 | N/A |  |  |  |  |
| 1600 | 1.6.4.3.1 | **Qualification Wave 2 QAD Prep** |  | 95d | 2024-11-18 | 2025-03-31 |  | 2024-11-18 | 2025-03-31 | 96d | 1d |  |  | -0 | N/A | N/A | -154.67 | 5.24 | N/A |  |  |  |  |
| 1601 | 1.6.4.3.1.1 | Initial QAD Submission window opens | milestone | 0d | 2024-11-18 | 2024-11-18 | 1389FS+6d | 2024-11-18 | 2024-11-18 | 0d | 1d | 0d |  |  | Participants | Participants | 102.71 | 5.24 | Laura Kennedy | yellow | GREEN |  |  |
| 1602 | 1.6.4.3.1.2 | Qualification Wave 2 Participants Submit Initial QAD |  | 69d | 2024-11-19 | 2025-02-21 | 1601 | 2024-11-18 | 2025-02-21 | 70d | 1d | 0d |  |  | Participants | Participants | 103.33 | 5.24 | Laura Kennedy | Green | GREEN |  |  |
| 1603 | 1.6.4.3.1.3 | Qualification Wave 2 Participants have submitted their initial QAD | milestone | 0d | 2025-02-21 | 2025-02-21 | 1602 | 2025-02-21 | 2025-02-21 | 0d | 1d | 0d |  |  | Participants | Participants | 197.71 | 5.25 | Laura Kennedy | Green | GREEN | T3-QU-0098 | QAG |
| 1604 | 1.6.4.3.1.4 | Code Bodies review of Wave 2 Participants' Initial QAD |  | 26d | 2025-02-24 | 2025-03-31 | 1603 | 2025-02-24 | 2025-03-31 | 26d | 1d | 0d |  |  | Code Bodies | Code Bodies | 200.33 | 5.24 | Laura Kennedy | Green | GREEN |  |  |
| 1605 | 1.6.4.3.1.5 | Completion of Code Bodies review of Initial QAD | milestone | 0d | 2025-03-31 | 2025-03-31 | 1604 | 2025-03-31 | 2025-03-31 | 0d | 1d | 0d |  |  | Code Bodies | Code Bodies | 235.71 | 5.24 | Laura Kennedy | Green | GREEN |  |  |
| 1606 | 1.6.4.3.2 | **Qualification Wave 2 Test Prep** |  | 60d | 2025-01-06 | 2025-03-28 |  | 2025-01-06 | 2025-03-28 | 60d | 17d |  |  | -0 | N/A | N/A | -555.67 | 5.24 | N/A |  |  |  |  |
| 1607 | 1.6.4.3.2.1 | Confirmation from Qualification Wave 2 Participants that DIP Onboarding has commenced | milestone | 0d | 2025-01-06 | 2025-01-06 |  | 2025-01-06 | 2025-01-06 | 0d | 17d | 0d | start no earlier than 2025-01-06 |  | Participants | Participants | 151.33 | 5.24 | Laura Kennedy | Green | GREEN | T3-QU-0021 | QAG |
| 1608 | 1.6.4.3.2.2 | Qualification Wave 2 Participants DIP Onboarding Window |  | 40d | 2025-01-06 | 2025-02-28 | 1607 | 2025-01-06 | 2025-02-28 | 40d | 17d | 0d |  |  | Participants | Participants | 151.33 | 5.24 | Laura Kennedy | Green | GREEN |  |  |
| 1609 | 1.6.4.3.2.3 | Confirmation from Qualificiation Wave 2 Participants that DIP onboarding has completed | milestone | 0d | 2025-02-28 | 2025-02-28 | 1608 | 2025-02-28 | 2025-02-28 | 0d | 17d | 16d |  |  | Participants | Participants | 204.71 | 5.24 | Laura Kennedy | Green | GREEN |  |  |
| 1610 | 1.6.4.3.2.4 | Qualification Wave 2 Participants' to provide status of PIT completion and submit QT Test Plan | milestone | 0d | 2025-01-31 | 2025-01-31 |  | 2025-01-31 | 2025-01-31 | 0d | 1d | 0d | start no earlier than 2025-01-31 |  | Participants | Participants | 176.33 | 5.25 | Laura Kennedy | Green | GREEN | T3-QU-0099 | QAG |
| 1611 | 1.6.4.3.2.5 | Review of Participants' PIT Status and QT Test Plan |  | 15d | 2025-02-03 | 2025-02-21 | 1610FS+1d | 2025-02-03 | 2025-02-21 | 15d | 590d | 0d |  |  | Code Bodies, Non-SIT S&A QT Test Team | Code Bodies, Non-SIT S&A QT Test Team | 179.33 | 5.24 | Laura Kennedy | Green | GREEN |  |  |
| 1612 | 1.6.4.3.2.6 | Qualification Test Plans for Wave 2 Participants approved | milestone | 0d | 2025-02-21 | 2025-02-21 | 1611 | 2025-02-21 | 2025-02-21 | 0d | 590d |  |  |  | Non-SIT S&A QT Test Team | Non-SIT S&A QT Test Team | 197.71 | 5.24 | Laura Kennedy | Green | GREEN | T3-QU-0020 | QAG |
| 1613 | 1.6.4.3.2.7 | Qualification Wave 2 Participants have submitted PIT Test Completion Report and evidence for QT entry | milestone | 0d | 2025-02-21 | 2025-02-21 |  | 2025-02-21 | 2025-02-21 | 0d | 3d | 0d | finish no earlier than 2025-02-21 |  | Participants | Participants | 197.71 | 5.25 | Laura Kennedy | yellow | GREEN | T3-QU-0100 | QAG |
| 1614 | 1.6.4.3.2.8 | Review of Participants' PIT Test Completion Report |  | 25d | 2025-02-24 | 2025-03-28 | 1613 | 2025-02-24 | 2025-03-28 | 25d | 3d | 0d |  |  | Code Bodies, Non-SIT S&A QT Test Team | Code Bodies, Non-SIT S&A QT Test Team | 200.33 | 5.24 | Laura Kennedy | Green | GREEN |  |  |
| 1615 | 1.6.4.3.2.9 | Onboarding to QTF & ADO |  | 25d | 2025-02-24 | 2025-03-28 | 1614SS | 2025-02-24 | 2025-03-28 | 25d | 3d | 2d |  |  | Code Bodies, Non-SIT S&A QT Test Team | Code Bodies, Non-SIT S&A QT Test Team | 200.33 | 5.25 | Laura Kennedy | Green | GREEN |  |  |

Notes:
- 1589: 6/8/24: Date at risk from scenario planning activity

| ID | WBS | Task | Type | Duration | Start | Finish | Predecessors | Baseline start | Baseline finish | Baseline duration | Total slack | Free slack | Constraint | Baseline cost | Responsible | Involved | Task Status | Update Version | MHHS Resource Name | Sched Status | RAG | Milestone ID | Text29 |
| --- | --- | --- | --- | --- | --- | --- | --- | --- | --- | --- | --- | --- | --- | --- | --- | --- | --- | --- | --- | --- | --- | --- | --- |
| 1616 | 1.6.4.3.3 | **Qualification Wave 2 QT Execution** |  | 99d | 2025-03-25 | 2025-08-08 |  | 2025-03-25 | 2025-08-08 | 99d | 1d |  |  | -0 | N/A | N/A | -154.67 | 5.24 | N/A |  |  |  |  |
| 1617 | 1.6.4.3.3.1 | Review Entry Criteria Evidence for each Wave 2 Participant |  | 5d | 2025-03-25 | 2025-03-31 | 1605FF, 1609 | 2025-03-25 | 2025-03-31 | 5d | 1d | 0d |  |  | Non-SIT S&A QT Test Team | Non-SIT S&A QT Test Team | 229.33 | 5.24 | Laura Kennedy | Green | GREEN |  |  |
| 1618 | 1.6.4.3.3.2 | Qualification Wave 2 Participant Test Readiness Confirmed | milestone | 0d | 2025-03-31 | 2025-03-31 | 1617, 1605, 1543, 1544 | 2025-03-31 | 2025-03-31 | 0d | 1d | 0d |  |  | Non-SIT S&A QT Test Team | Non-SIT S&A QT Test Team | 235.71 | 5.24 | Laura Kennedy | Green | GREEN | T3-QU-0033 | QAG |
| 1619 | 1.6.4.3.3.3 | Qualification Wave 2 Execution Start | milestone | 0d | 2025-04-01 | 2025-04-01 | 1618FS+1d, 1615 | 2025-04-01 | 2025-04-01 | 0d | 1d | 0d |  |  | Participants | Participants | 236.71 | 5.24 | Laura Kennedy | yellow | AMBER | T3-QU-0034 | QAG |
| 1620 | 1.6.4.3.3.4 | Qualification Wave 2 QT Execution Window |  | 93d | 2025-04-02 | 2025-08-08 | 1619 | 2025-04-01 | 2025-08-08 | 94d | 6d | 0d |  |  | Participants | Participants | 237.33 | 5.24 | Laura Kennedy | Green | GREEN |  |  |
| 1621 | 1.6.4.3.3.5 | Qualfication Wave 2 QT Execution End | milestone | 0d | 2025-08-08 | 2025-08-08 | 1620 | 2025-08-08 | 2025-08-08 | 0d | 6d | 5d |  |  | Participants | Participants | 365.71 | 5.24 | Laura Kennedy | Green | GREEN | T3-QU-0055 | QAG |
| 1622 | 1.6.4.3.4 | **Qualification Wave 2 Exit** |  | 153d | 2025-04-01 | 2025-10-31 |  | 2025-04-01 | 2025-10-31 | 153d | 1d |  |  | -0 | N/A | N/A | -154.67 | 5.24 | N/A |  |  |  |  |
| 1623 | 1.6.4.3.4.1 | Final QAD Submission window opens | milestone | 0d | 2025-04-01 | 2025-04-01 | 1619 | 2025-04-01 | 2025-04-01 | 0d | 1d | 0d |  |  | Participants | Participants | 236.71 | 5.24 | Laura Kennedy | yellow | GREEN |  |  |
| 1624 | 1.6.4.3.4.2 | Qualification Wave 2 Participants submit their Final QAD |  | 98d | 2025-04-02 | 2025-08-15 | 1623 | 2025-04-01 | 2025-08-15 | 99d | 1d | 0d |  |  | Participants | Participants | 237.33 | 5.24 | Laura Kennedy | Green | GREEN |  |  |
| 1625 | 1.6.4.3.4.3 | Qualification Wave 2 Participants have submitted their final QAD | milestone | 0d | 2025-08-15 | 2025-08-15 | 1624, 1621 | 2025-08-15 | 2025-08-15 | 0d | 1d | 0d |  |  | Participants | Participants | 372.71 | 5.25 | Laura Kennedy | Green | GREEN | T3-QU-0101 | QAG |
| 1626 | 1.6.4.3.4.4 | Completion of Code Bodies review of Final QAD |  | 27d | 2025-08-18 | 2025-09-23 | 1625 | 2025-08-18 | 2025-09-23 | 27d | 1d | 0d |  |  | Code Bodies | Code Bodies | 375.33 | 5.24 | Laura Kennedy | Green | GREEN |  |  |
| 1627 | 1.6.4.3.4.5 | QAD Sign Off deadline |  | 1d | 2025-09-30 | 2025-09-30 | 1626FS+4d | 2025-09-30 | 2025-09-30 | 1d | 1d | 0d |  |  | Participants | Participants | 418.33 | 5.24 | Laura Kennedy | Green | GREEN |  |  |
| 1628 | 1.6.4.3.4.6 | Qualification Wave 2 Participants Qualification approved by BSC PAB and REC Manager | milestone | 0d | 2025-10-31 | 2025-10-31 | 1627FS+23d | 2025-10-31 | 2025-10-31 | 0d | 1d | 0d |  |  | Code Bodies | Code Bodies | 449.71 | 5.24 | Laura Kennedy | yellow | GREEN | T2-QU-0200 | QAG |
| 1629 | 1.6.4.4 | **Qualification Wave 3** |  | 239d | 2025-01-20 | 2025-12-19 |  | 2025-01-20 | 2025-12-19 | 239d | 2d |  |  | -0 | N/A | N/A | -133.67 | 5.24 | N/A |  |  |  |  |
| 1630 | 1.6.4.4.1 | **Qualification Wave 3 QAD Prep** |  | 94d | 2025-01-20 | 2025-05-30 |  | 2025-01-20 | 2025-05-30 | 95d | 2d |  |  | -0 | N/A | N/A | -154.67 | 5.24 | N/A |  |  |  |  |
| 1631 | 1.6.4.4.1.1 | Initial QAD Submission window opens | milestone | 0d | 2025-01-20 | 2025-01-20 | 1390FS+6d | 2025-01-20 | 2025-01-20 | 0d | 2d | 0d |  |  | Participants | Participants | 165.71 | 5.24 | Laura Kennedy | yellow | GREEN |  |  |
| 1632 | 1.6.4.4.1.2 | Qualification Wave 3 Participants Submit Initial QAD |  | 64d | 2025-01-21 | 2025-04-18 | 1631 | 2025-01-20 | 2025-04-18 | 65d | 2d | 0d |  |  | Participants | Participants | 166.33 | 5.24 | Laura Kennedy | Green | GREEN |  |  |
| 1633 | 1.6.4.4.1.3 | Qualification Wave 3 Participants have submitted their initial QAD | milestone | 0d | 2025-04-18 | 2025-04-18 | 1632 | 2025-04-18 | 2025-04-18 | 0d | 2d | 0d |  |  | Participants | Participants | 253.71 | 5.25 | Laura Kennedy | yellow | GREEN | T3-QU-0102 | QAG |
| 1634 | 1.6.4.4.1.4 | Code Bodies review of Wave 3 Participants' Initial QAD |  | 30d | 2025-04-21 | 2025-05-30 | 1633 | 2025-04-21 | 2025-05-30 | 30d | 2d | 0d |  |  | Code Bodies | Code Bodies | 256.33 | 5.24 | Laura Kennedy | Green | GREEN |  |  |
| 1635 | 1.6.4.4.1.5 | Completion of Code Bodies review of Initial QAD | milestone | 0d | 2025-05-30 | 2025-05-30 | 1634 | 2025-05-30 | 2025-05-30 | 0d | 2d | 0d |  |  | Code Bodies | Code Bodies | 295.71 | 5.24 | Laura Kennedy | Green | GREEN |  |  |
| 1636 | 1.6.4.4.2 | **Qualification Wave 3 Test Prep** |  | 65d | 2025-03-03 | 2025-05-30 |  | 2025-03-03 | 2025-05-30 | 65d | 22d |  |  | -0 | N/A | N/A | -555.67 | 5.24 | N/A |  |  |  |  |
| 1637 | 1.6.4.4.2.1 | Qualification Wave 3 Participants' have started DIP Onboarding | milestone | 0d | 2025-03-03 | 2025-03-03 |  | 2025-03-03 | 2025-03-03 | 0d | 24d | 0d | start no earlier than 2025-03-03 |  | Participants | Participants | 207.33 | 5.24 | Laura Kennedy | Green | GREEN | T3-QU-0025 | QAG |
| 1638 | 1.6.4.4.2.2 | Qualification Wave 3 Participants DIP Onboarding window |  | 40d | 2025-03-03 | 2025-04-25 | 1637 | 2025-03-03 | 2025-04-25 | 40d | 24d | 0d |  |  | Participants | Participants | 207.33 | 5.24 | Laura Kennedy | Green | GREEN |  |  |
| 1639 | 1.6.4.4.2.3 | Confirmation from Qualification Wave 3 Participants that DIP onboarding has completed | milestone | 0d | 2025-04-25 | 2025-04-25 | 1638 | 2025-04-25 | 2025-04-25 | 0d | 24d | 22d |  |  | Participants | Participants | 260.71 | 5.24 | Laura Kennedy | Green | GREEN |  |  |
| 1640 | 1.6.4.4.2.4 | Qualification Wave 3 Participants' to provide status of PIT completion and submit QT Test Plan | milestone | 0d | 2025-03-31 | 2025-03-31 |  | 2025-03-31 | 2025-03-31 | 0d | 2d | 0d | start no earlier than 2025-03-31 |  | Participants | Participants | 235.33 | 5.25 | Laura Kennedy | Green | GREEN | T3-QU-0103 | QAG |
| 1641 | 1.6.4.4.2.5 | Review of Participants' PIT Status and QT Test Plan |  | 15d | 2025-03-31 | 2025-04-18 | 1640 | 2025-03-31 | 2025-04-18 | 15d | 550d | 0d |  |  | Code Bodies, Non-SIT S&A QT Test Team | Code Bodies, Non-SIT S&A QT Test Team | 235.33 | 5.24 | Laura Kennedy | Green | GREEN |  |  |
| 1642 | 1.6.4.4.2.6 | Qualification Test Plans for Wave 3 Participants approved | milestone | 0d | 2025-04-18 | 2025-04-18 | 1641 | 2025-04-18 | 2025-04-18 | 0d | 550d |  |  |  | Non-SIT S&A QT Test Team | Non-SIT S&A QT Test Team | 253.71 | 5.24 | Laura Kennedy | Green | GREEN | T3-QU-0024 | QAG |
| 1643 | 1.6.4.4.2.7 | Qualification Wave 3 Participants have submitted PIT Test Completion Report and evidence for QT Entry | milestone | 0d | 2025-04-18 | 2025-04-18 |  | 2025-04-18 | 2025-04-18 | 0d | 1d | 0d | finish no earlier than 2025-04-18 |  | Participants | Participants | 253.71 | 5.25 | Laura Kennedy | yellow | GREEN | T3-QU-0104 | QAG |
| 1644 | 1.6.4.4.2.8 | Review of Participants' PIT Test Completion Report |  | 30d | 2025-04-21 | 2025-05-30 | 1643 | 2025-04-21 | 2025-05-30 | 30d | 1d | 0d |  |  | Code Bodies, Non-SIT S&A QT Test Team | Code Bodies, Non-SIT S&A QT Test Team | 256.33 | 5.24 | Laura Kennedy | Green | GREEN |  |  |
| 1645 | 1.6.4.4.2.9 | Onboarding to QTF & ADO |  | 30d | 2025-04-21 | 2025-05-30 | 1644SS | 2025-04-21 | 2025-05-30 | 30d | 1d | 0d |  |  |  |  | 256.33 | 5.24 | Laura Kennedy | Green | GREEN |  |  |

Notes:
- 1619: 6/8/24: Date at risk from scenario planning activity
- 1628: 14/5: Baseline and name updated after cr48 approval at psg on 1/5

| ID | WBS | Task | Type | Duration | Start | Finish | Predecessors | Baseline start | Baseline finish | Baseline duration | Total slack | Free slack | Constraint | Baseline cost | Responsible | Involved | Task Status | Update Version | MHHS Resource Name | Sched Status | RAG | Milestone ID | Text29 |
| --- | --- | --- | --- | --- | --- | --- | --- | --- | --- | --- | --- | --- | --- | --- | --- | --- | --- | --- | --- | --- | --- | --- | --- |
| 1646 | 1.6.4.4.3 | **Qualification Wave 3 QT Execution** |  | 98d | 2025-05-28 | 2025-10-10 |  | 2025-05-26 | 2025-10-10 | 100d | 2d |  |  | -0 | N/A | N/A | -154.67 | 5.24 | N/A |  |  |  |  |
| 1647 | 1.6.4.4.3.1 | Review Entry Criteria Evidence for each Wave 3 Participant |  | 3d | 2025-05-28 | 2025-05-30 | 1639, 1635FF | 2025-05-26 | 2025-05-30 | 5d | 2d | 0d |  |  | Non-SIT S&A QT Test Team | Non-SIT S&A QT Test Team | 293.33 | 5.24 | Laura Kennedy | Green | GREEN |  |  |
| 1648 | 1.6.4.4.3.2 | Qualification Wave 3 Participant Test Readiness confirmed | milestone | 0d | 2025-05-30 | 2025-05-30 | 1639, 1647, 1548, 1549 | 2025-05-30 | 2025-05-30 | 0d | 2d | 1d |  |  | Non-SIT S&A QT Test Team | Non-SIT S&A QT Test Team | 295.71 | 5.24 | Laura Kennedy | yellow | GREEN | T3-QU-0038 | QAG |
| 1649 | 1.6.4.4.3.3 | Qualification Wave 3 Execution Start | milestone | 0d | 2025-06-02 | 2025-06-02 | 1648, 1645FS+1d | 2025-06-02 | 2025-06-02 | 0d | 1d | 0d |  |  | Participants | Participants | 298.71 | 5.24 | Laura Kennedy | yellow | AMBER | T3-QU-0039 | QAG |
| 1650 | 1.6.4.4.3.4 | Qualification Wave 3 QT Execution Window |  | 94d | 2025-06-03 | 2025-10-10 | 1647, 1649 | 2025-06-02 | 2025-10-10 | 95d | 6d | 0d |  |  | Participants | Participants | 299.33 | 5.24 | Laura Kennedy | Green | GREEN |  |  |
| 1651 | 1.6.4.4.3.5 | Qualification Wave 3 Projected Execution End | milestone | 0d | 2025-10-10 | 2025-10-10 | 1650 | 2025-10-10 | 2025-10-10 | 0d | 6d | 5d |  |  | Participants | Participants | 428.71 | 5.24 | Laura Kennedy | Green | GREEN | T3-QU-0056 | QAG |
| 1652 | 1.6.4.4.4 | **Qualification Wave 3 Exit** |  | 144d | 2025-06-02 | 2025-12-19 |  | 2025-06-02 | 2025-12-19 | 144d | 1d |  |  | -0 | N/A | N/A | -154.67 | 5.24 | N/A |  |  |  |  |
| 1653 | 1.6.4.4.4.1 | Final QAD Submission window opens | milestone | 0d | 2025-06-02 | 2025-06-02 | 1649 | 2025-06-02 | 2025-06-02 | 0d | 1d | 0d |  |  | Participants | Participants | 298.71 | 5.24 | Laura Kennedy | yellow | GREEN |  |  |
| 1654 | 1.6.4.4.4.2 | Qualification Wave 3 Participants submit their Final QAD |  | 99d | 2025-06-03 | 2025-10-17 | 1653 | 2025-06-02 | 2025-10-17 | 100d | 1d | 0d |  |  | Participants | Participants | 299.33 | 5.24 | Laura Kennedy | Green | GREEN |  |  |
| 1655 | 1.6.4.4.4.3 | Qualification Wave 3 Participants have submitted their Final QAD | milestone | 0d | 2025-10-17 | 2025-10-17 | 1654, 1651 | 2025-10-17 | 2025-10-17 | 0d | 1d | 0d |  |  | Participants | Participants | 435.71 | 5.25 | Laura Kennedy | Green | GREEN | T3-QU-0105 | QAG |
| 1656 | 1.6.4.4.4.4 | Completion of Code Bodies review of Final QAD |  | 20d | 2025-10-20 | 2025-11-14 | 1655 | 2025-10-20 | 2025-11-14 | 20d | 1d | 0d |  |  | Code Bodies | Code Bodies | 438.33 | 5.24 | Laura Kennedy | Green | GREEN |  |  |
| 1657 | 1.6.4.4.4.5 | QAD Sign Off deadline |  | 1d | 2025-11-21 | 2025-11-21 | 1656FS+4d | 2025-11-21 | 2025-11-21 | 1d | 1d | 0d |  |  | Participants | Participants | 470.33 | 5.24 | Laura Kennedy | Green | GREEN |  |  |
| 1658 | 1.6.4.4.4.6 | Qualification Wave 3 Participants Qualification approved by BSC PAB and REC Manager | milestone | 0d | 2025-12-19 | 2025-12-19 | 1657FS+20d | 2025-12-19 | 2025-12-19 | 0d | 1d | 0d |  |  | Code Bodies | Code Bodies | 498.71 | 5.24 | Laura Kennedy | yellow | GREEN | T2-QU-0250 | QAG |
| 1659 | 1.6.4.5 | **Qualification Wave 4** |  | 249d | 2025-03-17 | 2026-02-27 |  | 2025-03-17 | 2026-02-27 | 249d | 2d |  |  | -0 | N/A | N/A | -133.67 | 5.24 | N/A |  |  |  |  |
| 1660 | 1.6.4.5.1 | **Qualification Wave 4 QAD Prep** |  | 98d | 2025-03-17 | 2025-07-31 |  | 2025-03-17 | 2025-07-31 | 99d | 2d |  |  | -0 | N/A | N/A | -155.67 | 5.24 | N/A |  |  |  |  |
| 1661 | 1.6.4.5.1.1 | Initial QAD Submission window opens | milestone | 0d | 2025-03-17 | 2025-03-17 | 1391FS+6d | 2025-03-17 | 2025-03-17 | 0d | 2d | 0d |  |  | Participants | Participants | 221.71 | 5.24 | Laura Kennedy | yellow | GREEN |  |  |
| 1662 | 1.6.4.5.1.2 | Qualification Wave 4 Participants Submit Initial QAD |  | 69d | 2025-03-18 | 2025-06-20 | 1661 | 2025-03-17 | 2025-06-20 | 70d | 2d | 0d |  |  | Participants | Participants | 222.33 | 5.24 | Laura Kennedy | Green | GREEN |  |  |
| 1663 | 1.6.4.5.1.3 | Qualification Wave 4 Participants have submitted their Initial QAD | milestone | 0d | 2025-06-20 | 2025-06-20 | 1662 | 2025-06-20 | 2025-06-20 | 0d | 2d | 0d |  |  | Participants | Participants | 316.71 | 5.25 | Laura Kennedy | Green | GREEN | T3-QU-0106 | QAG |
| 1664 | 1.6.4.5.1.4 | Code Bodies review of Wave 4 Participants' Initial QAD |  | 29d | 2025-06-23 | 2025-07-31 | 1663 | 2025-06-23 | 2025-07-31 | 29d | 2d | 0d |  |  | Code Bodies | Code Bodies | 319.33 | 5.24 | Laura Kennedy | Green | GREEN |  |  |
| 1665 | 1.6.4.5.1.5 | Completion of Code Bodies review of Initial QAD | milestone | 0d | 2025-07-31 | 2025-07-31 | 1664 | 2025-07-31 | 2025-07-31 | 0d | 2d | 0d |  |  | Code Bodies | Code Bodies | 357.71 | 5.24 | Laura Kennedy | Green | GREEN |  |  |
| 1666 | 1.6.4.5.2 | **Qualification Wave 4 Test Prep** |  | 67d | 2025-05-01 | 2025-08-01 |  | 2025-05-01 | 2025-08-01 | 67d | 21d |  |  | -0 | N/A | N/A | -555.67 | 5.24 | N/A |  |  |  |  |
| 1667 | 1.6.4.5.2.1 | Confirmation from Qualification 4 Participants that DIP Onboarding has commenced | milestone | 0d | 2025-05-01 | 2025-05-01 |  | 2025-05-01 | 2025-05-01 | 0d | 21d | 0d | start no earlier than 2025-05-01 |  | Participants | Participants | 266.33 | 5.24 | Laura Kennedy | Green | GREEN | T3-QU-0031 | QAG |
| 1668 | 1.6.4.5.2.2 | Qualification Wave 4 Participants DIP Onboarding Window |  | 42d | 2025-05-01 | 2025-06-27 | 1667 | 2025-05-01 | 2025-06-27 | 42d | 21d | 0d |  |  | Participants | Participants | 266.33 | 5.24 | Laura Kennedy | Green | GREEN |  |  |
| 1669 | 1.6.4.5.2.3 | Confirmation from Qualification Wave 4 Participants that DIP onboarding has completed | milestone | 0d | 2025-06-27 | 2025-06-27 | 1668 | 2025-06-27 | 2025-06-27 | 0d | 21d | 19d |  |  | Participants | Participants | 323.71 | 5.24 | Laura Kennedy | Green | GREEN |  |  |
| 1670 | 1.6.4.5.2.4 | Qualification Wave 4 Participants' to provide status of PIT completion and submit QT Test Plan | milestone | 0d | 2025-05-30 | 2025-05-30 |  | 2025-05-30 | 2025-05-30 | 0d | 2d | 0d | start no earlier than 2025-05-30 |  | Participants | Participants | 295.33 | 5.25 | Laura Kennedy | Green | GREEN | T3-QU-0107 | QAG |
| 1671 | 1.6.4.5.2.5 | Review of Participants' PIT Status and QT Test Plan |  | 16d | 2025-05-30 | 2025-06-20 | 1670 | 2025-05-30 | 2025-06-20 | 16d | 505d | 0d |  |  | Code Bodies, Non-SIT S&A QT Test Team | Code Bodies, Non-SIT S&A QT Test Team | 295.33 | 5.24 | Laura Kennedy | Green | GREEN |  |  |
| 1672 | 1.6.4.5.2.6 | Qualification Test Plans for Qualification Wave 4 Participants approved | milestone | 0d | 2025-06-20 | 2025-06-20 | 1671 | 2025-06-20 | 2025-06-20 | 0d | 505d |  |  |  | Non-SIT S&A QT Test Team | Non-SIT S&A QT Test Team | 316.71 | 5.24 | Laura Kennedy | Green | GREEN | T3-QU-0030 | QAG |
| 1673 | 1.6.4.5.2.7 | Qualification Wave 4 Participants have submitted PIT Test Completion Report and evidence for QT entry | milestone | 0d | 2025-06-20 | 2025-06-20 |  | 2025-06-20 | 2025-06-20 | 0d | 1d | 0d | finish no earlier than 2025-06-20 |  | Participants | Participants | 316.71 | 5.25 | Laura Kennedy | yellow | GREEN | T3-QU-0108 | QAG |
| 1674 | 1.6.4.5.2.8 | Review of Participants' PIT Test Completion Report |  | 29d | 2025-06-23 | 2025-07-31 | 1673 | 2025-06-20 | 2025-07-31 | 30d | 1d | 0d |  |  | Code Bodies, Non-SIT S&A QT Test Team | Code Bodies, Non-SIT S&A QT Test Team | 319.33 | 5.24 | Laura Kennedy | Green | GREEN |  |  |
| 1675 | 1.6.4.5.2.9 | Onboarding to QTF & ADO |  | 30d | 2025-06-23 | 2025-08-01 | 1674SS | 2025-06-23 | 2025-08-01 | 30d | 1d | 0d |  |  | Code Bodies, Non-SIT S&A QT Test Team | Code Bodies, Non-SIT S&A QT Test Team | 319.33 | 5.25 | Laura Kennedy | Green | GREEN |  |  |

Notes:
- 1649: 6/8/24: Date at risk from scenario planning activity
- 1658: 14/5: Baseline and name updated after cr48 approval at psg on 1/5

| ID | WBS | Task | Type | Duration | Start | Finish | Predecessors | Complete | Remaining | Baseline start | Baseline finish | Baseline duration | Baseline 1 start | Baseline 1 finish | Total slack | Free slack | Constraint | Baseline cost | Responsible | Involved | Task Status | Update Version | MHHS Resource Name | Sched Status | RAG | Milestone ID | Text29 | MHHS Programme Phase | Artefact ID | Tier |
| --- | --- | --- | --- | --- | --- | --- | --- | --- | --- | --- | --- | --- | --- | --- | --- | --- | --- | --- | --- | --- | --- | --- | --- | --- | --- | --- | --- | --- | --- | --- |
| 1676 | 1.6.4.5.3 | **Qualification Wave 4 QT Execution** |  | 101d | 2025-07-25 | 2025-12-12 |  |  |  | 2025-07-25 | 2025-12-12 | 101d |  |  | 2d |  |  | -0 | N/A | N/A | -155.67 | 5.24 | N/A |  |  |  |  |  |  |  |
| 1677 | 1.6.4.5.3.1 | Review Entry Criteria Evidence for each Wave 4 Participant |  | 5d | 2025-07-25 | 2025-07-31 | 1665FF, 1669 |  |  | 2025-07-25 | 2025-07-31 | 5d |  |  | 2d | 0d |  |  | Non-SIT S&A QT Test Team | Non-SIT S&A QT Test Team | 351.33 | 5.24 | Laura Kennedy | Green | GREEN |  |  |  |  |  |
| 1678 | 1.6.4.5.3.2 | Qualification Test Plans for Qualification Wave 4 Participants approved | milestone | 0d | 2025-07-31 | 2025-07-31 | 1669, 1677, 1553, 1554 |  |  | 2025-07-31 | 2025-07-31 | 0d |  |  | 2d | 1d |  |  | Non-SIT S&A QT Test Team | Non-SIT S&A QT Test Team | 357.71 | 5.24 | Laura Kennedy | yellow | GREEN | T3-QU-0043 | QAG |  |  |  |
| 1679 | 1.6.4.5.3.3 | Qualification Wave 4 QT Execution Start | milestone | 0d | 2025-08-01 | 2025-08-01 | 1678, 1675 |  |  | 2025-08-01 | 2025-08-01 | 0d |  |  | 1d | 0d |  |  | Participants | Participants | 358.71 | 5.24 | Laura Kennedy | yellow | AMBER | T3-QU-0044 | QAG |  |  |  |
| 1680 | 1.6.4.5.3.4 | Qualification Wave 4 QT Execution Window |  | 95d | 2025-08-04 | 2025-12-12 | 1679, 1677 |  |  | 2025-08-01 | 2025-12-12 | 96d |  |  | 6d | 0d |  |  | Participants | Participants | 361.33 | 5.24 | Laura Kennedy | Green | GREEN |  |  |  |  |  |
| 1681 | 1.6.4.5.3.5 | Qualification Wave 4 Projected Execution End | milestone | 0d | 2025-12-12 | 2025-12-12 | 1680 |  |  | 2025-12-12 | 2025-12-12 | 0d |  |  | 6d | 5d |  |  | Participants | Participants | 491.71 | 5.24 | Laura Kennedy | Green | GREEN | T3-QU-0057 | QAG |  |  |  |
| 1682 | 1.6.4.5.4 | **Qualification Wave 4 Exit** |  | 150d | 2025-08-01 | 2026-02-27 |  |  |  | 2025-08-01 | 2026-02-27 | 150d |  |  | 1d |  |  | -0 | N/A | N/A | -155.67 | 5.24 | N/A |  |  |  |  |  |  |  |
| 1683 | 1.6.4.5.4.1 | Final QAD Submission window opens | milestone | 0d | 2025-08-01 | 2025-08-01 | 1679 |  |  | 2025-08-01 | 2025-08-01 | 0d |  |  | 1d | 0d |  |  | Participants | Participants | 358.71 | 5.24 | Laura Kennedy | yellow | GREEN |  |  |  |  |  |
| 1684 | 1.6.4.5.4.2 | Qualification Wave 4 Participants submit their Final QAD |  | 100d | 2025-08-04 | 2025-12-19 | 1683 |  |  | 2025-08-01 | 2025-12-19 | 101d |  |  | 1d | 0d |  |  | Participants | Participants | 361.33 | 5.24 | Laura Kennedy | Green | GREEN |  |  |  |  |  |
| 1685 | 1.6.4.5.4.3 | Qualification Wave 4 Participants have submitted their Final QAD | milestone | 0d | 2025-12-19 | 2025-12-19 | 1684, 1681 |  |  | 2025-12-19 | 2025-12-19 | 0d |  |  | 1d | 0d |  |  | Participants | Participants | 498.71 | 5.25 | Laura Kennedy | Green | GREEN | T3-QU-0109 | QAG |  |  |  |
| 1686 | 1.6.4.5.4.4 | Completion of Code Bodies review of Final QAD |  | 25d | 2025-12-22 | 2026-01-23 | 1685 |  |  | 2025-12-22 | 2026-01-23 | 25d |  |  | 1d | 0d |  |  | Code Bodies | Code Bodies | 501.33 | 5.24 | Laura Kennedy | Green | GREEN |  |  |  |  |  |
| 1687 | 1.6.4.5.4.5 | QAD Sign Off deadline |  | 1d | 2026-01-30 | 2026-01-30 | 1686FS+4d |  |  | 2026-01-30 | 2026-01-30 | 1d |  |  | 1d | 0d |  |  | Participants | Participants | 540.33 | 5.24 | Laura Kennedy | Green | GREEN |  |  |  |  |  |
| 1688 | 1.6.4.5.4.6 | Qualification Wave 4 Participants Qualification approved by BSC PAB and REC Manager | milestone | 0d | 2026-02-27 | 2026-02-27 | 1687FS+20d |  |  | 2026-02-27 | 2026-02-27 | 0d |  |  | 1d | 0d |  |  | Code Bodies | Code Bodies | 568.71 | 5.24 | Laura Kennedy | yellow | GREEN | T2-QU-0300 | QAG |  |  |  |
| 1689 | 1.7 | **REGULATORY** |  | 680d | 2022-10-31 A | 2025-06-06 |  | 94% | 42.5d | 2022-10-31 | 2025-06-06 | 680d | 2022-10-31 | 2025-03-07 | 515d |  |  | -0 | N/A | N/A |  |  | N/A |  |  |  |  | Regulatory |  |  |
| 1690 | 1.7.1 | **Baseline MHHS Code Changes** |  | 475d | 2022-10-31 A | 2024-08-23 |  | 99% | 2.44d | 2022-10-31 | 2024-08-23 | 475d | 2022-10-31 | 2024-08-23 | 720d |  |  | -0 | N/A | N/A |  | 5.0 | N/A |  |  |  |  | Regulatory |  |  |
| 1691 | 1.7.1.1 | **Preparation and planning** |  | 35d | 2022-10-31 A | 2022-12-16 A |  | 100% |  | 2022-10-31 | 2022-12-16 | 35d | 2022-10-31 | 2022-12-16 |  |  |  |  | N/A | N/A |  | 5.0 | N/A |  |  |  |  | Regulatory |  |  |
| 1692 | 1.7.1.1.1 | Impact assessment of Programme design on codes to determine required changes |  | 20d | 2022-10-31 A | 2022-11-25 A | 48 | 100% |  | 2022-10-31 | 2022-11-25 | 20d | 2022-10-31 | 2022-11-25 |  |  |  |  | Code Bodies,SRO Code Drafters | Code Drafting PM |  | 5.0 | Andrew Margan | Complete | COMPLETE |  |  | Regulatory |  |  |
| 1693 | 1.7.1.1.2 | Become 'code draft ready' |  | 35d | 2022-10-31 A | 2022-12-16 A |  | 100% |  | 2022-10-31 | 2022-12-16 | 35d | 2022-10-31 | 2022-12-16 |  |  |  |  | Code Bodies,SRO Code Drafters | Code Drafting PM |  | 5.0 | Andrew Margan | Complete | COMPLETE |  |  | Regulatory |  |  |
| 1694 | 1.7.1.1.3 | Soft start drafting where possible |  | 35d | 2022-10-31 A | 2022-12-16 A |  | 100% |  | 2022-10-31 | 2022-12-16 | 35d | 2022-10-31 | 2022-12-16 |  |  |  |  | Code Bodies,SRO Code Drafters | Code Drafting PM |  | 5.0 | Andrew Margan | Complete | COMPLETE |  |  | Regulatory |  |  |
| 1695 | 1.7.1.2 | **Code drafting** |  | 443d | 2022-12-12 A | 2024-08-21 |  | 99% | 2.39d | 2022-12-12 | 2024-08-23 | 445d | 2022-12-12 | 2024-08-23 | 722d |  |  | -0 | N/A | N/A | M6 | 5.0 | N/A |  |  |  |  | Regulatory |  |  |
| 1696 | 1.7.1.2.1 | **Data Services (BSC driven)** |  | 118d | 2022-12-12 A | 2023-05-24 A |  | 100% |  | 2022-12-12 | 2023-05-24 | 118d | 2022-12-12 | 2023-05-24 |  |  |  |  | N/A | N/A | M6 | 5.0 | N/A |  |  |  |  | Regulatory |  |  |
| 1697 | 1.7.1.2.1.1 | Pre Code Drafting activities |  | 5d | 2022-12-12 A | 2022-12-16 A |  | 100% |  | 2022-12-12 | 2022-12-16 | 5d | 2022-12-12 | 2022-12-16 |  |  | start no earlier than 2022-12-12 |  | Code Drafting PM |  |  | 5.0 | Andrew Margan | Complete | COMPLETE |  |  | Regulatory |  |  |
| 1698 | 1.7.1.2.1.2 | Code and subsidiary document drafting takes place offline |  | 19d | 2023-01-03 A | 2023-01-27 A | 1697FS+11d | 100% |  | 2023-01-03 | 2023-01-27 | 19d | 2023-01-03 | 2023-01-27 |  |  |  |  | Code Bodies,SRO Design | Code Drafting PM |  | 5.0 | Andrew Margan | Complete | COMPLETE |  |  | Regulatory |  |  |
| 1699 | 1.7.1.2.1.3 | Internal review and cross-checking of drafting across code drafters |  | 11d | 2023-01-30 A | 2023-02-13 A | 1698 | 100% |  | 2023-01-30 | 2023-02-13 | 11d | 2023-01-30 | 2023-02-13 |  |  |  |  | Code Bodies,SRO Design | Code Drafting PM |  | 5.0 | Andrew Margan | Complete | COMPLETE |  |  | Regulatory |  |  |
| 1700 | 1.7.1.2.1.4 | External industry review via consultation |  | 20d | 2023-02-14 A | 2023-03-13 A | 1699 | 100% |  | 2023-02-14 | 2023-03-13 | 20d | 2023-02-14 | 2023-03-13 |  |  |  |  | PP | Code Drafting PM |  | 5.0 | Andrew Margan | Complete | COMPLETE |  |  | Regulatory |  |  |
| 1701 | 1.7.1.2.1.5 | Triage and action comments |  | 19d | 2023-03-10 A | 2023-04-05 A | 1700FS-2d | 100% |  | 2023-03-10 | 2023-04-05 | 19d | 2023-03-10 | 2023-04-05 |  |  |  |  | Code Bodies,SRO Design | Code Drafting PM |  | 5.0 | Andrew Margan | Complete | COMPLETE |  |  | Regulatory |  |  |
| 1702 | 1.7.1.2.1.6 | CDWG review |  | 30d | 2023-04-06 A | 2023-05-17 A | 1701 | 100% |  | 2023-04-06 | 2023-05-17 | 30d | 2023-04-06 | 2023-05-17 |  |  |  |  | PP | Code Drafting PM |  | 5.0 | Andrew Margan | Complete | COMPLETE |  |  | Regulatory |  |  |
| 1703 | 1.7.1.2.1.7 | CCAG review |  | 5d | 2023-05-18 A | 2023-05-24 A | 1702 | 100% |  | 2023-05-18 | 2023-05-24 | 5d | 2023-05-18 | 2023-05-24 |  |  |  |  | PP |  |  | 5.0 | Andrew Margan | Complete | COMPLETE |  |  | Regulatory |  |  |
| 1704 | 1.7.1.2.1.8 | Code drafting for Data Services topic area approved | milestone | 0d | 2023-05-24 A | 2023-05-24 A | 1703 | 100% |  | 2023-05-24 | 2023-05-24 | 0d | 2023-05-24 | 2023-05-24 |  |  |  |  | PP | Code Drafting PM |  | 5.0 | Andrew Margan | Complete | COMPLETE | T2-RE-0100 | CCAG | Regulatory | MHHS-ART060 | T2 |

Notes:
- 1679: 6/8/24: Date at risk from scenario planning activity
- 1688: 14/5: Baseline and name updated after cr48 approval at psg on 1/5

| ID | WBS | Task | Type | Duration | Start | Finish | Predecessors | Complete | Baseline start | Baseline finish | Baseline duration | Baseline 1 start | Baseline 1 finish | Constraint | Responsible | Involved | Task Status | Update Version | MHHS Resource Name | MHHS Programme Phase | Sched Status | RAG | Artefact ID | Milestone ID | Text29 | Tier |
| --- | --- | --- | --- | --- | --- | --- | --- | --- | --- | --- | --- | --- | --- | --- | --- | --- | --- | --- | --- | --- | --- | --- | --- | --- | --- | --- |
| 1705 | 1.7.1.2.2 | **Metering (REC driven)** |  | 118d | 2022-12-12 A | 2023-05-24 A |  | 100% | 2022-12-12 | 2023-05-24 | 118d | 2022-12-12 | 2023-05-24 |  | N/A | N/A | M6 | 5.0 | N/A | Regulatory |  |  |  |  |  |  |
| 1706 | 1.7.1.2.2.1 | Pre Code Drafting activities |  | 5d | 2022-12-12 A | 2022-12-16 A | 1697SS | 100% | 2022-12-12 | 2022-12-16 | 5d | 2022-12-12 | 2022-12-16 |  | Code Drafting PM |  |  | 5.0 | Andrew Margan | Regulatory | Complete | COMPLETE |  |  |  |  |
| 1707 | 1.7.1.2.2.2 | Code and subsidiary document drafting takes place offline |  | 19d | 2023-01-03 A | 2023-01-27 A | 1706FS+11d | 100% | 2023-01-03 | 2023-01-27 | 19d | 2023-01-03 | 2023-01-27 |  | Code Bodies,SRO Design | Code Drafting PM |  | 5.0 | Andrew Margan | Regulatory | Complete | COMPLETE |  |  |  |  |
| 1708 | 1.7.1.2.2.3 | Internal review and cross-checking of drafting across code drafters |  | 11d | 2023-01-30 A | 2023-02-13 A | 1707 | 100% | 2023-01-30 | 2023-02-13 | 11d | 2023-01-30 | 2023-02-13 |  | Code Bodies,SRO Design | Code Drafting PM |  | 5.0 | Andrew Margan | Regulatory | Complete | COMPLETE |  |  |  |  |
| 1709 | 1.7.1.2.2.4 | External industry review via consultation |  | 20d | 2023-02-14 A | 2023-03-13 A | 1708 | 100% | 2023-02-14 | 2023-03-13 | 20d | 2023-02-14 | 2023-03-13 |  | PP | Code Drafting PM |  | 5.0 | Andrew Margan | Regulatory | Complete | COMPLETE |  |  |  |  |
| 1710 | 1.7.1.2.2.5 | Triage and action comments |  | 19d | 2023-03-10 A | 2023-04-05 A | 1709FS-2d | 100% | 2023-03-10 | 2023-04-05 | 19d | 2023-03-10 | 2023-04-05 |  | Code Bodies,SRO Design | Code Drafting PM |  | 5.0 | Andrew Margan | Regulatory | Complete | COMPLETE |  |  |  |  |
| 1711 | 1.7.1.2.2.6 | CDWG review |  | 30d | 2023-04-06 A | 2023-05-17 A | 1710 | 100% | 2023-04-06 | 2023-05-17 | 30d | 2023-04-06 | 2023-05-17 |  | PP | Code Drafting PM |  | 5.0 | Andrew Margan | Regulatory | Complete | COMPLETE |  |  |  |  |
| 1712 | 1.7.1.2.2.7 | CCAG review |  | 5d | 2023-05-18 A | 2023-05-24 A | 1711 | 100% | 2023-05-18 | 2023-05-24 | 5d | 2023-05-18 | 2023-05-24 |  | PP |  |  | 5.0 | Andrew Margan | Regulatory | Complete | COMPLETE |  |  |  |  |
| 1713 | 1.7.1.2.2.8 | Code drafting for Metering topic area approved | milestone | 0d | 2023-05-24 A | 2023-05-24 A | 1712 | 100% | 2023-05-24 | 2023-05-24 | 0d | 2023-05-24 | 2023-05-24 |  | PP | Code Drafting PM |  | 5.0 | Andrew Margan | Regulatory | Complete | COMPLETE | MHHS-ART060 | T2-RE-0150 | CCAG | T2 |
| 1714 | 1.7.1.2.3 | **BSC Central Services (BSC driven)** |  | 156d | 2023-02-22 A | 2023-09-27 A |  | 100% | 2023-02-22 | 2023-09-27 | 156d | 2023-02-22 | 2023-09-14 |  | N/A | N/A | M6 | 5.0 | N/A | Regulatory |  |  |  |  |  |  |
| 1715 | 1.7.1.2.3.1 | Pre Code Drafting activities |  | 5d | 2023-02-22 A | 2023-02-28 A | 1716SS-5d | 100% | 2023-02-22 | 2023-02-28 | 5d | 2023-02-22 | 2023-02-28 |  | Code Drafting PM |  |  | 5.0 | Andrew Margan | Regulatory | Complete | COMPLETE |  |  |  |  |
| 1716 | 1.7.1.2.3.2 | Code Drafting (offline) |  | 80d | 2023-03-01 A | 2023-06-20 A | 1700SS | 100% | 2023-03-01 | 2023-06-20 | 80d | 2023-03-01 | 2023-06-20 | must start on 2023-03-01 | Code Bodies,SRO Design | Code Drafting PM |  | 5.0 | Andrew Margan | Regulatory | Complete | COMPLETE |  |  |  |  |
| 1717 | 1.7.1.2.3.3 | Internal review and cross-checking of drafting across code drafters |  | 70d | 2023-03-15 A | 2023-06-20 A | 1716SS+10d | 100% | 2023-03-15 | 2023-06-20 | 70d | 2023-03-15 | 2023-06-20 |  | Code Bodies,SRO Design | Code Drafting PM |  | 5.0 | Andrew Margan | Regulatory | Complete | COMPLETE |  |  |  |  |
| 1718 | 1.7.1.2.3.4 | External industry review via consultation |  | 15d | 2023-06-21 A | 2023-07-11 A | 1717 | 100% | 2023-06-21 | 2023-07-11 | 15d | 2023-06-21 | 2023-07-11 |  | PP | Code Drafting PM |  | 5.0 | Andrew Margan | Regulatory | Complete | COMPLETE |  |  |  |  |
| 1719 | 1.7.1.2.3.5 | Triage and action comments |  | 19d | 2023-07-10 A | 2023-08-03 A | 1718FS-2d | 100% | 2023-07-10 | 2023-08-03 | 19d | 2023-07-10 | 2023-08-03 |  | Code Bodies,SRO Design | Code Drafting PM |  | 5.0 | Andrew Margan | Regulatory | Complete | COMPLETE |  |  |  |  |
| 1720 | 1.7.1.2.3.6 | CDWG review |  | 28d | 2023-08-04 A | 2023-09-12 A | 1719 | 100% | 2023-08-04 | 2023-09-12 | 28d | 2023-08-04 | 2023-09-07 |  | PP | Code Drafting PM |  | 5.0 | Andrew Margan | Regulatory | Complete | COMPLETE |  |  |  |  |
| 1721 | 1.7.1.2.3.7 | CCAG review |  | 11d | 2023-09-13 A | 2023-09-27 A | 1720 | 100% | 2023-09-13 | 2023-09-27 | 11d | 2023-09-08 | 2023-09-14 |  | PP |  |  | 5.0 | Andrew Margan | Regulatory | Complete | COMPLETE |  |  |  |  |
| 1722 | 1.7.1.2.3.8 | Code drafting for BSC Central Services topic area approved | milestone | 0d | 2023-09-27 A | 2023-09-27 A | 1721 | 100% | 2023-09-27 | 2023-09-27 | 0d | 2023-09-14 | 2023-09-14 |  | PP | Code Drafting PM |  | 5.0 | Andrew Margan | Regulatory | Complete | COMPLETE | MHHS-ART060 | T2-RE-0200 | CCAG | T2 |
| 1723 | 1.7.1.2.4 | **Registration (BSC & REC driven)** |  | 131d | 2023-02-22 A | 2023-08-23 A |  | 100% | 2023-02-22 | 2023-08-23 | 131d | 2023-02-22 | 2023-08-23 |  | N/A | N/A | M6 | 5.0 | N/A | Regulatory |  |  |  |  |  |  |
| 1724 | 1.7.1.2.4.1 | Pre Code Drafting activities |  | 5d | 2023-02-22 A | 2023-02-28 A | 1725SS-5d | 100% | 2023-02-22 | 2023-02-28 | 5d | 2023-02-22 | 2023-02-28 |  | Code Drafting PM |  |  | 5.0 | Andrew Margan | Regulatory | Complete | COMPLETE |  |  |  |  |
| 1725 | 1.7.1.2.4.2 | Code Drafting (offline) |  | 65d | 2023-03-01 A | 2023-05-30 A | 1699, 1708 | 100% | 2023-03-01 | 2023-05-30 | 65d | 2023-03-01 | 2023-05-30 | must start on 2023-03-01 | Code Bodies,SRO Design | Code Drafting PM |  | 5.0 | Andrew Margan | Regulatory | Complete | COMPLETE |  |  |  |  |
| 1726 | 1.7.1.2.4.3 | Internal review and cross-checking of drafting across code drafters |  | 55d | 2023-03-15 A | 2023-05-30 A | 1725SS+10d | 100% | 2023-03-15 | 2023-05-30 | 55d | 2023-03-15 | 2023-05-30 |  | Code Bodies,SRO Design | Code Drafting PM |  | 5.0 | Andrew Margan | Regulatory | Complete | COMPLETE |  |  |  |  |
| 1727 | 1.7.1.2.4.4 | External industry review via consultation |  | 15d | 2023-05-31 A | 2023-06-20 A | 1726 | 100% | 2023-05-31 | 2023-06-20 | 15d | 2023-05-31 | 2023-06-20 |  | PP | Code Drafting PM |  | 5.0 | Andrew Margan | Regulatory | Complete | COMPLETE |  |  |  |  |
| 1728 | 1.7.1.2.4.5 | Triage and action comments |  | 19d | 2023-06-19 A | 2023-07-13 A | 1727FS-2d | 100% | 2023-06-19 | 2023-07-13 | 19d | 2023-06-19 | 2023-07-13 |  | Code Bodies,SRO Design | Code Drafting PM |  | 5.0 | Andrew Margan | Regulatory | Complete | COMPLETE |  |  |  |  |
| 1729 | 1.7.1.2.4.6 | CDWG review |  | 18d | 2023-07-14 A | 2023-08-08 A | 1728 | 100% | 2023-07-14 | 2023-08-08 | 18d | 2023-07-14 | 2023-08-16 |  | PP | Code Drafting PM |  | 5.0 | Andrew Margan | Regulatory | Complete | COMPLETE |  |  |  |  |
| 1730 | 1.7.1.2.4.7 | CCAG review |  | 11d | 2023-08-09 A | 2023-08-23 A | 1729 | 100% | 2023-08-09 | 2023-08-23 | 11d | 2023-08-17 | 2023-08-23 |  | PP |  |  | 5.0 | Andrew Margan | Regulatory | Complete | COMPLETE |  |  |  |  |
| 1731 | 1.7.1.2.4.8 | Code drafting for Registration topic area approved | milestone | 0d | 2023-08-23 A | 2023-08-23 A | 1730 | 100% | 2023-08-23 | 2023-08-23 | 0d | 2023-08-23 | 2023-08-23 |  | PP | Code Drafting PM |  | 5.0 | Andrew Margan | Regulatory | Complete | COMPLETE | MHHS-ART060 | T2-RE-0250 | CCAG | T2 |

| ID | WBS | Task | Type | Duration | Start | Finish | Predecessors | Complete | Baseline start | Baseline finish | Baseline duration | Baseline 1 start | Baseline 1 finish | Responsible | Involved | Task Status | Update Version | MHHS Resource Name | MHHS Programme Phase | Sched Status | RAG | Artefact ID | Milestone ID | Text29 | Tier |
| --- | --- | --- | --- | --- | --- | --- | --- | --- | --- | --- | --- | --- | --- | --- | --- | --- | --- | --- | --- | --- | --- | --- | --- | --- | --- |
| 1732 | 1.7.1.2.5 | **Governance and Qualification (BSC & REC driven)** |  | 130d | 2023-05-25 A | 2023-11-22 A |  | 100% | 2023-05-25 | 2023-11-22 | 130d | 2023-05-25 | 2023-11-13 | N/A | N/A | M6 | 5.0 | N/A | Regulatory |  |  |  |  |  |  |
| 1733 | 1.7.1.2.5.1 | Pre Code Drafting activities |  | 5d | 2023-05-25 A | 2023-05-31 A | 1734SS-5d | 100% | 2023-05-25 | 2023-05-31 | 5d | 2023-05-25 | 2023-05-31 | Code Drafting PM |  |  | 5.0 | Andrew Margan | Regulatory | Complete | COMPLETE |  |  |  |  |
| 1734 | 1.7.1.2.5.2 | Code Drafting (offline) |  | 55d | 2023-06-01 A | 2023-08-16 A | 1727SS+1d | 100% | 2023-06-01 | 2023-08-16 | 55d | 2023-06-01 | 2023-08-16 | Code Bodies,SRO Design | Code Drafting PM |  | 5.0 | Andrew Margan | Regulatory | Complete | COMPLETE |  |  |  |  |
| 1735 | 1.7.1.2.5.3 | Internal review and cross-checking of drafting across code drafters |  | 45d | 2023-06-15 A | 2023-08-16 A | 1734SS+10d | 100% | 2023-06-15 | 2023-08-16 | 45d | 2023-06-15 | 2023-08-16 | Code Bodies,SRO Design | Code Drafting PM |  | 5.0 | Andrew Margan | Regulatory | Complete | COMPLETE |  |  |  |  |
| 1736 | 1.7.1.2.5.4 | External industry review via consultation |  | 15d | 2023-08-18 A | 2023-09-07 A | 1735FS+1d | 100% | 2023-08-18 | 2023-09-07 | 15d | 2023-08-18 | 2023-09-07 | PP | Code Drafting PM |  | 5.0 | Andrew Margan | Regulatory | Complete | COMPLETE |  |  |  |  |
| 1737 | 1.7.1.2.5.5 | Triage and action comments |  | 19d | 2023-09-06 A | 2023-10-02 A | 1736FS-2d | 100% | 2023-09-06 | 2023-10-02 | 19d | 2023-09-06 | 2023-10-02 | Code Bodies,SRO Design | Code Drafting PM |  | 5.0 | Andrew Margan | Regulatory | Complete | COMPLETE |  |  |  |  |
| 1738 | 1.7.1.2.5.6 | CDWG review |  | 31d | 2023-10-03 A | 2023-11-14 A | 1737 | 100% | 2023-10-03 | 2023-11-14 | 31d | 2023-10-03 | 2023-11-06 | PP | Code Drafting PM |  | 5.0 | Andrew Margan | Regulatory | Complete | COMPLETE |  |  |  |  |
| 1739 | 1.7.1.2.5.7 | CCAG review |  | 6d | 2023-11-15 A | 2023-11-22 A | 1738 | 100% | 2023-11-15 | 2023-11-22 | 6d | 2023-11-07 | 2023-11-13 | PP |  |  | 5.0 | Andrew Margan | Regulatory | Complete | COMPLETE |  |  |  |  |
| 1740 | 1.7.1.2.5.8 | Code drafting for Governance and Qualification topic areas approved | milestone | 0d | 2023-11-22 A | 2023-11-22 A | 1739 | 100% | 2023-11-22 | 2023-11-22 | 0d | 2023-11-13 | 2023-11-13 | PP | Code Drafting PM |  | 5.12 | Andrew Margan | Regulatory | Complete | COMPLETE | MHHS-ART060 | T3-RE-0300 | CCAG | T2 |
| 1741 | 1.7.1.2.6 | **Interfaces / Data Specification (REC driven)** |  | 174d | 2023-05-25 A | 2024-01-23 A |  | 100% | 2023-05-25 | 2024-01-24 | 175d | 2023-05-25 | 2023-11-13 | N/A | N/A | M6 | 5.2 | N/A | Regulatory |  |  |  |  |  |  |
| 1742 | 1.7.1.2.6.1 | Pre Code Drafting activities |  | 5d | 2023-05-25 A | 2023-05-31 A | 1743SS-5d | 100% | 2023-05-25 | 2023-05-31 | 5d | 2023-05-25 | 2023-05-31 | Code Drafting PM |  |  | 5.0 | Andrew Margan | Regulatory | Complete | COMPLETE |  |  |  |  |
| 1743 | 1.7.1.2.6.2 | Code Drafting (offline) |  | 94d | 2023-06-01 A | 2023-10-10 A | 1727SS+1d | 100% | 2023-06-01 | 2023-10-10 | 94d | 2023-06-01 | 2023-08-16 | Code Bodies,SRO Design | Code Drafting PM |  | 5.2 | Andrew Margan | Regulatory | Complete | COMPLETE |  |  |  |  |
| 1744 | 1.7.1.2.6.3 | Internal review and cross-checking of drafting across code drafters |  | 84d | 2023-06-15 A | 2023-10-10 A | 1743SS+10d | 100% | 2023-06-15 | 2023-10-10 | 84d | 2023-06-15 | 2023-08-16 | Code Bodies,SRO Design | Code Drafting PM |  | 5.2 | Andrew Margan | Regulatory | Complete | COMPLETE |  |  |  |  |
| 1745 | 1.7.1.2.6.4 | External industry review via consultation |  | 15d | 2023-10-11 A | 2023-10-31 A | 1744 | 100% | 2023-10-11 | 2023-10-31 | 15d | 2023-08-18 | 2023-09-07 | PP | Code Drafting PM |  | 5.2 | Andrew Margan | Regulatory | Complete | COMPLETE |  |  |  |  |
| 1746 | 1.7.1.2.6.5 | Triage and action comments |  | 20d | 2023-10-30 A | 2023-11-24 A | 1745FS-2d | 100% | 2023-10-30 | 2023-11-24 | 20d | 2023-09-06 | 2023-10-02 | Code Bodies,SRO Design | Code Drafting PM |  | 5.2 | Andrew Margan | Regulatory | Complete | COMPLETE |  |  |  |  |
| 1747 | 1.7.1.2.6.6 | CDWG review |  | 37d | 2023-11-27 A | 2024-01-16 A | 1746 | 100% | 2023-11-27 | 2024-01-09 | 32d | 2023-10-03 | 2023-11-06 | PP | Code Drafting PM |  | 5.2 | Andrew Margan | Regulatory | Complete | COMPLETE |  |  |  |  |
| 1748 | 1.7.1.2.6.7 | CCAG review |  | 5d | 2024-01-17 A | 2024-01-23 A | 1747 | 100% | 2024-01-10 | 2024-01-24 | 11d | 2023-11-07 | 2023-11-13 | PP | Code Drafting PM |  | 5.2 | Andrew Margan | Regulatory | Complete | COMPLETE |  |  |  |  |
| 1749 | 1.7.1.2.6.8 | Code drafting for Interfaces / Data Specification topic areas approved | milestone | 0d | 2024-01-23 A | 2024-01-23 A | 1748 | 100% | 2024-01-24 | 2024-01-24 | 0d | 2023-11-13 | 2023-11-13 | PP | Code Drafting PM |  | 5.16 | Andrew Margan | Regulatory | Complete | COMPLETE | MHHS-ART060 | T3-RE-0350 | CCAG | T2 |
| 1750 | 1.7.1.2.7 | **Migration (BSC & REC driven)** |  | 130d | 2023-05-25 A | 2023-11-22 A |  | 100% | 2023-05-25 | 2023-11-22 | 130d | 2023-05-25 | 2023-11-13 | N/A | N/A | M6 | 5.0 | N/A | Regulatory |  |  |  |  |  |  |
| 1751 | 1.7.1.2.7.1 | Pre Code Drafting activities |  | 5d | 2023-05-25 A | 2023-05-31 A | 1752SS-5d | 100% | 2023-05-25 | 2023-05-31 | 5d | 2023-05-25 | 2023-05-31 | Code Drafting PM |  |  | 5.0 | Andrew Margan | Regulatory | Complete | COMPLETE |  |  |  |  |
| 1752 | 1.7.1.2.7.2 | Code Drafting (offline) |  | 55d | 2023-06-01 A | 2023-08-16 A | 1727SS+1d | 100% | 2023-06-01 | 2023-08-16 | 55d | 2023-06-01 | 2023-08-16 | Code Bodies,SRO Design | Code Drafting PM |  | 5.0 | Andrew Margan | Regulatory | Complete | COMPLETE |  |  |  |  |
| 1753 | 1.7.1.2.7.3 | Internal review and cross-checking of drafting across code drafters |  | 45d | 2023-06-15 A | 2023-08-16 A | 1752SS+10d | 100% | 2023-06-15 | 2023-08-16 | 45d | 2023-06-15 | 2023-08-16 | Code Bodies,SRO Design | Code Drafting PM |  | 5.0 | Andrew Margan | Regulatory | Complete | COMPLETE |  |  |  |  |
| 1754 | 1.7.1.2.7.4 | External industry review via consultation |  | 15d | 2023-08-18 A | 2023-09-07 A | 1753FS+1d | 100% | 2023-08-18 | 2023-09-07 | 15d | 2023-08-18 | 2023-09-07 | PP | Code Drafting PM |  | 5.0 | Andrew Margan | Regulatory | Complete | COMPLETE |  |  |  |  |
| 1755 | 1.7.1.2.7.5 | Triage and action comments |  | 19d | 2023-09-06 A | 2023-10-02 A | 1754FS-2d | 100% | 2023-09-06 | 2023-10-02 | 19d | 2023-09-06 | 2023-10-02 | Code Bodies,SRO Design | Code Drafting PM |  | 5.0 | Andrew Margan | Regulatory | Complete | COMPLETE |  |  |  |  |
| 1756 | 1.7.1.2.7.6 | CDWG review |  | 31d | 2023-10-03 A | 2023-11-14 A | 1755 | 100% | 2023-10-03 | 2023-11-14 | 31d | 2023-10-03 | 2023-11-06 | PP | Code Drafting PM |  | 5.0 | Andrew Margan | Regulatory | Complete | COMPLETE |  |  |  |  |
| 1757 | 1.7.1.2.7.7 | CCAG review |  | 6d | 2023-11-15 A | 2023-11-22 A | 1756 | 100% | 2023-11-15 | 2023-11-22 | 6d | 2023-11-07 | 2023-11-13 | PP | Code Drafting PM |  | 5.0 | Andrew Margan | Regulatory | Complete | COMPLETE |  |  |  |  |
| 1758 | 1.7.1.2.7.8 | Code drafting for Migration topic area approved | milestone | 0d | 2023-11-22 A | 2023-11-22 A | 1757 | 100% | 2023-11-22 | 2023-11-22 | 0d | 2023-11-13 | 2023-11-13 | PP | Code Drafting PM |  | 5.12 | Andrew Margan | Regulatory | Complete | COMPLETE | MHHS-ART060 | T3-RE-0400 | CCAG | T2 |

Notes:
- 1740: 10/10 - CH - Agreed at PSG on 4/10 to downgrade from T2 to T3
- 1749: 10/10 - CH - Agreed at PSG on 4/10 to downgrade from T2 to T3
- 1758: 31/07/23 - Changed date to 22/11/23 from 13/11/23 after approval from CCAG on 28/6/23. 10/10 - CH - Agreed at PSG on 4/10 to downgrade from T2 to T3

| ID | WBS | Task | Type | Duration | Start | Finish | Predecessors | Complete | Baseline start | Baseline finish | Baseline duration | Baseline 1 start | Baseline 1 finish | Constraint | Baseline cost | Responsible | Involved | Update Version | MHHS Resource Name | MHHS Programme Phase | Sched Status | RAG | Task Status | Artefact ID | Milestone ID | Text29 | Tier |
| --- | --- | --- | --- | --- | --- | --- | --- | --- | --- | --- | --- | --- | --- | --- | --- | --- | --- | --- | --- | --- | --- | --- | --- | --- | --- | --- | --- |
| 1759 | 1.7.1.2.8 | **Consequential Code Change** |  | 109d | 2023-10-11 A | 2024-03-11 A |  | 100% | 2023-10-11 | 2024-03-08 | 108d | 2023-08-18 | 2024-03-08 |  | -0 | N/A | N/A | 5.0 | N/A | Regulatory |  |  |  |  |  |  |  |
| 1760 | 1.7.1.2.8.1 | External industry review via consultation - drop 1 (DCUSA) |  | 15d | 2023-10-11 A | 2023-10-31 A | 1766SS | 100% | 2023-10-11 | 2023-10-31 | 15d | 2023-08-18 | 2023-09-07 |  |  | Code Bodies | PP | 5.2 | Andrew Margan | Regulatory | Complete | COMPLETE |  |  |  |  |  |
| 1761 | 1.7.1.2.8.2 | External industry review via consultation - drop 2 (Elexon) |  | 16d | 2024-02-19 A | 2024-03-11 A | 1776SS | 100% | 2024-02-19 | 2024-03-08 | 15d | 2023-10-16 | 2023-11-03 | start no earlier than 2024-02-19 |  | Code Bodies | PP | 5.2 | Andrew Margan | Regulatory | Complete | COMPLETE |  |  |  |  |  |
| 1762 | 1.7.1.2.9 | **Transition Text (all codes)** |  | 118d | 2023-08-11 A | 2024-01-23 A |  | 100% | 2023-08-11 | 2024-01-24 | 119d | 2023-08-11 | 2024-01-25 |  |  | N/A | N/A | 5.2 | N/A | Regulatory |  |  | M6 |  |  |  |  |
| 1763 | 1.7.1.2.9.1 | Pre Code Drafting activities |  | 8d | 2023-08-11 A | 2023-08-22 A | 1764SS-5d | 100% | 2023-08-11 | 2023-08-22 | 8d | 2023-08-11 | 2023-08-17 |  |  | Code Drafting PM |  | 5.0 | Andrew Margan | Regulatory | Complete | COMPLETE |  |  |  |  |  |
| 1764 | 1.7.1.2.9.2 | Code Drafting (offline) |  | 38d | 2023-08-18 A | 2023-10-10 A | 1754SS | 100% | 2023-08-18 | 2023-10-10 | 38d | 2023-08-18 | 2023-10-12 |  |  | Code Bodies,SRO Design | Code Drafting PM | 5.2 | Andrew Margan | Regulatory | Complete | COMPLETE |  |  |  |  |  |
| 1765 | 1.7.1.2.9.3 | Internal review and cross-checking of drafting across code drafters |  | 28d | 2023-09-01 A | 2023-10-10 A | 1764SS+10d | 100% | 2023-09-01 | 2023-10-10 | 28d | 2023-09-01 | 2023-10-12 |  |  | Code Bodies,SRO Design | Code Drafting PM | 5.2 | Andrew Margan | Regulatory | Complete | COMPLETE |  |  |  |  |  |
| 1766 | 1.7.1.2.9.4 | External industry review via consultation |  | 15d | 2023-10-11 A | 2023-10-31 A | 1765 | 100% | 2023-10-11 | 2023-10-31 | 15d | 2023-10-16 | 2023-11-03 |  |  | PP | Code Drafting PM | 5.2 | Andrew Margan | Regulatory | Complete | COMPLETE |  |  |  |  |  |
| 1767 | 1.7.1.2.9.5 | Triage and action comments |  | 20d | 2023-10-30 A | 2023-11-24 A | 1766FS-2d | 100% | 2023-10-30 | 2023-11-24 | 20d | 2023-11-02 | 2023-11-21 |  |  | Code Bodies,SRO Design | Code Drafting PM | 5.2 | Andrew Margan | Regulatory | Complete | COMPLETE |  |  |  |  |  |
| 1768 | 1.7.1.2.9.6 | CDWG review |  | 37d | 2023-11-27 A | 2024-01-16 A | 1767 | 100% | 2023-11-27 | 2024-01-16 | 37d | 2023-11-22 | 2024-01-17 |  |  | PP | Code Drafting PM | 5.2 | Andrew Margan | Regulatory | Complete | COMPLETE |  |  |  |  |  |
| 1769 | 1.7.1.2.9.7 | CCAG review |  | 5d | 2024-01-17 A | 2024-01-23 A | 1768 | 100% | 2024-01-17 | 2024-01-24 | 6d | 2024-01-18 | 2024-01-25 |  |  | PP | Code Drafting PM | 5.2 | Andrew Margan | Regulatory | Complete | COMPLETE |  |  |  |  |  |
| 1770 | 1.7.1.2.9.8 | Code drafting for Transition Text topic area approved | milestone | 0d | 2024-01-23 A | 2024-01-23 A | 1769 | 100% | 2024-01-24 | 2024-01-24 | 0d | 2024-01-25 | 2024-01-25 |  |  | PP | Code Drafting PM | 5.16 | Andrew Margan | Regulatory | Complete | COMPLETE |  | MHHS-ART060 | T3-RE-0450 | CCAG | T2 |
| 1771 | 1.7.1.2.10 | **Final Code Drafting (mop-up) (all codes)** |  | 199d | 2023-08-18 A | 2024-05-22 A |  | 100% | 2023-08-18 | 2024-05-22 | 199d | 2023-08-18 | 2024-05-13 |  |  | N/A | N/A | 5.0 | N/A | Regulatory |  |  | M6 |  |  |  |  |
| 1772 | 1.7.1.2.10.1 | Forward look and confirm remaining plan |  | 15d | 2023-08-18 A | 2023-09-07 A | 1764SS | 100% | 2023-08-18 | 2023-09-07 | 15d | 2023-08-18 | 2023-09-07 |  |  | Code Drafting PM |  | 5.0 | Andrew Margan | Regulatory | Complete | COMPLETE |  |  |  |  |  |
| 1773 | 1.7.1.2.10.2 | Identify remaining or additional areas of code (e.g. consequential change requirements) to be completed |  | 15d | 2023-08-18 A | 2023-09-07 A | 1772SS | 100% | 2023-08-18 | 2023-09-07 | 15d | 2023-08-18 | 2023-09-07 |  |  | Code Bodies,SRO Design | Code Drafting PM | 5.0 | Andrew Margan | Regulatory | Complete | COMPLETE |  |  |  |  |  |
| 1774 | 1.7.1.2.10.3 | Code Drafting (offline) Interim Consultation (1) |  | 60d | 2023-09-08 A | 2023-11-30 A | 1773 | 100% | 2023-09-08 | 2023-11-30 | 60d | 2023-09-08 | 2024-02-15 |  |  | Code Bodies,SRO Design | Code Drafting PM | 5.0 | Andrew Margan | Regulatory | Complete | COMPLETE |  |  |  |  |  |
| 1775 | 1.7.1.2.10.4 | Internal review and cross-checking of drafting across code drafters Interim Consultation (1) |  | 50d | 2023-09-22 A | 2023-11-30 A | 1774SS+10d | 100% | 2023-09-22 | 2023-11-30 | 50d | 2023-09-22 | 2024-02-15 |  |  | Code Bodies,SRO Design | Code Drafting PM | 5.0 | Andrew Margan | Regulatory | Complete | COMPLETE |  |  |  |  |  |
| 1776 | 1.7.1.2.10.5 | External industry review via consultation Interim Consultation (1) |  | 23d | 2023-12-01 A | 2024-01-02 A | 1775 | 100% | 2023-12-01 | 2024-01-02 | 23d | 2024-02-19 | 2024-03-08 |  |  | PP | Code Drafting PM | 5.0 | Andrew Margan | Regulatory | Complete | COMPLETE |  |  |  |  |  |
| 1777 | 1.7.1.2.10.6 | Code Drafting (offline) Final Consultation (2) |  | 55d | 2023-12-01 A | 2024-02-15 A | 1775 | 100% | 2023-12-01 | 2024-02-15 | 55d | 2023-09-08 | 2024-02-15 |  |  | Code Bodies,SRO Design | Code Drafting PM | 5.0 | Andrew Margan | Regulatory | Complete | COMPLETE |  |  |  |  |  |
| 1778 | 1.7.1.2.10.7 | Internal review and cross-checking of drafting across code drafters Final Consultation (2) |  | 45d | 2023-12-15 A | 2024-02-15 A | 1777SS+10d | 100% | 2023-12-15 | 2024-02-15 | 45d | 2023-09-22 | 2024-02-15 |  |  | Code Bodies,SRO Design | Code Drafting PM | 5.0 | Andrew Margan | Regulatory | Complete | COMPLETE |  |  |  |  |  |
| 1779 | 1.7.1.2.10.8 | External industry review via consultation Final Consultation (2) |  | 16d | 2024-02-19 A | 2024-03-11 A | 1778FS+1d | 100% | 2024-02-19 | 2024-03-08 | 15d | 2024-02-19 | 2024-03-08 |  |  | PP | Code Drafting PM | 5.0 | Andrew Margan | Regulatory | Complete | COMPLETE |  |  |  |  |  |
| 1780 | 1.7.1.2.10.9 | Triage and action comments |  | 18d | 2024-03-11 A | 2024-04-03 A | 1779FS-1d | 100% | 2024-03-07 | 2024-04-01 | 18d | 2024-03-07 | 2024-04-03 |  |  | Code Bodies,SRO Design | Code Drafting PM | 5.0 | Andrew Margan | Regulatory | Complete | COMPLETE |  |  |  |  |  |
| 1781 | 1.7.1.2.10.10 | CDWG review |  | 29d | 2024-04-04 A | 2024-05-14 A | 1780 | 100% | 2024-04-02 | 2024-05-14 | 31d | 2024-04-04 | 2024-05-03 |  |  | PP | Code Drafting PM | 5.0 | Andrew Margan | Regulatory | Complete | COMPLETE |  |  |  |  |  |
| 1782 | 1.7.1.2.10.11 | CCAG review |  | 6d | 2024-05-15 A | 2024-05-22 A | 1781 | 100% | 2024-05-15 | 2024-05-22 | 6d | 2024-05-06 | 2024-05-13 |  |  | PP | Code Drafting PM | 5.0 | Andrew Margan | Regulatory | Complete | COMPLETE |  |  |  |  |  |
| 1783 | 1.7.1.2.10.12 | Final code drafting (mop-up) approved | milestone | 0d | 2024-05-22 A | 2024-05-22 A | 1782 | 100% | 2024-05-22 | 2024-05-22 | 0d | 2024-05-13 | 2024-05-13 |  |  | PP | Code Drafting PM | 5.25 | Andrew Margan | Regulatory | Complete | COMPLETE |  | MHHS-ART060 | T3-RE-0500 | CCAG | T2 |

Notes:
- 1760: Review of drop schedule and scope is being undertaken with CCAG.
- 1761: Review of drop schedule and scope is being undertaken with CCAG.
- 1764: Guidance: 14/8/23 - RECCo transition drafting activity is expected to take the full 38 days, noting BSE co-drafting will be expected to take approx. 21 days
- 1770: 10/10 - CH - Agreed at PSG on 4/10 to downgrade from T2 to T3
- 1783: 10/10 - CH - Agreed at PSG on 4/10 to downgrade from T2 to T3

| ID | WBS | Task | Type | Duration | Start | Finish | Predecessors | Complete | Remaining | Baseline start | Baseline finish | Baseline duration | Baseline 1 start | Baseline 1 finish | Total slack | Free slack | Baseline cost | Responsible | Involved | Task Status | Update Version | MHHS Resource Name | MHHS Programme Phase | Sched Status | RAG | Artefact ID | Milestone ID | Text29 | Tier | Guidance |
| --- | --- | --- | --- | --- | --- | --- | --- | --- | --- | --- | --- | --- | --- | --- | --- | --- | --- | --- | --- | --- | --- | --- | --- | --- | --- | --- | --- | --- | --- | --- |
| 1784 | 1.7.1.2.11 | **Final code review, consistency check and approval** |  | 100d | 2024-04-04 A | 2024-08-21 |  | 90% | 10.42d | 2024-04-04 | 2024-08-23 | 102d | 2024-05-06 | 2024-08-23 | 722d |  | -0 | N/A | N/A | M6 | 5.0 | N/A | Regulatory |  |  |  |  |  |  |  |
| 1785 | 1.7.1.2.11.1 | Gap analysis of final code against design artefacts (reverse process to code drafting) |  | 38d | 2024-04-04 A | 2024-05-27 A | 1781SS | 100% |  | 2024-04-04 | 2024-05-27 | 38d | 2024-05-06 | 2024-05-17 |  |  |  | Code Bodies,SRO Design | Code Drafting PM |  | 5.0 | Andrew Margan | Regulatory | Complete | COMPLETE |  |  |  |  |  |
| 1786 | 1.7.1.2.11.2 | Outputs of gap analysis actioned offline |  | 11d | 2024-05-28 A | 2024-06-11 A | 1785 | 100% |  | 2024-05-28 | 2024-06-11 | 11d | 2024-05-20 | 2024-06-07 |  |  |  | Code Bodies,SRO Design | Code Drafting PM |  | 5.0 | Andrew Margan | Regulatory | Complete | COMPLETE |  |  |  |  |  |
| 1787 | 1.7.1.2.11.3 | Final documentation collated for final consultation |  | 8d | 2024-06-12 A | 2024-06-21 A | 1786 | 100% |  | 2024-06-12 | 2024-06-24 | 9d | 2024-06-10 | 2024-06-13 |  |  |  | Code Drafting PM | Code Bodies,SRO Design |  | 5.23 | Andrew Margan | Regulatory | Complete | COMPLETE |  |  |  |  |  |
| 1788 | 1.7.1.2.11.4 | External industry review via consultation |  | 15d | 2024-06-24 A | 2024-07-12 A | 1787 | 100% |  | 2024-06-24 | 2024-07-19 | 20d | 2024-06-14 | 2024-07-04 |  |  |  | PP | Code Drafting PM |  | 5.0 | Andrew Margan | Regulatory | Complete | COMPLETE |  |  |  |  |  |
| 1789 | 1.7.1.2.11.5 | Triage and action comments |  | 10d | 2024-07-15 A | 2024-07-26 A | 1788 | 100% |  | 2024-07-18 | 2024-08-05 | 13d | 2024-07-03 | 2024-07-19 |  |  |  | Code Bodies,SRO Design | Code Drafting PM |  | 5.0 | Andrew Margan | Regulatory | Complete | COMPLETE |  |  |  |  |  |
| 1790 | 1.7.1.2.11.6 | Final CDWG review |  | 8d | 2024-08-02 A | 2024-08-13 | 1789FS+4d | 50% | 4d | 2024-08-06 | 2024-08-13 | 6d | 2024-07-22 | 2024-08-16 | 586d | 0d |  | PP | Code Drafting PM |  | 5.0 | Andrew Margan | Regulatory | Green | GREEN |  |  |  |  |  |
| 1791 | 1.7.1.2.11.7 | Final CCAG review |  | 6d | 2024-08-14 | 2024-08-21 | 1790 |  |  | 2024-08-14 | 2024-08-23 | 8d | 2024-08-19 | 2024-08-23 | 586d | 0d |  | PP | Code Drafting PM | 6.33 | 5.0 | Andrew Margan | Regulatory | Green | GREEN |  |  |  |  |  |
| 1792 | 1.7.1.2.11.8 | CCAG recommend final code to PSG for baselining | milestone | 0d | 2024-08-21 | 2024-08-21 | 1791 |  |  | 2024-08-23 | 2024-08-23 | 0d | 2024-08-23 | 2024-08-23 | 722d |  |  | PP | Code Drafting PM | 13.71 | 5.9 | Andrew Margan | Regulatory | Green | GREEN | MHHS-ART060 | T3-RE-0550 | CCAG | T2 |  |
| 1793 | 1.7.1.3 | Code changes baselined (M6) | milestone | 0d | 2024-08-23 | 2024-08-23 | 1791FS+2d, 1783, 1770, 1758, 1749, 1740, 1731, 1722, 1713, 1704 |  |  | 2024-08-23 | 2024-08-23 | 0d | 2024-08-23 | 2024-08-23 | 586d | 0d |  | CPT | PP | 15.71 | 5.0 | Andrew Margan | Regulatory | Green | GREEN | MHHS-ART012 | T1-RE-1000 | PSG | T1 |  |
| 1794 | 1.7.2 | **Ofgem preparation and enactment of SCR powers** |  | 201d | 2024-02-05 A | 2024-11-11 |  | 77% | 45.86d | 2024-02-05 | 2024-11-12 | 201d | 2024-01-26 | 2024-11-12 | 664d |  | -0 | N/A | N/A | M7 | 5.0 | N/A | Regulatory |  |  |  |  |  |  |  |
| 1795 | 1.7.2.1 | **Preparation and enactment of SCR Powers** |  | 201d | 2024-02-05 A | 2024-11-11 |  | 77% | 45.86d | 2024-02-05 | 2024-11-11 | 201d | 2024-01-26 | 2024-11-11 | 664d |  | -0 | N/A | N/A |  | 5.0 | N/A | Regulatory |  |  |  |  |  |  |  |
| 1796 | 1.7.2.1.1 | Ofgem to keep Ofgem legal informed of process followed and nature of Code drafting to ensure that prepared for SCR go/no go decision |  | 101d | 2024-02-05 A | 2024-06-24 A | 1797SF | 100% |  | 2024-02-05 | 2024-06-25 | 101d | 2024-01-26 | 2024-06-14 |  |  |  | Ofgem | Code Bodies |  | 5.0 | Andrew Margan | Regulatory | Complete | COMPLETE |  |  |  |  |  |
| 1797 | 1.7.2.1.2 | OFGEM Legal to review Code Artefacts deliver policy intent and process followed and confirm that SCR powers are appropriate to use rather than SMAP - SCR go/no go |  | 14d | 2024-06-24 A | 2024-07-11 A | 1788SS | 100% |  | 2024-06-24 | 2024-07-12 | 15d | 2024-06-14 | 2024-07-04 |  |  |  | Ofgem | Code Bodies |  | 5.0 | Andrew Margan | Regulatory | Complete | COMPLETE |  |  |  |  |  |
| 1798 | 1.7.2.1.3 | Code Bodies to draft MOD proposal forms |  | 20d | 2024-07-12 A | 2024-08-08 A | 1797 | 100% |  | 2024-07-15 | 2024-08-09 | 20d | 2024-07-05 | 2024-08-01 |  |  |  | Code Bodies | Ofgem |  | 5.0 | Andrew Margan | Regulatory | Complete | COMPLETE |  |  |  |  |  |
| 1799 | 1.7.2.1.4 | Ofgem discuss and agree code mod timetable with code bodies (and MHHSP in relation to the dates for expected decisions) |  | 20d | 2024-07-12 A | 2024-08-08 A | 1797 | 100% |  | 2024-07-15 | 2024-08-09 | 20d | 2024-07-05 | 2024-08-01 |  |  |  | Ofgem | Code Bodies |  | 5.0 | Andrew Margan | Regulatory | Complete | COMPLETE |  |  |  |  |  |
| 1800 | 1.7.2.1.5 | Ofgem to draft open letter and direction to each code body specifying the timetable for each modification |  | 5d | 2024-08-09 A | 2024-08-15 | 1799 | 80% | 1d | 2024-08-12 | 2024-08-16 | 5d | 2024-08-02 | 2024-08-08 | 726d |  |  | Ofgem | Code Bodies |  | 5.0 | Andrew Margan | Regulatory | Green | GREEN |  |  |  |  |  |
| 1801 | 1.7.2.1.6 | Ofgem to publish open letter |  | 1d | 2024-08-26 | 2024-08-26 | 1793, 1798 |  |  | 2024-08-26 | 2024-08-26 | 1d | 2024-08-26 | 2024-08-26 | 586d | 0d |  | Ofgem | Code Bodies | 18.33 | 5.0 | Andrew Margan | Regulatory | Green | GREEN |  |  |  |  |  |
| 1802 | 1.7.2.1.7 | Ofgem to publish each Direction to each code body specifying the timetable for each modification |  | 1d | 2024-08-28 | 2024-08-28 | 1801FS+1d |  |  | 2024-08-28 | 2024-08-28 | 1d | 2024-08-28 | 2024-08-28 | 717d |  |  | Ofgem | Code Bodies | 20.33 | 5.0 | Andrew Margan | Regulatory | Green | GREEN |  |  |  |  |  |
| 1803 | 1.7.2.1.8 | Formally submit (by separate email) Modification Proposal Forms and legal texts to each code body |  | 1d | 2024-08-28 | 2024-08-28 | 1801FS+1d |  |  | 2024-08-28 | 2024-08-28 | 1d | 2024-08-28 | 2024-08-28 | 586d | 0d |  | Ofgem | Code Bodies | 20.33 | 5.0 | Andrew Margan | Regulatory | Green | GREEN |  |  |  |  |  |
| 1804 | 1.7.2.1.9 | Each Code Body publishes and issues Modification Proposal Forms |  | 3d | 2024-08-29 | 2024-09-02 | 1803 |  |  | 2024-08-29 | 2024-09-02 | 3d | 2024-08-29 | 2024-09-02 | 586d | 0d |  | Code Bodies | Ofgem | 21.33 | 5.0 | Andrew Margan | Regulatory | Green | GREEN |  |  |  |  |  |
| 1805 | 1.7.2.1.10 | Each Code Body sends Modification Proposal Forms to Panel to approve Mod to go to consultation |  | 10d | 2024-09-03 | 2024-09-16 | 1804 |  |  | 2024-09-03 | 2024-09-16 | 10d | 2024-09-03 | 2024-09-16 | 586d | 0d |  | Code Bodies | Ofgem | 26.33 | 5.0 | Andrew Margan | Regulatory | Green | GREEN |  |  |  |  |  |
| 1806 | 1.7.2.1.11 | Modification Proposal approved by Panel for Consultation |  | 1d | 2024-09-17 | 2024-09-17 | 1805 |  |  | 2024-09-17 | 2024-09-17 | 1d | 2024-09-17 | 2024-09-17 | 586d | 0d |  | Code Bodies | Ofgem | 40.33 | 5.0 | Andrew Margan | Regulatory | Green | GREEN |  |  |  |  |  |
| 1807 | 1.7.2.1.12 | Draft Modification Report issued for consultation |  | 1d | 2024-09-18 | 2024-09-18 | 1806 |  |  | 2024-09-18 | 2024-09-18 | 1d | 2024-09-18 | 2024-09-18 | 586d | 0d |  | Code Bodies | Ofgem | 41.33 | 5.0 | Andrew Margan | Regulatory | Green | GREEN |  |  |  |  |  |
| 1808 | 1.7.2.1.13 | Consultation Close-out for representations |  | 15d | 2024-09-19 | 2024-10-09 | 1807 |  |  | 2024-09-19 | 2024-10-09 | 15d | 2024-09-19 | 2024-10-09 | 586d | 0d |  | Code Bodies | Ofgem | 42.33 | 5.0 | Andrew Margan | Regulatory | Green | GREEN |  |  |  |  |  |
| 1809 | 1.7.2.1.14 | Each Code Body reviews consultation response and drafts Modification Report |  | 10d | 2024-10-10 | 2024-10-23 | 1808 |  |  | 2024-10-10 | 2024-10-23 | 10d | 2024-10-10 | 2024-10-23 | 586d | 0d |  | Code Bodies | Ofgem | 63.33 | 5.0 | Andrew Margan | Regulatory | Green | GREEN |  |  |  |  |  |
| 1810 | 1.7.2.1.15 | Final Modification Report sent to Panel for decision with recommendation to approve |  | 1d | 2024-10-24 | 2024-10-24 | 1809 |  |  | 2024-10-24 | 2024-10-24 | 1d | 2024-10-24 | 2024-10-24 | 586d | 0d |  | Code Bodies | Ofgem | 77.33 | 5.0 | Andrew Margan | Regulatory | Green | GREEN |  |  |  |  |  |
| 1811 | 1.7.2.1.16 | Modification Panel decision |  | 1d | 2024-11-07 | 2024-11-07 | 1810FS+9d |  |  | 2024-11-07 | 2024-11-07 | 1d | 2024-11-07 | 2024-11-07 | 586d | 0d |  | Code Bodies | Ofgem | 91.33 | 5.0 | Andrew Margan | Regulatory | Green | GREEN |  |  |  |  |  |
| 1812 | 1.7.2.1.17 | Panel make recommendation to OFGEM |  | 1d | 2024-11-11 | 2024-11-11 | 1811FS+1d |  |  | 2024-11-08 | 2024-11-11 | 2d | 2024-11-08 | 2024-11-11 | 586d | 0d |  | Code Bodies | Ofgem | 95.33 | 5.0 | Andrew Margan | Regulatory | Green | GREEN |  |  |  |  |  |
| 1813 | 1.7.2.2 | SCR powers enabled (M7) | milestone | 0d | 2024-11-11 | 2024-11-11 | 1793, 1812 |  |  | 2024-11-11 | 2024-11-11 | 0d | 2024-11-11 | 2024-11-11 | 586d | 0d |  | CPT | PP | 95.71 | 5.0 | Andrew Margan | Regulatory | Green | AMBER | MHHS-ART012 | T2-RE-0600 | CCAG | T2 | 5/8/25 - CR no52 and going to PSG on 7/8/24 |

Notes:
- 1792: 10/10 - CH - Agreed at PSG on 4/10 to downgrade from T2 to T3
- 1813: Action: 5/8/24: New activities to be added once cr52 has been approved

| ID | WBS | Task | Type | Duration | Start | Finish | Predecessors | Complete | Remaining | Baseline start | Baseline finish | Baseline duration | Baseline 1 start | Baseline 1 finish | Total slack | Free slack | Constraint | Baseline cost | Responsible | Involved | Task Status | Update Version | MHHS Resource Name | MHHS Programme Phase | Sched Status | RAG | Artefact ID | Milestone ID | Text29 | Tier | Text3 |
| --- | --- | --- | --- | --- | --- | --- | --- | --- | --- | --- | --- | --- | --- | --- | --- | --- | --- | --- | --- | --- | --- | --- | --- | --- | --- | --- | --- | --- | --- | --- | --- |
| 1814 | 1.7.3 | **Deliver MHHS Code Changes** |  | 149d | 2024-11-12 | 2025-06-06 |  |  |  | 2024-11-12 | 2025-06-06 | 149d | 2024-11-12 | 2025-03-07 | 515d |  |  |  | N/A | N/A | M8 | 5.0 | N/A | Regulatory |  |  |  |  |  |  |  |
| 1815 | 1.7.3.1 | **Releases** |  | 149d | 2024-11-12 | 2025-06-06 |  |  |  | 2024-11-12 | 2025-06-06 | 149d | 2024-11-12 | 2025-03-07 | 515d |  |  |  | N/A | N/A |  | 5.0 | N/A | Regulatory |  |  |  |  |  |  |  |
| 1816 | 1.7.3.1.1 | Impacted codes make resourcing provisions and prepare to implement new Code via internal code body change processes |  | 78d | 2024-11-12 | 2025-02-27 | 1813 |  |  | 2024-11-12 | 2025-02-27 | 78d | 2024-11-12 | 2025-02-27 | 586d |  |  |  | Code Bodies |  | 96.33 | 5.0 | Andrew Margan | Regulatory | Green | GREEN |  |  |  |  |  |
| 1817 | 1.7.3.1.2 | **Main Code Release** |  | 71d | 2025-02-28 | 2025-06-06 |  |  |  | 2025-02-28 | 2025-06-06 | 71d | 2025-02-28 | 2025-03-07 | 515d |  |  |  | N/A | N/A |  | 5.0 | N/A | Regulatory |  |  |  |  |  |  |  |
| 1818 | 1.7.3.1.2.1 | Release preparation (e.g. preparing release documentation) |  | 6d | 2025-02-28 | 2025-03-07 | 1819SF |  |  | 2025-02-28 | 2025-03-07 | 5d | 2025-02-28 | 2025-03-07 | 580d |  |  |  | Code Bodies |  | 204.33 | 5.0 | Andrew Margan | Regulatory | yellow | GREEN |  |  |  |  |  |
| 1819 | 1.7.3.1.2.2 | Implement new code on day of code release | milestone | 0d | 2025-03-07 | 2025-03-07 | 1820SF |  |  | 2025-03-07 | 2025-03-07 | 1d | 2025-03-07 | 2025-03-07 | 580d | 0d |  |  | Code Bodies |  | 211.71 | 5.0 | Andrew Margan | Regulatory | Green | GREEN |  |  |  |  |  |
| 1820 | 1.7.3.1.2.3 | Code changes delivered (M8) | milestone | 0d | 2025-03-07 | 2025-03-07 | 2084SS, 1813, 1793 |  |  | 2025-03-07 | 2025-03-07 | 0d | 2025-03-07 | 2025-03-07 | 515d | 0d |  |  | CPT | Code Bodies,PP | 211.71 | 5.0 | Andrew Margan | Regulatory | Green | GREEN | MHHS-ART060 | T2-RE-0650 | CCAG | T2 |  |
| 1821 | 1.7.3.1.2.4 | Code changes delivered (M8*) late exit | milestone | 0d | 2025-06-06 | 2025-06-06 | 1820FS+65d |  |  | 2025-06-06 | 2025-06-06 | 0d |  |  | 515d |  |  |  | CPT | Code Bodies,PP | 302.71 | 5.1 | Andrew Margan | Regulatory | Green | GREEN | MHHS-ART060 | T2-RE-0700 | CCAG | T2 |  |
| 1822 | 1.7.4 | **External Programme Dependency Management** |  | 38d | 2023-12-01 A | 2024-01-24 A |  | 100% |  | 2023-12-01 | 2024-01-24 | 38d | 2023-09-08 | 2024-01-24 |  |  |  |  | N/A | N/A |  | 5.0 | N/A | Regulatory |  |  |  |  |  |  |  |
| 1823 | 1.7.4.1 | **DCP397** |  | 38d | 2023-12-01 A | 2024-01-24 A |  | 100% |  | 2023-12-01 | 2024-01-24 | 38d | 2023-09-08 | 2024-01-24 |  |  |  |  | N/A | N/A |  | 5.0 | N/A | Regulatory |  |  |  |  |  |  |  |
| 1824 | 1.7.4.1.1 | Ensure DCP397 drafting included in mop-up code drafting activity (link to mop-up) |  | 20d | 2023-12-01 A | 2023-12-28 A | 1777SS, 1774SS | 100% |  | 2023-12-01 | 2023-12-28 | 20d | 2023-09-08 | 2023-10-05 |  |  |  |  | CPT | Code Bodies,SRO Design, Code Drafting PM |  | 5.0 | Andrew Margan | Regulatory | Complete | COMPLETE |  |  |  |  |  |
| 1825 | 1.7.4.1.2 | Implementation of DCP397 | milestone | 0d | 2024-01-24 A | 2024-01-24 A |  | 100% |  | 2024-01-24 | 2024-01-24 | 0d | 2024-01-24 | 2024-01-24 |  |  | start no earlier than 2024-01-24 |  | Code Bodies |  |  | 5.0 | Andrew Margan | Regulatory | Complete | COMPLETE |  |  |  |  |  |
| 1826 | 1.8 | **MIGRATION** |  | 1091d | 2022-10-31 A | 2027-01-04 |  | 36% | 692.95d | 2022-10-31 | 2027-01-05 | 1092d | 2022-10-31 | 2027-01-05 | 104d |  |  | -0 | N/A | N/A |  |  | N/A | Migration |  |  |  |  |  |  | 1 Oct 2024 - 31 Oct 2025 |
| 1827 | 1.8.1 | Migration Period Plan Review 1 Completed | milestone, inactive | 0d | 2025-01-31 | 2025-01-31 |  |  |  | 2025-01-31 | 2025-01-31 | 0d | 2025-01-31 | 2025-01-31 | 605d |  | finish no earlier than 2025-01-31 |  | SRO | PP,IPA | 176.71 | 5.28 | Simon chidwick | Migration |  | GREEN |  | T3-MI-0016 | MCAG (Migration) | T3 |  |
| 1828 | 1.8.2 | **Regulatory Governance** |  | 198d | 2024-04-01 A | 2025-01-01 |  | 47% | 105d | 2024-04-01 | 2024-11-27 | 173d |  |  | 627d |  |  | -0 | N/A | N/A |  | 5.28 | N/A |  |  |  |  |  |  |  |  |
| 1829 | 1.8.2.1 | Incentive Mods Created |  | 110d | 2024-04-01 A | 2024-08-30 |  | 85% | 17d | 2024-04-01 | 2024-07-26 | 85d |  |  | 627d | 0d | start no earlier than 2024-04-01 |  | SRO Migration | SRO Migration,Code Bodies,PP |  | 5.28 | Simon chidwick |  | Red | RED |  |  |  |  |  |
| 1830 | 1.8.2.2 | Incentives Implemented |  | 88d | 2024-09-02 | 2025-01-01 | 1829 |  |  | 2024-07-29 | 2024-11-27 | 88d |  |  | 627d |  | start no earlier than 2024-07-02 |  | Code Bodies | Code Bodies,SRO Migration | 25.33 | 5.28 | Simon chidwick |  | Red | RED |  |  |  |  |  |
| 1831 | 1.8.3 | **Migration Framework Agreed and Implemented** |  | 214d | 2024-02-01 A | 2024-11-26 |  | 61% | 82.86d | 2024-02-01 | 2024-11-26 | 214d |  |  | 653d |  |  | -0 | N/A | N/A |  | 5.28 | N/A |  |  |  |  |  |  |  |  |
| 1832 | 1.8.3.1 | **Consultation 1 - Schedule** |  | 70d | 2024-02-01 A | 2024-05-08 A |  | 100% |  | 2024-02-01 | 2024-05-08 | 70d |  |  |  |  |  |  | N/A | N/A |  | 5.28 | N/A |  |  |  |  |  |  |  |  |
| 1833 | 1.8.3.1.1 | Prepare Artefacts for Consultation |  | 33d | 2024-02-01 A | 2024-03-18 A |  | 100% |  | 2024-02-01 | 2024-03-18 | 33d |  |  |  |  |  |  |  |  |  | 5.28 | Simon chidwick |  | Complete | COMPLETE |  |  |  |  |  |
| 1834 | 1.8.3.1.2 | Industry Consultation |  | 16d | 2024-03-18 A | 2024-04-08 A |  | 100% |  | 2024-03-18 | 2024-04-08 | 16d |  |  |  |  |  |  |  |  |  | 5.28 | Simon chidwick |  | Complete | COMPLETE |  |  |  |  |  |
| 1835 | 1.8.3.1.3 | Triage and Action Comments |  | 10d | 2024-04-08 A | 2024-04-19 A |  | 100% |  | 2024-04-08 | 2024-04-19 | 10d |  |  |  |  |  |  |  |  |  | 5.28 | Simon chidwick |  | Complete | COMPLETE |  |  |  |  |  |
| 1836 | 1.8.3.1.4 | Industry Assurance Review |  | 6d | 2024-04-19 A | 2024-04-26 A |  | 100% |  | 2024-04-19 | 2024-04-26 | 6d |  |  |  |  |  |  |  |  |  | 5.28 | Simon chidwick |  | Complete | COMPLETE |  |  |  |  |  |
| 1837 | 1.8.3.1.5 | MWG Recommendation |  | 1d | 2024-04-26 A | 2024-04-26 A |  | 100% |  | 2024-04-26 | 2024-04-26 | 1d |  |  |  |  |  |  |  |  |  | 5.28 | Simon chidwick |  | Complete | COMPLETE |  |  |  |  |  |
| 1838 | 1.8.3.1.6 | MCAG Interim Approval Artefacts |  | 1d | 2024-05-08 A | 2024-05-08 A |  | 100% |  | 2024-05-08 | 2024-05-08 | 1d |  |  |  |  |  |  |  |  |  | 5.28 | Simon chidwick |  | Complete | COMPLETE |  |  |  |  |  |

Notes:
- 1827: 2/7: To go to July MCAG for removal because milestone no longer reflects the delivery of the migration approach / Action: 11/7/24: MI-0016 warren is saying he wants another think about before going to MCAG so can you hold off doing anything official with that one please?

| ID | WBS | Task | Type | Duration | Start | Finish | Predecessors | Complete | Remaining | Baseline start | Baseline finish | Baseline duration | Total slack | Free slack | Constraint | Baseline cost | Responsible | Involved | Update Version | MHHS Resource Name | Sched Status | RAG | Milestone ID | Text29 | Task Status |
| --- | --- | --- | --- | --- | --- | --- | --- | --- | --- | --- | --- | --- | --- | --- | --- | --- | --- | --- | --- | --- | --- | --- | --- | --- | --- |
| 1839 | 1.8.3.2 | **Consultation 2 - Control** |  | 79d | 2024-04-08 A | 2024-07-25 A |  | 100% |  | 2024-04-08 | 2024-07-25 | 79d |  |  |  | -0 | N/A | N/A | 5.28 | N/A |  |  |  |  |  |
| 1840 | 1.8.3.2.1 | Prepare Artefacts for Consultation |  | 49d | 2024-04-08 A | 2024-06-13 A |  | 100% |  | 2024-04-08 | 2024-06-13 | 49d |  |  |  |  |  |  | 5.28 | Simon chidwick | Complete | COMPLETE |  |  |  |
| 1841 | 1.8.3.2.2 | Industry Consultation |  | 11d | 2024-06-14 A | 2024-06-28 A | 1840 | 100% |  | 2024-06-14 | 2024-06-28 | 11d |  |  |  |  |  |  | 5.28 | Simon chidwick | Complete | COMPLETE |  |  |  |
| 1842 | 1.8.3.2.3 | Triage and Action Comments |  | 9d | 2024-07-01 A | 2024-07-11 A | 1841 | 100% |  | 2024-07-01 | 2024-07-11 | 9d |  |  |  |  | SRO Migration | SRO Migration | 5.28 | Simon chidwick | Complete | COMPLETE |  |  |  |
| 1843 | 1.8.3.2.4 | Industry Assurance Review |  | 5d | 2024-07-12 A | 2024-07-18 A | 1842 | 100% |  | 2024-07-12 | 2024-07-18 | 5d |  |  |  |  | PP | PP,SRO Migration | 5.28 | Simon chidwick | Complete | COMPLETE |  |  |  |
| 1844 | 1.8.3.2.5 | MWG Recommendation | milestone | 0d | 2024-07-18 A | 2024-07-18 A | 1843 | 100% |  | 2024-07-18 | 2024-07-18 | 0d |  |  |  |  | PP | PP,SRO Migration | 5.28 | Simon chidwick | Complete | COMPLETE |  |  |  |
| 1845 | 1.8.3.2.6 | Consultation 2 - Control - MCAG Approval of Interim Artefacts | milestone | 0d | 2024-07-25 A | 2024-07-25 A | 1844FS+5d | 100% |  | 2024-07-25 | 2024-07-25 | 0d |  |  |  |  | PP | PP,SRO Migration | 5.30 | Simon chidwick | Complete | COMPLETE | T3-MI-0037 | MCAG (Migration) |  |
| 1846 | 1.8.3.3 | **Consultation 3 - Parameters** |  | 76d | 2024-07-09 A | 2024-10-22 |  | 35% | 49.46d | 2024-07-09 | 2024-10-22 | 76d | 678d |  |  | -0 | N/A | N/A | 5.28 | N/A |  |  |  |  |  |
| 1847 | 1.8.3.3.1 | Prepare Artefacts (9) for Consultation |  | 36d | 2024-07-09 A | 2024-08-27 | 1861SS+6d | 61% | 14d | 2024-07-09 | 2024-08-27 | 36d | 678d | 0d |  |  | SRO Migration | SRO Migration | 5.28 | Simon chidwick | Green | GREEN |  |  |  |
| 1848 | 1.8.3.3.2 | Industry Consultation |  | 10d | 2024-08-28 | 2024-09-10 | 1847 |  |  | 2024-08-28 | 2024-09-10 | 10d | 678d | 0d |  |  | PP | PP,SRO Migration | 5.28 | Simon chidwick | Green | GREEN |  |  | 20.33 |
| 1849 | 1.8.3.3.3 | Triage and Action Comments |  | 10d | 2024-09-11 | 2024-09-24 | 1848 |  |  | 2024-09-11 | 2024-09-24 | 10d | 678d | 0d |  |  | SRO Migration | SRO Migration | 5.28 | Simon chidwick | Green | GREEN |  |  | 34.33 |
| 1850 | 1.8.3.3.4 | Industry Assurance Review |  | 7d | 2024-09-25 | 2024-10-03 | 1849 |  |  | 2024-09-25 | 2024-10-03 | 7d | 678d | 0d |  |  | PP | PP,SRO Migration | 5.28 | Simon chidwick | Green | GREEN |  |  | 48.33 |
| 1851 | 1.8.3.3.5 | MWG Recommendation | milestone | 0d | 2024-10-03 | 2024-10-03 | 1850 |  |  | 2024-10-03 | 2024-10-03 | 0d | 678d | 0d |  |  | PP | PP,SRO Migration | 5.28 | Simon chidwick | Green | GREEN |  |  | 56.71 |
| 1852 | 1.8.3.3.6 | MCAG Approval of Migration Framework Artefacts (Baselined) | milestone | 0d | 2024-10-22 | 2024-10-22 | 1862, 1851FS+13d |  |  | 2024-10-22 | 2024-10-22 | 0d | 678d |  |  |  | PP | PP,SRO Migration | 5.30 | Simon chidwick | Green | GREEN | T3-MI-0017 | MCAG (Migration) | 75.71 |
| 1853 | 1.8.3.4 | **Consultation 4 - Test** |  | 70d | 2024-08-21 | 2024-11-26 |  |  |  | 2024-08-21 | 2024-11-26 | 70d | 585d |  |  | -0 | N/A | N/A | 5.29 | N/A |  |  |  |  |  |
| 1854 | 1.8.3.4.1 | Prepare Artefacts for Consultation |  | 37d | 2024-08-21 | 2024-10-10 |  |  |  | 2024-08-21 | 2024-10-10 | 37d | 585d | 0d | start no earlier than 2024-08-21 |  | SRO Migration | SRO Migration | 5.29 | Simon chidwick | Green | GREEN |  |  | 13.33 |
| 1855 | 1.8.3.4.2 | Industry Consultation |  | 10d | 2024-10-11 | 2024-10-24 | 1854 |  |  | 2024-10-11 | 2024-10-24 | 10d | 585d | 0d |  |  | PP | PP,SRO Migration | 5.29 | Simon chidwick | Green | GREEN |  |  | 64.33 |
| 1856 | 1.8.3.4.3 | Triage and Action Comments |  | 10d | 2024-10-25 | 2024-11-07 | 1855 |  |  | 2024-10-25 | 2024-11-07 | 10d | 585d | 0d |  |  | SRO Migration | SRO Migration | 5.29 | Simon chidwick | Green | GREEN |  |  | 78.33 |
| 1857 | 1.8.3.4.4 | Industry Assurance Review |  | 5d | 2024-11-08 | 2024-11-14 | 1856 |  |  | 2024-11-08 | 2024-11-14 | 5d | 585d | 0d |  |  | PP | PP,SRO Migration | 5.29 | Simon chidwick | Green | GREEN |  |  | 92.33 |
| 1858 | 1.8.3.4.5 | MWG Recommendation | milestone | 0d | 2024-11-14 | 2024-11-14 | 1857 |  |  | 2024-11-14 | 2024-11-14 | 0d | 585d | 0d |  |  | PP | PP,SRO Migration | 5.29 | Simon chidwick | Green | GREEN |  |  | 98.71 |
| 1859 | 1.8.3.4.6 | Consultation 4 - Test - MCAG Approval of Interim Artefacts | milestone | 0d | 2024-11-26 | 2024-11-26 | 1858FS+8d, 1862 |  |  | 2024-11-26 | 2024-11-26 | 0d | 585d | 0d |  |  | PP | PP,SRO Migration | 5.30 | Simon chidwick | Green | GREEN | T3-MI-0038 | MCAG (Migration) | 110.71 |
| 1860 | 1.8.4 | **Migration Schedule Agreed and Maintained** |  | 207d | 2024-07-01 A | 2025-04-15 |  | 20% | 166.18d | 2024-07-01 | 2025-04-15 | 207d | 553d |  |  | -0 | N/A | N/A | 5.28 | N/A |  |  |  |  |  |
| 1861 | 1.8.4.1 | Indicative Envelopes Issued |  | 23d | 2024-07-01 A | 2024-07-31 A | 1838FS+37d | 100% |  | 2024-07-01 | 2024-07-31 | 23d |  |  |  |  | SRO Migration | SRO Migration,PP | 5.28 | Simon chidwick | Complete | COMPLETE |  |  |  |
| 1862 | 1.8.4.2 | Supplier Submissions |  | 45d | 2024-08-01 A | 2024-10-02 | 1861, 1845 | 11% | 40d | 2024-08-01 | 2024-10-02 | 45d | 573d | 0d |  |  | PP | SRO Migration,PP | 5.28 | Simon chidwick | Green | GREEN |  |  |  |
| 1863 | 1.8.4.3 | Team Assess Responses |  | 10d | 2024-10-03 | 2024-10-16 | 1862 |  |  | 2024-10-03 | 2024-10-16 | 10d | 573d | 0d |  |  | SRO Migration | SRO Migration | 5.28 | Simon chidwick | Green | GREEN |  |  | 56.33 |
| 1864 | 1.8.4.4 | Discuss and Agree Approach with Participants where necessary |  | 4d | 2024-10-17 | 2024-10-22 | 1863 |  |  | 2024-10-17 | 2024-10-22 | 4d | 573d | 0d |  |  | SRO Migration | SRO Migration,PP | 5.28 | Simon chidwick | Green | GREEN |  |  | 70.33 |
| 1865 | 1.8.4.5 | V1.0 of Migration Schedule Baseline Approved at MCAG | milestone | 0d | 2024-10-22 | 2024-10-22 | 1874, 1864 |  |  | 2024-10-22 | 2024-10-22 | 0d | 573d | 20d |  |  | PP | SRO Migration,PP | 5.30 | Simon chidwick | Green | GREEN | T3-MI-0039 | MCAG (Migration) | 75.71 |
| 1866 | 1.8.4.6 | Sprint Planning (Cycle 1) |  | 20d | 2024-11-20 | 2024-12-17 | 1884, 1865 |  |  | 2024-11-20 | 2024-12-17 | 20d | 553d | 0d |  |  | SRO Migration | SRO Migration,PP | 5.28 | Simon chidwick | Green | GREEN |  |  | 104.33 |
| 1867 | 1.8.4.7 | Sprint Planning (Cycle 2) |  | 20d | 2025-01-22 | 2025-02-18 | 1866FS+25d |  |  | 2025-01-22 | 2025-02-18 | 20d | 553d | 0d |  |  | SRO Migration | SRO Migration,PP | 5.28 | Simon chidwick | Green | GREEN |  |  | 167.33 |
| 1868 | 1.8.4.8 | Sprint Planning (Cycle 3) |  | 20d | 2025-03-19 | 2025-04-15 | 1867FS+20d, 1886 |  |  | 2025-03-20 | 2025-04-15 | 19d | 553d |  |  |  | SRO Migration | SRO Migration,PP | 5.28 | Simon chidwick | Green | GREEN |  |  | 223.33 |

Notes:
- 1845: New milestone added to reflect updated delivery approach for migration. To go to July MCAG for approval / Guidance: 25/7/24: New Milestone approved at MCAG on 25/7/24
- 1852: 2/7: Milestone to go to July MCAG for baseline date and name change approval. Name change to 'MCAG Approval of Migration Framework Artefacts (Baselined)' / Guidance: 25/7/24: Milestone name and date change approved at MCAG on 25/7/24. Date from 2/8/24 to 22/10/24. Name from 'Migration Processes & Procedures approved' to 'MCAG Approval of Migration Framework Artefacts (Baselined)’ / Notes (2): to reflect updated delivery process. Date change from 2/8/24 to 2/10/24 to reflect updated delivery timeline.
- 1859: 2/7: New milestone to reflect updated delivery approach for migration / Guidance: 25/7/24: New Milestone approved at MCAG on 25/7/24
- 1865: 2/7: New milestone to reflect updated delivery approach for migration / Guidance: 25/7/24: New Milestone approved at MCAG on 25/7/24
- 1868: Action: 8/7/24: Successor was on M10 (1861 id903) - I removed as it was moving the date out

| ID | WBS | Task | Type | Duration | Start | Finish | Predecessors | Complete | Remaining | Baseline start | Baseline finish | Baseline duration | Baseline 1 start | Baseline 1 finish | Total slack | Free slack | Baseline cost | Responsible | Involved | Update Version | MHHS Resource Name | Sched Status | RAG | Action | Task Status | MHHS Programme Phase | Artefact ID | Milestone ID | Text29 | Tier |
| --- | --- | --- | --- | --- | --- | --- | --- | --- | --- | --- | --- | --- | --- | --- | --- | --- | --- | --- | --- | --- | --- | --- | --- | --- | --- | --- | --- | --- | --- | --- |
| 1869 | 1.8.5 | **Migration Control Centre Tooling** |  | 182d | 2024-05-09 A | 2025-01-17 |  | 45% | 99.27d | 2024-05-09 | 2025-01-17 | 182d |  |  | 594d |  |  | N/A | N/A | 5.28 | N/A |  |  |  |  |  |  |  |  |  |
| 1870 | 1.8.5.1 | Data Source Definition |  | 60d | 2024-05-09 A | 2024-07-31 | 1838 | 92% | 5d | 2024-05-09 | 2024-07-31 | 60d |  |  | 575d | 0d |  | SRO Migration | SRO Migration | 5.28 | Simon chidwick | Overdue | RED |  |  |  |  |  |  |  |
| 1871 | 1.8.5.2 | Scheduling and Data Requirements |  | 60d | 2024-05-09 A | 2024-07-31 | 1838 | 92% | 5d | 2024-05-09 | 2024-07-31 | 60d |  |  | 575d | 0d |  | SRO Migration | SRO Migration | 5.28 | Simon chidwick | Overdue | RED |  |  |  |  |  |  |  |
| 1872 | 1.8.5.3 | Tool Phase 1 |  | 11d | 2024-08-01 | 2024-08-15 | 1871, 1870 |  |  | 2024-08-01 | 2024-08-15 | 11d |  |  | 575d | 0d |  | SRO Migration | SRO Migration | 5.28 | Simon chidwick | Overdue Start | GREEN | 9/7/24: To be expanded once clarified | -6.67 |  |  |  |  |  |
| 1873 | 1.8.5.4 | Data Requirements |  | 21d | 2024-08-16 | 2024-09-13 | 1838, 1872 |  |  | 2024-08-16 | 2024-09-13 | 21d |  |  | 575d | 0d |  | SRO Migration | SRO Migration | 5.28 | Simon chidwick | Green | GREEN | 9/7/24: To be expanded once clarified | 8.33 |  |  |  |  |  |
| 1874 | 1.8.5.5 | Tool Phase 2 |  | 25d | 2024-09-16 | 2024-10-18 | 1873 |  |  | 2024-09-16 | 2024-10-18 | 25d |  |  | 575d | 0d |  | SRO Migration | SRO Migration | 5.28 | Simon chidwick | Green | GREEN | 9/7/24: To be expanded once clarified | 39.33 |  |  |  |  |  |
| 1875 | 1.8.5.6 | Data Source Provision |  | 7d | 2024-10-21 | 2024-10-29 | 1874, 1880 |  |  | 2024-10-21 | 2024-10-29 | 7d |  |  | 594d | 0d |  | SRO Migration | SRO Migration | 5.28 | Simon chidwick | Green | GREEN | 9/7/24: To be expanded once clarified | 74.33 |  |  |  |  |  |
| 1876 | 1.8.5.7 | Tool - Internal and External Testing |  | 58d | 2024-10-30 | 2025-01-17 | 1875 |  |  | 2024-10-30 | 2025-01-17 | 58d |  |  | 594d | 10d |  | SRO Migration | SRO Migration,PP | 5.28 | Simon chidwick | Green | GREEN | 9/7/24: To be expanded once clarified | 83.33 |  |  |  |  |  |
| 1877 | 1.8.6 | **Data Arrangements** |  | 88d | 2024-05-09 A | 2024-09-09 |  | 63% | 33d | 2024-05-09 | 2024-09-09 | 88d |  |  | 623d |  |  | N/A | N/A | 5.28 | N/A |  |  |  |  |  |  |  |  |  |
| 1878 | 1.8.6.1 | Agree and Ratify Approach |  | 60d | 2024-05-09 A | 2024-07-31 | 1870SS | 92% | 5d | 2024-05-09 | 2024-07-31 | 60d |  |  | 623d | 0d |  | SRO Migration | SRO Migration,Elexon | 5.28 | Simon chidwick | Overdue | RED |  |  |  |  |  |  |  |
| 1879 | 1.8.6.2 | Arrange for Data to be received |  | 4d | 2024-08-01 | 2024-08-06 | 1878 |  |  | 2024-08-01 | 2024-08-06 | 4d |  |  | 623d | 0d |  | SRO Migration | SRO Migration,Elexon | 5.28 | Simon chidwick | Overdue Start | RED |  | -6.67 |  |  |  |  |  |
| 1880 | 1.8.6.3 | Test Data Being Received |  | 24d | 2024-08-07 | 2024-09-09 | 1879 |  |  | 2024-08-07 | 2024-09-09 | 24d |  |  | 623d | 29d |  | SRO Migration | SRO Migration,Elexon | 5.28 | Simon chidwick | Overdue Start | GREEN |  | -0.67 |  |  |  |  |  |
| 1881 | 1.8.7 | **Migration Control Centre Mobilised and Ready** |  | 135d | 2024-07-30 A | 2025-02-03 |  | 2% | 132.95d | 2024-07-31 | 2025-02-03 | 134d |  |  | 584d |  |  | N/A | N/A | 5.28 | N/A |  |  |  |  |  |  |  |  |  |
| 1882 | 1.8.7.1 | Migration Control Centre TOM Definition |  | 29d | 2024-07-30 A | 2024-09-06 | 1845FS+2d | 7% | 27d | 2024-07-31 | 2024-09-09 | 29d |  |  | 553d | 0d |  | SRO Migration | SRO Migration | 5.28 | Simon chidwick | Green | GREEN |  |  |  |  |  |  |  |
| 1883 | 1.8.7.2 | Access to Data |  | 25d | 2024-09-13 | 2024-10-17 | 1882FS+4d |  |  | 2024-09-16 | 2024-10-18 | 25d |  |  | 553d | 0d |  | SRO Migration | SRO Migration | 5.28 | Simon chidwick | Green | GREEN |  | 36.33 |  |  |  |  |  |
| 1884 | 1.8.7.3 | Migration Control Centre Delegation of Authority |  | 12d | 2024-11-04 | 2024-11-19 | 1883FS+11d |  |  | 2024-11-04 | 2024-11-19 | 12d |  |  | 553d | 0d |  | SRO Migration | SRO Migration | 5.28 | Simon chidwick | Green | GREEN |  | 88.33 |  |  |  |  |  |
| 1885 | 1.8.7.4 | Recruit and Train |  | 65d | 2024-11-04 | 2025-01-31 | 1884SS |  |  | 2024-11-04 | 2025-01-31 | 65d |  |  | 584d | 0d |  | SRO Migration | SRO Migration | 5.28 | Simon chidwick | Green | GREEN |  | 88.33 |  |  |  |  |  |
| 1886 | 1.8.7.5 | Dress Rehearsal |  | 1d | 2025-02-03 | 2025-02-03 | 1876, 1885, 1890, 1891 |  |  | 2025-02-03 | 2025-02-03 | 1d |  |  | 584d | 31d |  | SRO Migration | SRO Migration | 5.28 | Simon chidwick | Green | GREEN |  | 179.33 |  |  |  |  |  |
| 1887 | 1.8.8 | **PP's Prepared for Migration** |  | 154d | 2024-07-01 A | 2025-01-30 |  | 23% | 118.46d | 2024-07-01 | 2025-01-30 | 154d |  |  | 585d |  | -0 | N/A | N/A | 5.28 | N/A |  |  |  |  |  |  |  |  |  |
| 1888 | 1.8.8.1 | Prep for Envelope Webinar |  | 26d | 2024-07-01 A | 2024-08-05 A | 1861SS | 100% |  | 2024-07-01 | 2024-08-05 | 26d |  |  |  |  |  | SRO Migration | SRO Migration | 5.28 | Simon chidwick | Complete | COMPLETE |  |  |  |  |  |  |  |
| 1889 | 1.8.8.2 | Envelope/Submission Webinar |  | 1d | 2024-08-05 A | 2024-08-05 A | 1888FF | 100% |  | 2024-08-05 | 2024-08-05 | 1d |  |  |  |  |  | SRO Migration | SRO Migration,PP | 5.28 | Simon chidwick | Complete | COMPLETE |  |  |  |  |  |  |  |
| 1890 | 1.8.8.3 | Guides Creation |  | 45d | 2024-11-29 | 2025-01-30 | 1859FS+2d |  |  | 2024-11-29 | 2025-01-30 | 45d |  |  | 585d | 1d |  | SRO Migration | SRO Migration,PP | 5.28 | Simon chidwick | Green | GREEN |  | 113.33 |  |  |  |  |  |
| 1891 | 1.8.8.4 | Support Channels |  | 45d | 2024-11-29 | 2025-01-30 | 1859FS+2d |  |  | 2024-11-29 | 2025-01-30 | 45d |  |  | 585d | 1d |  | SRO Migration | SRO Migration,PP | 5.28 | Simon chidwick | Green | GREEN |  | 113.33 |  |  |  |  |  |
| 1892 | 1.8.9 | **Migration Artefact Development and Publication** |  | 635d | 2022-10-31 A | 2025-04-04 |  | 78% | 137.21d | 2022-10-31 | 2025-04-04 | 635d | 2022-10-31 | 2025-04-04 | 560d |  | -0 | N/A | N/A | 5.0 | N/A |  |  |  |  | Migration |  |  |  |  |
| 1893 | 1.8.9.1 | **Migration Approach** |  | 28d | 2022-10-31 A | 2022-12-07 A |  | 100% |  | 2022-10-31 | 2022-12-07 | 28d | 2022-10-31 | 2022-12-07 |  |  |  | N/A | N/A | 5.0 | N/A |  |  |  |  | Migration |  |  |  |  |
| 1894 | 1.8.9.1.1 | Option analysis (via MWG and PPIR) and recommendation |  | 23d | 2022-10-31 A | 2022-11-30 A |  | 100% |  | 2022-10-31 | 2022-11-30 | 23d | 2022-10-31 | 2022-11-30 |  |  |  | PP | SI Migration | 5.0 | John Wiggins,Matthew Breen | Complete | COMPLETE |  |  | Migration |  |  |  |  |
| 1895 | 1.8.9.1.2 | Migration Approach approved | milestone | 0d | 2022-12-07 A | 2022-12-07 A | 1894FS+5d | 100% |  | 2022-12-07 | 2022-12-07 | 0d | 2022-12-07 | 2022-12-07 |  |  |  | SI Migration | PP,IPA | 5.0 | John Wiggins,Matthew Breen | Complete | COMPLETE |  |  | Migration | MHHS-DEL770 | T3-MI-0010 | PSG | T3 |

| ID | WBS | Task | Type | Duration | Start | Finish | Predecessors | Complete | Baseline start | Baseline finish | Baseline duration | Baseline 1 start | Baseline 1 finish | Baseline cost | Responsible | Involved | Update Version | MHHS Resource Name | MHHS Programme Phase | Sched Status | RAG | Milestone ID | Text29 | Tier | Guidance |
| --- | --- | --- | --- | --- | --- | --- | --- | --- | --- | --- | --- | --- | --- | --- | --- | --- | --- | --- | --- | --- | --- | --- | --- | --- | --- |
| 1896 | 1.8.9.2 | **Migration Design** |  | 100d | 2022-11-14 A | 2023-03-31 A |  | 100% | 2022-11-14 | 2023-03-31 | 100d | 2022-11-14 | 2023-03-31 |  | N/A | N/A | 5.0 | N/A | Migration |  |  |  |  |  |  |
| 1897 | 1.8.9.2.1 | Review and update existing design artefacts and socialise with participants ahead of MDSG |  | 10d | 2022-11-14 A | 2022-11-25 A |  | 100% | 2022-11-14 | 2022-11-25 | 10d | 2022-11-14 | 2022-11-25 |  | SI Migration | SRO Design,CPT | 5.0 | John Wiggins,Matthew Breen | Migration | Complete | COMPLETE |  |  |  |  |
| 1898 | 1.8.9.2.2 | Develop design artefacts and supporting technical documents in line with MDSG |  | 53d | 2022-11-30 A | 2023-02-10 A | 1897FS+2d | 100% | 2022-11-30 | 2023-02-10 | 53d | 2022-11-30 | 2023-02-10 |  | SI Migration | PP,SRO Function,CPT | 5.0 | John Wiggins,Matthew Breen | Migration | Complete | COMPLETE |  |  |  |  |
| 1899 | 1.8.9.2.3 | Migration design artefacts issued for consultation | milestone | 0d | 2023-02-13 A | 2023-02-13 A | 1898FS+1d | 100% | 2023-02-13 | 2023-02-13 | 0d | 2023-02-13 | 2023-02-13 |  | SI Migration | PP,SRO Function,CPT | 5.0 | John Wiggins,Matthew Breen | Migration | Complete | COMPLETE | T3-MI-0011 | DAG | T3 |  |
| 1900 | 1.8.9.2.4 | Industry consultation |  | 5d | 2023-02-14 A | 2023-02-20 A | 1899SS | 100% | 2023-02-14 | 2023-02-20 | 5d | 2023-02-14 | 2023-02-20 |  | PP | SI Migration | 5.0 | John Wiggins,Matthew Breen | Migration | Complete | COMPLETE |  |  |  |  |
| 1901 | 1.8.9.2.5 | Review consultation feedback, address comments and update artefacts |  | 5d | 2023-02-21 A | 2023-02-27 A | 1900 | 100% | 2023-02-21 | 2023-02-27 | 5d | 2023-02-21 | 2023-02-27 |  | SI Migration | PP | 5.0 | John Wiggins,Matthew Breen | Migration | Complete | COMPLETE |  |  |  |  |
| 1902 | 1.8.9.2.6 | Internal artefact review and comms preparation |  | 3d | 2023-02-28 A | 2023-03-02 A | 1901 | 100% | 2023-02-28 | 2023-03-02 | 3d | 2023-02-28 | 2023-03-02 |  | SI Migration | SRO Function | 5.0 | John Wiggins,Matthew Breen | Migration | Complete | COMPLETE |  |  |  |  |
| 1903 | 1.8.9.2.7 | Updated Migration Design artefacts issued to PPs for assurance review | milestone | 0d | 2023-03-03 A | 2023-03-03 A | 1902FS+1d | 100% | 2023-03-03 | 2023-03-03 | 0d | 2023-03-03 | 2023-03-03 |  | SI Migration | PP | 5.0 | John Wiggins,Matthew Breen | Migration | Complete | COMPLETE | T3-MI-0013 | DAG | T3 |  |
| 1904 | 1.8.9.2.8 | Final Migration Design artefacts walkthrough with PPs | milestone | 0d | 2023-03-22 A | 2023-03-22 A | 1903FS+13d | 100% | 2023-03-22 | 2023-03-22 | 0d | 2023-03-22 | 2023-03-22 |  | SI Migration | PP | 5.0 | John Wiggins,Matthew Breen | Migration | Complete | COMPLETE |  |  |  |  |
| 1905 | 1.8.9.2.9 | Migration Design approved | milestone | 0d | 2023-03-31 A | 2023-03-31 A | 1904FS+7d | 100% | 2023-03-31 | 2023-03-31 | 0d | 2023-03-31 | 2023-03-31 |  | SI Migration | PP,SRO Function,CPT | 5.0 | John Wiggins,Matthew Breen | Migration | Complete | COMPLETE | T2-MI-0050 | DAG | T2 |  |
| 1906 | 1.8.9.3 | **Transition Design** |  | 186d | 2023-03-01 A | 2023-11-15 A |  | 100% | 2023-03-01 | 2023-11-15 | 186d | 2023-03-01 | 2023-08-03 | -0 | N/A | N/A | 5.0 | N/A | Migration |  |  |  |  |  |  |
| 1907 | 1.8.9.3.1 | **Tranche 1** |  | 56d | 2023-03-01 A | 2023-05-17 A |  | 100% | 2023-03-01 | 2023-05-17 | 56d | 2023-03-01 | 2023-05-17 |  | N/A | N/A | 5.0 | N/A | Migration |  |  |  |  |  |  |
| 1908 | 1.8.9.3.1.1 | Develop design artefacts and supporting technical details with participants |  | 50d | 2023-03-01 A | 2023-05-09 A |  | 100% | 2023-03-01 | 2023-05-09 | 50d | 2023-03-01 | 2023-05-09 |  | SI Design | PP | 5.0 | Andrew Margan | Migration | Complete | COMPLETE |  |  |  |  |
| 1909 | 1.8.9.3.1.2 | Issue Material for DAG approval |  | 1d | 2023-05-10 A | 2023-05-10 A | 1908 | 100% | 2023-05-10 | 2023-05-10 | 1d | 2023-05-10 | 2023-05-10 |  | PP | SI Design | 5.0 | Andrew Margan | Migration | Complete | COMPLETE |  |  |  |  |
| 1910 | 1.8.9.3.1.3 | Tranche 1 Transition Design approved | milestone | 0d | 2023-05-17 A | 2023-05-17 A | 1909FS+5d | 100% | 2023-05-17 | 2023-05-17 | 0d | 2023-05-17 | 2023-05-17 |  | SI Design | PP | 5.0 | Andrew Margan | Migration | Complete | COMPLETE | T2-DB-0150 | DAG | T2 |  |
| 1911 | 1.8.9.3.2 | **Tranche 2** |  | 130d | 2023-05-18 A | 2023-11-15 A |  | 100% | 2023-05-18 | 2023-11-15 | 130d | 2023-05-18 | 2023-08-03 | -0 | N/A | N/A | 5.0 | N/A | Migration |  |  |  |  |  |  |
| 1912 | 1.8.9.3.2.1 | Develop Initial design artefacts and supporting technical details |  | 76d | 2023-05-18 A | 2023-08-31 A | 1910 | 100% | 2023-05-18 | 2023-08-31 | 76d | 2023-05-18 | 2023-07-26 |  | SRO | PP, CPT, SRO Design | 5.5 | Andrew Margan | Migration | Complete | COMPLETE |  |  |  |  |
| 1913 | 1.8.9.3.2.2 | Communicate Initial Design Artefacts with Industry (MTDSG) |  | 1d | 2023-09-01 A | 2023-09-01 A | 1912 | 100% | 2023-09-01 | 2023-09-01 | 1d |  |  |  | SRO | PP, CPT, SRO Design | 5.5 | Andrew Margan | Migration | Complete | COMPLETE |  |  |  |  |
| 1914 | 1.8.9.3.2.3 | Host MTDSG |  | 1d | 2023-09-11 A | 2023-09-11 A | 1913FS+5d | 100% | 2023-09-11 | 2023-09-11 | 1d |  |  |  | SRO | PP, CPT, SRO Design | 5.5 | Andrew Margan | Migration | Complete | COMPLETE |  |  |  |  |
| 1915 | 1.8.9.3.2.4 | Process MTDSG Feedback and Amend Design Artefacts |  | 4d | 2023-09-12 A | 2023-09-15 A | 1914 | 100% | 2023-09-12 | 2023-09-15 | 4d |  |  |  | SRO | PP, CPT, SRO Design | 5.5 | Andrew Margan | Migration | Complete | COMPLETE |  |  |  |  |
| 1916 | 1.8.9.3.2.5 | Communicate Amended Design Artefacts with Industry |  | 1d | 2023-09-15 A | 2023-09-15 A | 1915FF | 100% | 2023-09-15 | 2023-09-15 | 1d |  |  |  | SRO | PP, CPT, SRO Design | 5.5 | Andrew Margan | Migration | Complete | COMPLETE |  |  |  |  |
| 1917 | 1.8.9.3.2.6 | Host MTDSG |  | 1d | 2023-09-26 A | 2023-09-26 A | 1916FS+6d | 100% | 2023-09-26 | 2023-09-26 | 1d |  |  |  | SRO | PP, CPT, SRO Design | 5.5 | Andrew Margan | Migration | Complete | COMPLETE |  |  |  |  |
| 1918 | 1.8.9.3.2.7 | Make Final Amendments to Design Artefact |  | 5d | 2023-09-27 A | 2023-10-03 A | 1917 | 100% | 2023-09-27 | 2023-10-03 | 5d |  |  |  | SRO | PP, CPT, SRO Design | 5.5 | Andrew Margan | Migration | Complete | COMPLETE |  |  |  |  |
| 1919 | 1.8.9.3.2.8 | Request DAG Consultation |  | 1d | 2023-10-04 A | 2023-10-04 A | 1918 | 100% | 2023-10-04 | 2023-10-04 | 1d |  |  |  | SRO | PP, CPT, SRO Design | 5.5 | Andrew Margan | Migration | Complete | COMPLETE |  |  |  |  |
| 1920 | 1.8.9.3.2.9 | Consultation Period |  | 11d | 2023-10-04 A | 2023-10-18 A | 1919SS | 100% | 2023-10-04 | 2023-10-18 | 11d |  |  |  | SRO | PP, CPT, SRO Design | 5.5 | Andrew Margan | Migration | Complete | COMPLETE |  |  |  |  |
| 1921 | 1.8.9.3.2.10 | Action Consultation Comments |  | 5d | 2023-10-19 A | 2023-10-25 A | 1920 | 100% | 2023-10-19 | 2023-10-25 | 5d |  |  |  | SRO | PP, CPT, SRO Design | 5.5 | Andrew Margan | Migration | Complete | COMPLETE |  |  |  |  |
| 1922 | 1.8.9.3.2.11 | Post Consultation Industry Assurance |  | 5d | 2023-10-26 A | 2023-11-01 A | 1921 | 100% | 2023-10-26 | 2023-11-01 | 5d |  |  |  | SRO | PP, CPT, SRO Design | 5.5 | Andrew Margan | Migration | Complete | COMPLETE |  |  |  |  |
| 1923 | 1.8.9.3.2.12 | Request DAG Approval |  | 1d | 2023-11-01 A | 2023-11-01 A | 1922FF | 100% | 2023-11-01 | 2023-11-01 | 1d |  |  |  | SRO | PP, CPT, SRO Design | 5.5 | Andrew Margan | Migration | Complete | COMPLETE |  |  |  |  |
| 1924 | 1.8.9.3.2.13 | DAG Transition Design Approved |  | 1d | 2023-11-08 A | 2023-11-08 A | 1923FS+4d | 100% | 2023-11-08 | 2023-11-08 | 1d |  |  |  | SRO | PP, CPT, SRO Design | 5.5 | Andrew Margan | Migration | Complete | COMPLETE |  |  |  |  |
| 1925 | 1.8.9.3.2.14 | Update Transition Design Admin |  | 5d | 2023-11-09 A | 2023-11-15 A | 1924 | 100% | 2023-11-09 | 2023-11-15 | 5d |  |  |  | SRO | PP, CPT, SRO Design | 5.5 | Andrew Margan | Migration | Complete | COMPLETE |  |  |  |  |
| 1926 | 1.8.9.3.2.15 | Tranche 2 Transition Design Baselined | milestone | 0d | 2023-11-15 A | 2023-11-15 A | 1925 | 100% | 2023-11-15 | 2023-11-15 | 0d | 2023-08-03 | 2023-08-03 |  | SRO | PP, CPT, SRO Design | 5.12 | Andrew Margan | Migration | Complete | COMPLETE | T2-DB-0250 | DAG | T2 | 14/8 - Date aligns with DAG |

Notes:
- 1926: 14/8 - Milestone aligned to 5 days after DAG approval, to update comms and admin on collaboration base. CR number to be added. 15/9 - Rebaseline approved at DAG on 13/9/23 / Action: 2/8/23 - needs to be replanned to 15//11/23. AM to raise CR as T2 milestone

| ID | WBS | Task | Type | Duration | Start | Finish | Predecessors | Complete | Remaining | Baseline start | Baseline finish | Baseline duration | Baseline 1 start | Baseline 1 finish | Total slack | Free slack | Baseline cost | Responsible | Involved | Update Version | MHHS Resource Name | MHHS Programme Phase | Sched Status | RAG | Milestone ID | Text29 | Tier | Task Status |
| --- | --- | --- | --- | --- | --- | --- | --- | --- | --- | --- | --- | --- | --- | --- | --- | --- | --- | --- | --- | --- | --- | --- | --- | --- | --- | --- | --- | --- |
| 1927 | 1.8.9.4 | **Data Assessment Report** |  | 61d | 2022-12-06 A | 2023-02-28 A |  | 100% |  | 2022-12-06 | 2023-02-28 | 61d | 2022-12-06 | 2023-02-28 |  |  |  | N/A | N/A | 5.0 | N/A | Migration |  |  |  |  |  |  |
| 1928 | 1.8.9.4.1 | Develop document with MWG |  | 49d | 2022-12-06 A | 2023-02-10 A |  | 100% |  | 2022-12-06 | 2023-02-10 | 49d | 2022-12-06 | 2023-02-10 |  |  |  | SI Migration |  | 5.0 | John Wiggins,Matthew Breen | Migration | Complete | COMPLETE |  |  |  |  |
| 1929 | 1.8.9.4.2 | Artefact review (via TMAG) and updates |  | 25d | 2023-01-18 A | 2023-02-21 A | 1928FS-18d | 100% |  | 2023-01-18 | 2023-02-21 | 25d | 2023-01-18 | 2023-02-21 |  |  |  | PP | IPA,SI Migration | 5.0 | John Wiggins,Matthew Breen | Migration | Complete | COMPLETE |  |  |  |  |
| 1930 | 1.8.9.4.3 | Data Assessment Report approved | milestone | 0d | 2023-02-28 A | 2023-02-28 A | 1929FS+5d | 100% |  | 2023-02-28 | 2023-02-28 | 0d | 2023-02-28 | 2023-02-28 |  |  |  | SI Migration | PP,IPA | 5.0 | John Wiggins,Matthew Breen | Migration | Complete | COMPLETE | T3-MI-0012 | MCAG | T3 |  |
| 1931 | 1.8.9.5 | **Migration, Cutover & Data Strategy (incl. Migration Entry Criteria)** |  | 102d | 2022-12-08 A | 2023-04-28 A |  | 100% |  | 2022-12-08 | 2023-04-28 | 102d | 2022-12-08 | 2023-04-28 |  |  |  | N/A | N/A | 5.0 | N/A | Migration |  |  |  |  |  |  |
| 1932 | 1.8.9.5.1 | Develop document with MWG |  | 67d | 2022-12-08 A | 2023-03-10 A | 1895 | 100% |  | 2022-12-08 | 2023-03-10 | 67d | 2022-12-08 | 2023-03-10 |  |  |  | SI Migration | PP | 5.0 | John Wiggins,Matthew Breen | Migration | Complete | COMPLETE |  |  |  |  |
| 1933 | 1.8.9.5.2 | Artefact review (via TMAG) and updates |  | 28d | 2023-03-15 A | 2023-04-21 A | 1932FS+2d | 100% |  | 2023-03-15 | 2023-04-21 | 28d | 2023-03-15 | 2023-04-21 |  |  |  | PP | SI Migration | 5.0 | John Wiggins,Matthew Breen | Migration | Complete | COMPLETE |  |  |  |  |
| 1934 | 1.8.9.5.3 | Migration, Cutover & Data Strategy approved | milestone | 0d | 2023-04-28 A | 2023-04-28 A | 1933FF+5d | 100% |  | 2023-04-28 | 2023-04-28 | 0d | 2023-04-28 | 2023-04-28 |  |  |  | SI Migration | PP | 5.0 | John Wiggins,Matthew Breen | Migration | Complete | COMPLETE | T3-MI-0014 | MCAG | T3 |  |
| 1935 | 1.8.9.6 | **Data Cleanse Plan** |  | 547d | 2023-03-02 A | 2025-04-04 |  | 63% | 205.01d | 2023-03-02 | 2025-04-04 | 547d | 2023-03-02 | 2025-04-04 | 560d |  | -0 | N/A | N/A | 5.0 | N/A | Migration |  |  |  |  |  |  |
| 1936 | 1.8.9.6.1 | Develop document with MWG |  | 50d | 2023-03-02 A | 2023-05-10 A |  | 100% |  | 2023-03-02 | 2023-05-10 | 50d | 2023-03-02 | 2023-05-10 |  |  |  | SI Migration | PP | 5.0 | John Wiggins,Matthew Breen | Migration | Complete | COMPLETE |  |  |  |  |
| 1937 | 1.8.9.6.2 | Artefact review (via TMAG) and updates |  | 20d | 2023-05-11 A | 2023-06-07 A | 1936 | 100% |  | 2023-05-11 | 2023-06-07 | 20d | 2023-05-11 | 2023-06-07 |  |  |  | PP | SI Migration,IPA | 5.0 | John Wiggins,Matthew Breen | Migration | Complete | COMPLETE |  |  |  |  |
| 1938 | 1.8.9.6.3 | Data Cleanse Plan approved | milestone | 0d | 2023-07-19 A | 2023-07-19 A | 1937FS+30d | 100% |  | 2023-07-19 | 2023-07-19 | 0d | 2023-06-14 | 2023-06-14 |  |  |  | SI Migration | PP | 5.0 | John Wiggins,Matthew Breen | Migration | Complete | COMPLETE | T3-MI-0020 | MCAG | T3 |  |
| 1939 | 1.8.9.6.4 | Monitor Programme Participant adherence to Data Cleanse Plan |  | 467d | 2023-06-15 A | 2025-03-28 | 1938 | 64% | 167d | 2023-06-15 | 2025-03-28 | 467d | 2023-06-15 | 2025-03-28 | 560d | 0d |  | SI Migration | PP | 5.0 | Matthew Breen | Migration | Green | GREEN |  |  |  |  |
| 1940 | 1.8.9.6.5 | **MTDs** |  | 115d | 2024-08-16 | 2025-01-24 |  |  |  | 2024-08-16 | 2024-12-23 | 91d |  |  | 610d |  | -0 | N/A | N/A | 5.4 | N/A | Migration |  |  |  |  |  |  |
| 1941 | 1.8.9.6.5.1 | **ESME ID** |  | 90d | 2024-08-16 | 2024-12-20 |  |  |  | 2024-08-16 | 2024-12-20 | 90d |  |  | 635d |  | -0 | N/A | N/A | 5.4 | N/A | Migration |  |  |  |  |  |  |
| 1942 | 1.8.9.6.5.1.1 | DCC to extract ESME ID and share with LDSO | milestone | 0d | 2024-08-16 | 2024-08-16 | 1938FS+282d |  |  | 2024-08-16 | 2024-08-16 | 0d |  |  | 635d | 0d |  | DCC/SI |  | 5.5 | Matthew Breen | Migration | Green | GREEN | T3-MI-0024 | MCAG (Transition) | T3 | 8.71 |
| 1943 | 1.8.9.6.5.1.2 | LDSO ‘full refresh’ between their Registration Service and the EES (ESME ID) |  | 16d | 2024-10-21 | 2024-11-11 | 1942FS+45d |  |  | 2024-09-27 | 2024-09-27 | 0d |  |  | 635d | 0d |  | LDSO/EES |  | 5.5 | Matthew Breen | Migration | Red | RED | T3-MI-0025 | MCAG (Transition) | T3 | 74.33 |
| 1944 | 1.8.9.6.5.1.3 | Suppliers complete investigation of exceptions and resolution of exceptions |  | 1d | 2024-12-20 | 2024-12-20 | 1943FS+28d |  |  | 2024-12-20 | 2024-12-20 | 1d |  |  | 635d | 0d |  | Supplier |  | 5.4 | Matthew Breen | Migration | Green | GREEN |  |  |  | 134.33 |
| 1945 | 1.8.9.6.5.1.4 | ESME ID Complete | milestone | 0d | 2024-12-20 | 2024-12-20 | 1944 |  |  | 2024-12-20 | 2024-12-20 | 0d |  |  | 635d | 75d |  |  |  | 5.4 | Matthew Breen | Migration | Green | GREEN |  |  |  | 134.71 |
| 1946 | 1.8.9.6.5.2 | **Meter Location and Number of Displayed Register Digits** |  | 96d | 2024-09-13 | 2025-01-24 |  |  |  | 2024-08-16 | 2024-12-23 | 91d |  |  | 610d |  |  | N/A | N/A | 5.4 | N/A | Migration |  |  |  |  |  |  |
| 1947 | 1.8.9.6.5.2.1 | MEM to extract data and share with LDSO |  | 1d | 2024-09-13 | 2024-09-13 | 1938FS+301d |  |  | 2024-08-16 | 2024-08-16 | 1d |  |  | 610d | 0d |  | MEM/SI |  | 5.4 | Matthew Breen | Migration | Red | RED |  |  |  | 36.33 |
| 1948 | 1.8.9.6.5.2.2 | LDSO ‘full refresh’ between their Registration Service and the EES (Meter Location and Number of Displayed Register Digits) |  | 16d | 2024-10-21 | 2024-11-11 | 1947FS+25d |  |  | 2024-09-27 | 2024-09-27 | 0d |  |  | 610d | 0d |  | LDSO /EES |  | 5.5 | Matthew Breen | Migration | Red | RED | T3-MI-0026 | MCAG (Transition) | T3 | 74.33 |
| 1949 | 1.8.9.6.5.2.3 | Suppliers complete investigation of exceptions and resolution of exceptions |  | 1d | 2025-01-24 | 2025-01-24 | 1948FS+53d |  |  | 2024-12-20 | 2024-12-20 | 1d |  |  | 610d | 0d |  | Supplier |  | 5.4 | Matthew Breen | Migration | Red | RED |  |  |  | 169.33 |
| 1950 | 1.8.9.6.5.2.4 | Meter Location and Number of Displayed Register Digits Complete | milestone | 0d | 2025-01-24 | 2025-01-24 | 1949 |  |  | 2024-12-23 | 2024-12-23 | 0d |  |  | 610d | 50d |  |  |  | 5.4 | Matthew Breen | Migration | Red | RED |  |  |  | 169.71 |

Notes:
- 1940: 27/7 - CH added in with Matthew Breen
- 1941: 27/7 - CH added in with Matthew Breen
- 1942: 27/7 - CH added in with Matthew Breen
- 1943: 2/8/24: Date missed because Meter Location and Number of Displayed Register Digits has been delayed due to additional data validation activities. This will delay some of the data migration activities. To go to August MCAG for date change approval
- 1944: 27/7 - CH added in with Matthew Breen
- 1945: 27/7 - CH added in with Matthew Breen / Action: 2/8/24: is date right as different to baseline? Why was it 23rd?
- 1946: 27/7 - CH added in with Matthew Breen
- 1947: 27/7 - CH added in with Matthew Breen
- 1948: Date missed due to additional data validation activities for Meter Location and Number of Displayed Register Digits. This will cause a delay to some of the other data migration activities. To go to August MCAG for date change approval
- 1949: 27/7 - CH added in with Matthew Breen
- 1950: 27/7 - CH added in with Matthew Breen

| ID | WBS | Task | Type | Duration | Start | Finish | Predecessors | Complete | Remaining | Baseline start | Baseline finish | Baseline duration | Baseline 1 start | Baseline 1 finish | Total slack | Free slack | Baseline cost | Responsible | Involved | Update Version | MHHS Resource Name | MHHS Programme Phase | Task Status | Sched Status | RAG | Milestone ID | Text29 | Tier | Guidance |
| --- | --- | --- | --- | --- | --- | --- | --- | --- | --- | --- | --- | --- | --- | --- | --- | --- | --- | --- | --- | --- | --- | --- | --- | --- | --- | --- | --- | --- | --- |
| 1951 | 1.8.9.6.6 | **Registration Data** |  | 147d | 2024-09-06 | 2025-03-31 |  |  |  | 2024-09-06 | 2025-03-31 | 147d |  |  | 564d |  |  | N/A | N/A | 5.4 | N/A | Migration |  |  |  |  |  |  |  |
| 1952 | 1.8.9.6.6.1 | **Connection Type** |  | 47d | 2024-09-06 | 2024-11-11 |  |  |  | 2024-09-06 | 2024-09-27 | 16d |  |  | 664d |  |  | N/A | N/A | 5.4 | N/A | Migration |  |  |  |  |  |  |  |
| 1953 | 1.8.9.6.6.1.1 | Automated Population of Connection Type for Measurement Classes ‘B’, ‘D’, ‘F’ & ‘G’ | milestone | 0d | 2024-10-04 | 2024-10-04 | 1938FS+317d |  |  | 2024-09-13 | 2024-09-13 | 0d |  |  | 690d | 26d |  | LDSO |  | 5.5 | Matthew Breen | Migration | 57.71 | Red | RED | T3-MI-0027 | MCAG (Transition) | T3 |  |
| 1954 | 1.8.9.6.6.1.2 | BAU Population of Connection Type for Site Specific LLFCs within Measurement Classes ‘C’ & ‘E’ | milestone | 0d | 2024-10-04 | 2024-10-04 | 1938FS+317d |  |  | 2024-09-13 | 2024-09-13 | 0d |  |  | 690d | 26d |  | LDSO |  | 5.5 | Matthew Breen | Migration | 57.71 | Red | RED | T3-MI-0028 | MCAG (Transition) | T3 |  |
| 1955 | 1.8.9.6.6.1.3 | Automated Population of Connection Type for Smart Meters within Measurement Class ‘A’ | milestone | 0d | 2024-10-04 | 2024-10-04 | 1938FS+317d |  |  | 2024-09-13 | 2024-09-13 | 0d |  |  | 690d | 26d |  | LDSO |  | 5.5 | Matthew Breen | Migration | 57.71 | Red | RED | T3-MI-0029 | MCAG (Transition) | T3 |  |
| 1956 | 1.8.9.6.6.1.4 | Population of Connection Type for Traditional and Advanced Meters within Measurement Class ‘A’ |  | 1d | 2024-09-06 | 2024-09-06 | 1938FS+296d |  |  | 2024-09-06 | 2024-09-06 | 1d |  |  | 710d | 46d |  | Suppliers |  | 5.4 | Matthew Breen | Migration | 29.33 | Green | GREEN |  |  |  |  |
| 1957 | 1.8.9.6.6.1.5 | Automated Population of Null Connection Type | milestone | 0d | 2024-10-04 | 2024-10-04 | 1938FS+317d |  |  | 2024-09-13 | 2024-09-13 | 0d |  |  | 690d | 26d |  | LDSO |  | 5.5 | Matthew Breen | Migration | 57.71 | Red | RED | T3-MI-0030 | MCAG (Transition) | T3 |  |
| 1958 | 1.8.9.6.6.1.6 | Full MPAN refresh to ESS |  | 16d | 2024-10-21 | 2024-11-11 | 1938FS+327d |  |  | 2024-09-27 | 2024-09-27 | 1d |  |  | 664d | 0d |  | LDSO/EES |  | 5.4 | Matthew Breen | Migration | 74.33 | Red | RED |  |  |  | Actually takes place on 29/9/24 which is a Sunday |
| 1959 | 1.8.9.6.6.1.7 | Connection Type Complete | milestone | 0d | 2024-11-11 | 2024-11-11 | 1953, 1954, 1955, 1956, 1957, 1958 |  |  | 2024-09-27 | 2024-09-27 | 0d |  |  | 664d | 104d |  |  |  | 5.4 | Matthew Breen | Migration | 95.71 | Red | RED |  |  |  |  |
| 1960 | 1.8.9.6.6.2 | **Domestic Premises Indicator** |  | 17d | 2025-03-07 | 2025-03-31 |  |  |  | 2025-03-07 | 2025-03-31 | 17d |  |  | 564d |  |  | N/A | N/A | 5.4 | N/A | Migration |  |  |  |  |  |  |  |
| 1961 | 1.8.9.6.6.2.1 | The DCC to extract Domestic Premises Indicator from the CSS and provide a file to each LDSO and EES. |  | 1d | 2025-03-07 | 2025-03-07 | 1938FS+426d |  |  | 2025-03-07 | 2025-03-07 | 1d |  |  | 564d | 0d |  | DCC |  | 5.4 | Matthew Breen | Migration | 211.33 | Green | GREEN |  |  |  | 27/7 - needs to end on date of M10 7/3/25 |
| 1962 | 1.8.9.6.6.2.2 | Each LDSO notifies the DCC of any exceptions |  | 1d | 2025-03-07 | 2025-03-07 | 1938FS+426d |  |  | 2025-03-07 | 2025-03-07 | 1d |  |  | 564d | 0d |  | LDSO |  | 5.4 | Matthew Breen | Migration | 211.33 | Green | GREEN |  |  |  | 27/7 - needs to end on date of M10 7/3/25 |
| 1963 | 1.8.9.6.6.2.3 | Each LDSO and DCC completes investigation and resolution of exceptions |  | 1d | 2025-03-31 | 2025-03-31 | 1961FS+15d, 1962FS+15d |  |  | 2025-03-31 | 2025-03-31 | 1d |  |  | 564d | 0d |  | LDSO / DCC |  | 5.4 | Matthew Breen | Migration | 235.33 | Green | GREEN |  |  |  | 27/7 Needs to take place approx. 1 month after M10 |
| 1964 | 1.8.9.6.6.2.4 | Domestic Premises Indicator Complete | milestone | 0d | 2025-03-31 | 2025-03-31 | 1963 |  |  | 2025-03-31 | 2025-03-31 | 0d |  |  | 564d | 4d |  |  |  | 5.4 | Matthew Breen | Migration | 235.71 | Green | GREEN |  |  |  |  |
| 1965 | 1.8.9.6.7 | **Export / Import MPANs** |  | 151d | 2024-03-22 A | 2024-10-18 |  | 67% | 50.33d | 2024-03-22 | 2024-10-18 | 151d |  |  | 680d |  |  | N/A | N/A | 5.4 | N/A | Migration |  |  |  |  |  |  |  |
| 1966 | 1.8.9.6.7.1 | **Linking of Export / Import MPANS** |  | 151d | 2024-03-22 A | 2024-10-18 |  | 67% | 50.33d | 2024-03-22 | 2024-10-18 | 151d |  |  | 680d |  |  | N/A | N/A | 5.4 | N/A | Migration |  |  |  |  |  |  |  |
| 1967 | 1.8.9.6.7.1.1 | LDSO utilises BAU processing (DB05s) to populate each import/export association |  | 1d | 2024-03-22 A | 2024-03-22 A | 1938FS+176d | 100% |  | 2024-03-22 | 2024-03-22 | 1d |  |  |  |  |  | LDSO |  | 5.4 | Matthew Breen | Migration |  | Complete | COMPLETE |  |  |  |  |
| 1968 | 1.8.9.6.7.1.2 | Each LDSO notifies the Registered Supplier of any exceptions |  | 1d | 2024-04-19 A | 2024-04-19 A | 1967FS+19d | 100% |  | 2024-04-19 | 2024-04-19 | 1d |  |  |  |  |  | LDSO |  | 5.4 | Matthew Breen | Migration |  | Complete | COMPLETE |  |  |  |  |
| 1969 | 1.8.9.6.7.1.3 | Each Supplier completes investigation and resolution of exceptions |  | 1d | 2024-08-23 | 2024-08-23 | 1968FS+89d |  |  | 2024-08-23 | 2024-08-23 | 1d |  |  | 680d | 0d |  | Supplier |  | 5.4 | Matthew Breen | Migration | 15.33 | Green | GREEN |  |  |  |  |
| 1970 | 1.8.9.6.7.1.4 | Each LDSO has linked al relevant import/export MPANS | milestone | 0d | 2024-10-18 | 2024-10-18 | 1969FS+40d |  |  | 2024-10-18 | 2024-10-18 | 0d |  |  | 680d | 0d |  | LDSO |  | 5.5 | Matthew Breen | Migration | 71.71 | Green | GREEN | T3-MI-0031 | MCAG (Transition) | T3 |  |
| 1971 | 1.8.9.6.7.1.5 | Linking of Export / Import MPANS Complete | milestone | 0d | 2024-10-18 | 2024-10-18 | 1970 |  |  | 2024-10-18 | 2024-10-18 | 0d |  |  | 680d | 120d |  |  |  | 5.4 | Matthew Breen | Migration | 71.71 | Green | GREEN |  |  |  |  |
| 1972 | 1.8.9.6.8 | Pre-migration data cleanse complete | milestone | 0d | 2025-04-04 | 2025-04-04 | 2088FS-20d, 2090FS-20d, 1939FS+5d, 1945, 1950, 1959, 1964, 1971 |  |  | 2025-04-04 | 2025-04-04 | 0d | 2025-04-04 | 2025-04-04 | 560d |  |  | SI Migration | PP | 5.0 | Matthew Breen | Migration | 239.71 | Green | GREEN | T2-MI-0450 | MCAG (Transition) | T2 |  |
| 1973 | 1.8.10 | **Migration Period Planning** |  | 367d | 2023-07-03 A | 2024-11-26 |  | 77% | 85.09d | 2023-07-03 | 2026-10-05 | 851d | 2023-07-03 | 2026-10-05 | 529d |  | -0 | N/A | N/A | 5.0 | N/A | Migration | M10 |  |  |  |  |  |  |
| 1974 | 1.8.10.1 | **Migration Implementation Plan (incl. Migration Exit Criteria)** |  | 367d | 2023-07-03 A | 2024-11-26 |  | 77% | 85.09d | 2023-07-03 | 2026-10-05 | 851d | 2023-07-03 | 2026-10-05 | 529d |  | -0 | N/A | N/A | 5.0 | N/A | Migration |  |  |  |  |  |  |  |
| 1975 | 1.8.10.1.1 | **Migration Threshold Volumes** |  | 101d | 2023-07-03 A | 2023-11-20 A |  | 100% |  | 2023-07-03 | 2023-11-15 | 98d | 2023-07-03 | 2023-08-31 |  |  | -0 | N/A | N/A | 5.0 | N/A | Migration |  |  |  |  |  |  |  |
| 1976 | 1.8.10.1.1.1 | Threshold volumes reviewed by MWG |  | 54d | 2023-07-03 A | 2023-09-14 A |  | 100% |  | 2023-07-03 | 2023-09-14 | 54d | 2023-07-03 | 2023-07-28 |  |  |  | SI Migration | PP | 5.6 | John Wiggins,Matthew Breen | Migration |  | Complete | COMPLETE |  |  |  |  |
| 1977 | 1.8.10.1.1.2 | Artefact review (via TMAG) and updates |  | 47d | 2023-09-15 A | 2023-11-20 A | 1976 | 100% |  | 2023-09-15 | 2023-11-15 | 44d | 2023-07-31 | 2023-08-31 |  |  |  | PP | SI Migration | 5.9 | John Wiggins,Matthew Breen | Migration |  | Complete | COMPLETE |  |  |  |  |
| 1978 | 1.8.10.1.1.3 | Threshold volumes approved at TMAG | milestone | 0d | 2023-11-20 A | 2023-11-20 A | 1977 | 100% |  | 2023-11-15 | 2023-11-15 | 0d | 2023-08-31 | 2023-08-31 |  |  |  | SI Migration | PP | 5.12 | John Wiggins,Matthew Breen | Migration |  | Complete | COMPLETE | T3-MI-0021 | SITAG | T3 |  |

Notes:
- 1951: 27/7 - CH added in with Matthew Breen
- 1952: 27/7 - CH added in with Matthew Breen
- 1953: 2/8/24: Date missed due to additional data validation activities for Meter Location and Number of Displayed Register Digits. This will cause a delay to some of the other data migration activities. To go to August MCAG for date change approval
- 1954: 2/8/24: Date missed due to additional data validation activities for Meter Location and Number of Displayed Register Digits. This will cause a delay to some of the other data migration activities. To go to August MCAG for date change approval
- 1955: 2/8/24: Date missed due to additional data validation activities for Meter Location and Number of Displayed Register Digits. This will cause a delay to some of the other data migration activities. To go to August MCAG for date change approval
- 1956: 27/7 - CH added in with Matthew Breen
- 1957: 2/8/24: Date missed due to additional data validation activities for Meter Location and Number of Displayed Register Digits. This will cause a delay to some of the other data migration activities. To go to August MCAG for date change approval
- 1958: 27/7 - CH added in with Matthew Breen
- 1959: 27/7 - CH added in with Matthew Breen
- 1960: 27/7 - CH added in with Matthew Breen
- 1961: 27/7 - CH added in with Matthew Breen
- 1962: 27/7 - CH added in with Matthew Breen
- 1963: 27/7 - CH added in with Matthew Breen
- 1964: 27/7 - CH added in with Matthew Breen
- 1965: 27/7 - CH added in with Matthew Breen
- 1966: 27/7 - CH added in with Matthew Breen
- 1967: 27/7 - CH added in with Matthew Breen
- 1968: 27/7 - CH added in with Matthew Breen
- 1969: 27/7 - CH added in with Matthew Breen
- 1970: 27/7 - CH added in with Matthew Breen
- 1971: 27/7 - CH added in with Matthew Breen
- 1977: 7/11 - Red because date of TMAG chnaged
- 1978: Red as plan was to approve at extraordinary TMAG on 8/11, however regular TMAG taking place on 15/11 so deferred approval to this date. To go to TMAG for date change. Approved for date change at TMAG on 23/10/23. 7/11 - Red because date of TMAG changed

| ID | WBS | Task | Type | Duration | Start | Finish | Predecessors | Complete | Remaining | Baseline start | Baseline finish | Baseline duration | Baseline 1 start | Baseline 1 finish | Total slack | Free slack | Constraint | Baseline cost | Responsible | Involved | Update Version | MHHS Resource Name | MHHS Programme Phase | Sched Status | RAG | Milestone ID | Text29 | Tier | Task Status | Action |
| --- | --- | --- | --- | --- | --- | --- | --- | --- | --- | --- | --- | --- | --- | --- | --- | --- | --- | --- | --- | --- | --- | --- | --- | --- | --- | --- | --- | --- | --- | --- |
| 1979 | 1.8.10.1.2 | **Define acceptance criteria for M15** |  | 78d | 2023-09-04 A | 2023-12-20 A |  | 100% |  | 2023-09-04 | 2023-12-20 | 78d | 2023-09-04 | 2023-11-30 |  |  |  | -0 | N/A | N/A | 5.0 | N/A | Migration |  |  |  |  |  |  |  |
| 1980 | 1.8.10.1.2.1 | Review acceptance criteria and reporting requirements with MWG |  | 49d | 2023-09-04 A | 2023-11-09 A |  | 100% |  | 2023-09-04 | 2023-10-27 | 40d | 2023-09-04 | 2023-10-27 |  |  | start no earlier than 2023-09-04 |  | SI Migration |  | 5.0 | John Wiggins,Matthew Breen | Migration | Complete | COMPLETE |  |  |  |  |  |
| 1981 | 1.8.10.1.2.2 | Artefact review (via TMAG) and updates |  | 29d | 2023-11-10 A | 2023-12-20 A | 1980 | 100% |  | 2023-11-10 | 2023-12-20 | 29d | 2023-10-30 | 2023-11-30 |  |  | start no earlier than 2023-10-30 |  | PP | SI Migration | 5.0 | John Wiggins,Matthew Breen | Migration | Complete | COMPLETE |  |  |  |  |  |
| 1982 | 1.8.10.1.2.3 | Acceptance criteria for M15 agreed at TMAG | milestone | 0d | 2023-12-20 A | 2023-12-20 A | 1981 | 100% |  | 2023-12-20 | 2023-12-20 | 0d | 2023-11-30 | 2023-11-30 |  |  | finish no earlier than 2023-11-30 |  | SI Migration |  | 5.14 | John Wiggins,Matthew Breen | Migration | Complete | COMPLETE | T3-MI-0022 | SITAG | T3 |  |  |
| 1983 | 1.8.10.1.3 | **M10/M11 cut-over plan** |  | 119d | 2023-12-21 A | 2024-06-04 A |  | 100% |  | 2023-12-21 | 2024-06-04 | 119d | 2024-01-01 | 2024-05-31 |  |  |  | -0 | N/A | N/A | 5.16 | N/A | Migration |  |  |  |  |  |  |  |
| 1984 | 1.8.10.1.3.1 | Draft Document |  | 84d | 2023-12-21 A | 2024-04-16 A | 1982 | 100% |  | 2023-12-21 | 2024-04-16 | 84d |  |  |  |  |  |  | SI Transition | SI Transition,PP,SRO | 5.16 | Matthew Breen | Migration | Complete | COMPLETE |  |  |  |  |  |
| 1985 | 1.8.10.1.3.2 | Share Document with SRO |  | 1d | 2024-04-17 A | 2024-04-17 A | 1984 | 100% |  | 2024-04-17 | 2024-04-17 | 1d |  |  |  |  |  |  | SI Transition | SI Transition,PP,SRO | 5.16 | Matthew Breen | Migration | Complete | COMPLETE |  |  |  |  |  |
| 1986 | 1.8.10.1.3.3 | Industry Consultation |  | 11d | 2024-04-23 A | 2024-05-07 A | 1985FS+3d | 100% |  | 2024-04-23 | 2024-05-07 | 11d |  |  |  |  |  |  | SI Transition | SI Transition,PP,SRO | 5.16 | Matthew Breen | Migration | Complete | COMPLETE |  |  |  |  |  |
| 1987 | 1.8.10.1.3.4 | Assurance Meeting |  | 1d | 2024-05-21 A | 2024-05-21 A | 1986FS+9d | 100% |  | 2024-05-14 | 2024-05-14 | 1d |  |  |  |  |  |  | SI Transition | SI Transition,PP,SRO | 5.16 | Matthew Breen | Migration | Complete | COMPLETE |  |  |  |  |  |
| 1988 | 1.8.10.1.3.5 | MCAG Approval of M10/M11 Cut-over Plan | milestone | 0d | 2024-06-04 A | 2024-06-04 A | 1987FS+10d | 100% |  | 2024-06-04 | 2024-06-04 | 0d | 2024-05-31 | 2024-05-31 |  |  |  |  | SI Transition | SI Transition,PP,SRO | 5.26 | Matthew Breen | Migration | Complete | COMPLETE | T3-MI-0023 | MCAG | T3 |  |  |
| 1989 | 1.8.10.1.4 | **M15/M16 cut-over plan** |  | 105d | 2024-06-05 A | 2024-10-29 |  | 52% | 50.11d | 2024-06-05 | 2024-10-29 | 105d | 2024-01-01 | 2024-05-31 | 504d |  |  | -0 | N/A | N/A | 5.16 | N/A | Migration |  |  |  |  |  |  |  |
| 1990 | 1.8.10.1.4.1 | Draft Document |  | 75d | 2024-06-05 A | 2024-09-17 | 1988 | 61% | 29d | 2024-06-05 | 2024-09-17 | 75d |  |  | 504d | 0d |  |  | SI Transition | SI Transition,PP,SRO | 5.26 | Matthew Breen | Migration | Green | GREEN |  |  |  |  |  |
| 1991 | 1.8.10.1.4.2 | Share Document with SRO |  | 1d | 2024-09-18 | 2024-09-18 | 1990 |  |  | 2024-09-18 | 2024-09-18 | 1d |  |  | 504d | 0d |  |  | SI Transition | SI Transition,PP,SRO | 5.26 | Matthew Breen | Migration | Green | GREEN |  |  |  | 41.33 |  |
| 1992 | 1.8.10.1.4.3 | Industry Consultation |  | 11d | 2024-09-24 | 2024-10-08 | 1991FS+3d |  |  | 2024-09-24 | 2024-10-08 | 11d |  |  | 504d | 0d |  |  | SI Transition | SI Transition,PP,SRO | 5.26 | Matthew Breen | Migration | Green | GREEN |  |  |  | 47.33 |  |
| 1993 | 1.8.10.1.4.4 | Assurance Meeting |  | 1d | 2024-10-22 | 2024-10-22 | 1992FS+9d |  |  | 2024-10-22 | 2024-10-22 | 1d |  |  | 504d | 0d |  |  | SI Transition | SI Transition,PP,SRO | 5.26 | Matthew Breen | Migration | Green | GREEN |  |  |  | 75.33 |  |
| 1994 | 1.8.10.1.4.5 | Approval of M15/M16 cut-over plan | milestone | 0d | 2024-10-29 | 2024-10-29 | 1993FS+5d |  |  | 2024-10-29 | 2024-10-29 | 0d | 2024-05-31 | 2024-05-31 | 504d | 503d |  |  | SI Transition | SI Transition,PP,SRO | 5.26 | Matthew Breen | Migration | Green | GREEN | T3-MI-0032 | MCAG (Transition) | T3 | 82.71 |  |
| 1995 | 1.8.10.1.5 | **M16 Methodology** |  | 85d | 2024-07-31 A | 2024-11-26 |  | 10% | 76.9d | 2024-07-31 | 2024-11-26 | 85d | 2023-10-02 | 2024-04-26 | 529d |  |  | -0 | N/A | N/A | 5.0 | N/A | Migration |  |  |  |  |  |  |  |
| 1996 | 1.8.10.1.5.1 | Draft Document |  | 50d | 2024-07-31 A | 2024-10-08 | 1990SS+40d | 12% | 44d | 2024-07-31 | 2024-10-08 | 50d | 2023-10-02 | 2023-12-29 | 529d | 0d |  |  | SI Transition | SI Transition,PP,SRO | 5.26 | Matthew Breen | Migration | Green | GREEN |  |  |  |  |  |
| 1997 | 1.8.10.1.5.2 | Share Document with SRO |  | 1d | 2024-10-09 | 2024-10-09 | 1996 |  |  | 2024-10-09 | 2024-10-09 | 1d | 2024-01-01 | 2024-01-26 | 529d | 0d |  |  | SI Transition | SI Transition,PP,SRO | 5.26 | Matthew Breen | Migration | Green | GREEN |  |  |  | 62.33 |  |
| 1998 | 1.8.10.1.5.3 | Industry Consultation |  | 11d | 2024-10-15 | 2024-10-29 | 1997FS+3d |  |  | 2024-10-15 | 2024-10-29 | 11d | 2024-01-29 | 2024-03-29 | 529d | 0d |  |  | SI Transition | SI Transition,PP,SRO | 5.26 | Matthew Breen | Migration | Green | GREEN |  |  |  | 68.33 |  |
| 1999 | 1.8.10.1.5.4 | Assurance Meeting |  | 1d | 2024-11-12 | 2024-11-12 | 1998FS+9d |  |  | 2024-11-12 | 2024-11-12 | 1d | 2024-04-01 | 2024-04-26 | 529d | 0d |  |  | SI Transition | SI Transition,PP,SRO | 5.26 | Matthew Breen | Migration | Green | GREEN |  |  |  | 96.33 |  |
| 2000 | 1.8.10.1.5.5 | M16 methodology approved | milestone | 0d | 2024-11-26 | 2024-11-26 | 1999FS+10d |  |  | 2024-11-26 | 2024-11-26 | 0d | 2024-04-26 | 2024-04-26 | 529d |  |  |  | SI Transition | SI Transition,PP,SRO | 5.26 | Matthew Breen | Migration | Green | GREEN | T3-MI-0500 | MCAG (Transition) | T2 | 110.71 |  |
| 2001 | 1.8.11 | **Go-Live Dress Rehearsals** | inactive | 114d | 2024-09-30 | 2025-03-06 |  |  |  | 2024-10-04 | 2025-03-06 | 110d | 2024-10-04 | 2025-03-06 | 581d |  |  |  | N/A | N/A | 5.24 | N/A | Migration |  |  |  |  |  |  |  |
| 2002 | 1.8.11.1 | Define dress rehearsal scenarios (incl. engagement with MWG) | inactive | 20d | 2024-09-30 | 2024-10-25 | 2088FS-135d, 2090FS-135d |  |  | 2024-10-04 | 2024-10-31 | 20d | 2024-10-04 | 2024-10-31 | 675d |  |  |  | SI Migration | SI Transition,PP | 5.24 | Matthew Breen | Migration |  | GREEN |  |  |  | 53.33 |  |
| 2003 | 1.8.11.2 | Set up, coordinate and conduct dress rehearsals | inactive | 9d | 2025-02-10 | 2025-02-20 | 1073 |  |  | 2025-02-07 | 2025-02-20 | 10d | 2025-02-07 | 2025-02-20 | 581d | 0d |  |  | SI Migration | SI Transition,PP | 5.24 | Matthew Breen | Migration |  | GREEN |  |  |  | 186.33 |  |
| 2004 | 1.8.11.3 | Evaluate dress rehearsals and identify lessons learned | inactive | 10d | 2025-02-21 | 2025-03-06 | 2003 |  |  | 2025-02-21 | 2025-03-06 | 10d | 2025-02-21 | 2025-03-06 | 581d |  |  |  | SI Migration | SI Transition,PP | 5.24 | Matthew Breen | Migration |  | GREEN |  |  |  | 197.33 | 1/7: Further detail to be added when available |

Notes:
- 1982: 17/10 - Red because initial date was not aligned to a TMAG. On track to delivery by 20/12. To go to 20/11/23 TMAG for approval to change date. 20/11 - Date rebaselined. 20/12 - Approved at TMAG on 20/12
- 1988: 27/2 - Approved at MCAG on 27/2/24. 30/4: To go to 8th Red MCAG for rebaselining because MCAG is being rescheduled. 8/5 - Approved date change at MCAG on 8/5/24
- 1994: 28/5 - Date change due to re-planning following other transition activities. 4/6: Baseline date change from 24/9/24 to 29/10/24 approved at mcag on 4/6/24
- 2000: 28/5 - Date change due to re-planning following other transition activities. 4/6: Baseline date change from 24/9/24 to 29/10/24 approved at mcag on 4/6/24
- 2001: Activity no longer needed to be superceeded by activivity in the cutover plan

| ID | WBS | Task | Type | Duration | Start | Finish | Predecessors | Complete | Remaining | Baseline start | Baseline finish | Baseline duration | Baseline 1 start | Baseline 1 finish | Total slack | Free slack | Constraint | Baseline cost | Responsible | Involved | Update Version | MHHS Resource Name | MHHS Programme Phase | Task Status | Sched Status | RAG | Action | Milestone ID | Text29 |
| --- | --- | --- | --- | --- | --- | --- | --- | --- | --- | --- | --- | --- | --- | --- | --- | --- | --- | --- | --- | --- | --- | --- | --- | --- | --- | --- | --- | --- | --- |
| 2005 | 1.8.12 | **Preparation for Cutover to Live** |  | 635d | 2022-10-31 A | 2025-04-04 |  |  | 635d | 2024-06-28 | 2025-04-04 | 201d | 2025-02-07 | 2025-04-04 | 0d |  |  | -0 | N/A | N/A | 5.27 | N/A | Migration |  |  |  |  |  |  |
| 2006 | 1.8.12.1 | **Central Systems Prepare for Cutover to Live** |  | 620d | 2022-10-31 A | 2025-03-14 |  |  | 620d | 2024-06-28 | 2025-03-14 | 186d | 2025-02-07 | 2025-03-07 | 11d |  |  | -0 | N/A | N/A | 5.27 | N/A | Migration | M13 |  |  |  |  |  |
| 2007 | 1.8.12.1.1 | DCC (Functionality available June 2024) | milestone | 0d | 2024-06-28 A | 2024-06-28 A |  | 100% |  | 2024-06-28 | 2024-06-28 | 0d |  |  |  |  | start no earlier than 2024-06-28 |  | DCC |  | 5.27 | Matthew Breen |  |  | Complete | COMPLETE |  |  |  |
| 2008 | 1.8.12.1.2 | **Development of Comms Approach and Declaration Guidance** |  | 79d | 2024-10-01 | 2025-01-17 |  |  |  | 2024-10-01 | 2025-01-17 | 79d |  |  | 35d |  |  |  | N/A | N/A | 5.28 | N/A |  | 95.33 |  |  |  |  |  |
| 2009 | 1.8.12.1.2.1 | Draft Cutover Comms Approach |  | 59d | 2024-10-01 | 2024-12-20 | 1988FS+84d |  |  | 2024-10-01 | 2024-12-20 | 59d |  |  | 35d | 0d |  |  | SI Transition | SI Transition | 5.28 | Matthew Breen |  | 54.33 | Green | GREEN |  |  |  |
| 2010 | 1.8.12.1.2.2 | Draft Cutover Comms Approach shared | milestone | 0d | 2024-12-20 | 2024-12-20 | 2009 |  |  | 2024-12-20 | 2024-12-20 | 0d |  |  | 35d | 0d |  |  | SI Transition | SI Transition | 5.28 | Matthew Breen |  | 134.71 | Green | GREEN |  |  |  |
| 2011 | 1.8.12.1.2.3 | Development of Implementation Group |  | 59d | 2024-10-01 | 2024-12-20 | 1988FS+84d |  |  | 2024-10-01 | 2024-12-20 | 59d |  |  | 35d | 0d |  |  | SI Transition | SI Transition | 5.28 | Matthew Breen |  | 54.33 | Green | GREEN |  |  |  |
| 2012 | 1.8.12.1.2.4 | Implementation Group Established | milestone | 0d | 2024-12-20 | 2024-12-20 | 2011 |  |  | 2024-12-20 | 2024-12-20 | 0d |  |  | 35d | 0d |  |  | SI Transition | SI Transition | 5.28 | Matthew Breen |  | 134.71 | Green | GREEN |  |  |  |
| 2013 | 1.8.12.1.2.5 | Finalised Cutover Comms Approach shared | milestone | 0d | 2025-01-17 | 2025-01-17 | 2010FS+20d, 2012FS+20d |  |  | 2025-01-17 | 2025-01-17 | 0d |  |  | 35d |  |  |  | SI Transition | SI Transition | 5.28 | Matthew Breen |  | 162.71 | Green | GREEN |  |  |  |
| 2014 | 1.8.12.1.3 | **Development of Cutover Plan requirements with Participants** |  | 113d | 2024-10-01 | 2025-03-06 |  |  |  | 2024-10-01 | 2024-12-20 | 59d |  |  | 1d |  |  |  | N/A | N/A | 5.28 | N/A |  | -605.67 |  |  |  |  |  |
| 2015 | 1.8.12.1.3.1 | Development of SIT Participant Cutover Plans |  | 59d | 2024-10-01 | 2024-12-20 | 1988FS+84d |  |  | 2024-10-01 | 2024-12-20 | 59d |  |  | 1d | 0d |  |  | SI Transition | SI Transition | 5.28 | Matthew Breen |  | 54.33 | Green | GREEN |  |  |  |
| 2016 | 1.8.12.1.3.2 | SIT Participant Cutover Plans Ready | milestone | 0d | 2024-12-20 | 2024-12-20 | 2015 |  |  | 2024-12-20 | 2024-12-20 | 0d |  |  | 1d | 0d |  |  | SI Transition | SI Transition | 5.28 | Matthew Breen |  | 134.71 | Green | GREEN |  |  |  |
| 2017 | 1.8.12.1.3.3 | Programme SIT Participant Cutover Plan Assurance |  | 44d | 2025-01-06 | 2025-03-06 | 2016FS+10d |  |  | 2025-01-06 | 2025-03-06 | 44d |  |  | 1d |  |  |  | SI Transition | SI Transition | 5.28 | Matthew Breen |  | 151.33 | Green | GREEN |  |  |  |
| 2018 | 1.8.12.1.4 | **M10/M11 Cutover Activities** |  | 620d | 2022-10-31 | 2025-03-14 |  |  |  | 2025-02-21 | 2025-03-14 | 15d |  |  | 11d |  |  | -0 |  |  | 5.27 |  |  | -608.67 |  |  |  |  |  |
| 2019 | 1.8.12.1.4.1 | Production DIP Portal (DIP Deployment) | milestone | 0d | 2025-02-21 | 2025-02-21 | 1073FS+10d |  |  | 2025-02-21 | 2025-02-21 | 0d |  |  | 7d |  |  |  | Elexon,DIP Manager | Elexon,DIP Manager, SI Transition | 5.27 | Matthew Breen |  | 197.71 | Green | GREEN |  |  |  |
| 2020 | 1.8.12.1.4.2 | Production Certificates (DIP Deployment) | milestone | 0d | 2025-02-21 | 2025-02-21 | 1073FS+10d |  |  | 2025-02-21 | 2025-02-21 | 0d |  |  | 7d |  |  |  | Elexon,DIP Manager | Elexon,DIP Manager, SI Transition | 5.27 | Matthew Breen |  | 197.71 | Green | GREEN |  |  |  |
| 2021 | 1.8.12.1.4.3 | Completion of the MHHS Data Cleanse | milestone | 0d | 2025-02-26 | 2025-02-26 | 1938FS+420d |  |  | 2025-02-26 | 2025-02-26 | 0d |  |  | 2d | 0d |  |  | PP,DCC,SI Transition | PP,DCC,SI Transition | 5.27 | Matthew Breen |  | 202.71 | Green | GREEN |  |  |  |
| 2022 | 1.8.12.1.4.4 | Market-wide Participant MHHS Supporting Functionality Ready - Confirmation from Code Bodies | milestone | 0d | 2025-03-03 | 2025-03-03 | 1905FS+501d |  |  | 2025-03-03 | 2025-03-03 | 0d |  |  | -3d | 0d |  |  | Code Bodies | Code Bodies,SI Transition | 5.27 | Matthew Breen |  | 207.71 | Green | GREEN |  |  |  |
| 2023 | 1.8.12.1.4.5 | Market-wide Participant MHHS Supporting Functionality Ready | milestone | 0d | 2025-03-07 | 2025-03-07 | 2022FS+4d |  |  | 2025-03-07 | 2025-03-07 | 0d |  |  | -3d | 0d |  |  | PP | PP,SI Transition | 5.27 | Matthew Breen |  | 211.71 | Green | GREEN |  |  |  |
| 2024 | 1.8.12.1.4.6 | Elexon Central Services Deployment | milestone | 0d | 2025-03-07 | 2025-03-07 | 2043 |  |  | 2025-03-07 | 2025-03-07 | 0d |  |  | -3d | 0d |  |  | DIP Manager,Elexon | DIP Manager,Elexon,SI Transition | 5.27 | Matthew Breen |  | 211.71 | Green | GREEN |  |  |  |
| 2025 | 1.8.12.1.4.7 | Service Management Go-Live | milestone | 0d | 2025-03-07 | 2025-03-07 | 2043 |  |  | 2025-03-07 | 2025-03-07 | 0d |  |  | -3d | 0d |  |  | Elexon | Elexon,SI Transition | 5.27 | Matthew Breen |  | 211.71 | Green | GREEN |  |  |  |
| 2026 | 1.8.12.1.4.8 | Data Transfer Service (DTS) New Functionality Deployment | milestone | 0d | 2025-03-07 | 2025-03-07 | 2043 |  |  | 2025-03-07 | 2025-03-07 | 0d |  |  | -3d | 0d |  |  | Code Bodies,Electralink | Code Bodies,SI Transition | 5.27 | Matthew Breen |  | 211.71 | Green | GREEN |  |  |  |
| 2027 | 1.8.12.1.4.9 | Electricity Enquiry Service (EES) Deployment | milestone | 0d | 2025-03-07 | 2025-03-07 | 2043 |  |  | 2025-03-07 | 2025-03-07 | 0d |  |  | -3d | 0d |  |  | Code Bodies | Code Bodies,SI Transition | 5.27 | Matthew Breen |  | 211.71 | Green | GREEN |  |  |  |
| 2028 | 1.8.12.1.4.10 | MPRS, UMSO Role, LDSO Role Operational | milestone | 0d | 2025-03-07 | 2025-03-07 | 2043 |  |  | 2025-03-07 | 2025-03-07 | 0d |  |  | -3d | 0d |  |  | PP | SI Transition,PP | 5.27 | Matthew Breen |  | 211.71 | Green | GREEN |  |  |  |
| 2029 | 1.8.12.1.4.11 | Population of Domestic Premises Indicator | milestone | 0d | 2025-03-07 | 2025-03-07 | 2043 |  |  | 2025-03-07 | 2025-03-07 | 0d |  |  | -3d | 0d |  |  | PP,DCC,SI Transition | PP,DCC,SI Transition | 5.27 | Matthew Breen |  | 211.71 | Green | GREEN |  |  |  |
| 2030 | 1.8.12.1.4.12 | Population of Market Segment | milestone | 0d | 2025-03-07 | 2025-03-07 | 2043 |  |  | 2025-03-07 | 2025-03-07 | 0d |  |  | -3d | 0d |  |  | PP,SI Transition | PP,SI Transition | 5.27 | Matthew Breen |  | 211.71 | Green | GREEN |  |  |  |
| 2031 | 1.8.12.1.4.13 | Early Life Support Implemented | milestone | 0d | 2025-03-07 | 2025-03-07 | 2107FS+158d |  |  | 2025-03-07 | 2025-03-07 | 0d |  |  | 0d |  |  |  | SI Transition,Elexon,Central Services | SI Transition,Elexon,Central Services | 5.27 | Matthew Breen |  | 211.71 | Green | GREEN |  |  |  |
| 2032 | 1.8.12.1.4.14 | MCC Tested and Ready to Operate | milestone | 0d | 2022-10-31 | 2022-10-31 |  |  |  | 2025-03-07 | 2025-03-07 | 0d |  |  | 615d | 0d |  |  | SI Migration | SI Migration | 5.27 | Matthew Breen |  | -646.67 | Overdue Start | GREEN | 1/7: To link into migration/service activation |  |  |
| 2033 | 1.8.12.1.4.15 | MCC Operational | milestone | 0d | 2022-10-31 | 2022-10-31 | 2032 |  |  | 2025-03-07 | 2025-03-07 | 0d |  |  | 615d |  |  |  | SI Migration | SI Migration | 5.27 | Matthew Breen |  | -646.67 | Overdue Start | GREEN | 1/7: To link into migration/service activation |  |  |
| 2034 | 1.8.4.1.4 | Central Systems live and Codes designated at 00:00 | milestone | 0d | 2025-03-10 | 2025-03-10 | 2023FS+1d, 2024FS+1d, 2025FS+1d, 2026FS+1d, 2027FS+1d, 2028FS+1d, 2029FS+1d, 2030FS+1d, 2007FS+1d |  |  | 2025-03-07 | 2025-03-07 | 0d |  |  | -3d | 0d |  |  | SI Transition | SI Transition | 5.30 | Matthew Breen |  | 214.71 | yellow | RED |  | T3-MI-0034 | MCAG (Transition) |
| 2035 | 1.8.12.1.4.17 | SIT Participant Qualification - The final date by which participant qualification status can be confirmed for participants to be ready for the start of Migration at M11. | milestone | 0d | 2025-03-14 | 2025-03-14 | 1073FS+25d |  |  | 2025-03-14 | 2025-03-14 | 0d |  |  | 11d |  |  |  | PP,Code Bodies,BSC PAB | SI Transition,PP,Code Bodies,BSC PAB | 5.27 | Matthew Breen |  | 218.71 | Green | GREEN |  |  |  |

Notes:
- 2034: 6/8/24: Forecast date updated to correctly reflect the cutover plan which was approved in June. To go to August MCAG for date change approval / Guidance: 25/7/24: New Milestone approved at MCAG on 25/7/24. It was initially approved at MCAG on 4/6 but didn't follow the usual process so addded to July MCAG for noting

| ID | WBS | Task | Type | Duration | Start | Finish | Predecessors | Baseline start | Baseline finish | Baseline duration | Total slack | Free slack | Baseline cost | Responsible | Involved | Task Status | Update Version | MHHS Resource Name | Sched Status | RAG | Milestone ID | Text29 |
| --- | --- | --- | --- | --- | --- | --- | --- | --- | --- | --- | --- | --- | --- | --- | --- | --- | --- | --- | --- | --- | --- | --- |
| 2036 | 1.8.12.2 | **Cutover Governance** |  | 27d | 2025-02-26 | 2025-04-04 |  | 2025-02-26 | 2025-04-04 | 27d | 0d |  |  | N/A | N/A | -595.67 | 5.27 | N/A |  |  |  |  |
| 2037 | 1.8.12.2.1 | Confirmation that Pre-migration Data Cleanse Activities have successfully taken place | milestone | 0d | 2025-02-26 | 2025-02-26 | 2021 | 2025-02-26 | 2025-02-26 | 0d | 2d |  |  | PP | SI Transition,PP | 202.71 | 5.27 | Matthew Breen | Green | GREEN |  |  |
| 2038 | 1.8.12.2.2 | Confirmation of Qualification Status for SIT MVC | milestone | 0d | 2025-03-03 | 2025-03-03 | 1073FS+16d | 2025-03-03 | 2025-03-03 | 0d | -3d | 0d |  | SIT MVC,Code Bodies | SI Transition,SIT MVC,Code Bodies | 207.71 | 5.27 | Matthew Breen | Green | GREEN |  |  |
| 2039 | 1.8.12.2.3 | Confirmation of Qualification Status for Non-SIT LDSOs | milestone | 0d | 2025-03-03 | 2025-03-03 | 1331FS+6d | 2025-03-03 | 2025-03-03 | 0d | -3d | 0d |  | PP,Code Bodies | SI Transition,PP,Code Bodies | 207.71 | 5.27 | Matthew Breen | Green | GREEN |  |  |
| 2040 | 1.8.12.2.4 | Confirmation of Qualification Status of at least one Supplier and their contracted Agents | milestone | 0d | 2025-03-03 | 2025-03-03 | 2038 | 2025-03-03 | 2025-03-03 | 0d | -3d | 0d |  | S&A Qualification | SI Transition,S&A Qualification | 207.71 | 5.27 | Matthew Breen | Green | GREEN |  |  |
| 2041 | 1.8.12.2.5 | Declaration from all Central Services and LDSOs that they are in a position to move forwards | milestone | 0d | 2025-03-03 | 2025-03-03 | 1073, 1331FS+6d | 2025-03-03 | 2025-03-03 | 0d | -1d | 0d |  | DIP Manager,Elexon,PP,Code Bodies | SI Transition,DIP Manager,Elexon,PP,Code Bodies | 207.71 | 5.27 | Matthew Breen | Green | GREEN |  |  |
| 2042 | 1.8.12.2.6 | TORWG (Recommendation from TORWG that the Programme should enter M10) | milestone | 0d | 2025-03-05 | 2025-03-05 | 2037, 2038FS+2d, 2039FS+2d, 2040FS+2d, 2041 | 2025-03-05 | 2025-03-05 | 0d | -3d | 0d |  | SI Transition | SI Transition | 209.71 | 5.27 | Matthew Breen | Green | GREEN |  |  |
| 2043 | 1.8.4.1.4 | MCAG (Confirm that the Programme can Enter M10) | milestone | 0d | 2025-03-07 | 2025-03-07 | 2019, 2020, 2042FS+2d | 2025-03-07 | 2025-03-07 | 0d | -3d | 0d |  | SI Migration | SI Transition,SI Migration | 211.71 | 5.30 | Matthew Breen | Green | GREEN | T3-MI-0035 | MCAG (Transition) |
| 2044 | 1.8.12.2.8 | Self-Declaration from all Central Services and LDSOs that Cutover activities have been successfully carried out | milestone | 0d | 2025-03-10 | 2025-03-10 | 2043FS+1d | 2025-03-10 | 2025-03-10 | 0d | 0d |  |  | PP,DCC,Code Bodies | SI Transition,PP,DCC,Code Bodies | 214.71 | 5.27 | Matthew Breen | Green | GREEN |  |  |
| 2045 | 1.8.12.2.9 | Confirmation that DIP and ECS have been deployed, Service management is active, ISD has been populated | milestone | 0d | 2025-03-10 | 2025-03-10 | 2043FS+1d | 2025-03-10 | 2025-03-10 | 0d | 0d |  |  | Elexon,DIP Manager | SI Transition,Elexon,DIP Manager | 214.71 | 5.27 | Matthew Breen | Green | GREEN |  |  |
| 2046 | 1.8.12.2.10 | Self-Declarations against all M10 Data Cleanse Activities | milestone | 0d | 2025-03-10 | 2025-03-10 | 2043FS+1d | 2025-03-10 | 2025-03-10 | 0d | 0d |  |  | PP | SI Transition,PP | 214.71 | 5.27 | Matthew Breen | Green | GREEN |  |  |
| 2047 | 1.8.12.2.11 | IF-047 has been sent | milestone | 0d | 2025-03-10 | 2025-03-10 | 2043FS+1d | 2025-03-10 | 2025-03-10 | 0d | 0d |  |  | ECS | SI Transition,ECS | 214.71 | 5.27 | Matthew Breen | Green | GREEN |  |  |
| 2048 | 1.8.12.2.12 | Recommendation from TORWG that PSG should approve M10 | milestone | 0d | 2025-03-11 | 2025-03-11 | 2044FS+1d, 2045FS+1d, 2046FS+1d, 2047FS+1d | 2025-03-11 | 2025-03-11 | 0d | 0d |  |  | SI Transition | SI Transition | 215.71 | 5.27 | Matthew Breen | Green | GREEN |  |  |
| 2049 | 1.8.12.2.13 | PSG (OFGEM and PSG to Approve That Conditions of M10 and M13 Have Been Met) | milestone | 0d | 2025-03-12 | 2025-03-12 | 2048FS+1d | 2025-03-12 | 2025-03-12 | 0d | 0d |  |  | SI Transition,Ofgem | SI Transition,Ofgem | 216.71 | 5.27 | Matthew Breen | Green | GREEN |  |  |
| 2050 | 1.8.12.2.14 | Confirmation of Qualified Parties from Code Bodies |  | 11d | 2025-03-14 | 2025-03-28 | 2049FS+1d | 2025-03-14 | 2025-03-28 | 11d | 0d |  |  | Code Bodies,SIT Participants | SI Transition,Code Bodies,SIT Participants | 218.33 | 5.27 | Matthew Breen | Green | GREEN |  |  |
| 2051 | 1.8.12.2.15 | Self-Declaration that MHHS Functionality will be deployed to Production by Qualified parties | milestone | 0d | 2025-03-28 | 2025-03-28 | 2049FS+12d | 2025-03-28 | 2025-03-28 | 0d | 0d |  |  | PP | SI Transition,PP | 232.71 | 5.27 | Matthew Breen | Green | GREEN |  |  |
| 2052 | 1.8.12.2.16 | Production Service Activation Activities have taken place | milestone | 0d | 2025-03-28 | 2025-03-28 | 2049FS+12d | 2025-03-28 | 2025-03-28 | 0d | 0d |  |  | PP | SI Transition,PP | 232.71 | 5.27 | Matthew Breen | Green | GREEN |  |  |
| 2053 | 1.8.12.2.17 | TORWG (Confirmation of Qualified Parties from TORWG) | milestone | 0d | 2025-03-31 | 2025-03-31 | 2050FS+1d, 2051FS+1d, 2052FS+1d, 2035 | 2025-03-31 | 2025-03-31 | 0d | 0d |  |  | SI Transition | SI Transition | 235.71 | 5.27 | Matthew Breen | Green | GREEN |  |  |
| 2054 | 1.8.12.2.18 | MCAG (Provide recommendation to PSG on M11 decision) | milestone | 0d | 2025-04-02 | 2025-04-02 | 2053FS+2d | 2025-04-02 | 2025-04-02 | 0d | 0d |  |  | SI Migration | SI Transition,SI Migration | 237.71 | 5.30 | Matthew Breen | Green | GREEN | T3-MI-0036 | MCAG (Transition) |
| 2055 | 1.8.12.2.19 | PSG (OFGEM and PSG Decision to Confirm M11 and M12) | milestone | 0d | 2025-04-04 | 2025-04-04 | 2054FS+2d | 2025-04-04 | 2025-04-04 | 0d | 0d |  |  | SI Transition | SI Transition | 239.71 | 5.27 | Matthew Breen | Green | GREEN |  |  |
| 2056 | 1.8.13 | **UMS / Advanced Migration** |  | 391d | 2025-04-04 | 2026-10-02 |  | 2025-04-04 | 2026-10-02 | 391d | 1d |  | -0 | N/A | N/A | -555.67 | 5.24 | N/A |  |  |  |  |
| 2057 | 1.8.13.1 | SIT MVC UMS / Advanced Migration |  | 391d | 2025-04-04 | 2026-10-02 | 2114 | 2025-04-04 | 2026-10-02 | 391d | 1d | 0d |  |  |  | 239.33 | 5.24 |  | Green | GREEN |  |  |
| 2058 | 1.8.13.2 | SIT Non-MVC UMS / Advanced Migration |  | 326d | 2025-07-04 | 2026-10-02 | 2117 | 2025-07-04 | 2026-10-02 | 326d | 1d | 0d |  |  |  | 330.33 | 5.24 |  | Green | GREEN |  |  |
| 2059 | 1.8.13.3 | Wave 1 UMS / Advanced Migration |  | 261d | 2025-10-03 | 2026-10-02 | 2120 | 2025-10-03 | 2026-10-02 | 261d | 1d | 0d |  |  |  | 421.33 | 5.24 |  | Green | GREEN |  |  |
| 2060 | 1.8.13.4 | Wave 2 UMS / Advanced Migration |  | 216d | 2025-12-05 | 2026-10-02 | 2123 | 2025-12-05 | 2026-10-02 | 216d | 1d | 0d |  |  |  | 484.33 | 5.24 |  | Green | GREEN |  |  |
| 2061 | 1.8.13.5 | Wave 3 UMS / Advanced Migration |  | 181d | 2026-01-23 | 2026-10-02 | 2126 | 2026-01-23 | 2026-10-02 | 181d | 1d | 0d |  |  |  | 533.33 | 5.24 |  | Green | GREEN |  |  |
| 2062 | 1.8.13.6 | Wave 4 UMS / Advanced Migration |  | 131d | 2026-04-03 | 2026-10-02 | 2129 | 2026-04-03 | 2026-10-02 | 131d | 1d | 0d |  |  |  | 603.33 | 5.24 |  | Green | GREEN |  |  |

Notes:
- 2043: 18/6: New T3 milestone agreed at MCAG on 4/6/24 / Guidance: 25/7/24: New Milestone approved at MCAG on 25/7/24. It was initially approved at MCAG on 4/6 but didn't follow the usual process so addded to July MCAG for noting
- 2054: 18/6: New T3 milestone agreed at MCAG on 4/6/24 / Guidance: 25/7/24: New Milestone approved at MCAG on 25/7/24. It was initially approved at MCAG on 4/6 but didn't follow the usual process so addded to July MCAG for noting

| ID | WBS | Task | Type | Duration | Start | Finish | Predecessors | Complete | Remaining | Baseline start | Baseline finish | Baseline duration | Baseline 1 start | Baseline 1 finish | Total slack | Free slack | Constraint | Baseline cost | Responsible | Involved | Task Status | Update Version | MHHS Resource Name | Sched Status | RAG | MHHS Programme Phase | Milestone ID | Text29 | Tier |
| --- | --- | --- | --- | --- | --- | --- | --- | --- | --- | --- | --- | --- | --- | --- | --- | --- | --- | --- | --- | --- | --- | --- | --- | --- | --- | --- | --- | --- | --- |
| 2063 | 1.8.14 | **Smart / Non-Smart Migration** |  | 391d | 2025-04-04 | 2026-10-02 |  |  |  | 2025-04-04 | 2026-10-02 | 391d |  |  | 1d |  |  | -0 | N/A | N/A | -555.67 | 5.24 | N/A |  |  |  |  |  |  |
| 2064 | 1.8.14.1 | SIT MVC Smart / Non-Smart Migration |  | 391d | 2025-04-04 | 2026-10-02 | 2114 |  |  | 2025-04-04 | 2026-10-02 | 391d |  |  | 1d | 0d |  |  |  |  | 239.33 | 5.24 |  | Green | GREEN |  |  |  |  |
| 2065 | 1.8.14.2 | SIT Non-MVC Smart / Non-Smart Migration |  | 326d | 2025-07-04 | 2026-10-02 | 2117 |  |  | 2025-07-04 | 2026-10-02 | 326d |  |  | 1d | 0d |  |  |  |  | 330.33 | 5.24 |  | Green | GREEN |  |  |  |  |
| 2066 | 1.8.14.3 | Wave 1 Smart / Non-Smart Migration |  | 261d | 2025-10-03 | 2026-10-02 | 2120 |  |  | 2025-10-03 | 2026-10-02 | 261d |  |  | 1d | 0d |  |  |  |  | 421.33 | 5.24 |  | Green | GREEN |  |  |  |  |
| 2067 | 1.8.14.4 | Wave 2 Smart / Non-Smart Migration |  | 216d | 2025-12-05 | 2026-10-02 | 2123 |  |  | 2025-12-05 | 2026-10-02 | 216d |  |  | 1d | 0d |  |  |  |  | 484.33 | 5.24 |  | Green | GREEN |  |  |  |  |
| 2068 | 1.8.14.5 | Wave 3 Smart / Non-Smart Migration |  | 181d | 2026-01-23 | 2026-10-02 | 2126 |  |  | 2026-01-23 | 2026-10-02 | 181d |  |  | 1d | 0d |  |  |  |  | 533.33 | 5.24 |  | Green | GREEN |  |  |  |  |
| 2069 | 1.8.14.6 | Wave 4 Smart / Non-Smart Migration |  | 131d | 2026-04-03 | 2026-10-02 | 2129 |  |  | 2026-04-03 | 2026-10-02 | 131d |  |  | 1d | 0d |  |  |  |  | 603.33 | 5.24 |  | Green | GREEN |  |  |  |  |
| 2070 | 1.8.15 | **External Programme Dependency Management** |  | 713d | 2022-10-31 A | 2025-07-23 |  | 66% | 244.19d | 2022-10-31 | 2025-12-30 | 827d | 2022-10-31 | 2025-07-01 | 482d |  |  | -0 | N/A | N/A |  | 5.0 | N/A |  |  | Migration |  |  |  |
| 2071 | 1.8.15.1 | **BSC Mod P432 & REC CP R0015** |  | 392d | 2022-10-31 A | 2024-04-30 A |  | 100% |  | 2022-10-31 | 2025-12-30 | 827d | 2022-10-31 | 2025-07-01 |  |  |  | -0 | N/A | N/A |  | 5.0 | N/A |  |  | Migration |  |  |  |
| 2072 | 1.8.15.1.1 | MHHSP engagement with BSCCo until Ofgem decision |  | 316d | 2022-10-31 A | 2024-01-15 A |  | 100% |  | 2022-10-31 | 2024-05-10 | 400d | 2022-10-31 | 2022-12-30 |  |  |  |  | CPT,SRO Function | Code Bodies |  | 5.0 | MHHS Programme | Complete | COMPLETE | Migration |  |  |  |
| 2073 | 1.8.15.1.2 | Monitor progress and await implementation date |  | 76d | 2024-01-16 A | 2024-04-30 A | 2072 | 100% |  | 2023-07-03 | 2025-12-30 | 652d | 2023-01-02 | 2025-07-01 |  |  |  |  | CPT,SRO Function | Code Bodies |  | 5.0 | MHHS Programme | Complete | COMPLETE | Migration |  |  |  |
| 2074 | 1.8.15.2 | **BSC Mod P434** |  | 713d | 2022-10-31 A | 2025-07-23 |  | 57% | 310d | 2022-10-31 | 2025-07-23 | 713d | 2022-10-31 | 2025-07-01 | 482d |  |  |  | N/A | N/A |  | 5.0 | N/A |  |  | Migration |  |  |  |
| 2075 | 1.8.15.2.1 | MHHSP engagement with BSCCo until Ofgem decision |  | 61d | 2022-10-31 A | 2023-01-23 A |  | 100% |  | 2022-10-31 | 2023-01-23 | 61d | 2022-10-31 | 2022-12-30 |  |  |  |  | CPT,SRO Function | Code Bodies |  | 5.0 | MHHS Programme | Complete | COMPLETE | Migration |  |  |  |
| 2076 | 1.8.15.2.2 | Monitor progress and await implementation date |  | 652d | 2023-01-24 A | 2025-07-23 | 2075 | 52% | 310d | 2023-01-24 | 2025-07-23 | 652d | 2023-01-02 | 2025-07-01 | 482d |  |  |  | CPT,SRO Function | Code Bodies |  | 5.0 | MHHS Programme | Green | GREEN | Migration |  |  |  |
| 2077 | 1.8.15.3 | **Elexon System Capacity Upgrade** |  | 697d | 2022-10-31 A | 2025-07-01 |  | 58% | 294d | 2022-10-31 | 2025-07-01 | 697d | 2022-10-31 | 2025-07-01 | 498d |  |  |  | N/A | N/A |  | 5.0 | N/A |  |  | Migration |  |  |  |
| 2078 | 1.8.15.3.1 | Monitor progress to implementation |  | 697d | 2022-10-31 A | 2025-07-01 |  | 58% | 294d | 2022-10-31 | 2025-07-01 | 697d | 2022-10-31 | 2025-07-01 | 498d | 0d |  |  | SI Migration | PP |  | 5.0 | MHHS Programme | Green | GREEN | Migration |  |  |  |
| 2079 | 1.8.15.3.2 | Implementation date | milestone | 0d | 2025-07-01 | 2025-07-01 | 2078 |  |  | 2025-07-01 | 2025-07-01 | 0d | 2025-07-01 | 2025-07-01 | 498d |  |  |  | PP | SI Migration | 327.71 | 5.0 | MHHS Programme | Green | GREEN | Migration |  |  |  |
| 2080 | 1.8.15.4 | **DCC System Capacity Upgrade** |  | 25d | 2025-01-08 | 2025-02-11 |  |  |  | 2025-01-13 | 2025-02-14 | 25d | 2025-01-13 | 2025-02-14 | 598d |  |  |  | N/A | N/A |  | 5.0 | N/A |  |  | Migration |  |  |  |
| 2081 | 1.8.15.4.1 | Assurance of DCC capacity upgrade to ensure suitability to support migration |  | 20d | 2025-01-08 | 2025-02-04 | 2084FF-23d |  |  | 2025-01-13 | 2025-02-07 | 20d | 2025-01-13 | 2025-02-07 | 598d | 0d |  |  | SI Migration | PP | 153.33 | 5.0 | MHHS Programme | Green | GREEN | Migration |  |  |  |
| 2082 | 1.8.15.4.2 | DCC Capacity Upgrade Operational | milestone | 0d | 2025-02-11 | 2025-02-11 | 2081FS+5d |  |  | 2025-02-14 | 2025-02-14 | 0d | 2025-02-14 | 2025-02-14 | 598d |  |  |  | PP | SI Migration,IPA | 187.71 | 5.0 | MHHS Programme | Green | GREEN | Migration | T2-MI-0350 | MCAG | T2 |
| 2083 | 1.8.16 | **Migration - Tier 1 Milestones** |  | 476d | 2025-03-07 | 2027-01-04 |  |  |  | 2025-03-07 | 2027-01-05 | 477d | 2025-03-07 | 2027-01-05 | 0d |  |  |  | N/A | N/A |  | 5.0 | N/A |  |  | Migration |  |  |  |
| 2084 | 1.8.16.1 | Central systems ready for migrating MPANs (M10) | milestone | 0d | 2025-03-07 | 2025-03-07 | 1073FS+20d, 2132, 2034FS+2d, 2031, 2043, 2033, 2013, 2017 |  |  | 2025-03-07 | 2025-03-07 | 0d | 2025-03-07 | 2025-03-07 | -3d | 0d | must finish on 2025-03-07 |  | CPT | CPT | 211.71 | 5.0 | CPT | Green | GREEN | Migration | T1-MI-1000 | PSG | T1 |
| 2085 | 1.8.16.2 | Central systems ready for migrating MPANs (M10*) - Late Exit | milestone | 0d | 2025-06-06 | 2025-06-06 | 2084FS+65d |  |  | 2025-06-06 | 2025-06-06 | 0d | 2025-06-06 | 2025-06-06 | 515d |  |  |  | CPT | CPT | 302.71 | 5.0 | CPT | Green | GREEN | Migration | T2-MI-1500 | PSG | T1 |
| 2086 | 1.8.16.3 | Load Shaping Service switched on (M13) | milestone | 0d | 2025-03-07 | 2025-03-07 | 2084 |  |  | 2025-03-07 | 2025-03-07 | 0d | 2025-03-07 | 2025-03-07 | 20d | 0d |  |  | CPT | CPT | 211.71 | 5.0 | CPT | Green | GREEN | Migration | T1-MI-2000 | PSG | T1 |
| 2087 | 1.8.16.4 | Load Shaping Service switched on (M13*) - Late Exit | milestone | 0d | 2025-06-06 | 2025-06-06 | 2086FS+65d |  |  | 2025-06-06 | 2025-06-06 | 0d | 2025-06-06 | 2025-06-06 | 515d |  |  |  | CPT | CPT | 302.71 | 5.0 | CPT | Green | GREEN | Migration | T2-MI-2500 | PSG | T1 |
| 2088 | 1.8.16.5 | Start of 18-month migration for UMS / Advanced (M11) | milestone | 0d | 2025-04-04 | 2025-04-04 | 2084FS+15d, 2086, 2114, 2054, 2055 |  |  | 2025-04-04 | 2025-04-04 | 0d | 2025-04-04 | 2025-04-04 | 0d |  |  |  | CPT | CPT | 239.71 | 5.0 | CPT | Green | GREEN | Migration | T1-MI-3000 | PSG | T1 |
| 2089 | 1.8.16.6 | Start of 18-month migration for UMS / Advanced (M11*) - Late Exit | milestone | 0d | 2025-07-04 | 2025-07-04 | 2088FS+65d |  |  | 2025-07-04 | 2025-07-04 | 0d | 2025-07-04 | 2025-07-04 | 495d |  |  |  | CPT | CPT | 330.71 | 5.0 | CPT | Green | GREEN | Migration | T2-MI-3500 | PSG | T1 |
| 2090 | 1.8.16.7 | Start of 18-month migration for Smart / Non-smart (M12) | milestone | 0d | 2025-04-04 | 2025-04-04 | 2084FS+20d, 2086 |  |  | 2025-04-04 | 2025-04-04 | 0d | 2025-04-04 | 2025-04-04 | 495d | 0d |  |  | CPT | CPT | 239.71 | 5.0 | CPT | Green | GREEN | Migration | T1-MI-4000 | PSG | T1 |
| 2091 | 1.8.16.8 | Start of 18-month migration for Smart / Non-smart (M12*) - Late Exit | milestone | 0d | 2025-07-04 | 2025-07-04 | 2090FS+65d |  |  | 2025-07-04 | 2025-07-04 | 0d | 2025-07-04 | 2025-07-04 | 495d |  |  |  | CPT | CPT | 330.71 | 5.0 | CPT | Green | GREEN | Migration | T2-MI-4500 | PSG | T1 |
| 2092 | 1.8.16.9 | All suppliers must be able to access MPANs under the new TOM (M14) | milestone | 0d | 2026-03-12 | 2026-03-12 |  |  |  | 2026-03-16 | 2026-03-16 | 0d | 2026-03-16 | 2026-03-16 | 0d |  | must start on 2026-03-12 |  | CPT | CPT | 581.71 | 5.0 | CPT | Green | GREEN | Migration | T1-MI-5000 | PSG | T1 |
| 2093 | 1.8.16.10 | All suppliers must be able to access MPANs under the new TOM (M14*) - Late Exit | milestone | 0d | 2026-06-12 | 2026-06-12 | 2092FS+66d |  |  | 2026-06-16 | 2026-06-16 | 0d | 2026-06-16 | 2026-06-16 | 250d |  |  |  | CPT | CPT | 673.71 | 5.0 | CPT | Green | GREEN | Migration | T1-MI-5500 | PSG | T1 |
| 2094 | 1.8.16.11 | Full transition complete (M15) | milestone | 0d | 2026-10-02 | 2026-10-02 | 2057, 2058, 2059, 2060, 2061, 2062, 2064, 2065, 2066, 2067, 2068, 2069, 1994 |  |  | 2026-10-05 | 2026-10-05 | 0d | 2026-10-05 | 2026-10-05 | 1d | 0d |  |  | CPT | CPT | 785.71 | 5.0 | CPT | Green | GREEN | Migration | T1-MI-6000 | PSG | T1 |
| 2095 | 1.8.16.12 | Full transition complete (M15*) - Late Exit | milestone | 0d | 2027-01-04 | 2027-01-04 | 2094FS+66d |  |  | 2027-01-05 | 2027-01-05 | 0d | 2027-01-05 | 2027-01-05 | 104d |  |  |  | CPT | CPT | 879.71 | 5.0 | CPT | Green | GREEN | Migration | T2-MI-6500 | PSG | T1 |

Notes:
- 2084: Text3: Central systems ready for migrating MPANs
- 2085: Text3: Central systems ready for migrating MPANs
- 2086: Text3: Load Shaping Service switched on
- 2087: Text3: Load Shaping Service switched on
- 2088: Text3: Start of 1 year migration for UMS / Advanced
- 2089: Text3: Start of 1 year migration for UMS / Advanced
- 2090: Text3: Start of 1 year migration for Smart / Non-smart
- 2091: Text3: Start of 1 year migration for Smart / Non-smart
- 2092: Text3: All suppliers must be able to accept MPANs under the new TOM (one way gate)
- 2093: Text3: All suppliers must be able to accept MPANs under the new TOM (one way gate)
- 2094: Text3: Full transition complete
- 2095: Text3: Full transition complete

| ID | WBS | Task | Type | Duration | Start | Finish | Predecessors | Complete | Remaining | Baseline start | Baseline finish | Baseline duration | Baseline 1 start | Baseline 1 finish | Total slack | Free slack | Constraint | Baseline cost | Responsible | Involved | MHHS Resource Name | MHHS Programme Phase | Update Version | Sched Status | RAG | Milestone ID | Text29 | Tier | Task Status | Notes (2) |
| --- | --- | --- | --- | --- | --- | --- | --- | --- | --- | --- | --- | --- | --- | --- | --- | --- | --- | --- | --- | --- | --- | --- | --- | --- | --- | --- | --- | --- | --- | --- |
| 2096 | 1.9 | **BUSINESS & OPERATIONAL READINESS** |  | 1195d | 2022-10-31 A | 2027-05-28 |  | 8% | 1099.85d | 2023-09-19 | 2027-05-28 | 964d | 2023-03-01 | 2026-12-07 | 0d |  |  | -0 | N/A | N/A | N/A | Business & Operational Readiness |  |  |  |  |  |  |  |  |
| 2097 | 1.9.1 | **Service Management** |  | 839d | 2023-09-19 A | 2026-12-04 |  | 26% | 621.65d | 2023-09-19 | 2026-12-07 | 840d | 2023-03-01 | 2026-12-07 | 125d |  |  | -0 | N/A | N/A | N/A | Business & Operational Readiness | 5.0 |  |  |  |  |  |  |  |
| 2098 | 1.9.1.1 | **Service Management Strategy** |  | 116d | 2023-09-19 A | 2024-02-27 A |  | 100% |  | 2023-09-19 | 2024-02-27 | 116d | 2023-03-01 | 2023-05-31 |  |  |  | -0 | N/A | N/A | N/A | Business & Operational Readiness | 5.0 |  |  |  |  |  |  |  |
| 2099 | 1.9.1.1.1 | Develop document with relevant participants (incl. review of the design baseline to ensure service management arrangements are in place across the solution architecture) |  | 84d | 2023-09-19 A | 2024-01-12 A |  | 100% |  | 2023-09-19 | 2024-01-12 | 84d | 2023-03-01 | 2023-04-28 |  |  | start no earlier than 2023-09-19 |  | SI Design |  | Matthew Breen | Business & Operational Readiness | 5.0 | Complete | COMPLETE |  |  |  |  |  |
| 2100 | 1.9.1.1.2 | Artefact review (via relevant Advisory Group) and updates |  | 31d | 2024-01-15 A | 2024-02-26 A | 2099 | 100% |  | 2024-01-15 | 2024-02-26 | 31d | 2023-05-01 | 2023-05-24 |  |  |  |  | PP | SI Design,IPA | Matthew Breen | Business & Operational Readiness | 5.0 | Complete | COMPLETE |  |  |  |  |  |
| 2101 | 1.9.1.1.3 | Service Management Strategy approved | milestone | 0d | 2024-02-27 A | 2024-02-27 A | 2100FS+1d | 100% |  | 2024-02-27 | 2024-02-27 | 0d | 2023-05-31 | 2023-05-31 |  |  |  |  | SI Design | PP | Matthew Breen | Business & Operational Readiness | 5.16 | Complete | COMPLETE | T3-BC-0010 | MCAG | T3 |  |  |
| 2102 | 1.9.1.2 | **Early Life Support Model** |  | 110d | 2024-02-28 A | 2024-07-30 |  | 82% | 20.23d | 2024-02-28 | 2024-07-30 | 110d |  |  | 0d |  |  | -0 | N/A | N/A | N/A | Business & Operational Readiness | 5.16 |  |  |  |  |  | -441.67 |  |
| 2103 | 1.9.1.2.1 | Draft Document |  | 74d | 2024-02-28 A | 2024-06-10 | 2101 | 96% | 3d | 2024-02-28 | 2024-06-10 | 74d |  |  | 0d |  |  |  | SI Transition | SI Transition,PP,SRO | Matthew Breen | Business & Operational Readiness | 5.24 | Overdue | RED |  |  |  |  |  |
| 2104 | 1.9.1.2.2 | Share document with SRO |  | 1d | 2024-06-11 | 2024-06-11 | 2103 |  |  | 2024-06-11 | 2024-06-11 | 1d |  |  | 0d |  |  |  | SI Transition | SI Transition,PP,SRO | Matthew Breen | Business & Operational Readiness | 5.24 | Overdue Start | RED |  |  |  | -57.67 |  |
| 2105 | 1.9.1.2.3 | Industry Consultation |  | 11d | 2024-06-18 | 2024-07-02 | 2104FS+4d |  |  | 2024-06-18 | 2024-07-02 | 11d |  |  | 0d |  |  |  | SI Transition | SI Transition,PP,SRO | Matthew Breen | Business & Operational Readiness | 5.24 | Overdue Start | RED |  |  |  | -50.67 |  |
| 2106 | 1.9.1.2.4 | Assurance Meeting |  | 1d | 2024-07-16 | 2024-07-16 | 2105FS+9d |  |  | 2024-07-16 | 2024-07-16 | 1d |  |  | 0d |  |  |  | SI Transition | SI Transition,PP,SRO | Matthew Breen | Business & Operational Readiness | 5.24 | Overdue Start | RED |  |  |  | -22.67 |  |
| 2107 | 1.9.1.2.5 | MCAG Approval of Early Life Support Model | milestone | 0d | 2024-07-30 | 2024-07-30 | 2106FS+10d |  |  | 2024-07-30 | 2024-07-30 | 0d |  |  | 0d |  |  |  | SI Transition | PP,SRO,SI Transition | Matthew Breen | Business & Operational Readiness | 5.24 | Overdue Start | RED | T3-MI-0033 | MCAG (Transition) |  | -8.29 | been held with the Code Bodies at the end of August |
| 2108 | 1.9.1.3 | **Service Management Arrangements Implementation** |  | 455d | 2025-03-10 | 2026-12-04 |  |  |  | 2025-03-13 | 2026-12-07 | 453d | 2025-03-10 | 2026-12-07 | 125d |  |  | -0 | N/A | N/A | N/A | Business & Operational Readiness | 5.0 |  |  |  |  |  |  |  |
| 2109 | 1.9.1.3.1 | Hypercare post M10 |  | 80d | 2025-03-10 | 2025-06-27 | 2084 |  |  | 2025-03-13 | 2025-07-02 | 80d | 2025-03-10 | 2025-06-27 | 500d |  |  |  | SI Design | PP | Claire Silk | Business & Operational Readiness | 5.0 | Green | GREEN |  |  |  | 214.33 |  |
| 2110 | 1.9.1.3.2 | Monitor Elexon implementation of Service Management arrangements |  | 436d | 2025-04-04 | 2026-12-04 | 2057SS, 2064SS |  |  | 2025-04-07 | 2026-12-07 | 436d | 2025-04-07 | 2026-12-07 | 125d |  |  |  | PP | SI Design | Claire Silk | Business & Operational Readiness | 5.0 | Green | GREEN |  |  |  | 239.33 |  |
| 2111 | 1.9.2 | **Service Activation** |  | 894d | 2022-10-31 | 2026-04-02 |  |  |  | 2025-02-24 | 2026-04-02 | 289d |  |  | 301d |  |  | -0 | N/A | N/A | N/A |  | 5.24 |  |  |  |  |  | -555.67 |  |
| 2112 | 1.9.2.1 | Helix Preparatory Activities Complete | milestone | 0d | 2022-10-31 | 2022-10-31 |  |  |  |  |  |  |  |  | 1195d |  |  |  |  |  |  |  | 5.29 | Overdue Start | RED |  |  |  | -646.67 |  |
| 2113 | 1.9.2.2 | MHHSP Confirms SIT MVC PPs MHHS Enabled |  | 1d | 2022-10-31 | 2022-10-31 |  |  |  |  |  |  |  |  | 610d | 609d |  |  |  |  |  |  | 5.28 | Overdue Start | RED |  |  |  | -646.67 |  |
| 2114 | 1.9.2.3 | SIT MVC Service Activation |  | 24d | 2025-03-03 | 2025-04-03 | 1404SS, 2113 |  |  | 2025-02-28 | 2025-04-03 | 25d |  |  | 1d | 0d |  |  |  |  |  |  | 5.24 | Green | GREEN |  |  |  | 207.33 |  |
| 2115 | 1.9.2.4 | Helix Preparatory Activities Complete | milestone | 0d | 2022-10-31 | 2022-10-31 |  |  |  |  |  |  |  |  | 1195d |  |  |  |  |  |  |  | 5.29 | Overdue Start | RED |  |  |  | -646.67 |  |
| 2116 | 1.9.2.5 | MHHSP Confirms SIT Non-MVC PPs MHHS Enabled |  | 1d | 2022-10-31 | 2022-10-31 |  |  |  |  |  |  |  |  | 675d | 674d |  |  |  |  |  |  | 5.28 | Overdue Start | RED |  |  |  | -646.67 |  |
| 2117 | 1.9.2.6 | SIT Non-MVC Service Activation |  | 24d | 2025-06-02 | 2025-07-03 | 1410SS, 2116 |  |  | 2025-05-30 | 2025-07-03 | 25d |  |  | 1d | 0d |  |  |  |  |  |  | 5.24 | Green | GREEN |  |  |  | 298.33 |  |
| 2118 | 1.9.2.7 | Helix Preparatory Activities Complete | milestone | 0d | 2022-10-31 | 2022-10-31 |  |  |  |  |  |  |  |  | 1195d |  |  |  |  |  |  |  | 5.29 | Overdue Start | RED |  |  |  | -646.67 |  |
| 2119 | 1.9.2.8 | MHHSP Confirms Wave 1 PPs MHHS Enabled |  | 1d | 2022-10-31 | 2022-10-31 |  |  |  |  |  |  |  |  | 740d | 739d |  |  |  |  |  |  | 5.28 | Overdue Start | RED |  |  |  | -646.67 |  |
| 2120 | 1.9.2.9 | Wave 1 Service Activation |  | 24d | 2025-09-01 | 2025-10-02 | 1598, 2119 |  |  | 2025-08-29 | 2025-10-02 | 25d |  |  | 1d | 0d |  |  |  |  |  |  | 5.24 | Green | GREEN |  |  |  | 389.33 |  |
| 2121 | 1.9.2.10 | Helix Preparatory Activities Complete | milestone | 0d | 2022-10-31 | 2022-10-31 |  |  |  |  |  |  |  |  | 1195d |  |  |  |  |  |  |  | 5.29 | Overdue Start | RED |  |  |  | -646.67 |  |
| 2122 | 1.9.2.11 | MHHSP Confirms Wave 2 PPs MHHS Enabled |  | 1d | 2022-10-31 | 2022-10-31 |  |  |  |  |  |  |  |  | 785d | 784d |  |  |  |  |  |  | 5.28 | Overdue Start | RED |  |  |  | -646.67 |  |
| 2123 | 1.9.2.12 | Wave 2 Service Activation |  | 24d | 2025-11-03 | 2025-12-04 | 1628, 2122 |  |  | 2025-10-31 | 2025-12-04 | 25d |  |  | 1d | 0d |  |  |  |  |  |  | 5.24 | Green | GREEN |  |  |  | 452.33 |  |
| 2124 | 1.9.2.13 | Helix Preparatory Activities Complete | milestone | 0d | 2022-10-31 | 2022-10-31 |  |  |  |  |  |  |  |  | 1195d |  |  |  |  |  |  |  | 5.29 | Overdue Start | RED |  |  |  | -646.67 |  |
| 2125 | 1.9.2.14 | MHHSP Confirms Wave 3 PPs MHHS Enabled |  | 1d | 2022-10-31 | 2022-10-31 |  |  |  |  |  |  |  |  | 820d | 819d |  |  |  |  |  |  | 5.28 | Overdue Start | RED |  |  |  | -646.67 |  |
| 2126 | 1.9.2.15 | Wave 3 Service Activation |  | 24d | 2025-12-22 | 2026-01-22 | 1658, 2125 |  |  | 2025-12-19 | 2026-01-22 | 25d |  |  | 1d | 0d |  |  |  |  |  |  | 5.24 | Green | GREEN |  |  |  | 501.33 |  |
| 2127 | 1.9.2.16 | Helix Preparatory Activities Complete | milestone | 0d | 2022-10-31 | 2022-10-31 |  |  |  |  |  |  |  |  | 1195d |  |  |  |  |  |  |  | 5.29 | Overdue Start | RED |  |  |  | -646.67 |  |
| 2128 | 1.9.2.17 | MHHSP Confirms Wave 4 PPs MHHS Enabled |  | 1d | 2022-10-31 | 2022-10-31 |  |  |  |  |  |  |  |  | 870d | 869d |  |  |  |  |  |  | 5.28 | Overdue Start | RED |  |  |  | -646.67 |  |
| 2129 | 1.9.2.18 | Wave 4 Service Activation |  | 24d | 2026-03-02 | 2026-04-02 | 1688, 2128 |  |  | 2026-02-27 | 2026-04-02 | 25d |  |  | 1d | 0d |  |  |  |  |  |  | 5.24 | Green | GREEN |  |  |  | 571.33 |  |
| 2130 | 1.9.2.19 | Helix Preparatory Activities Complete | milestone | 0d | 2022-10-31 | 2022-10-31 |  |  |  |  |  |  |  |  | 1195d |  |  |  |  |  |  |  | 5.29 | Overdue Start | RED |  |  |  | -646.67 |  |
| 2131 | 1.9.2.20 | MHHSP Confirms Non-SIT LDSO PPs MHHS Enabled |  | 1d | 2022-10-31 | 2022-10-31 |  |  |  |  |  |  |  |  | 605d | 604d |  |  |  |  |  |  | 5.28 | Overdue Start | RED |  |  |  | -646.67 |  |
| 2132 | 1.9.2.21 | Non-SIT LDSO Service Activation |  | 9d | 2025-02-24 | 2025-03-06 | 1331, 2131 |  |  | 2025-02-24 | 2025-03-06 | 9d |  |  | 1d |  |  |  |  |  |  |  | 5.24 | Green | GREEN |  |  |  | 200.33 |  |

Notes:
- 2101: 17/1 - Baseline change approved at TMAG to change date from 21/2/24 to 27/2/24. Changed because MCAG has been scheduled for 27/2/24. Approved at TMAG on 7/1/24
- 2107: Date will be missed because of input required from Code-Bodies. Because of this drafting and publication of the document have been delayed. Impact will be further defined once timelines are understood. Update will be given when further discussions have
- 2109: 10/5: Detail to be added when available
- 2110: 10/5: Detail to be added when available
- 2111: 8/7/24: Likely Servce action will be on a pp by pp basis , may want to capture it here
- 2113: 8/7/24: For M11 need mcc enabled - need confirmation suppliers agree to being mhhs enabled
- 2116: 8/7/24: Confirm Predecessors
- 2119: 8/7/24: Confirm Predecessors
- 2122: 8/7/24: Confirm Predecessors
- 2125: 8/7/24: Confirm Predecessors
- 2128: 8/7/24: Confirm Predecessors
- 2131: 8/7/24: Confirm Predecessors

| ID | WBS | Task | Type | Duration | Start | Finish | Predecessors | Baseline start | Baseline finish | Baseline duration | Baseline 1 start | Baseline 1 finish | Total slack | Free slack | Constraint | Baseline cost | Responsible | Involved | Update Version | MHHS Resource Name | MHHS Programme Phase | Artefact ID | Task Status | Sched Status | RAG | Action | Milestone ID | Text29 | Tier |
| --- | --- | --- | --- | --- | --- | --- | --- | --- | --- | --- | --- | --- | --- | --- | --- | --- | --- | --- | --- | --- | --- | --- | --- | --- | --- | --- | --- | --- | --- |
| 2133 | 1.9.3 | **Implement Early Life Support Plan** |  | 45d | 2025-01-06 | 2025-03-07 |  | 2025-01-06 | 2025-03-07 | 45d | 2025-01-06 | 2025-02-28 | 580d |  |  | -0 | N/A | N/A | 5.0 | N/A | Business & Operational Readiness |  |  |  |  |  |  |  |  |
| 2134 | 1.9.3.1 | Implement Early Life Support Plan |  | 45d | 2025-01-06 | 2025-03-07 | 2107 | 2025-01-06 | 2025-03-07 | 45d | 2025-02-28 | 2025-02-28 | 580d |  | start no earlier than 2025-01-06 |  | SI Transition | SI Transition,CPT | 5.23 | Matthew Breen | Business & Operational Readiness | MHHS-ART095 | 151.33 | Green | GREEN |  |  |  |  |
| 2135 | 1.9.4 | **Business Continuity and Disaster Recovery Plan** |  | 40d | 2025-01-13 | 2025-03-07 |  | 2025-01-13 | 2025-03-07 | 40d | 2025-01-13 | 2025-03-07 | 580d |  |  |  | N/A | N/A | 5.0 | N/A | Business & Operational Readiness |  |  |  |  |  |  |  |  |
| 2136 | 1.9.4.1 | Central Parties BCDRs in Place |  | 20d | 2025-01-13 | 2025-02-07 | 1820FS-40d | 2025-01-13 | 2025-02-07 | 20d | 2025-01-13 | 2025-02-07 | 580d | 0d |  |  | SI Design |  | 5.0 | MHHS Programme | Business & Operational Readiness |  | 158.33 | Green | GREEN |  |  |  |  |
| 2137 | 1.9.4.2 | Risk Based Assurance of Cental Party BCDRs |  | 20d | 2025-02-10 | 2025-03-07 | 2136 | 2025-02-10 | 2025-03-07 | 20d | 2025-02-10 | 2025-03-07 | 580d |  |  |  | PP | SI Design | 5.0 | MHHS Programme | Business & Operational Readiness |  | 186.33 | Green | GREEN |  |  |  |  |
| 2138 | 1.9.5 | **Training and Support Materials** |  | 39d | 2025-02-03 | 2025-03-27 |  | 2025-02-03 | 2025-03-28 | 40d | 2025-02-03 | 2025-03-28 | 566d |  |  |  | N/A | N/A | 5.0 | N/A | Business & Operational Readiness |  |  |  |  | 10/5: To be reworked with better clarity (LH) |  |  |  |
| 2139 | 1.9.5.1 | Develop document |  | 20d | 2025-02-03 | 2025-02-28 | 2090FS-45d | 2025-02-03 | 2025-02-28 | 20d | 2025-02-03 | 2025-02-28 | 566d | 0d |  |  | SI Migration | CPT | 5.0 | PPC | Business & Operational Readiness |  | 179.33 | Green | GREEN |  |  |  |  |
| 2140 | 1.9.5.2 | Document review and update |  | 19d | 2025-03-03 | 2025-03-27 | 2139 | 2025-03-03 | 2025-03-28 | 20d | 2025-03-03 | 2025-03-28 | 566d | 0d |  |  | SI Migration | PMO,CPT,IPA,PP | 5.0 | PPC | Business & Operational Readiness |  | 207.33 | Green | GREEN |  |  |  |  |
| 2141 | 1.9.5.3 | Training and Support Materials approved | milestone | 0d | 2025-03-27 | 2025-03-27 | 2140 | 2025-03-28 | 2025-03-28 | 0d | 2025-03-28 | 2025-03-28 | 566d |  |  |  | SI Migration | PMO,CPT | 5.0 | PPC | Business & Operational Readiness | MHHS-ART118 | 231.71 | Green | GREEN |  |  |  |  |
| 2142 | 1.9.6 | **PP Business Change** |  | 129d | 2025-02-03 | 2025-07-31 |  | 2025-02-03 | 2025-07-31 | 129d | 2025-02-03 | 2025-07-31 | 476d |  |  |  | N/A | N/A | 5.0 | N/A | Business & Operational Readiness |  | M11 |  |  | 10/5: Review with PPC (LH) |  |  |  |
| 2143 | 1.9.6.1 | Plan stakeholder management |  | 129d | 2025-02-03 | 2025-07-31 |  | 2025-02-03 | 2025-07-31 | 129d | 2025-02-03 | 2025-07-31 | 476d |  | start no earlier than 2025-02-03 |  | PP | PPC | 5.0 | PPC | Business & Operational Readiness |  | 179.33 | Green | GREEN |  |  |  |  |
| 2144 | 1.9.6.2 | Manage stakeholders |  | 129d | 2025-02-03 | 2025-07-31 |  | 2025-02-03 | 2025-07-31 | 129d | 2025-02-03 | 2025-07-31 | 476d |  | start no earlier than 2025-02-03 |  | PP | PPC | 5.0 | PPC | Business & Operational Readiness |  | 179.33 | Green | GREEN |  |  |  |  |
| 2145 | 1.9.6.3 | Develop & implement changes to KPIs, organisation & people management |  | 129d | 2025-02-03 | 2025-07-31 |  | 2025-02-03 | 2025-07-31 | 129d | 2025-02-03 | 2025-07-31 | 476d |  | start no earlier than 2025-02-03 |  | PP | PPC | 5.0 | PPC | Business & Operational Readiness |  | 179.33 | Green | GREEN |  |  |  |  |
| 2146 | 1.9.6.4 | Develop & test changes to business processes |  | 129d | 2025-02-03 | 2025-07-31 |  | 2025-02-03 | 2025-07-31 | 129d | 2025-02-03 | 2025-07-31 | 476d |  | start no earlier than 2025-02-03 |  | PP | PPC | 5.0 | PPC | Business & Operational Readiness |  | 179.33 | Green | GREEN |  |  |  |  |
| 2147 | 1.9.6.5 | Develop and deliver training |  | 129d | 2025-02-03 | 2025-07-31 |  | 2025-02-03 | 2025-07-31 | 129d | 2025-02-03 | 2025-07-31 | 476d |  | start no earlier than 2025-02-03 |  | PP | PPC | 5.0 | PPC | Business & Operational Readiness |  | 179.33 | Green | GREEN |  |  |  |  |
| 2148 | 1.9.6.6 | Programme support for PP Business Change activities |  | 129d | 2025-02-03 | 2025-07-31 |  | 2025-02-03 | 2025-07-31 | 129d | 2025-02-03 | 2025-07-31 | 476d |  | start no earlier than 2025-02-03 |  | PPC | PP | 5.0 | PPC | Business & Operational Readiness |  | 179.33 | Green | GREEN |  |  |  |  |
| 2149 | 1.9.7 | **Transition to New Settlement Timetable (M16)** |  | 560d | 2025-04-04 | 2027-05-28 |  | 2025-04-04 | 2027-05-28 | 560d |  |  | 0d |  |  | -0 | N/A | N/A | 5.15 | N/A | Business & Operational Readiness |  | -434.67 |  |  |  |  |  |  |
| 2150 | 1.9.7.1 | Elexon to produce Settlement Calendar for Settlement Year 2025/2026 | milestone | 0d | 2025-04-04 | 2025-04-04 | 2088 | 2025-04-04 | 2025-04-04 | 0d |  |  | 0d |  |  |  | PP | PP, Code Bodies | 5.15 | Matthew Breen | Business & Operational Readiness |  | 239.71 | Green | GREEN |  |  |  |  |
| 2151 | 1.9.7.2 | Elexon monitor settlement data of migrated MPANs |  | 436d | 2025-04-07 | 2026-12-07 | 2150 | 2025-04-07 | 2026-12-07 | 436d |  |  | 0d |  |  |  | PP | PP, Code Bodies | 5.15 | Matthew Breen | Business & Operational Readiness |  | 242.33 | Green | GREEN |  |  |  |  |
| 2152 | 1.9.7.3 | M16 Checkpoint 1 | milestone | 0d | 2025-12-08 | 2025-12-08 | 2150FS+176d | 2025-12-08 | 2025-12-08 | 0d |  |  | 0d |  |  |  | PP | PP, Code Bodies | 5.15 | Matthew Breen | Business & Operational Readiness |  | 487.71 | Green | GREEN |  |  |  |  |
| 2153 | 1.9.7.4 | Confirm if M16 date retained as 07/12/2026 | milestone | 0d | 2026-01-05 | 2026-01-05 | 2152FS+20d | 2026-01-05 | 2026-01-05 | 0d |  |  | 0d |  |  |  | CPT | PP | 5.15 | Matthew Breen | Business & Operational Readiness |  | 515.71 | Green | GREEN |  |  |  |  |
| 2154 | 1.9.7.5 | Readiness assessment of participants' readiness to transition to new Settlement Timetable | milestone | 0d | 2026-02-02 | 2026-02-02 | 2153FS+20d | 2026-02-02 | 2026-02-02 | 0d |  |  | 0d |  |  |  | CPT | PP | 5.15 | Matthew Breen | Business & Operational Readiness |  | 543.71 | Green | GREEN |  |  |  |  |
| 2155 | 1.9.7.6 | Elexon to produce Settlement Calendar for Settlement Year 2026 up until day before M16 cutover | milestone | 0d | 2026-04-01 | 2026-04-01 | 2154FS+42d | 2026-04-01 | 2026-04-01 | 0d |  |  | 0d |  |  |  | PP | PP, Code Bodies | 5.15 | Matthew Breen | Business & Operational Readiness |  | 601.71 | Green | GREEN |  |  |  |  |
| 2156 | 1.9.7.7 | M16 Checkpoint 2 | milestone | 0d | 2026-09-15 | 2026-09-15 | 2155FS+119d | 2026-09-15 | 2026-09-15 | 0d |  |  | 0d |  |  |  | PP | PP, Code Bodies | 5.15 | Matthew Breen | Business & Operational Readiness |  | 768.71 | Green | GREEN |  |  |  |  |
| 2157 | 1.9.7.8 | Readiness assessment of participants' readiness to transition to new Settlement Timetable | milestone | 0d | 2026-09-30 | 2026-09-30 | 2156FS+11d | 2026-09-30 | 2026-09-30 | 0d |  |  | 0d |  |  |  | CPT | PP | 5.15 | Matthew Breen | Business & Operational Readiness |  | 783.71 | Green | GREEN |  |  |  |  |
| 2158 | 1.9.7.9 | Confirm M16 Date | milestone | 0d | 2026-10-13 | 2026-10-13 | 2157FS+9d | 2026-10-13 | 2026-10-13 | 1d |  |  | 0d |  |  |  | CPT | Code Bodies,CPT,PP,SRO | 5.3 | Matthew Breen | Business & Operational Readiness |  | 796.71 | Green | GREEN |  | T2-EL-0100 | PSG/BSC PAB | T2 |
| 2159 | 1.9.7.10 | Raise fast track change to ISD (November publish) | milestone | 0d | 2026-10-13 | 2026-10-13 | 2158 | 2026-10-13 | 2026-10-13 | 0d |  |  | 39d |  |  |  | PP | PP,CPT,Code Bodies | 5.15 | Matthew Breen | Business & Operational Readiness |  | 796.71 | Green | GREEN |  |  |  |  |

| ID | WBS | Task | Type | Duration | Start | Finish | Predecessors | Baseline start | Baseline finish | Baseline duration | Baseline 1 start | Baseline 1 finish | Total slack | Free slack | Responsible | Involved | Update Version | MHHS Resource Name | MHHS Programme Phase | Task Status | Sched Status | RAG | Milestone ID | Text29 | Tier | Text3 | Artefact ID |
| --- | --- | --- | --- | --- | --- | --- | --- | --- | --- | --- | --- | --- | --- | --- | --- | --- | --- | --- | --- | --- | --- | --- | --- | --- | --- | --- | --- |
| 2160 | 1.9.7.11 | **M16 Approval Window** |  | 124d | 2026-12-07 | 2027-05-28 |  | 2026-12-07 | 2027-05-28 | 124d | 2026-12-07 | 2027-05-24 | 0d |  | N/A | N/A | 5.0 | N/A | Business & Operational Readiness |  |  |  |  |  |  |  |  |
| 2161 | 1.9.7.11.1 | Panel approval that M16 criteria met | milestone | 0d | 2026-12-07 | 2026-12-07 | 2158FS+39d | 2026-12-07 | 2026-12-07 | 0d | 2026-12-07 | 2026-12-07 | 0d |  | Panel | Code Bodies,CPT,PP,SRO | 5.0 | Matthew Breen | Business & Operational Readiness | 851.71 | Green | GREEN |  |  |  |  |  |
| 2162 | 1.9.7.11.2 | Cut over to new settlement timetable (M16) | milestone | 0d | 2026-12-07 | 2026-12-07 | 2161, 2094FS+45d, 2151, 2159, 2000 | 2026-12-07 | 2026-12-07 | 0d | 2026-12-07 | 2026-12-07 | 0d |  | CPT | PP | 5.0 | Matthew Breen | Business & Operational Readiness | 851.71 | Green | GREEN | T1-EL-1000 | PSG | T1 |  |  |
| 2163 | 1.9.7.11.3 | Maximum 6-month window for approval of M16 |  | 124d | 2026-12-08 | 2027-05-28 | 2162 | 2026-12-08 | 2027-05-28 | 124d | 2026-12-08 | 2027-05-24 | 0d |  | CPT |  | 5.0 | Matthew Breen | Business & Operational Readiness | 852.33 | Green | GREEN |  |  |  |  |  |
| 2164 | 1.9.7.11.4 | Cut over to new settlement timetable (M16*) - Late Exit | milestone | 0d | 2027-05-28 | 2027-05-28 | 2163 | 2027-05-28 | 2027-05-28 | 0d | 2027-05-24 | 2027-05-24 | 0d |  | CPT | PP | 5.0 | Matthew Breen | Business & Operational Readiness | 1023.71 | Green | GREEN | T1-EL-2000 | PSG | T1 |  |  |
| 2165 | 1.10 | **EARLY LIVE RUNNING** |  | 45d | 2026-10-05 | 2026-12-04 |  | 2024-01-02 | 2027-05-28 | 889d | 2024-01-02 | 2027-05-28 | 125d |  | N/A | N/A |  | N/A | Early Live Running |  |  |  |  |  |  | 1 Nov 2025 - 30 Apr 2026 |  |
| 2166 | 1.10.1 | **Early Live Running Stabilisation Period** |  | 45d | 2026-10-05 | 2026-12-04 |  | 2026-10-06 | 2026-12-07 | 45d | 2026-10-06 | 2026-12-07 | 125d |  | N/A | N/A | 5.0 | N/A | Early Live Running |  |  |  |  |  |  |  |  |
| 2167 | 1.10.1.1 | Manage Early Live Running stabilisation period |  | 45d | 2026-10-05 | 2026-12-04 | 2094 | 2026-10-06 | 2026-12-07 | 45d | 2026-10-06 | 2026-12-07 | 125d | 0d | Code Bodies | PP | 5.0 | Matthew Breen | Early Live Running | 788.33 | Green | GREEN |  |  |  |  |  |
| 2168 | 1.10.1.2 | Monitor Early Live Running stabilisation period |  | 45d | 2026-10-05 | 2026-12-04 | 2167SS | 2026-10-06 | 2026-12-07 | 45d | 2026-10-06 | 2026-12-07 | 125d |  | SI Migration | Code Bodies,PP | 5.0 | Matthew Breen | Early Live Running | 788.33 | Green | GREEN |  |  |  |  |  |
| 2169 | 1.11 | **PROGRAMME CLOSURE** |  | 86d | 2026-08-03 | 2026-11-30 |  | 2026-08-04 | 2026-11-30 | 85d | 2026-08-04 | 2026-11-30 | 129d |  | N/A | N/A |  | N/A | Programme Closure |  |  |  |  |  |  |  |  |
| 2170 | 1.11.1 | **Handover Pack** |  | 86d | 2026-08-03 | 2026-11-30 |  | 2026-08-04 | 2026-11-30 | 85d | 2026-08-04 | 2026-11-30 | 129d |  | N/A | N/A | 5.0 | N/A | Programme Closure |  |  |  |  |  |  |  |  |
| 2171 | 1.11.1.1 | **Draft Handover Pack (for M15)** |  | 40d | 2026-08-03 | 2026-09-25 |  | 2026-08-04 | 2026-09-28 | 40d | 2026-08-04 | 2026-09-28 | 175d |  | N/A | N/A | 5.0 | N/A | Programme Closure |  |  |  |  |  |  |  |  |
| 2172 | 1.11.1.1.1 | Develop document |  | 20d | 2026-08-03 | 2026-08-28 | 2094FS-45d | 2026-08-04 | 2026-08-31 | 20d | 2026-08-04 | 2026-08-31 | 175d | 0d | PMO | CPT | 5.0 |  | Programme Closure | 725.33 | Green | GREEN |  |  |  |  |  |
| 2173 | 1.11.1.1.2 | Document review and update |  | 20d | 2026-08-31 | 2026-09-25 | 2172 | 2026-09-01 | 2026-09-28 | 20d | 2026-09-01 | 2026-09-28 | 175d | 0d | SRO | PMO,CPT,IPA,PP | 5.0 |  | Programme Closure | 753.33 | Green | GREEN |  |  |  |  |  |
| 2174 | 1.11.1.1.3 | Draft Handover Pack approved | milestone | 0d | 2026-09-25 | 2026-09-25 | 2173 | 2026-09-28 | 2026-09-28 | 0d | 2026-09-28 | 2026-09-28 | 175d |  | SRO | PMO,CPT | 5.0 |  | Programme Closure | 778.71 | Green | GREEN |  |  |  |  | MHHS-ART126 |
| 2175 | 1.11.1.2 | **Master Handover Pack (for M16)** |  | 40d | 2026-10-06 | 2026-11-30 |  | 2026-10-06 | 2026-11-30 | 40d | 2026-10-06 | 2026-11-30 | 129d |  | N/A | N/A | 5.0 | N/A | Programme Closure |  |  |  |  |  |  |  |  |
| 2176 | 1.11.1.2.1 | Update document |  | 20d | 2026-10-06 | 2026-11-02 | 2162FS-45d | 2026-10-06 | 2026-11-02 | 20d | 2026-10-06 | 2026-11-02 | 129d | 0d | PMO | CPT | 5.0 |  | Programme Closure | 789.33 | Green | GREEN |  |  |  |  |  |
| 2177 | 1.11.1.2.2 | Document review and update |  | 20d | 2026-11-03 | 2026-11-30 | 2176 | 2026-11-03 | 2026-11-30 | 20d | 2026-11-03 | 2026-11-30 | 129d | 0d | SRO | PMO,CPT,IPA,PP | 5.0 |  | Programme Closure | 817.33 | Green | GREEN |  |  |  |  |  |
| 2178 | 1.11.1.2.3 | Master Handover Pack approved | milestone | 0d | 2026-11-30 | 2026-11-30 | 2177 | 2026-11-30 | 2026-11-30 | 0d | 2026-11-30 | 2026-11-30 | 129d |  | SRO | PMO,CPT | 5.0 |  | Programme Closure | 844.71 | Green | GREEN |  |  |  |  | MHHS-ART126 |
| 2179 | 1.11.2 | **Programme Lessons Learned** |  | 40d | 2026-08-03 | 2026-09-25 |  | 2026-08-04 | 2026-09-28 | 40d | 2026-08-04 | 2026-09-28 | 175d |  | N/A | N/A | 5.0 | N/A | Programme Closure |  |  |  |  |  |  |  |  |
| 2180 | 1.11.2.1 | Develop document |  | 20d | 2026-08-03 | 2026-08-28 | 2094FS-45d | 2026-08-04 | 2026-08-31 | 20d | 2026-08-04 | 2026-08-31 | 175d | 0d | PMO | CPT | 5.0 |  | Programme Closure | 725.33 | Green | GREEN |  |  |  |  |  |
| 2181 | 1.11.2.2 | Document review and update |  | 20d | 2026-08-31 | 2026-09-25 | 2180 | 2026-09-01 | 2026-09-28 | 20d | 2026-09-01 | 2026-09-28 | 175d | 0d | SRO | PMO,CPT,IPA | 5.0 |  | Programme Closure | 753.33 | Green | GREEN |  |  |  |  |  |
| 2182 | 1.11.2.3 | Programme Lessons Learned document approved | milestone | 0d | 2026-09-25 | 2026-09-25 | 2181 | 2026-09-28 | 2026-09-28 | 0d | 2026-09-28 | 2026-09-28 | 175d |  | SRO | PMO,CPT | 5.0 |  | Programme Closure | 778.71 | Green | GREEN |  |  |  |  | MHHS-ART131 |
| 2183 | 1.11.3 | **Programme Closure Report** |  | 40d | 2026-08-03 | 2026-09-25 |  | 2026-08-04 | 2026-09-28 | 40d | 2026-08-04 | 2026-09-28 | 175d |  | N/A | N/A | 5.0 | N/A | Programme Closure |  |  |  |  |  |  |  |  |
| 2184 | 1.11.3.1 | Develop document |  | 20d | 2026-08-03 | 2026-08-28 | 2094FS-45d | 2026-08-04 | 2026-08-31 | 20d | 2026-08-04 | 2026-08-31 | 175d | 0d | PMO | CPT | 5.0 |  | Programme Closure | 725.33 | Green | GREEN |  |  |  |  |  |
| 2185 | 1.11.3.2 | Document review and update |  | 20d | 2026-08-31 | 2026-09-25 | 2184 | 2026-09-01 | 2026-09-28 | 20d | 2026-09-01 | 2026-09-28 | 175d | 0d | Ofgem | PMO,CPT,IPA,SRO | 5.0 |  | Programme Closure | 753.33 | Green | GREEN |  |  |  |  |  |
| 2186 | 1.11.3.3 | Programme Closure Report approved | milestone | 0d | 2026-09-25 | 2026-09-25 | 2185 | 2026-09-28 | 2026-09-28 | 0d | 2026-09-28 | 2026-09-28 | 175d |  | Ofgem | PMO,CPT,IPA,SRO | 5.0 |  | Programme Closure | 778.71 | Green | GREEN |  |  |  |  | MHHS-ART130 |

| ID | WBS | Task | Type | Duration | Start | Finish | Predecessors | Complete | Remaining | Baseline start | Baseline finish | Baseline duration | Baseline 1 start | Baseline 1 finish | Total slack | Free slack | Responsible | Involved | Update Version | MHHS Resource Name | MHHS Programme Phase | Task Status | Sched Status | RAG | Artefact ID | Milestone ID | Text29 | Tier |
| --- | --- | --- | --- | --- | --- | --- | --- | --- | --- | --- | --- | --- | --- | --- | --- | --- | --- | --- | --- | --- | --- | --- | --- | --- | --- | --- | --- | --- |
| 2187 | 1.11.4 | **Benefit Realisation Report** |  | 45d | 2026-08-03 | 2026-10-02 |  |  |  | 2026-08-04 | 2026-10-05 | 45d | 2026-08-04 | 2026-10-05 | 170d |  | N/A | N/A | 5.0 | N/A | Programme Closure |  |  |  |  |  |  |  |
| 2188 | 1.11.4.1 | Develop document |  | 20d | 2026-08-03 | 2026-08-28 | 2094FS-45d |  |  | 2026-08-04 | 2026-08-31 | 20d | 2026-08-04 | 2026-08-31 | 170d | 0d | PMO | CPT | 5.0 |  | Programme Closure | 725.33 | Green | GREEN |  |  |  |  |
| 2189 | 1.11.4.2 | Document review and update |  | 20d | 2026-08-31 | 2026-09-25 | 2188 |  |  | 2026-09-01 | 2026-09-28 | 20d | 2026-09-01 | 2026-09-28 | 170d | 0d | PP | PMO,CPT,IPA,SRO | 5.0 |  | Programme Closure | 753.33 | Green | GREEN |  |  |  |  |
| 2190 | 1.11.4.3 | Benefit Realisation Report approved | milestone | 0d | 2026-10-02 | 2026-10-02 | 2189FS+5d |  |  | 2026-10-05 | 2026-10-05 | 0d | 2026-10-05 | 2026-10-05 | 170d |  | PMO | CPT,PP,IPA,SRO | 5.0 |  | Programme Closure | 785.71 | Green | GREEN | MHHS-ART124 | T3-PC-0010 | PSG | T3 |
| 2191 | 1.11.5 | **Operating Model Gap Review with recommendations** |  | 45d | 2026-08-03 | 2026-10-02 |  |  |  | 2026-08-04 | 2026-10-05 | 45d | 2026-08-04 | 2026-10-05 | 170d |  | N/A | N/A | 5.0 | N/A | Programme Closure |  |  |  |  |  |  |  |
| 2192 | 1.11.5.1 | Develop document |  | 20d | 2026-08-03 | 2026-08-28 | 2094FS-45d |  |  | 2026-08-04 | 2026-08-31 | 20d | 2026-08-04 | 2026-08-31 | 170d | 0d | PMO | CPT | 5.0 |  | Programme Closure | 725.33 | Green | GREEN |  |  |  |  |
| 2193 | 1.11.5.2 | Document review and update |  | 20d | 2026-08-31 | 2026-09-25 | 2192 |  |  | 2026-09-01 | 2026-09-28 | 20d | 2026-09-01 | 2026-09-28 | 170d | 0d | PP | PMO,CPT,IPA,SRO | 5.0 |  | Programme Closure | 753.33 | Green | GREEN |  |  |  |  |
| 2194 | 1.11.5.3 | Operating Model Gap Review with recommendations approved | milestone | 0d | 2026-10-02 | 2026-10-02 | 2193FS+5d |  |  | 2026-10-05 | 2026-10-05 | 0d | 2026-10-05 | 2026-10-05 | 170d |  | Paul Pettitt | CPT,PP,IPA,SRO | 5.0 | Paul Pettitt | Programme Closure | 785.71 | Green | GREEN | MHHS-ART128 | T3-PC-0020 | DAG | T3 |
| 2195 | 1.11.6 | **Post-Implementation Review** |  | 45d | 2026-08-03 | 2026-10-02 |  |  |  | 2026-08-04 | 2026-10-05 | 45d | 2026-08-04 | 2026-10-05 | 170d |  | N/A | N/A | 5.0 | N/A | Programme Closure |  |  |  |  |  |  |  |
| 2196 | 1.11.6.1 | Develop document |  | 20d | 2026-08-03 | 2026-08-28 | 2094FS-45d |  |  | 2026-08-04 | 2026-08-31 | 20d | 2026-08-04 | 2026-08-31 | 170d | 0d | PMO | CPT | 5.0 |  | Programme Closure | 725.33 | Green | GREEN |  |  |  |  |
| 2197 | 1.11.6.2 | Document review and update |  | 20d | 2026-08-31 | 2026-09-25 | 2196 |  |  | 2026-09-01 | 2026-09-28 | 20d | 2026-09-01 | 2026-09-28 | 170d | 0d | PP | PMO,CPT,IPA,SRO | 5.0 |  | Programme Closure | 753.33 | Green | GREEN |  |  |  |  |
| 2198 | 1.11.6.3 | Post-Implementation Review approved | milestone | 0d | 2026-10-02 | 2026-10-02 | 2197FS+5d |  |  | 2026-10-05 | 2026-10-05 | 0d | 2026-10-05 | 2026-10-05 | 170d |  | PMO | CPT,PP,IPA,SRO | 5.0 |  | Programme Closure | 785.71 | Green | GREEN | MHHS-ART129 | T3-PC-0030 | PSG | T3 |
| 2199 | 1.11.7 | **Reinforcement Guide** |  | 45d | 2026-08-03 | 2026-10-02 |  |  |  | 2026-08-04 | 2026-10-05 | 45d | 2026-08-04 | 2026-10-05 | 170d |  | N/A | N/A | 5.0 | N/A | Programme Closure |  |  |  |  |  |  |  |
| 2200 | 1.11.7.1 | Develop document |  | 20d | 2026-08-03 | 2026-08-28 | 2094FS-45d |  |  | 2026-08-04 | 2026-08-31 | 20d | 2026-08-04 | 2026-08-31 | 170d | 0d | PMO | CPT | 5.0 |  | Programme Closure | 725.33 | Green | GREEN |  |  |  |  |
| 2201 | 1.11.7.2 | Document review and update |  | 20d | 2026-08-31 | 2026-09-25 | 2200 |  |  | 2026-09-01 | 2026-09-28 | 20d | 2026-09-01 | 2026-09-28 | 170d | 0d | PP | PMO,CPT,IPA,SRO | 5.0 |  | Programme Closure | 753.33 | Green | GREEN |  |  |  |  |
| 2202 | 1.11.7.3 | Reinforcement Guide approved | milestone | 0d | 2026-10-02 | 2026-10-02 | 2201FS+5d |  |  | 2026-10-05 | 2026-10-05 | 0d | 2026-10-05 | 2026-10-05 | 170d |  | PMO | CPT,PP,IPA,SRO | 5.0 |  | Programme Closure | 785.71 | Green | GREEN | MHHS-ART133 | T3-PC-0040 | PSG | T3 |
| 2203 | 1.11.8 | **Material and Licenses Transfer** |  | 60d | 2026-09-08 | 2026-11-30 |  |  |  | 2026-09-08 | 2026-11-30 | 60d | 2026-09-08 | 2026-11-30 | 129d |  | N/A | N/A | 5.0 | N/A | Programme Closure |  |  |  |  |  |  |  |
| 2204 | 1.11.8.1 | Transfer of Programme material to Elexon and perpetual licenses as appropriate |  | 60d | 2026-09-08 | 2026-11-30 | 2162FF-5d |  |  | 2026-09-08 | 2026-11-30 | 60d | 2026-09-08 | 2026-11-30 | 129d |  | PMO | CPT,PP | 5.0 |  | Programme Closure | 761.33 | Green | GREEN | MHHS-ART139 |  |  |  |
| 2205 | 1.12 | **READINESS ASSESSMENTS** |  | 849d | 2023-09-05 A | 2026-12-04 |  | 23% | 657.29d | 2023-09-05 | 2026-12-04 | 849d | 2023-09-11 | 2026-12-04 | 125d |  | N/A | N/A |  | N/A | Readiness Assessments |  |  |  |  |  |  |  |
| 2206 | 1.12.1 | **Readiness Assessment 3 - Design and Build Progress Check and CP2 Check** |  | 60d | 2023-09-05 A | 2023-11-27 A |  | 100% |  | 2023-09-05 | 2023-11-13 | 50d | 2023-09-11 | 2023-11-17 |  |  | N/A | N/A | 5.5 | N/A | Readiness Assessments | M5,M6 |  |  |  |  |  |  |
| 2207 | 1.12.1.1 | Launch Readiness Assessment survey | milestone | 0d | 2023-09-05 A | 2023-09-05 A | 1001FS-40d | 100% |  | 2023-09-05 | 2023-09-05 | 0d | 2023-09-11 | 2023-09-11 |  |  | PPC |  | 5.5 | PPC | Readiness Assessments |  | Complete | COMPLETE |  |  |  |  |
| 2208 | 1.12.1.2 | PPs submit survey responses |  | 15d | 2023-09-05 A | 2023-09-25 A | 2207 | 100% |  | 2023-09-05 | 2023-09-25 | 15d | 2023-09-11 | 2023-09-29 |  |  | PP | PPC | 5.5 | PPC | Readiness Assessments |  | Complete | COMPLETE |  |  |  |  |
| 2209 | 1.12.1.3 | Analyse survey responses |  | 15d | 2023-09-26 A | 2023-10-16 A | 2208 | 100% |  | 2023-09-26 | 2023-10-16 | 15d | 2023-10-02 | 2023-10-20 |  |  | PPC | CPT | 5.5 | PPC | Readiness Assessments |  | Complete | COMPLETE |  |  |  |  |
| 2210 | 1.12.1.4 | Conduct deep-dive interviews (sample of PPs) |  | 15d | 2023-09-26 A | 2023-10-16 A | 2208 | 100% |  | 2023-09-26 | 2023-10-16 | 15d | 2023-10-02 | 2023-10-20 |  |  | PPC | CPT | 5.5 | PPC | Readiness Assessments |  | Complete | COMPLETE |  |  |  |  |
| 2211 | 1.12.1.5 | Produce Readiness Assessment Reports (Overall Report & Individual Participant Reports) |  | 25d | 2023-10-17 A | 2023-11-20 A | 2209, 2210 | 100% |  | 2023-10-17 | 2023-11-06 | 15d | 2023-10-23 | 2023-11-10 |  |  | PPC |  | 5.5 | PPC | Readiness Assessments |  | Complete | COMPLETE |  |  |  |  |
| 2212 | 1.12.1.6 | Readiness Assessment 3 - Design & Build Checkpoint 1 - Completed (incl. Readiness Assessment Report approval) | milestone | 0d | 2023-11-27 A | 2023-11-27 A | 2211FS+5d | 100% |  | 2023-11-13 | 2023-11-13 | 0d | 2023-11-17 | 2023-11-17 |  |  | CPT | PPC | 5.13 | PPC | Readiness Assessments |  | Complete | COMPLETE |  | T2-RA-0200 | PSG | T2 |

Notes:
- 2194: Action: 5/2 - PP said ask MB if belonged to him. MB says doesn't sit with him
- 2210: 16/11- FD confirmed activity didn't take place for RA3 because responses did not warrant follow-up
- 2212: 16/11-RA3 outputs and initial findings shared with PSG to support M9 decision making. Individual reports and final closure report being finalised. No impact to Programme timelines or activities

| ID | WBS | Task | Type | Duration | Start | Finish | Predecessors | Baseline start | Baseline finish | Baseline duration | Baseline 1 start | Baseline 1 finish | Total slack | Free slack | Constraint | Responsible | Involved | Text3 | Task Status | Update Version | MHHS Resource Name | MHHS Programme Phase | Sched Status | RAG | Milestone ID | Text29 | Tier |
| --- | --- | --- | --- | --- | --- | --- | --- | --- | --- | --- | --- | --- | --- | --- | --- | --- | --- | --- | --- | --- | --- | --- | --- | --- | --- | --- | --- |
| 2213 | 1.12.2 | **Readiness Assessment 5 / 6 - Start of Qualification and Participant Readiness for M10 and M11 and CP3/CP4 check** |  | 47d | 2024-11-12 | 2025-01-15 |  | 2024-11-12 | 2025-01-17 | 49d | 2024-11-12 | 2025-01-17 | 0d |  |  | N/A | N/A | D25 - RA6 Readiness Report | M11 | 5.0 | N/A | Readiness Assessments |  |  |  |  |  |
| 2214 | 1.12.2.1 | Launch Readiness Assessment survey | milestone | 0d | 2024-11-12 | 2024-11-12 |  | 2024-11-12 | 2024-11-12 | 0d | 2024-11-12 | 2024-11-12 | 0d |  | must start on 2024-11-12 | PPC |  |  | 96.33 | 5.0 | PPC | Readiness Assessments | Green | GREEN |  |  |  |
| 2215 | 1.12.2.2 | PPs submit survey responses |  | 15d | 2024-11-12 | 2024-12-02 | 2214 | 2024-11-12 | 2024-12-02 | 15d | 2024-11-12 | 2024-12-02 | 617d | 0d |  | PP | PPC |  | 96.33 | 5.0 | PPC | Readiness Assessments | Green | GREEN |  |  |  |
| 2216 | 1.12.2.3 | Analyse survey responses |  | 15d | 2024-12-03 | 2024-12-23 | 2215 | 2024-12-03 | 2024-12-23 | 15d | 2024-12-03 | 2024-12-23 | 617d | 0d |  | PPC | CPT |  | 117.33 | 5.0 | PPC | Readiness Assessments | Green | GREEN |  |  |  |
| 2217 | 1.12.2.4 | Conduct deep-dive interviews (sample of PPs) |  | 15d | 2024-12-03 | 2024-12-23 | 2215 | 2024-12-03 | 2024-12-23 | 15d | 2024-12-03 | 2024-12-23 | 617d | 0d |  | PPC | CPT |  | 117.33 | 5.0 | PPC | Readiness Assessments | Green | GREEN |  |  |  |
| 2218 | 1.12.2.5 | Produce Readiness Assessment Reports (Overall Report & Individual Participant Reports) |  | 15d | 2024-12-24 | 2025-01-13 | 2216, 2217 | 2024-12-24 | 2025-01-13 | 15d | 2024-12-24 | 2025-01-13 | 617d | 0d |  | PPC |  |  | 138.33 | 5.0 | PPC | Readiness Assessments | Green | GREEN |  |  |  |
| 2219 | 1.12.2.6 | Readiness Assessment 5 / 6 - Start of Qualification and Participant Readiness for M10 and M11 and CP3/CP4 check (incl. Readiness Assessment Report approval) Completed | milestone | 0d | 2025-01-15 | 2025-01-15 | 2218FS+2d | 2025-01-17 | 2025-01-17 | 0d | 2025-01-17 | 2025-01-17 | 617d |  |  | CPT | PPC |  | 160.71 | 5.18 | PPC | Readiness Assessments | Green | GREEN | T2-RA-0400 | PSG | T2 |
| 2220 | 1.12.3 | **Readiness Assessment 7 - Migration Checkpoint** |  | 49d | 2025-08-04 | 2025-10-09 |  | 2025-08-04 | 2025-10-09 | 49d | 2025-08-04 | 2025-10-09 | 0d |  |  | N/A | N/A | D29 - RA8 Readiness Report | M14 | 5.0 | N/A | Readiness Assessments |  |  |  |  |  |
| 2221 | 1.12.3.1 | Launch Readiness Assessment survey | milestone | 0d | 2025-08-04 | 2025-08-04 |  | 2025-08-04 | 2025-08-04 | 0d | 2025-08-04 | 2025-08-04 | 0d |  | must start on 2025-08-04 | PPC |  |  | 361.33 | 5.0 | PPC | Readiness Assessments | Green | GREEN |  |  |  |
| 2222 | 1.12.3.2 | PPs submit survey responses |  | 15d | 2025-08-04 | 2025-08-22 | 2221 | 2025-08-04 | 2025-08-22 | 15d | 2025-08-04 | 2025-08-22 | 426d | 0d |  | PP | PPC |  | 361.33 | 5.0 | PPC | Readiness Assessments | Green | GREEN |  |  |  |
| 2223 | 1.12.3.3 | Analyse survey responses |  | 15d | 2025-08-25 | 2025-09-12 | 2222 | 2025-08-25 | 2025-09-12 | 15d | 2025-08-25 | 2025-09-12 | 426d | 0d |  | PPC | CPT |  | 382.33 | 5.0 | PPC | Readiness Assessments | Green | GREEN |  |  |  |
| 2224 | 1.12.3.4 | Conduct deep-dive interviews (sample of PPs) |  | 15d | 2025-08-25 | 2025-09-12 | 2222 | 2025-08-25 | 2025-09-12 | 15d | 2025-08-25 | 2025-09-12 | 426d | 0d |  | PPC | CPT |  | 382.33 | 5.0 | PPC | Readiness Assessments | Green | GREEN |  |  |  |
| 2225 | 1.12.3.5 | Produce Readiness Assessment Reports (Overall Report & Individual Participant Reports) |  | 15d | 2025-09-15 | 2025-10-03 | 2223, 2224 | 2025-09-15 | 2025-10-03 | 15d | 2025-09-15 | 2025-10-03 | 426d | 0d |  | PPC |  |  | 403.33 | 5.0 | PPC | Readiness Assessments | Green | GREEN |  |  |  |
| 2226 | 1.12.3.6 | Readiness Assessment 7 - Migration Checkpoint - Completed (incl. Readiness Assessment Report approval) | milestone | 0d | 2025-10-09 | 2025-10-09 | 2225FS+4d | 2025-10-09 | 2025-10-09 | 0d | 2025-10-09 | 2025-10-09 | 426d |  |  | CPT | PPC |  | 427.71 | 5.0 | PPC | Readiness Assessments | Green | GREEN | T2-RA-0600 | PSG | T2 |
| 2227 | 1.12.4 | **Readiness Assessment 8 - Ready to Accept New MPANs** |  | 49d | 2026-01-02 | 2026-03-11 |  | 2026-01-06 | 2026-03-13 | 49d | 2026-01-06 | 2026-03-13 | 317d |  |  | N/A | N/A | D29 - RA8 Readiness Report | M14 | 5.0 | N/A | Readiness Assessments |  |  |  |  |  |
| 2228 | 1.12.4.1 | Launch Readiness Assessment survey | milestone | 0d | 2026-01-02 | 2026-01-02 | 2092FS-50d | 2026-01-06 | 2026-01-06 | 0d | 2026-01-06 | 2026-01-06 | 317d | 0d |  | PPC |  |  | 512.33 | 5.0 | PPC | Readiness Assessments | Green | GREEN |  |  |  |
| 2229 | 1.12.4.2 | PPs submit survey responses |  | 15d | 2026-01-02 | 2026-01-22 | 2228 | 2026-01-06 | 2026-01-26 | 15d | 2026-01-06 | 2026-01-26 | 317d | 0d |  | PP | PPC |  | 512.33 | 5.0 | PPC | Readiness Assessments | Green | GREEN |  |  |  |
| 2230 | 1.12.4.3 | Analyse survey responses |  | 15d | 2026-01-23 | 2026-02-12 | 2229 | 2026-01-27 | 2026-02-16 | 15d | 2026-01-27 | 2026-02-16 | 317d | 0d |  | PPC | CPT |  | 533.33 | 5.0 | PPC | Readiness Assessments | Green | GREEN |  |  |  |
| 2231 | 1.12.4.4 | Conduct deep-dive interviews (sample of PPs) |  | 15d | 2026-01-23 | 2026-02-12 | 2229 | 2026-01-27 | 2026-02-16 | 15d | 2026-01-27 | 2026-02-16 | 317d | 0d |  | PPC | CPT |  | 533.33 | 5.0 | PPC | Readiness Assessments | Green | GREEN |  |  |  |
| 2232 | 1.12.4.5 | Produce Readiness Assessment Reports (Overall Report & Individual Participant Reports) |  | 15d | 2026-02-13 | 2026-03-05 | 2230, 2231 | 2026-02-17 | 2026-03-09 | 15d | 2026-02-17 | 2026-03-09 | 317d | 0d |  | PPC |  |  | 554.33 | 5.0 | PPC | Readiness Assessments | Green | GREEN |  |  |  |
| 2233 | 1.12.4.6 | Readiness Assessment 8 - Ready to Accept New MPANs - Completed (incl. Readiness Assessment Report approval) | milestone | 0d | 2026-03-11 | 2026-03-11 | 2232FS+4d | 2026-03-13 | 2026-03-13 | 0d | 2026-03-13 | 2026-03-13 | 317d |  |  | CPT | PPC |  | 580.71 | 5.0 | PPC | Readiness Assessments | Green | GREEN | T2-RA-0700 | PSG | T2 |
| 2234 | 1.12.5 | **Readiness Assessment 9 - Ready for New Settlement Timetable and CP5 Check** |  | 49d | 2026-09-29 | 2026-12-04 |  | 2026-09-29 | 2026-12-04 | 49d | 2026-09-29 | 2026-12-04 | 125d |  |  | N/A | N/A | D32 - RA10 Readiness Report | M16 | 5.0 | N/A | Readiness Assessments |  |  |  |  |  |
| 2235 | 1.12.5.1 | Launch Readiness Assessment survey | milestone | 0d | 2026-09-29 | 2026-09-29 | 2162FS-50d | 2026-09-29 | 2026-09-29 | 0d | 2026-09-29 | 2026-09-29 | 125d | 0d |  | PPC |  |  | 782.33 | 5.0 | PPC | Readiness Assessments | Green | GREEN |  |  |  |
| 2236 | 1.12.5.2 | PPs submit survey responses |  | 15d | 2026-09-29 | 2026-10-19 | 2235 | 2026-09-29 | 2026-10-19 | 15d | 2026-09-29 | 2026-10-19 | 125d | 0d |  | PP | PPC |  | 782.33 | 5.0 | PPC | Readiness Assessments | Green | GREEN |  |  |  |
| 2237 | 1.12.5.3 | Analyse survey responses |  | 15d | 2026-10-20 | 2026-11-09 | 2236 | 2026-10-20 | 2026-11-09 | 15d | 2026-10-20 | 2026-11-09 | 125d | 0d |  | PPC | CPT |  | 803.33 | 5.0 | PPC | Readiness Assessments | Green | GREEN |  |  |  |
| 2238 | 1.12.5.4 | Conduct deep-dive interviews (sample of PPs) |  | 15d | 2026-10-20 | 2026-11-09 | 2236 | 2026-10-20 | 2026-11-09 | 15d | 2026-10-20 | 2026-11-09 | 125d | 0d |  | PPC | CPT |  | 803.33 | 5.0 | PPC | Readiness Assessments | Green | GREEN |  |  |  |
| 2239 | 1.12.5.5 | Produce Readiness Assessment Reports (Overall Report & Individual Participant Reports) |  | 15d | 2026-11-10 | 2026-11-30 | 2237, 2238 | 2026-11-10 | 2026-11-30 | 15d | 2026-11-10 | 2026-11-30 | 125d | 0d |  | PPC |  |  | 824.33 | 5.0 | PPC | Readiness Assessments | Green | GREEN |  |  |  |
| 2240 | 1.12.5.6 | Readiness Assessment 9 - Readiness for New Settlement Timetable - Completed (incl. Readiness Assessment Report approval) | milestone | 0d | 2026-12-04 | 2026-12-04 | 2239FS+4d | 2026-12-04 | 2026-12-04 | 0d | 2026-12-04 | 2026-12-04 | 125d |  |  | CPT | PPC |  | 848.71 | 5.0 | PPC | Readiness Assessments | Green | GREEN | T2-RA-0800 | PSG | T2 |

Notes:
- 2219: 08/02/2024 Name change approval at PSG on 07/02/24 from 'Readiness Assessment 5 - Start of Qualification - Completed (incl. Readiness Assessment Report approval)'

| ID | WBS | Task | Type | Duration | Start | Finish | Predecessors | Complete | Remaining | Baseline start | Baseline finish | Baseline duration | Baseline 1 start | Baseline 1 finish | Total slack | Free slack | Constraint | Responsible | Involved | Update Version | MHHS Resource Name | MHHS Programme Phase | Task Status | Sched Status | RAG | Milestone ID | Text29 | Tier | Text3 |
| --- | --- | --- | --- | --- | --- | --- | --- | --- | --- | --- | --- | --- | --- | --- | --- | --- | --- | --- | --- | --- | --- | --- | --- | --- | --- | --- | --- | --- | --- |
| 2241 | 1.12.6 | **Readiness Assessments - Tier 1 Milestones** |  | 435d | 2025-04-04 | 2026-12-04 |  |  |  | 2023-11-13 | 2026-12-04 | 799d | 2023-11-17 | 2026-12-04 | 125d |  |  | N/A | N/A | 5.0 | N/A | Readiness Assessments |  |  |  |  |  |  |  |
| 2242 | 1.12.6.1 | Readiness Assessment 6 - Start of Migration - Completed (incl. Readiness Assessment Report approval) | milestone | 0d | 2025-04-04 | 2025-04-04 |  |  |  | 2025-04-04 | 2025-04-04 | 0d | 2025-04-04 | 2025-04-04 | 560d |  | finish no earlier than 2025-04-04 | CPT | PPC | 5.0 | PPC | Readiness Assessments | 239.71 | Green | GREEN | T2-RA-0500 | PSG | T2 |  |
| 2243 | 1.12.6.2 | Readiness Assessment 7 - Migration Checkpoint - Completed (incl. Readiness Assessment Report approval) | milestone | 0d | 2025-10-09 | 2025-10-09 | 2225FS+4d |  |  | 2025-10-09 | 2025-10-09 | 0d | 2025-10-09 | 2025-10-09 | 426d |  |  | CPT | PPC | 5.0 | PPC | Readiness Assessments | 427.71 | Green | GREEN | T2-RA-0600 | PSG | T2 |  |
| 2244 | 1.12.6.3 | Readiness Assessment 8 - Ready to Accept New MPANs - Completed (incl. Readiness Assessment Report approval) | milestone | 0d | 2026-03-11 | 2026-03-11 | 2232FS+4d |  |  | 2026-03-13 | 2026-03-13 | 0d | 2026-03-13 | 2026-03-13 | 317d |  |  | CPT | PPC | 5.0 | PPC | Readiness Assessments | 580.71 | Green | GREEN | T2-RA-0700 | PSG | T2 |  |
| 2245 | 1.12.6.4 | Readiness Assessment 9 - Readiness for New Settlement Timetable - Completed (incl. Readiness Assessment Report approval) | milestone | 0d | 2026-12-04 | 2026-12-04 | 2239FS+4d |  |  | 2026-12-04 | 2026-12-04 | 0d | 2026-12-04 | 2026-12-04 | 125d |  |  | CPT | PPC | 5.0 | PPC | Readiness Assessments | 848.71 | Green | GREEN | T2-RA-0800 | PSG | T2 |  |
| 2246 | 1.13 | **CONTROL POINTS** |  | 1063d | 2022-11-10 A | 2026-12-07 |  | 51% | 522.49d | 2022-11-10 | 2026-12-07 | 1063d | 2022-11-10 | 2026-12-07 | 124d |  |  | N/A | N/A |  | N/A | Control Points |  |  |  |  |  |  |  |
| 2247 | 1.13.1 | **Control Point 1 - Start of System Design, Build & Test** |  | 20d | 2022-11-10 A | 2022-12-07 A |  | 100% |  | 2022-11-10 | 2022-12-07 | 20d | 2022-11-10 | 2022-12-07 |  |  |  | N/A | N/A | 5.0 | N/A | Control Points |  |  |  |  |  |  |  |
| 2248 | 1.13.1.1 | Control Point 1 Preparation (incl. Control Point Report development and review) |  | 15d | 2022-11-10 A | 2022-11-30 A | 2249SS-20d | 100% |  | 2022-11-10 | 2022-11-30 | 15d | 2022-11-10 | 2022-11-30 |  |  |  | CPT | PMO | 5.0 | PMO | Control Points |  | Complete | COMPLETE |  |  |  |  |
| 2249 | 1.13.1.2 | Control Point 1 - Start of System Design, Build & Test (incl. Control Point Report approval) | milestone | 0d | 2022-12-07 A | 2022-12-07 A |  | 100% |  | 2022-12-07 | 2022-12-07 | 0d | 2022-12-07 | 2022-12-07 |  |  | must finish on 2022-12-07 | CPT | PMO | 5.0 | PMO | Control Points |  | Complete | COMPLETE | T1-CP-1000 | PSG | T1 | D24 - CP2 Approval |
| 2250 | 1.13.2 | **Control Point 2 - Start of Integration & Test** |  | 20d | 2023-10-02 A | 2023-10-30 A |  | 100% |  | 2023-10-03 | 2023-10-30 | 20d | 2023-10-02 | 2023-10-30 |  |  |  | N/A | N/A | 5.0 | N/A | Control Points |  |  |  |  |  |  |  |
| 2251 | 1.13.2.1 | Control Point 2 Preparation (incl. Control Point Report development and review) |  | 15d | 2023-10-02 A | 2023-10-20 A | 2252SS-20d | 100% |  | 2023-10-03 | 2023-10-23 | 15d | 2023-10-02 | 2023-10-20 |  |  |  | CPT | PMO | 5.0 | PMO | Control Points |  | Complete | COMPLETE |  |  |  |  |
| 2252 | 1.13.2.2 | Control Point 2 - Start of Integration & Test (incl. Control Point Report approval) | milestone | 0d | 2023-10-30 A | 2023-10-30 A | 1001 | 100% |  | 2023-10-30 | 2023-10-30 | 0d | 2023-10-30 | 2023-10-30 |  |  |  | CPT | PMO | 5.11 | PMO | Control Points |  | Complete | COMPLETE | T1-CP-2000 | PSG | T1 | D24 - CP2 Approval |
| 2253 | 1.13.3 | **Control Point 3/4 - Readiness for Migration** |  | 20d | 2025-02-28 | 2025-03-27 |  |  |  | 2025-03-03 | 2025-03-28 | 20d | 2025-03-03 | 2025-03-28 | 20d |  |  | N/A | N/A | 5.0 | N/A | Control Points |  |  |  |  |  |  | D26 - CP3 Approval |
| 2254 | 1.13.3.1 | Control Point 3/4 Preparation (incl. Control Point Report development and review) |  | 14d | 2025-02-28 | 2025-03-19 | 2255SS-20d |  |  | 2025-03-03 | 2025-03-20 | 14d | 2025-03-03 | 2025-03-21 | 572d |  |  | CPT | PMO | 5.0 | PMO | Control Points | 204.33 | Green | GREEN |  |  |  |  |
| 2255 | 1.13.3.2 | Control Point 3/4 - Readiness for Migration (incl. Control Point Report approval) | milestone | 0d | 2025-03-27 | 2025-03-27 |  |  |  | 2025-03-28 | 2025-03-28 | 0d | 2025-03-28 | 2025-03-28 | 0d |  | must start on 2025-03-27 | CPT | PMO | 5.0 | PMO | Control Points | 231.71 | Green | GREEN | T1-CP-3000 | PSG | T1 |  |
| 2256 | 1.13.4 | **Control Point 5 - Cut Over to New Settlement Timetable** |  | 20d | 2026-11-10 | 2026-12-07 |  |  |  | 2026-11-10 | 2026-12-07 | 20d | 2026-11-10 | 2026-12-07 | 124d |  |  | N/A | N/A | 5.0 | N/A | Control Points | M16 |  |  |  |  |  | D33 - Control Point 6 Approval |
| 2257 | 1.13.4.1 | Control Point 5 Preparation (incl. Control Point Report development and review) |  | 15d | 2026-11-10 | 2026-11-30 | 2258SS-20d |  |  | 2026-11-10 | 2026-11-30 | 15d | 2026-11-10 | 2026-11-30 | 129d |  |  | CPT | PP | 5.0 | PMO | Control Points | 824.33 | Green | GREEN |  |  |  |  |
| 2258 | 1.13.4.2 | Control Point 5 - Cut Over to New Settlement Timetable (incl. Control Point Report approval) | milestone | 0d | 2026-12-07 | 2026-12-07 | 2162 |  |  | 2026-12-07 | 2026-12-07 | 0d | 2026-12-07 | 2026-12-07 | 124d | 0d |  | CPT | CPT | 5.0 | PMO | Control Points | 851.71 | Green | GREEN | T1-CP-4000 | PSG | T1 | D33 - Control Point 6 Approval |
| 2259 | 1.13.5 | **Control Points - Tier 1 Milestones** |  | 1043d | 2022-12-07 A | 2026-12-07 |  |  | 1043d | 2022-12-07 | 2026-12-07 | 1043d | 2022-12-07 | 2026-12-07 | 124d |  |  | N/A | N/A | 5.0 | N/A | Control Points |  |  |  |  |  |  |  |
| 2260 | 1.13.5.1 | Control Point 1 - Start of System Design, Build & Test (incl. Control Point Report approval) | milestone | 0d | 2022-12-07 A | 2022-12-07 A | 2249SS | 100% |  | 2022-12-07 | 2022-12-07 | 0d | 2022-12-07 | 2022-12-07 |  |  |  | CPT | PMO | 5.0 | PMO | Control Points |  | Complete | COMPLETE | T1-CP-1000 | PSG | T1 |  |
| 2261 | 1.13.5.2 | Control Point 2 - Start of Integration & Test (incl. Control Point Report approval) | milestone | 0d | 2023-10-30 A | 2023-10-30 A | 2252SS | 100% |  | 2023-10-30 | 2023-10-30 | 0d | 2023-10-30 | 2023-10-30 |  |  |  | CPT | PMO | 5.11 | PMO | Control Points |  | Complete | COMPLETE | T1-CP-2000 | PSG | T1 | D24 - CP2 Approval |
| 2262 | 1.13.5.3 | Control Point 3/4 - Readiness for Migration (incl. Control Point Report approval) | milestone | 0d | 2025-03-27 | 2025-03-27 | 2255SS |  |  | 2025-03-28 | 2025-03-28 | 0d | 2025-03-28 | 2025-03-28 | 566d |  |  | CPT | PMO | 5.0 | PMO | Control Points | 231.71 | Green | GREEN | T1-CP-3000 | PSG | T1 |  |
| 2263 | 1.13.5.4 | Control Point 5 - Cut Over to New Settlement Timetable (incl. Control Point Report approval) | milestone | 0d | 2026-12-07 | 2026-12-07 | 2258SS |  |  | 2026-12-07 | 2026-12-07 | 0d | 2026-12-07 | 2026-12-07 | 124d |  |  | CPT | CPT | 5.0 | PMO | Control Points | 851.71 | Green | GREEN | T1-CP-4000 | PSG | T1 | D33 - Control Point 6 Approval |
| 2264 | 1.14 | **MILESTONE RANGE CHECKPOINTS** |  | 436d | 2025-01-13 | 2026-09-15 |  |  |  | 2025-01-13 | 2026-09-15 | 436d | 2025-01-13 | 2026-09-15 | 184d |  |  | N/A | N/A |  | N/A | Milestone Range Checkpoints |  |  |  |  |  |  |  |
| 2265 | 1.14.1 | **M10, M11, M12 and M13 milestone checkpoint** |  | 0d | 2025-01-13 | 2025-01-13 |  |  |  | 2025-01-13 | 2025-01-13 | 0d | 2025-01-13 | 2025-01-13 | 620d |  |  | N/A | N/A | 5.0 | N/A | Milestone Range Checkpoints |  |  |  |  |  |  |  |
| 2266 | 1.14.1.1 | M10, M11, M12, and M13 milestone checkpoint - date approval | milestone | 0d | 2025-01-13 | 2025-01-13 | 2084FS-3mo, 2088FS-3mo, 2090FS-3mo, 2086FS-3mo |  |  | 2025-01-13 | 2025-01-13 | 0d | 2025-01-13 | 2025-01-13 | 620d |  |  | CPT | CPT | 5.0 | PMO | Milestone Range Checkpoints | 158.33 | Green | GREEN | T2-MR-0100 | PSG | T2 |  |

| ID | WBS | Task | Type | Duration | Start | Finish | Predecessors | Baseline start | Baseline finish | Baseline duration | Baseline 1 start | Baseline 1 finish | Total slack | Responsible | Involved | Update Version | MHHS Resource Name | MHHS Programme Phase | Task Status | Sched Status | RAG | Milestone ID | Text29 | Tier |
| --- | --- | --- | --- | --- | --- | --- | --- | --- | --- | --- | --- | --- | --- | --- | --- | --- | --- | --- | --- | --- | --- | --- | --- | --- |
| 2267 | 1.14.2 | **M14 milestone checkpoint** |  | 0d | 2025-12-19 | 2025-12-19 |  | 2025-12-23 | 2025-12-23 | 0d | 2025-12-23 | 2025-12-23 | 376d | N/A | N/A | 5.0 | N/A | Milestone Range Checkpoints |  |  |  |  |  |  |
| 2268 | 1.14.2.1 | M14 milestone checkpoint - date approval | milestone | 0d | 2025-12-19 | 2025-12-19 | 2092FS-3mo | 2025-12-23 | 2025-12-23 | 0d | 2025-12-23 | 2025-12-23 | 376d | CPT | CPT | 5.0 | PMO | Milestone Range Checkpoints | 498.33 | Green | GREEN | T2-MR-0200 | PSG | T2 |
| 2269 | 1.14.3 | **M15 milestone checkpoint** |  | 0d | 2026-07-13 | 2026-07-13 |  | 2026-07-14 | 2026-07-14 | 0d | 2026-07-14 | 2026-07-14 | 230d | N/A | N/A | 5.0 | N/A | Milestone Range Checkpoints |  |  |  |  |  |  |
| 2270 | 1.14.3.1 | M15 milestone checkpoint - date approval | milestone | 0d | 2026-07-13 | 2026-07-13 | 2094FS-3mo | 2026-07-14 | 2026-07-14 | 0d | 2026-07-14 | 2026-07-14 | 230d | CPT | CPT | 5.0 | PMO | Milestone Range Checkpoints | 704.33 | Green | GREEN | T2-MR-0300 | PSG | T2 |
| 2271 | 1.14.4 | **M16 milestone checkpoint** |  | 0d | 2026-09-15 | 2026-09-15 |  | 2026-09-15 | 2026-09-15 | 0d | 2026-09-15 | 2026-09-15 | 184d | N/A | N/A | 5.0 | N/A | Milestone Range Checkpoints |  |  |  |  |  |  |
| 2272 | 1.14.4.1 | M16 milestone checkpoint - date approval | milestone | 0d | 2026-09-15 | 2026-09-15 | 2162FS-3mo | 2026-09-15 | 2026-09-15 | 0d | 2026-09-15 | 2026-09-15 | 184d | CPT | CPT | 5.0 | PMO | Milestone Range Checkpoints | 768.33 | Green | GREEN | T2-MR-0400 | PSG | T2 |
