# Outline ELEXON Plan_kc

Schedule from MS Project, 2022-10-31 to 2027-12-23, status date 2026-10-21, A marks actual dates.

## Calendars

- Standard: Mon-Fri 08:00-12:00, 13:00-17:00; Sat-Sun off.

## Resources

| Resource |
| --- |
| PMO |
| SI |
| PPC |
| Lead Workstream |
| CPT |
| PP |
| SI Design |
| SI Design |
| SI Design |
| Design |
| SI DevOps |
| SI Test |
| PSG |
| DAG |
| TMAG |
| CCAG |
| Code drafters (SRO Design Team |
| Code Bodies) |
| CCAG PM |
| Programme Participants |
| Code drafters |
| CDWG |
| SRO Design Team |
| Code Bodies |
| Ofgem |
| Elexon resources TBC |
| LDP Programme Manager |
| SRO Client Programme Director |
| IPA |
| LDP |
| SRO |
| )) |
| ? |
| TBC |
| OOC |
| MHHSP |
| Adrian Page |
| Amy Clayton |
| Anand Kaveripatna |
| Berlinda Kugara |
| Cesar Lopes |
| Charlie Blanks |
| Chetan Ubale |
| Daniel Callender |
| Daniel Gee |
| David Hollinshead |
| Dean Bailey |
| Dominic Mooney |
| Elayaraja Jeyaraman |
| Georgi Rabotov |
| Giles Clayden |
| Helen Richardson |
| Ishti Bhatti |
| Jafer Shah |
| Jason Brogden |
| John Edmonds Bell |
| John Wiggins |
| Karthikeyan Ganesan |
| Kasimali Hajiyani |
| Kate Goodman |
| Keegan Moodley |
| Keith Clark |
| Keith Lawlor |
| kevin Davis |
| Kishore Konduru |
| Kyle Abraham |
| Mahjabeen Newaz |
| Martin Freeman |
| Matt Hall |
| Matthew Breen |
| Michael Inije |
| Michael Walton |
| Ming Li |
| Nathalia Revlien |
| Nick Sewell |
| Nigel Hunt |
| Oskar Cahill |
| Paul Pettitt |
| Rakhee Shah |
| Rebecca Farooq |
| Renu Rathor |
| Robert Short |
| Robert Topley |
| Saadia Sajjad |
| Sean Tuffy |
| Shaid Hussain |
| Sharmeen Shaikh |
| Simon Berry |
| Steve Bradford |
| Steve Weston |
| Taaran Suri |
| Waseem Mohammed |
| Zak Hussain |
| berli |
| SI Migration |
| v |
| Andrew Margan |
| Lee Cox |
| DIP SP |
| DIPS SP |
| DIPSP |
| Ian Smith |
| N/A |
| SIT Component Integration Testing 2 Preparation Complete (incl. approval of SI SIT Component Integration Test Readiness Report) |
| Nich |
| Nicola Farley |
| Warren Fulton |
| Richard Puddephatt |
| Matthew Bray |
| Programme |
| LDSOs |
| Ben Wickins |
| paul |
| LDSO |
| Simon chidwick |
| Stuart Scott |
| MHHS Programme |
| Claire Silk |
| Laura Kennedy |
| Rowan B |
| FD |
| MB |
| AM |
| Roger Robar |
| Laura Kennedy. |

## Schedule

| ID | WBS | Task | Type | Duration | Start | Finish | Complete | Remaining | Baseline start | Baseline finish | Baseline duration | Baseline 1 start | Baseline 1 finish | Total slack | Constraint | Baseline cost | Responsible | Involved | Update Version | MHHS Resource Name | Sched Status | RAG | Text9 | Task Status | Future RAG |
| --- | --- | --- | --- | --- | --- | --- | --- | --- | --- | --- | --- | --- | --- | --- | --- | --- | --- | --- | --- | --- | --- | --- | --- | --- | --- |
| 1 | 1 | **PROGRAMME PLAN.** |  | 1344d? | 2022-10-31 A | 2027-12-23 | 97% | 40.1d? | 2022-10-31 | 2027-12-23 | 1195d |  |  |  |  | -0 | N/A | N/A | 5.0 | N/A |  |  |  |  |  |
| 2 | 1.1 | MHHS Programme Start | milestone | 0d | 2022-10-31 A | 2022-10-31 A | 100% |  | 2022-10-31 | 2022-10-31 | 0d |  |  |  |  |  | N/A | N/A | 5.7 | N/A | Complete | COMPLETE |  |  |  |
| 3 | 1.2 | **PROGRAMME MANAGEMENT** |  | 1089d | 2022-10-31 A | 2026-12-31 | 95% | 50.36d | 2022-10-31 | 2026-12-31 | 1089d | 2022-10-31 | 2026-12-31 | 255d |  |  | N/A | N/A | 5.0 | N/A |  |  |  |  |  |
| 4 | 1.2.1 | **Programme Management** |  | 1089d | 2022-10-31 A | 2026-12-31 | 95% | 51d | 2022-10-31 | 2026-12-31 | 1089d | 2022-10-31 | 2026-12-31 | 255d |  |  | N/A | N/A | 5.0 | N/A |  |  | Programme Management | M10 |  |
| 5 | 1.2.1.1 | Sprint-based prioritisation planning and execution |  | 1089d | 2022-10-31 A | 2026-12-31 | 95% | 51d | 2022-10-31 | 2026-12-31 | 1089d | 2022-10-31 | 2026-12-31 | 255d | finish no earlier than 2026-12-31 |  | PMO | CPT | 5.0 | N/A | Green | GREEN | Programme Management |  |  |
| 6 | 1.2.1.2 | Programme governance secretariat |  | 1089d | 2022-10-31 A | 2026-12-31 | 95% | 51d | 2022-10-31 | 2026-12-31 | 1089d | 2022-10-31 | 2026-12-31 | 255d |  |  | PMO | CPT | 5.0 | N/A | Green | GREEN | Programme Management |  |  |
| 7 | 1.2.1.3 | RAID management and reporting |  | 1089d | 2022-10-31 A | 2026-12-31 | 95% | 51d | 2022-10-31 | 2026-12-31 | 1089d | 2022-10-31 | 2026-12-31 | 255d |  |  | PMO | CPT | 5.0 | N/A | Green | GREEN | Programme Management |  |  |
| 8 | 1.2.1.4 | Tracking against Programme outcomes and KPIs |  | 1089d | 2022-10-31 A | 2026-12-31 | 95% | 51d | 2022-10-31 | 2026-12-31 | 1089d | 2022-10-31 | 2026-12-31 | 255d |  |  | PMO | CPT | 5.0 | N/A | Green | GREEN | Programme Management |  |  |
| 9 | 1.2.1.5 | Change control and reporting |  | 1089d | 2022-10-31 A | 2026-12-31 | 95% | 51d | 2022-10-31 | 2026-12-31 | 1089d | 2022-10-31 | 2026-12-31 | 255d |  |  | PMO | CPT | 5.0 | N/A | Green | GREEN | Programme Management |  |  |
| 10 | 1.2.1.6 | Ongoing identification of lessons learned relating to the PMO and implementation of improvements |  | 1089d | 2022-10-31 A | 2026-12-31 | 95% | 51d | 2022-10-31 | 2026-12-31 | 1089d | 2022-10-31 | 2026-12-31 | 255d |  |  | PMO | CPT | 5.0 | N/A | Green | GREEN | Programme Management |  |  |
| 11 | 1.2.2 | **Programme Internal Assurance Reviews** |  | 1089d | 2022-10-31 A | 2026-12-31 | 95% | 51d | 2022-10-31 | 2026-12-31 | 1089d | 2022-10-31 | 2026-12-31 | 255d |  |  | N/A | N/A | 5.0 | N/A |  |  | Programme Management | M9 | D18A - Quarterly Assurance Report |
| 12 | 1.2.2.1 | Programme Internal Assurance Reviews |  | 1089d | 2022-10-31 A | 2026-12-31 | 95% | 51d | 2022-10-31 | 2026-12-31 | 1089d | 2022-10-31 | 2026-12-31 | 255d |  |  | CPT | PMO | 5.0 | N/A | Green | GREEN | Programme Management |  | D18A - Quarterly Assurance Report |
| 13 | 1.2.3 | **Engagement with PPs** |  | 1089d | 2022-10-31 A | 2026-12-31 | 95% | 50.76d | 2022-10-31 | 2026-12-31 | 1089d | 2022-10-31 | 2026-12-31 | 255d |  |  | N/A | N/A | 5.0 | N/A |  |  | Programme Management | M5,M6 |  |
| 14 | 1.2.3.1 | Ongoing PP liaison activities |  | 1089d | 2022-10-31 A | 2026-12-31 | 95% | 51d | 2022-10-31 | 2026-12-31 | 1089d | 2022-10-31 | 2026-12-31 | 255d |  |  | PPC | CPT | 5.0 | N/A | Green | GREEN | Programme Management |  |  |
| 15 | 1.2.3.2 | Milestone and Control Point objective setting |  | 1089d | 2022-10-31 A | 2026-12-31 | 95% | 51d | 2022-10-31 | 2026-12-31 | 1089d | 2022-10-31 | 2026-12-31 | 255d |  |  | PPC | CPT | 5.0 | N/A | Green | GREEN | Programme Management |  |  |
| 16 | 1.2.3.3 | Reporting |  | 1089d | 2022-10-31 A | 2026-12-31 | 95% | 51d | 2022-10-31 | 2026-12-31 | 1089d | 2022-10-31 | 2026-12-31 | 255d |  |  | PPC |  | 5.0 | N/A | Green | GREEN | Programme Management |  |  |
| 17 | 1.2.3.4 | **PP Engagement Events** |  | 1089d | 2022-10-31 A | 2026-12-31 | 95% | 51d | 2022-10-31 | 2026-12-31 | 1089d | 2022-10-31 | 2026-12-31 | 255d |  |  | N/A | N/A | 5.0 | N/A |  |  | Programme Management |  |  |
| 18 | 1.2.3.4.1 | Bilateral meetings |  | 1089d | 2022-10-31 A | 2026-12-31 | 95% | 51d | 2022-10-31 | 2026-12-31 | 1089d | 2022-10-31 | 2026-12-31 | 255d |  |  | PPC | CPT | 5.0 | N/A | Green | GREEN | Programme Management |  |  |
| 19 | 1.2.3.4.2 | Monthly webinars |  | 1089d | 2022-10-31 A | 2026-12-31 | 95% | 51d | 2022-10-31 | 2026-12-31 | 1089d | 2022-10-31 | 2026-12-31 | 255d |  |  | PPC | CPT | 5.0 | N/A | Green | GREEN | Programme Management |  |  |
| 20 | 1.2.3.4.3 | Open days |  | 1089d | 2022-10-31 A | 2026-12-31 | 95% | 51d | 2022-10-31 | 2026-12-31 | 1089d | 2022-10-31 | 2026-12-31 | 255d |  |  | PPC | CPT | 5.0 | N/A | Green | GREEN | Programme Management |  |  |
| 21 | 1.2.3.5 | **PP Communications** |  | 1088d | 2022-10-31 A | 2026-12-30 | 95% | 50d | 2022-10-31 | 2026-12-30 | 1088d | 2022-10-31 | 2026-12-30 | 256d |  |  | N/A | N/A | 5.0 | N/A |  |  | Programme Management |  |  |
| 22 | 1.2.3.5.1 | The Clock updates (weekly) |  | 1088d | 2022-10-31 A | 2026-12-30 | 95% | 50d | 2022-10-31 | 2026-12-30 | 1088d | 2022-10-31 | 2026-12-30 | 256d | finish no earlier than 2026-12-30 |  | PPC |  | 5.0 | N/A | Green | GREEN | Programme Management |  |  |
| 23 | 1.2.3.5.2 | Maintain and update content on public-facing Portal (and ongoing feedback reviews to identify and implement Portal improvements) |  | 1088d | 2022-10-31 A | 2026-12-30 | 95% | 50d | 2022-10-31 | 2026-12-30 | 1088d | 2022-10-31 | 2026-12-30 | 256d |  |  | PPC |  | 5.0 | N/A | Green | GREEN | Programme Management |  |  |
| 24 | 1.2.4 | **Code Change Support / Other Programme Alignment** |  | 1089d | 2022-10-31 A | 2026-12-31 | 95% | 51d | 2022-10-31 | 2026-12-31 | 1089d | 2022-10-31 | 2026-12-31 | 255d |  |  | N/A | N/A | 5.0 | N/A |  |  | Programme Management | M6 | D17 - Code Change Report & Recommendations |
| 25 | 1.2.4.1 | Support DCC/BEIS on SEC change |  | 1089d | 2022-10-31 A | 2026-12-31 | 95% | 51d | 2022-10-31 | 2026-12-31 | 1089d | 2022-10-31 | 2026-12-31 | 255d |  |  | CPT |  | 5.0 | N/A | Green | GREEN | Programme Management |  |  |
| 26 | 1.2.4.2 | Support on Smart Meters Act changes |  | 1089d | 2022-10-31 A | 2026-12-31 | 95% | 51d | 2022-10-31 | 2026-12-31 | 1089d | 2022-10-31 | 2026-12-31 | 255d |  |  | CPT |  | 5.0 | N/A | Green | GREEN | Programme Management |  |  |
| 27 | 1.2.4.3 | Support DCC/RECCo on CSS change |  | 1089d | 2022-10-31 A | 2026-12-31 | 95% | 51d | 2022-10-31 | 2026-12-31 | 1089d | 2022-10-31 | 2026-12-31 | 255d |  |  | CPT |  | 5.0 | N/A | Green | GREEN | Programme Management |  |  |
| 28 | 1.2.4.4 | Support Elexon on BSC change |  | 1089d | 2022-10-31 A | 2026-12-31 | 95% | 51d | 2022-10-31 | 2026-12-31 | 1089d | 2022-10-31 | 2026-12-31 | 255d |  |  | CPT |  | 5.0 | N/A | Green | GREEN | Programme Management |  |  |
| 29 | 1.2.4.5 | Support code change inside & outside CCIAG |  | 1089d | 2022-10-31 A | 2026-12-31 | 95% | 51d | 2022-10-31 | 2026-12-31 | 1089d | 2022-10-31 | 2026-12-31 | 255d |  |  | CPT |  | 5.0 | N/A | Green | GREEN | Programme Management |  |  |
| 30 | 1.2.4.6 | Support code change inside & outside CCAG |  | 1089d | 2022-10-31 A | 2026-12-31 | 95% | 51d | 2022-10-31 | 2026-12-31 | 1089d | 2022-10-31 | 2026-12-31 | 255d |  |  | CPT |  | 5.0 | N/A | Green | GREEN | Programme Management |  |  |

| ID | WBS | Task | Type | Duration | Start | Finish | Predecessors | Complete | Remaining | Baseline start | Baseline finish | Baseline duration | Baseline 1 start | Baseline 1 finish | Total slack | Constraint | Baseline cost | Responsible | Involved | Text9 | Task Status | Update Version | MHHS Resource Name | Sched Status | RAG | Future RAG | MHHS Programme Phase | Text29 | Artefact ID | Milestone ID | Tier |
| --- | --- | --- | --- | --- | --- | --- | --- | --- | --- | --- | --- | --- | --- | --- | --- | --- | --- | --- | --- | --- | --- | --- | --- | --- | --- | --- | --- | --- | --- | --- | --- |
| 31 | 1.2.5 | **Programme Replan Baseline** |  | 163d | 2022-10-31 A | 2023-06-14 A |  | 100% |  | 2022-10-31 | 2023-06-14 | 163d | 2022-10-31 | 2023-06-14 |  |  |  | N/A | N/A | Programme Management | M5+ | 5.0 | N/A |  |  |  |  |  |  |  |  |
| 32 | 1.2.5.1 | Round 3 consultation preparation |  | 32d | 2022-10-31 A | 2022-12-13 A |  | 100% |  | 2022-10-31 | 2022-12-13 | 32d | 2022-10-31 | 2022-12-13 |  |  |  | PMO | CPT | Programme Management |  | 5.0 | N/A | Complete | COMPLETE |  |  |  |  |  |  |
| 33 | 1.2.5.2 | PSG decision to launch Round 3 consultation | milestone | 0d | 2022-12-07 A | 2022-12-07 A | 32FS-5d | 100% |  | 2022-12-07 | 2022-12-07 | 0d | 2022-12-07 | 2022-12-07 |  |  |  | PMO | PPC | Programme Management |  | 5.0 | N/A | Complete | COMPLETE |  |  |  |  |  |  |
| 34 | 1.2.5.3 | Round 3 consultation (incl. walkthroughs and Q&A) |  | 35d | 2022-12-14 A | 2023-01-31 A | 33FS+5d | 100% |  | 2022-12-14 | 2023-01-31 | 35d | 2022-12-14 | 2023-01-31 |  |  |  | PP | PMO, PPC,IPA | Programme Management |  | 5.0 | N/A | Complete | COMPLETE |  |  |  |  |  |  |
| 35 | 1.2.5.4 | Review and uplift of foundational testing documents to align with replan approach |  | 92d | 2022-12-14 A | 2023-04-20 A | 34SS | 100% |  | 2022-12-14 | 2023-04-20 | 92d | 2022-12-14 | 2023-04-20 |  |  |  | SI Test | CPT | Programme Management |  | 5.0 | N/A | Complete | COMPLETE |  |  |  |  |  |  |
| 36 | 1.2.5.5 | Round 3 consultation responses analysis (incl. identification of SIT volunteers) |  | 10d | 2023-02-01 A | 2023-02-14 A | 34 | 100% |  | 2023-02-01 | 2023-02-14 | 10d | 2023-02-01 | 2023-02-14 |  |  |  | PMO | CPT | Programme Management |  | 5.0 | N/A | Complete | COMPLETE |  |  |  |  |  |  |
| 37 | 1.2.5.6 | Replan re-drafting and supporting artefact updates (incl. engagement with Ofgem) |  | 26d | 2023-02-15 A | 2023-03-22 A | 36 | 100% |  | 2023-02-15 | 2023-03-22 | 26d | 2023-02-15 | 2023-03-22 |  |  |  | PMO | CPT,IPA,Ofgem | Programme Management |  | 5.0 | N/A | Complete | COMPLETE |  |  |  |  |  |  |
| 38 | 1.2.5.7 | Draft Replan Change Request |  | 31d | 2023-02-15 A | 2023-03-29 A | 36 | 100% |  | 2023-02-15 | 2023-03-29 | 31d | 2023-02-15 | 2023-03-29 |  |  |  | PMO | CPT | Programme Management |  | 5.0 | N/A | Complete | COMPLETE |  |  |  |  |  |  |
| 39 | 1.2.5.8 | PSG decision to issue CR for industry impact assessment | milestone | 0d | 2023-04-05 A | 2023-04-05 A | 38FS+5d | 100% |  | 2023-04-05 | 2023-04-05 | 0d | 2023-04-05 | 2023-04-05 |  |  |  | PMO | CPT | Programme Management |  | 5.0 | N/A | Complete | COMPLETE |  |  |  |  |  |  |
| 40 | 1.2.5.9 | Industry impact assessment |  | 10d | 2023-04-06 A | 2023-04-19 A | 39 | 100% |  | 2023-04-06 | 2023-04-19 | 10d | 2023-04-06 | 2023-04-19 |  |  |  | PP | PMO,PPC | Programme Management |  | 5.0 | N/A | Complete | COMPLETE |  |  |  |  |  |  |
| 41 | 1.2.5.10 | Replan playbacks (to assist PPs in impact assessment) |  | 5d | 2023-04-11 A | 2023-04-17 A | 40SS+3d | 100% |  | 2023-04-11 | 2023-04-17 | 5d | 2023-04-11 | 2023-04-17 |  |  |  | CPT | PPC,PP | Programme Management |  | 5.0 | N/A | Complete | COMPLETE |  |  |  |  |  |  |
| 42 | 1.2.5.11 | Industry impact assessment responses analysis |  | 5d | 2023-04-20 A | 2023-04-26 A | 40 | 100% |  | 2023-04-20 | 2023-04-26 | 5d | 2023-04-20 | 2023-04-26 |  |  |  | PMO | CPT | Programme Management |  | 5.0 | N/A | Complete | COMPLETE |  |  |  |  |  |  |
| 43 | 1.2.5.12 | Extraordinary PSG decision to agree baseline recommendation | milestone | 0d | 2023-05-03 A | 2023-05-03 A | 42FS+5d | 100% |  | 2023-05-03 | 2023-05-03 | 0d | 2023-05-03 | 2023-05-03 |  |  |  | CPT | PMO,PP | Programme Management |  | 5.0 | N/A | Complete | COMPLETE |  |  |  |  |  |  |
| 44 | 1.2.5.13 | Programme Replan playbacks and drop-in sessions |  | 5d | 2023-06-08 A | 2023-06-14 A |  | 100% |  | 2023-06-08 | 2023-06-14 | 5d | 2023-06-08 | 2023-06-14 |  |  |  | PMO | PPC, PP | Programme Management |  | 5.0 | N/A | Complete | COMPLETE |  |  |  |  |  |  |
| 45 | 1.3 | **DESIGN, BUILD & TEST (PIT)** |  | 1101d? | 2022-10-31 A | 2027-01-18 |  | 99% | 7.46d? | 2022-10-31 | 2027-07-05 | 1101d | 2022-10-31 | 2027-01-18 | 243d |  | -0 | N/A | N/A | DBT |  |  | N/A |  |  | 1 May 2022 - 31 Jul 2023 | Design, Build & Test (PIT) | DAG |  |  |  |
| 46 | 1.3.1 | **Design Baseline & Enduring PP Support** |  | 1101d | 2022-10-31 A | 2027-01-18 |  | 97% | 29.71d | 2022-10-31 | 2027-01-18 | 1101d | 2022-10-31 | 2027-01-18 | 243d |  | -0 | N/A | N/A | DBT |  | 5.0 | N/A |  |  |  | Design, Build & Test (PIT) |  |  |  |  |
| 47 | 1.3.1.1 | Physical design baselined (M5) | milestone | 0d | 2022-10-31 A | 2022-10-31 A |  | 100% |  | 2022-10-31 | 2022-10-31 | 0d | 2022-10-31 | 2022-10-31 |  |  |  | SRO Design | SI Design,PP,IPA | DBT |  | 5.0 | Paul Pettitt | Complete | COMPLETE |  | Design, Build & Test (PIT) | PSG | MHHS-ART001 | T1-DB-1000 | T1 |
| 48 | 1.3.1.2 | **M5 Design Work-Off Plan Implementation & Approval** |  | 79d | 2022-10-31 A | 2023-02-16 A |  | 100% |  | 2022-10-31 | 2023-02-16 | 79d | 2022-10-31 | 2023-02-16 |  |  |  | N/A | N/A | DBT |  | 5.0 | N/A |  |  |  | Design, Build & Test (PIT) |  |  |  |  |
| 49 | 1.3.1.2.1 | Implementation of M5 design Work-Off Plan |  | 74d | 2022-10-31 A | 2023-02-09 A | 47 | 100% |  | 2022-10-31 | 2023-02-09 | 74d | 2022-10-31 | 2023-02-09 |  |  |  | SI Design | PP | DBT |  | 5.0 | Paul Pettitt | Complete | COMPLETE |  | Design, Build & Test (PIT) |  |  |  |  |
| 50 | 1.3.1.2.2 | M5 design Work-Off Plan completion approved | milestone | 0d | 2023-02-16 A | 2023-02-16 A | 49FS+5d | 100% |  | 2023-02-16 | 2023-02-16 | 0d | 2023-02-16 | 2023-02-16 |  |  |  | SI Design | PP | DBT |  | 5.0 | Paul Pettitt | Complete | COMPLETE |  | Design, Build & Test (PIT) | DAG |  | T3-DB-0014 | T3 |
| 51 | 1.3.1.3 | **Enduring PP Design Support** |  | 1089d | 2022-10-31 A | 2026-12-31 A |  | 100% |  | 2022-10-31 | 2026-12-31 | 1089d | 2022-10-31 | 2026-12-31 |  |  |  | N/A | N/A | DBT |  | 5.0 | N/A |  |  |  | Design, Build & Test (PIT) |  |  |  |  |
| 52 | 1.3.1.3.1 | Design playbacks and drop-in sessions |  | 45d | 2022-10-31 A | 2022-12-30 A | 47 | 100% |  | 2022-10-31 | 2022-12-30 | 45d | 2022-10-31 | 2022-12-30 |  |  |  | SI Design | PMO,PPC, SRO Design | DBT |  | 5.0 | Paul Pettitt | Complete | COMPLETE |  | Design, Build & Test (PIT) |  |  |  |  |
| 53 | 1.3.1.3.2 | Support participants on E2E MHHS Design |  | 1089d | 2022-10-31 A | 2026-12-31 A | 47 | 100% |  | 2022-10-31 | 2026-12-31 | 1089d | 2022-10-31 | 2026-12-31 |  |  |  | SI Design | PP | DBT |  | 5.0 | Paul Pettitt | Complete | COMPLETE |  | Design, Build & Test (PIT) |  |  |  |  |
| 54 | 1.3.1.3.3 | DIP Onboarding Support |  | 70d | 2022-11-14 A | 2023-02-17 A |  | 100% |  | 2022-11-14 | 2023-02-17 | 70d | 2022-11-14 | 2023-02-17 |  | must start on 2022-11-14 |  | SI Design | SRO Design | DBT |  | 5.0 | Paul Pettitt | Complete | COMPLETE |  | Design, Build & Test (PIT) |  |  |  |  |
| 55 | 1.3.1.3.4 | iServer Launch | milestone | 0d | 2023-02-16 A | 2023-02-16 A | 50 | 100% |  | 2023-02-16 | 2023-02-16 | 0d | 2023-02-16 | 2023-02-16 |  |  |  | SI Design | PP | DBT |  | 5.0 | Paul Pettitt | Complete | COMPLETE |  | Design, Build & Test (PIT) |  |  |  |  |

| ID | WBS | Task | Type | Duration | Start | Finish | Predecessors | Complete | Remaining | Baseline start | Baseline finish | Baseline duration | Baseline 1 start | Baseline 1 finish | Total slack | Constraint | Baseline cost | Responsible | Involved | Text9 | Update Version | MHHS Resource Name | MHHS Programme Phase | Sched Status | RAG | Milestone ID | Text29 | Tier |
| --- | --- | --- | --- | --- | --- | --- | --- | --- | --- | --- | --- | --- | --- | --- | --- | --- | --- | --- | --- | --- | --- | --- | --- | --- | --- | --- | --- | --- |
| 56 | 1.3.1.4 | **Establish Design Change Management Processes** |  | 1101d | 2022-10-31 A | 2027-01-18 |  | 94% | 65.62d | 2022-10-31 | 2027-01-18 | 1101d | 2022-10-31 | 2027-01-18 | 243d |  |  | N/A | N/A | DBT | 5.0 | N/A | Design, Build & Test (PIT) |  |  |  |  |  |
| 57 | 1.3.1.4.1 | Internal review of internal change management processes |  | 35d | 2022-10-31 A | 2022-12-16 A |  | 100% |  | 2022-10-31 | 2022-12-16 | 35d | 2022-10-31 | 2022-12-16 |  |  |  | SRO | SI Design | DBT | 5.0 | Paul Pettitt | Design, Build & Test (PIT) | Complete | COMPLETE |  |  |  |
| 58 | 1.3.1.4.2 | SRO approval of internal change management processes | milestone | 0d | 2022-12-16 A | 2022-12-16 A | 57FF | 100% |  | 2022-12-16 | 2022-12-16 | 0d | 2022-12-16 | 2022-12-16 |  |  |  | SRO | SI Design | DBT | 5.0 | Paul Pettitt | Design, Build & Test (PIT) | Complete | COMPLETE |  |  |  |
| 59 | 1.3.1.4.3 | Change Process Webinar | milestone | 0d | 2023-01-16 A | 2023-01-16 A |  | 100% |  | 2023-01-16 | 2023-01-16 | 0d | 2023-01-16 | 2023-01-16 |  | must start on 2023-01-16 |  | SI Design | PP | DBT | 5.0 | Paul Pettitt | Design, Build & Test (PIT) | Complete | COMPLETE |  |  |  |
| 60 | 1.3.1.4.4 | Enduring change management process approved | milestone | 0d | 2023-02-16 A | 2023-02-16 A | 50FF | 100% |  | 2023-02-16 | 2023-02-16 | 0d | 2023-02-16 | 2023-02-16 |  |  |  | SI Design | PP | DBT | 5.0 | Paul Pettitt | Design, Build & Test (PIT) | Complete | COMPLETE | T3-DB-0016 | DAG | T3 |
| 61 | 1.3.1.4.5 | Maintain E2E MHHS Design (post-M5 design change management processes operational) |  | 1022d | 2023-02-17 A | 2027-01-18 | 60 | 94% | 63d | 2023-02-17 | 2027-01-18 | 1022d | 2023-02-17 | 2027-01-18 | 243d |  |  | SI Design | PP | DBT | 5.0 | Paul Pettitt | Design, Build & Test (PIT) | Green | GREEN |  |  |  |
| 62 | 1.3.1.5 | **Design Authority Mobilisation** |  | 29d | 2022-12-14 A | 2023-01-23 A |  | 100% |  | 2022-12-14 | 2023-01-23 | 29d | 2022-12-14 | 2023-01-23 |  |  |  | N/A | N/A | DBT | 5.0 | N/A | Design, Build & Test (PIT) |  |  |  |  |  |
| 63 | 1.3.1.5.1 | Design Authority ToR approved | milestone | 0d | 2022-12-14 A | 2022-12-14 A |  | 100% |  | 2022-12-14 | 2022-12-14 | 0d | 2022-12-14 | 2022-12-14 |  | must start on 2022-12-14 |  | SI Design | PP | DBT | 5.0 | Paul Pettitt | Design, Build & Test (PIT) | Complete | COMPLETE | T3-DB-0010 | DAG | T3 |
| 64 | 1.3.1.5.2 | Inaugural Design Authority | milestone | 0d | 2023-01-23 A | 2023-01-23 A | 63FS+29d | 100% |  | 2023-01-23 | 2023-01-23 | 0d | 2023-01-23 | 2023-01-23 |  |  |  | SI Design | PP | DBT | 5.0 | Paul Pettitt | Design, Build & Test (PIT) | Complete | COMPLETE |  |  |  |
| 65 | 1.3.1.6 | **Network Operation Services Adaptor Procurement** |  | 0d | 2023-05-23 A | 2023-05-23 A |  | 100% |  | 2023-05-23 | 2023-05-23 | 0d | 2023-02-01 | 2025-03-14 |  |  | -0 | N/A | N/A | DBT | 5.0 | N/A | Design, Build & Test (PIT) |  |  |  |  |  |
| 66 | 1.3.1.6.1 | All SIT LDSOs have procured their adapter providers | milestone | 0d | 2023-05-23 A | 2023-05-23 A | 588SS | 100% |  | 2023-05-23 | 2023-05-23 | 0d | 2023-05-23 | 2023-05-23 |  |  |  | SI Design | PP | DBT | 5.0 | Paul Pettitt | Design, Build & Test (PIT) | Complete | COMPLETE | T3-DB-0020 | DAG | T3 |
| 67 | 1.3.2 | **PP Mobilisation** |  | 67d | 2022-10-31 A | 2023-01-31 A |  | 100% |  | 2022-10-31 | 2023-01-31 | 67d | 2022-10-31 | 2023-01-31 |  |  |  | N/A | N/A | DBT | 5.0 | N/A | Design, Build & Test (PIT) |  |  |  |  |  |
| 68 | 1.3.2.1 | Set up governance |  | 67d | 2022-10-31 A | 2023-01-31 A |  | 100% |  | 2022-10-31 | 2023-01-31 | 67d | 2022-10-31 | 2023-01-31 |  |  |  | PP |  | DBT | 5.0 | PP | Design, Build & Test (PIT) | Complete | COMPLETE |  |  |  |
| 69 | 1.3.2.2 | Set up reporting |  | 67d | 2022-10-31 A | 2023-01-31 A |  | 100% |  | 2022-10-31 | 2023-01-31 | 67d | 2022-10-31 | 2023-01-31 |  |  |  | PP |  | DBT | 5.0 | PP | Design, Build & Test (PIT) | Complete | COMPLETE |  |  |  |
| 70 | 1.3.2.3 | Obtain funding |  | 67d | 2022-10-31 A | 2023-01-31 A |  | 100% |  | 2022-10-31 | 2023-01-31 | 67d | 2022-10-31 | 2023-01-31 |  |  |  | PP |  | DBT | 5.0 | PP | Design, Build & Test (PIT) | Complete | COMPLETE |  |  |  |
| 71 | 1.3.2.4 | Earmark resources |  | 67d | 2022-10-31 A | 2023-01-31 A |  | 100% |  | 2022-10-31 | 2023-01-31 | 67d | 2022-10-31 | 2023-01-31 |  |  |  | PP |  | DBT | 5.0 | PP | Design, Build & Test (PIT) | Complete | COMPLETE |  |  |  |
| 72 | 1.3.2.5 | Mobilise initial team |  | 67d | 2022-10-31 A | 2023-01-31 A |  | 100% |  | 2022-10-31 | 2023-01-31 | 67d | 2022-10-31 | 2023-01-31 |  |  |  | PP |  | DBT | 5.0 | PP | Design, Build & Test (PIT) | Complete | COMPLETE |  |  |  |
| 73 | 1.3.3 | **PIT Stub Specification and Delivery** |  | 435d | 2022-10-31 A | 2024-06-28 A |  | 100% |  | 2022-10-31 | 2024-06-28 | 430d | 2022-10-31 | 2023-05-31 |  |  | -0 | N/A | N/A | DBT | 5.0 | N/A | Design, Build & Test (PIT) |  |  |  |  |  |
| 74 | 1.3.3.1 | **DIP Simulator** |  | 108d | 2022-10-31 A | 2023-03-29 A |  | 100% |  | 2022-10-31 | 2023-03-29 | 108d | 2022-10-31 | 2023-03-29 |  |  |  | N/A | N/A | DBT | 5.0 | N/A | Design, Build & Test (PIT) |  |  |  |  |  |
| 75 | 1.3.3.1.1 | Build & Test |  | 95d | 2022-10-31 A | 2023-03-10 A | 47 | 100% |  | 2022-10-31 | 2023-03-10 | 95d | 2022-10-31 | 2023-03-10 |  |  |  | SI DevOps |  | DBT | 5.0 | Rebecca Farooq | Design, Build & Test (PIT) | Complete | COMPLETE |  |  |  |
| 76 | 1.3.3.1.2 | UAT |  | 85d | 2022-11-14 A | 2023-03-10 A | 75SS+10d | 100% |  | 2022-11-14 | 2023-03-10 | 85d | 2022-11-14 | 2023-03-10 |  |  |  | SI Test |  | DBT | 5.0 | Rebecca Farooq | Design, Build & Test (PIT) | Complete | COMPLETE |  |  |  |
| 77 | 1.3.3.1.3 | Beta test |  | 95d | 2022-10-31 A | 2023-03-10 A | 75SS | 100% |  | 2022-10-31 | 2023-03-10 | 95d | 2022-10-31 | 2023-03-10 |  |  |  | PP | SI Test | DBT | 5.0 | Rebecca Farooq | Design, Build & Test (PIT) | Complete | COMPLETE |  |  |  |
| 78 | 1.3.3.1.4 | Prepare for release |  | 18d | 2023-03-06 A | 2023-03-29 A | 77FS-5d | 100% |  | 2023-03-06 | 2023-03-29 | 18d | 2023-03-06 | 2023-03-29 |  |  |  | SI DevOps |  | DBT | 5.0 | Rebecca Farooq | Design, Build & Test (PIT) | Complete | COMPLETE |  |  |  |
| 79 | 1.3.3.1.5 | DIP Simulator released | milestone | 0d | 2023-03-29 A | 2023-03-29 A | 78FF | 100% |  | 2023-03-29 | 2023-03-29 | 0d | 2023-03-29 | 2023-03-29 |  | start no earlier than 2023-01-30 |  | SI DevOps |  | DBT | 5.0 | Rebecca Farooq | Design, Build & Test (PIT) | Complete | COMPLETE | T3-DB-0018 | SITAG | T3 |

| ID | WBS | Task | Type | Duration | Start | Finish | Predecessors | Complete | Baseline start | Baseline finish | Baseline duration | Baseline 1 start | Baseline 1 finish | Constraint | Baseline cost | Responsible | Involved | Text9 | Update Version | MHHS Resource Name | MHHS Programme Phase | Sched Status | RAG | Milestone ID | Text29 | Tier |
| --- | --- | --- | --- | --- | --- | --- | --- | --- | --- | --- | --- | --- | --- | --- | --- | --- | --- | --- | --- | --- | --- | --- | --- | --- | --- | --- |
| 80 | 1.3.3.2 | **DIP Simulator Uplifts** |  | 257d | 2023-07-06 A | 2024-06-28 A |  | 100% | 2023-07-06 | 2024-06-28 | 252d |  |  |  | -0 | N/A | N/A | DBT | 5.1 | N/A | Design, Build & Test (PIT) |  |  |  |  |  |
| 81 | 1.3.3.2.1 | DIP Simulator uplifted to align with design releases - design/build/test |  | 27d | 2023-07-06 A | 2023-08-11 A | 117 | 100% | 2023-07-06 | 2023-08-11 | 27d |  |  |  |  | SI DevOps |  | DBT | 5.1 | Rebecca Farooq | Design, Build & Test (PIT) | Complete | COMPLETE |  |  |  |
| 82 | 1.3.3.2.2 | DIP Simulator uplifted to align with Interim Release 2 | milestone | 0d | 2023-08-11 A | 2023-08-11 A | 81 | 100% | 2023-08-11 | 2023-08-11 | 0d |  |  |  |  | SI DevOps |  | DBT | 5.1 | Rebecca Farooq | Design, Build & Test (PIT) | Complete | COMPLETE | T3-DB-0035 | SITAG | T3 |
| 83 | 1.3.3.2.3 | DIP Simulator uplifted to align with design releases - design/build/test |  | 20d | 2023-10-09 A | 2023-11-03 A | 126FS+2d | 100% | 2023-10-09 | 2023-11-03 | 20d |  |  |  |  | SI DevOps |  | DBT | 5.3 | Rebecca Farooq | Design, Build & Test (PIT) | Complete | COMPLETE |  |  |  |
| 84 | 1.3.3.2.4 | DIP Simulator uplifted to align with Interim Release 5 | milestone | 0d | 2023-11-03 A | 2023-11-03 A | 83 | 100% | 2023-11-03 | 2023-11-03 | 0d |  |  |  |  | SI DevOps |  | DBT | 5.11 | Rebecca Farooq | Design, Build & Test (PIT) | Complete | COMPLETE | T3-DB-0039 | SITAG | T3 |
| 85 | 1.3.3.2.5 | DIP Simulator uplifted to align with design releases - design/build/test |  | 37d | 2024-02-01 A | 2024-03-22 A | 134 | 100% | 2024-02-01 | 2024-03-22 | 37d |  |  |  |  | SI DevOps | PP,SRO,Testing | DBT | 5.14 | Matthew Bray | Design, Build & Test (PIT) | Complete | COMPLETE |  |  |  |
| 86 | 1.3.3.2.6 | DIP Simulator uplifted to align with Interim Release 7 | milestone | 0d | 2024-03-22 A | 2024-03-22 A | 85 | 100% | 2024-03-22 | 2024-03-22 | 0d |  |  |  |  | SI DevOps | PP,SRO,Testing | DBT | 5.14 | Matthew Bray | Design, Build & Test (PIT) | Complete | COMPLETE | T3-DB-0182 | SITAG | T3 |
| 87 | 1.3.3.2.7 | DIP Simulator uplifted to align with design releases - design/build/test |  | 57d | 2024-04-04 A | 2024-06-21 A | 138 | 100% | 2024-04-04 | 2024-06-21 | 57d |  |  |  |  | SI DevOps | PP,SRO,Testing | DBT | 5.14 | Matthew Bray | Design, Build & Test (PIT) | Complete | COMPLETE |  |  |  |
| 88 | 1.3.3.2.8 | DIP Simulator uplifted to align with Interim Release 8 | milestone | 0d | 2024-06-28 A | 2024-06-28 A | 87FS+5d | 100% | 2024-06-28 | 2024-06-28 | 0d |  |  |  |  | SI DevOps | PP,SRO,Testing | DBT | 5.28 | Matthew Bray | Design, Build & Test (PIT) | Complete | COMPLETE | T3-DB-0183 | SITAG | T3 |
| 89 | 1.3.3.3 | **Data Generator** |  | 130d | 2022-12-01 A | 2023-05-31 A |  | 100% | 2022-12-01 | 2023-05-31 | 130d | 2022-12-01 | 2023-05-31 |  |  | N/A | N/A | DBT | 5.0 | N/A | Design, Build & Test (PIT) |  |  |  |  |  |
| 90 | 1.3.3.3.1 | Design | manual | 15d | 2022-12-01 A | 2022-12-21 A |  | 100% | 2022-12-01 | 2022-12-21 | 15d | 2022-12-01 | 2022-12-21 |  |  | SI DevOps |  | DBT | 5.0 | Rebecca Farooq | Design, Build & Test (PIT) | Complete | COMPLETE |  |  |  |
| 91 | 1.3.3.3.2 | Build & Test |  | 50d | 2023-02-16 A | 2023-04-26 A | 90FS+40d | 100% | 2023-02-16 | 2023-04-26 | 50d | 2023-02-16 | 2023-04-26 |  |  | SI DevOps |  | DBT | 5.0 | Rebecca Farooq | Design, Build & Test (PIT) | Complete | COMPLETE |  |  |  |
| 92 | 1.3.3.3.3 | UAT |  | 10d | 2023-04-27 A | 2023-05-10 A | 91 | 100% | 2023-04-27 | 2023-05-10 | 10d | 2023-04-27 | 2023-05-10 |  |  | SI Test |  | DBT | 5.0 | Rebecca Farooq | Design, Build & Test (PIT) | Complete | COMPLETE |  |  |  |
| 93 | 1.3.3.3.4 | Beta test |  | 45d | 2023-03-30 A | 2023-05-31 A | 91FS-20d, 95FF | 100% | 2023-03-30 | 2023-05-31 | 45d | 2023-03-30 | 2023-05-31 |  |  | PP | SI Test | DBT | 5.0 | Rebecca Farooq | Design, Build & Test (PIT) | Complete | COMPLETE |  |  |  |
| 94 | 1.3.3.3.5 | Prepare for release |  | 24d | 2023-04-27 A | 2023-05-30 A | 92SS | 100% | 2023-04-27 | 2023-05-30 | 24d | 2023-04-27 | 2023-05-30 |  |  | SI DevOps |  | DBT | 5.0 | Rebecca Farooq | Design, Build & Test (PIT) | Complete | COMPLETE |  |  |  |
| 95 | 1.3.3.3.6 | Data Generator released | milestone | 0d | 2023-05-31 A | 2023-05-31 A | 94FS+1d | 100% | 2023-05-31 | 2023-05-31 | 0d | 2023-05-31 | 2023-05-31 |  |  | SI DevOps |  | DBT | 5.0 | Rebecca Farooq | Design, Build & Test (PIT) | Complete | COMPLETE | T3-DB-0022 | SITAG | T3 |
| 96 | 1.3.4 | **Design Artefact Releases** |  | 566d? | 2023-02-22 A | 2025-04-23 A |  | 100% | 2023-02-22 | 2024-11-13 | 398d | 2023-02-22 | 2023-09-29 |  | -0 | N/A | N/A | DBT | 5.0 | N/A | Design, Build & Test (PIT) |  |  |  | DAG |  |
| 97 | 1.3.4.1 | **Interim release 1** |  | 79d | 2023-02-22 A | 2023-06-12 A |  | 100% | 2023-02-22 | 2023-06-12 | 79d | 2023-02-22 | 2023-06-28 |  |  | N/A | N/A | DBT | 5.0 | N/A | Design, Build & Test (PIT) |  |  |  |  |  |
| 98 | 1.3.4.1.1 | Prioritise DINs and CR |  | 1d | 2023-02-22 A | 2023-02-22 A |  | 100% | 2023-02-22 | 2023-02-22 | 1d | 2023-02-22 | 2023-02-22 | must start on 2023-02-22 |  | SI Design |  | DBT | 5.0 | Paul Pettitt | Design, Build & Test (PIT) | Complete | COMPLETE |  |  |  |
| 99 | 1.3.4.1.2 | **Industry input session** |  | 7d | 2023-02-23 A | 2023-03-03 A |  | 100% | 2023-02-23 | 2023-03-03 | 7d | 2023-02-23 | 2023-03-03 |  |  | N/A | N/A | DBT | 5.0 | N/A | Design, Build & Test (PIT) |  |  |  |  |  |
| 100 | 1.3.4.1.2.1 | Raise a CR covering prioritized assessment cluster |  | 1d | 2023-02-23 A | 2023-02-23 A | 98 | 100% | 2023-02-23 | 2023-02-23 | 1d | 2023-02-23 | 2023-02-23 |  |  | SI Design |  | DBT | 5.0 | Paul Pettitt | Design, Build & Test (PIT) | Complete | COMPLETE |  |  |  |
| 101 | 1.3.4.1.2.2 | Organize Industry Input session to go through significant items to reach consensus |  | 1d | 2023-02-23 A | 2023-02-23 A | 100SS | 100% | 2023-02-23 | 2023-02-23 | 1d | 2023-02-23 | 2023-02-23 |  |  | SI Design | PP | DBT | 5.0 | Paul Pettitt,Berlinda Kugara | Design, Build & Test (PIT) | Complete | COMPLETE |  |  |  |
| 102 | 1.3.4.1.2.3 | Conduct Meeting |  | 1d | 2023-03-03 A | 2023-03-03 A | 101FS+5d | 100% | 2023-03-03 | 2023-03-03 | 1d | 2023-03-03 | 2023-03-03 |  |  | SI Design | PP | DBT | 5.0 | Paul Pettitt,Berlinda Kugara | Design, Build & Test (PIT) | Complete | COMPLETE |  |  |  |
| 103 | 1.3.4.1.3 | Update baselined artefacts |  | 10d | 2023-03-24 A | 2023-04-06 A |  | 100% | 2023-03-24 | 2023-04-06 | 10d | 2023-03-24 | 2023-04-06 |  |  | SI Design |  | DBT | 5.0 | Paul Pettitt | Design, Build & Test (PIT) | Complete | COMPLETE |  |  |  |

Notes:
- 84: Action: 26/7/23 - forecast changed from 15/12/23 - 3/11/23 - Changed from Interim Release 6 to 5. Updated in milestone register

| ID | WBS | Task | Type | Duration | Start | Finish | Predecessors | Complete | Baseline start | Baseline finish | Baseline duration | Baseline 1 start | Baseline 1 finish | Constraint | Baseline cost | Responsible | Involved | Text9 | Update Version | MHHS Resource Name | MHHS Programme Phase | Sched Status | RAG | Milestone ID | Text29 | Tier | Action |
| --- | --- | --- | --- | --- | --- | --- | --- | --- | --- | --- | --- | --- | --- | --- | --- | --- | --- | --- | --- | --- | --- | --- | --- | --- | --- | --- | --- |
| 104 | 1.3.4.1.4 | **Participant review and impact assess changes** |  | 18d | 2023-04-14 A | 2023-05-09 A |  | 100% | 2023-04-14 | 2023-05-09 | 18d | 2023-04-14 | 2023-05-09 |  |  | N/A | N/A | DBT | 5.0 | N/A | Design, Build & Test (PIT) |  |  |  |  |  |  |
| 105 | 1.3.4.1.4.1 | Issue Redline Version of documents |  | 1d | 2023-04-14 A | 2023-04-14 A | 103FS+5d | 100% | 2023-04-14 | 2023-04-14 | 1d | 2023-04-14 | 2023-04-14 |  |  | SI Design |  | DBT | 5.0 | Paul Pettitt | Design, Build & Test (PIT) | Complete | COMPLETE |  |  |  |  |
| 106 | 1.3.4.1.4.2 | Participants provide review comments to common log |  | 17d | 2023-04-17 A | 2023-05-09 A | 105 | 100% | 2023-04-17 | 2023-05-09 | 17d | 2023-04-17 | 2023-05-09 |  |  | PP |  | DBT | 5.0 | Paul Pettitt | Design, Build & Test (PIT) | Complete | COMPLETE |  |  |  |  |
| 107 | 1.3.4.1.5 | **Assurance review** |  | 19d | 2023-05-10 A | 2023-06-05 A |  | 100% | 2023-05-10 | 2023-06-05 | 19d | 2023-05-10 | 2023-06-05 |  |  | N/A | N/A | DBT | 5.0 | N/A | Design, Build & Test (PIT) |  |  |  |  |  |  |
| 108 | 1.3.4.1.5.1 | SI Design Review and Respond to Comments |  | 5d | 2023-05-10 A | 2023-05-16 A | 106 | 100% | 2023-05-10 | 2023-05-16 | 5d | 2023-05-10 | 2023-05-16 |  |  | SI Design |  | DBT | 5.0 | Paul Pettitt | Design, Build & Test (PIT) | Complete | COMPLETE |  |  |  |  |
| 109 | 1.3.4.1.5.2 | Prep for Assurance Review Meeting |  | 7d | 2023-05-17 A | 2023-05-25 A | 108 | 100% | 2023-05-17 | 2023-05-25 | 7d | 2023-05-17 | 2023-05-25 |  |  | SI Design |  | DBT | 5.0 | Paul Pettitt | Design, Build & Test (PIT) | Complete | COMPLETE |  |  |  |  |
| 110 | 1.3.4.1.5.3 | Conduct Assurance Review Meeting |  | 1d | 2023-05-26 A | 2023-05-26 A | 109 | 100% | 2023-05-26 | 2023-05-26 | 1d | 2023-05-26 | 2023-05-26 |  |  | SI Design |  | DBT | 5.0 | Paul Pettitt | Design, Build & Test (PIT) | Complete | COMPLETE |  |  |  |  |
| 111 | 1.3.4.1.5.4 | Update Artefacts following Assurance Review |  | 6d | 2023-05-29 A | 2023-06-05 A | 110 | 100% | 2023-05-29 | 2023-06-05 | 6d | 2023-05-29 | 2023-06-05 |  |  | SI Design |  | DBT | 5.0 | Paul Pettitt | Design, Build & Test (PIT) | Complete | COMPLETE |  |  |  |  |
| 112 | 1.3.4.1.6 | PSG Approval of interim release plan |  | 1d | 2023-06-08 A | 2023-06-08 A |  | 100% | 2023-06-08 | 2023-06-08 | 1d |  |  | must start on 2023-06-08 |  | PP | SI Design | DBT | 5.1 | Paul Pettitt | Design, Build & Test (PIT) | Complete | COMPLETE |  |  |  |  |
| 113 | 1.3.4.1.7 | Publish updated baselined artefacts | milestone | 0d | 2023-06-06 A | 2023-06-06 A | 111 | 100% | 2023-06-06 | 2023-06-12 | 5d | 2023-06-15 | 2023-06-21 |  |  | SI Design |  | DBT | 5.0 | Paul Pettitt | Design, Build & Test (PIT) | Complete | COMPLETE |  |  |  |  |
| 114 | 1.3.4.1.8 | Interim release 1 Go live | milestone | 0d | 2023-06-12 A | 2023-06-12 A | 113 | 100% | 2023-06-12 | 2023-06-12 | 0d | 2023-06-28 | 2023-06-28 |  |  | SI Design |  | DBT | 5.0 | Paul Pettitt | Design, Build & Test (PIT) | Complete | COMPLETE | T3-DB-0095 | DAG | T3 |  |
| 115 | 1.3.4.2 | **Interim release 2** |  | 27d | 2023-05-30 A | 2023-07-05 A |  | 100% | 2023-05-30 | 2023-07-05 | 27d | 2023-05-24 | 2023-07-28 |  |  | N/A | N/A | DBT | 5.0 | N/A | Design, Build & Test (PIT) |  |  |  |  |  |  |
| 116 | 1.3.4.2.1 | Update baselined artefacts |  | 27d | 2023-05-30 A | 2023-07-05 A |  | 100% | 2023-05-30 | 2023-07-05 | 27d |  |  | must start on 2023-05-30 |  | SI Design | PP | DBT | 5.1 | Paul Pettitt | Design, Build & Test (PIT) | Complete | COMPLETE |  |  |  |  |
| 117 | 1.3.4.2.2 | Interim release 2 Go live | milestone | 0d | 2023-07-05 A | 2023-07-05 A | 116 | 100% | 2023-07-05 | 2023-07-05 | 0d | 2023-07-28 | 2023-07-28 |  |  | SI Design |  | DBT | 5.0 | Paul Pettitt | Design, Build & Test (PIT) | Complete | COMPLETE | T3-DB-0096 | DAG | T3 |  |
| 118 | 1.3.4.3 | **Interim release 3** |  | 35d | 2023-06-15 A | 2023-08-02 A |  | 100% | 2023-06-15 | 2023-08-02 | 35d | 2023-06-29 | 2023-09-29 |  |  | N/A | N/A | DBT | 5.0 | N/A | Design, Build & Test (PIT) |  |  |  |  |  |  |
| 119 | 1.3.4.3.1 | Update baselined artefacts |  | 35d | 2023-06-15 A | 2023-08-02 A |  | 100% | 2023-06-15 | 2023-08-02 | 35d |  |  | must start on 2023-06-15 |  | SI Design | PP | DBT | 5.1 | Paul Pettitt | Design, Build & Test (PIT) | Complete | COMPLETE |  |  |  |  |
| 120 | 1.3.4.3.2 | Interim release 3 Go live | milestone | 0d | 2023-08-02 A | 2023-08-02 A | 119 | 100% | 2023-08-02 | 2023-08-02 | 0d | 2023-09-29 | 2023-09-29 |  |  | SI Design |  | DBT | 5.0 | Paul Pettitt | Design, Build & Test (PIT) | Complete | COMPLETE | T3-DB-0097 | DAG | T3 |  |
| 121 | 1.3.4.4 | **Interim release 4** |  | 36d | 2023-07-12 A | 2023-08-30 A |  | 100% | 2023-07-12 | 2023-08-30 | 36d |  |  |  |  | N/A | N/A | DBT | 5.1 | N/A | Design, Build & Test (PIT) |  |  |  |  |  |  |
| 122 | 1.3.4.4.1 | Update baselined artefacts |  | 36d | 2023-07-12 A | 2023-08-30 A |  | 100% | 2023-07-12 | 2023-08-30 | 36d |  |  | must start on 2023-07-12 |  | SI Design | PP | DBT | 5.1 | Paul Pettitt | Design, Build & Test (PIT) | Complete | COMPLETE |  |  |  |  |
| 123 | 1.3.4.4.2 | Interim release 4 Go live | milestone | 0d | 2023-08-30 A | 2023-08-30 A | 122 | 100% | 2023-08-30 | 2023-08-30 | 0d |  |  |  |  | SI Design |  | DBT | 5.1 | Paul Pettitt | Design, Build & Test (PIT) | Complete | COMPLETE | T3-DB-0081 | DAG | T3 |  |
| 124 | 1.3.4.5 | **Interim release 5** |  | 147d | 2023-08-17 A | 2024-03-08 A |  | 100% | 2023-08-17 | 2024-03-08 | 147d |  |  |  | -0 | N/A | N/A | DBT | 5.1 | N/A | Design, Build & Test (PIT) |  |  |  |  |  |  |
| 125 | 1.3.4.5.1 | Update baselined artefacts |  | 35d | 2023-08-17 A | 2023-10-04 A |  | 100% | 2023-08-17 | 2023-10-04 | 35d |  |  | must start on 2023-08-17 |  | SI Design | PP | DBT | 5.1 | Paul Pettitt | Design, Build & Test (PIT) | Complete | COMPLETE |  |  |  |  |
| 126 | 1.3.4.5.2 | Interim release 5 Go live | milestone | 0d | 2023-10-04 A | 2023-10-04 A | 125 | 100% | 2023-10-04 | 2023-10-04 | 0d |  |  |  |  | SI Design |  | DBT | 5.1 | Paul Pettitt | Design, Build & Test (PIT) | Complete | COMPLETE | T3-DB-0083 | DAG | T3 | 11/8 - successor is SIT functional (starts in march) |
| 127 | 1.3.4.5.3 | Interim Release 5 Deployed to SIT |  | 10d | 2024-02-26 A | 2024-03-08 A | 126FS+102d | 100% | 2024-02-26 | 2024-03-08 | 10d |  |  |  |  | SI Testing | PP | DBT | 5.16 |  |  | Complete | COMPLETE |  |  |  |  |

| ID | WBS | Task | Type | Duration | Start | Finish | Predecessors | Complete | Baseline start | Baseline finish | Baseline duration | Constraint | Baseline cost | Responsible | Involved | Text9 | Update Version | MHHS Resource Name | MHHS Programme Phase | Sched Status | RAG | Milestone ID | Text29 | Tier | Action | Task Status |
| --- | --- | --- | --- | --- | --- | --- | --- | --- | --- | --- | --- | --- | --- | --- | --- | --- | --- | --- | --- | --- | --- | --- | --- | --- | --- | --- |
| 128 | 1.3.4.6 | **Interim release 6** |  | 192d | 2023-09-14 A | 2024-06-07 A |  | 100% | 2023-09-14 | 2024-06-07 | 192d |  | -0 | N/A | N/A | DBT | 5.1 | N/A | Design, Build & Test (PIT) |  |  |  |  |  |  |  |
| 129 | 1.3.4.6.1 | Update baselined artefacts |  | 35d | 2023-09-14 A | 2023-11-01 A |  | 100% | 2023-09-14 | 2023-11-01 | 32d | must start on 2023-09-14 |  | SI Design | PP | DBT | 5.1 | Paul Pettitt | Design, Build & Test (PIT) | Complete | COMPLETE |  |  |  |  |  |
| 130 | 1.3.4.6.2 | Interim release 6 Go live | milestone | 0d | 2023-11-01 A | 2023-11-01 A | 129 | 100% | 2023-11-01 | 2023-11-01 | 0d |  |  | SI Design |  | DBT | 5.11 | Paul Pettitt | Design, Build & Test (PIT) | Complete | COMPLETE | T3-DB-0085 | DAG | T3 |  |  |
| 131 | 1.3.4.6.3 | Interim Release 6 Deployed to SIT |  | 10d | 2024-05-27 A | 2024-06-07 A | 130FS+147d | 100% | 2024-05-27 | 2024-06-07 | 10d |  |  | SI Testing | PP | DBT | 5.16 |  |  | Complete | COMPLETE |  |  |  |  |  |
| 132 | 1.3.4.7 | **Interim release 7** |  | 168d | 2023-10-18 A | 2024-06-07 A |  | 100% | 2023-10-18 | 2024-06-07 | 168d |  | -0 | N/A | N/A | DBT | 5.5 | N/A | Design, Build & Test (PIT) |  |  |  |  |  |  |  |
| 133 | 1.3.4.7.1 | Update baselined artefacts |  | 76d | 2023-10-18 A | 2024-01-31 A |  | 100% | 2023-10-18 | 2024-01-31 | 76d | start no earlier than 2023-10-18 |  | SI Design | PP | DBT | 5.5 | Paul Pettitt | Design, Build & Test (PIT) | Complete | COMPLETE |  |  |  |  |  |
| 134 | 1.3.4.7.2 | Interim release 7 Go live | milestone | 0d | 2024-01-31 A | 2024-01-31 A | 133 | 100% | 2024-01-31 | 2024-01-31 | 0d |  |  | SI Design | PP | DBT | 5.14 | Paul Pettitt | Design, Build & Test (PIT) | Complete | COMPLETE | T3-DB-0098 | DAG | T3 | 4/8 - add as t3 milestones. Awaiting approval at TMAG |  |
| 135 | 1.3.4.7.3 | Interim Release 7 Deployed to SIT |  | 10d | 2024-05-27 A | 2024-06-07 A | 134FS+82d | 100% | 2024-05-27 | 2024-06-07 | 10d |  |  | SI Testing | PP | DBT | 5.16 |  |  | Complete | COMPLETE |  |  |  |  |  |
| 136 | 1.3.4.8 | **Interim release 8** |  | 311d? | 2024-02-14 A | 2025-04-23 A |  | 100% | 2024-02-14 | 2024-11-13 | 143d |  | -0 | N/A | N/A | DBT | 5.5 | N/A | Design, Build & Test (PIT) |  |  |  | DAG |  |  |  |
| 137 | 1.3.4.8.1 | Update baselined artefacts |  | 36d | 2024-02-14 A | 2024-04-03 A |  | 100% | 2024-02-14 | 2024-04-03 | 36d | start no earlier than 2024-02-14 |  | SI Design | PP | DBT | 5.5 | Paul Pettitt | Design, Build & Test (PIT) | Complete | COMPLETE |  |  |  |  |  |
| 138 | 1.3.4.8.2 | Interim release 8 Go live | milestone | 0d | 2024-04-03 A | 2024-04-03 A | 137 | 100% | 2024-04-03 | 2024-04-03 | 0d | start no earlier than 2024-01-10 |  | SI Design | PP | DBT | 5.14 | Paul Pettitt | Design, Build & Test (PIT) | Complete | COMPLETE | T3-DB-0099 | DAG | T3 | 4/8 - add as t3 milestones. Awaiting approval at TMAG |  |
| 139 | 1.3.4.8.3 | **Interim Release 8.3 - Maintenance Window** |  | 11d | 2024-10-07 A | 2024-10-21 A |  | 100% | 2024-10-07 | 2024-10-21 | 0d |  |  | Design |  | DBT | 6.0 |  |  |  |  |  |  |  |  | -686.67 |
| 140 | 1.3.4.8.3.1 | Interim Release 8.3 'effective from date' to SIT A | milestone | 0d | 2024-10-21 A | 2024-10-21 A | 138FS+143d | 100% | 2024-10-21 | 2024-10-21 | 10d |  |  | SI Testing | PP | DBT | 5.16 | Roger Robar |  | Complete | COMPLETE |  |  |  |  |  |
| 141 | 1.3.4.8.3.2 | Interim Release 8.3 'effective from date' to SIT B | milestone | 0d | 2024-10-07 A | 2024-10-07 A | 140SS-11d | 100% | 2024-10-07 | 2024-10-07 | 0d |  |  | Design |  | DBT | 5.16 |  |  | Complete | COMPLETE |  |  |  |  |  |
| 142 | 1.3.4.8.4 | **Interim Release 8.4** |  | 49d | 2024-09-25 A | 2024-12-02 A |  | 100% | 2024-09-25 | 2024-11-13 | 0d |  |  | Design |  | DBT | 6.1 | Paul Pettitt |  |  |  |  | DAG |  |  | -694.67 |
| 143 | 1.3.4.8.4.1 | Update baselined artefacts |  | 8d | 2024-09-25 A | 2024-10-04 A |  | 100% | 2024-09-25 | 2024-10-04 | 0d | start no earlier than 2024-09-25 |  | Design |  | DBT | 6.1 | Paul Pettitt |  | Complete | COMPLETE |  |  |  |  |  |
| 144 | 1.3.4.8.4.2 | Interim Release 8.4 Published | milestone | 0d | 2024-10-16 A | 2024-10-16 A | 143FS+8d | 100% | 2024-10-16 | 2024-10-16 | 0d | start no earlier than 2024-10-09 |  | Design |  | DBT | 6.1 | Paul Pettitt |  | Complete | COMPLETE | T3-DB-0184 | DAG | T3 |  |  |
| 145 | 1.3.4.8.4.3 | Interim Release 8.4 Deployed to SIT by Participants |  | 6d | 2024-11-25 A | 2024-12-02 A | 144FS+25d | 100% | 2024-11-13 | 2024-11-13 | 0d |  |  | Design |  | DBT | 6.12 | Paul Pettitt |  | Complete | COMPLETE |  |  |  |  |  |
| 146 | 1.3.4.8.5 | **Interim Release 8.5** |  | 71d | 2024-10-16 A | 2025-01-22 A |  | 100% | 2024-10-16 | 2024-12-04 | 0d |  |  | Design |  | DBT | 6.11 | Paul Pettitt |  |  |  |  | DAG |  |  | -728.67 |
| 147 | 1.3.4.8.5.1 | Update baselined artefacts |  | 8d | 2024-10-16 A | 2024-10-25 A |  | 100% | 2024-10-16 | 2024-10-25 | 0d | start no earlier than 2024-10-16 |  | Design |  | DBT | 6.11 | Paul Pettitt |  | Complete | COMPLETE |  |  |  |  |  |
| 148 | 1.3.4.8.5.2 | Interim Release 8.5 Published | milestone | 0d | 2024-11-06 A | 2024-11-06 A | 147FS+8d | 100% | 2024-11-06 | 2024-11-06 | 0d |  |  | Design |  | DBT | 6.11 | Paul Pettitt |  | Complete | COMPLETE | T3-DB-0185 | DAG | T3 |  |  |
| 149 | 1.3.4.8.5.3 | Interim Release 8.5 Deployed to SIT by Participants |  | 3d | 2025-01-20 A | 2025-01-22 A | 148FS+52d | 100% | 2024-12-04 | 2024-12-04 | 0d |  |  | Design |  | DBT | 6.12 | Paul Pettitt |  | Complete | COMPLETE |  |  |  |  |  |
| 150 | 1.3.4.8.6 | **Interim Release 8.6** |  | 45d? | 2024-11-21 A | 2025-01-22 A |  | 100% | 2024-11-21 | 2025-01-22 | 0d |  |  | Design |  | DBT | 6.14 | Paul Pettitt |  |  |  |  | DAG |  |  | -769.67 |
| 151 | 1.3.4.8.6.1 | Update baselined artefacts |  | 2d? | 2024-11-21 A | 2024-11-22 A |  | 100% | 2024-11-21 | 2024-11-22 | 0d | start no earlier than 2024-11-21 |  | Design |  | DBT | 6.14 | Paul Pettitt |  | Complete | COMPLETE |  |  |  |  |  |
| 152 | 1.3.4.8.6.2 | Interim Release 8.6 Published |  | 1d? | 2024-11-25 A | 2024-11-25 A | 151 | 100% | 2024-11-25 | 2024-11-25 | 0d |  |  | Design |  | DBT | 6.14 | Paul Pettitt |  | Complete | COMPLETE |  |  |  |  |  |
| 153 | 1.3.4.8.6.3 | Interim Release 8.6 Deployed to SIT by Participants |  | 3d | 2025-01-20 A | 2025-01-22 A | 152FS+39d | 100% | 2025-01-20 | 2025-01-22 | 0d |  |  | Design |  | DBT | 6.14 | Paul Pettitt |  | Complete | COMPLETE | T3-TE-0187 | DAG | T3 |  |  |

| ID | WBS | Task | Type | Duration | Start | Finish | Predecessors | Complete | Baseline start | Baseline finish | Baseline duration | Baseline 1 start | Baseline 1 finish | Constraint | Responsible | Text9 | Task Status | Update Version | MHHS Resource Name | Text29 | Sched Status | RAG | Milestone ID | Tier | Involved | MHHS Programme Phase | Action |
| --- | --- | --- | --- | --- | --- | --- | --- | --- | --- | --- | --- | --- | --- | --- | --- | --- | --- | --- | --- | --- | --- | --- | --- | --- | --- | --- | --- |
| 154 | 1.3.4.8.7 | **Interim Release 8.7** |  | 5d | 2025-01-20 A | 2025-01-24 A |  | 100% | 2025-01-20 | 2025-01-27 | 0d |  |  |  | Design | DBT | -769.67 | 6.16 | Paul Pettitt | DAG |  |  |  |  |  |  |  |
| 155 | 1.3.4.8.7.1 | Update baselined artefacts |  | 2d | 2025-01-20 A | 2025-01-21 A |  | 100% | 2025-01-20 | 2025-01-21 | 0d |  |  | start no earlier than 2025-01-20 | Design | DBT |  | 6.16 | Paul Pettitt |  | Complete | COMPLETE |  |  |  |  |  |
| 156 | 1.3.4.8.7.2 | Interim Release 8.7 Published |  | 1d | 2025-01-22 A | 2025-01-22 A | 155 | 100% | 2025-01-22 | 2025-01-22 | 0d |  |  |  | Design | DBT |  | 6.16 | Paul Pettitt |  | Complete | COMPLETE |  |  |  |  |  |
| 157 | 1.3.4.8.7.3 | Interim Release 8.7 Deployed to SIT by Participants |  | 3d | 2025-01-22 A | 2025-01-24 A | 156FS-1d | 100% | 2025-01-23 | 2025-01-27 | 0d |  |  |  | Design | DBT |  | 6.16 | Paul Pettitt | DAG | Complete | COMPLETE | T3-TE-0188 | T3 |  |  |  |
| 158 | 1.3.4.8.8 | **Interim Release 8.8** |  | 26d | 2025-02-05 A | 2025-03-12 A |  | 100% | 2025-02-05 | 2025-03-12 | 0d |  |  |  | Design | DBT | -829.67 | 6.18 | Paul Pettitt | DAG |  |  |  |  |  |  |  |
| 159 | 1.3.4.8.8.1 | Update baselined artefacts |  | 4d | 2025-02-05 A | 2025-02-10 A |  | 100% | 2025-02-05 | 2025-02-10 | 0d |  |  | start no earlier than 2025-02-05 | Design | DBT |  | 6.18 | Paul Pettitt |  | Complete | COMPLETE |  |  |  |  |  |
| 160 | 1.3.4.8.8.2 | Interim Release 8.8 Published |  | 1d | 2025-02-12 A | 2025-02-12 A | 159FS+1d | 100% | 2025-02-12 | 2025-02-12 | 0d |  |  |  | Design | DBT |  | 6.18 | Paul Pettitt |  | Complete | COMPLETE |  |  |  |  |  |
| 161 | 1.3.4.8.8.3 | Interim Release 8.8 Deployed to SIT by Participants |  | 20d | 2025-02-13 A | 2025-03-12 A | 160 | 100% | 2025-02-13 | 2025-03-12 | 0d |  |  |  | Design | DBT |  | 6.18 | Paul Pettitt | DAG | Complete | COMPLETE |  |  |  |  |  |
| 162 | 1.3.4.8.9 | **Interim Release 8.9** |  | 45d | 2025-02-05 A | 2025-04-08 A |  | 100% | 2025-02-05 | 2025-03-12 | 0d |  |  |  | Design | DBT | -829.67 | 6.21 | Paul Pettitt | DAG |  |  |  |  |  |  |  |
| 163 | 1.3.4.8.9.1 | Update baselined artefacts |  | 4d | 2025-02-05 A | 2025-02-10 A |  | 100% | 2025-02-05 | 2025-02-10 | 0d |  |  | start no earlier than 2025-02-05 | Design | DBT |  | 6.21 | Paul Pettitt |  | Complete | COMPLETE |  |  |  |  |  |
| 164 | 1.3.4.8.9.2 | Interim Release 8.9 Published | milestone | 0d | 2025-03-11 A | 2025-03-11 A | 163FS+1d | 100% | 2025-02-12 | 2025-02-12 | 0d |  |  | finish no earlier than 2025-03-26 | Design | DBT |  | 6.21 | Paul Pettitt |  | Complete | COMPLETE |  |  |  |  |  |
| 165 | 1.3.4.8.9.3 | Interim Release 8.9 Deployed to SIT by Participants |  | 20d | 2025-03-12 A | 2025-04-08 A | 164 | 100% | 2025-03-12 | 2025-04-08 | 0d |  |  |  | Design | DBT |  | 6.21 | Paul Pettitt | DAG | Complete | COMPLETE |  |  |  |  |  |
| 166 | 1.3.4.8.10 | **Interim Release 8.10** |  | 56d | 2025-02-05 A | 2025-04-23 A |  | 100% | 2025-02-05 | 2025-03-12 | 0d |  |  |  | Design | DBT | -829.67 | 6.21 | Paul Pettitt | DAG |  |  |  |  |  |  |  |
| 167 | 1.3.4.8.10.1 | Update baselined artefacts |  | 4d | 2025-02-05 A | 2025-02-10 A |  | 100% | 2025-02-05 | 2025-02-10 | 0d |  |  | start no earlier than 2025-02-05 | Design | DBT |  | 6.21 | Paul Pettitt |  | Complete | COMPLETE |  |  |  |  |  |
| 168 | 1.3.4.8.10.2 | Interim Release 8.10 Published |  | 1d | 2025-03-26 A | 2025-03-26 A | 167FS+1d | 100% | 2025-02-12 | 2025-02-12 | 0d |  |  | finish no earlier than 2025-03-26 | Design | DBT |  | 6.21 | Paul Pettitt |  | Complete | COMPLETE |  |  |  |  |  |
| 169 | 1.3.4.8.10.3 | Interim Release 8.10 Deployed to SIT by Participants |  | 20d | 2025-03-27 A | 2025-04-23 A | 168 | 100% | 2025-03-27 | 2025-04-23 | 0d |  |  | finish no earlier than 2025-03-27 | Design | DBT |  | 6.21 | Paul Pettitt | DAG | Complete | COMPLETE |  |  |  |  |  |
| 170 | 1.3.5 | **Queries Support / Knowledgebase & Tool Roll-Out (Systems)** |  | 325d | 2023-01-03 A | 2024-04-01 A |  | 100% | 2023-01-03 | 2024-04-01 | 325d | 2023-01-03 | 2024-04-01 |  | N/A | DBT |  | 5.0 | N/A |  |  |  |  |  | N/A | Design, Build & Test (PIT) |  |
| 171 | 1.3.5.1 | **Query Management** |  | 325d | 2023-01-03 A | 2024-04-01 A |  | 100% | 2023-01-03 | 2024-04-01 | 325d | 2023-01-03 | 2024-04-01 |  | N/A | DBT |  | 5.0 | N/A |  |  |  |  |  | N/A | Design, Build & Test (PIT) |  |
| 172 | 1.3.5.1.1 | Respond to Participant Queries |  | 325d | 2023-01-03 A | 2024-04-01 A |  | 100% | 2023-01-03 | 2024-04-01 | 325d | 2023-01-03 | 2024-04-01 | must start on 2023-01-03 | SI Design | DBT |  | 5.0 | Paul Pettitt |  | Complete | COMPLETE |  |  | PP | Design, Build & Test (PIT) | 11/8 - runs out to end of the programme |
| 173 | 1.3.5.1.2 | Respond to Programme Queries |  | 325d | 2023-01-03 A | 2024-04-01 A | 172SS | 100% | 2023-01-03 | 2024-04-01 | 325d | 2023-01-03 | 2024-04-01 |  | SI Design | DBT |  | 5.0 | Paul Pettitt |  | Complete | COMPLETE |  |  | PP | Design, Build & Test (PIT) | 11/8 - runs out to end of the programme |
| 174 | 1.3.5.2 | **Query Support tooling (FreshDesk)** |  | 23d | 2023-06-01 A | 2023-07-03 A |  | 100% | 2023-06-01 | 2023-07-03 | 23d | 2023-06-01 | 2023-07-03 |  | N/A | DBT |  | 5.0 | N/A |  |  |  |  |  | N/A | Design, Build & Test (PIT) |  |
| 175 | 1.3.5.2.1 | Migrate to Standalone Freshdesk |  | 10d | 2023-06-01 A | 2023-06-14 A |  | 100% | 2023-06-01 | 2023-06-14 | 10d | 2023-06-01 | 2023-06-14 | must start on 2023-06-01 | SI Design | DBT |  | 5.0 | Paul Pettitt |  | Complete | COMPLETE |  |  |  | Design, Build & Test (PIT) |  |
| 176 | 1.3.5.2.2 | Develop reporting dashboard |  | 5d | 2023-06-15 A | 2023-06-21 A | 175 | 100% | 2023-06-15 | 2023-06-21 | 5d | 2023-06-15 | 2023-06-21 |  | SI Design | DBT |  | 5.0 | Paul Pettitt |  | Complete | COMPLETE |  |  |  | Design, Build & Test (PIT) |  |
| 177 | 1.3.5.2.3 | Issue to SRO for Review |  | 5d | 2023-06-22 A | 2023-06-28 A | 176 | 100% | 2023-06-22 | 2023-06-28 | 5d | 2023-06-22 | 2023-06-28 |  | SI Design | DBT |  | 5.0 | Paul Pettitt |  | Complete | COMPLETE |  |  |  | Design, Build & Test (PIT) |  |
| 178 | 1.3.5.2.4 | Update following review |  | 2d | 2023-06-29 A | 2023-06-30 A | 177 | 100% | 2023-06-29 | 2023-06-30 | 2d | 2023-06-29 | 2023-06-30 |  | SI Design | DBT |  | 5.0 | Paul Pettitt |  | Complete | COMPLETE |  |  |  | Design, Build & Test (PIT) |  |
| 179 | 1.3.5.2.5 | Sign off |  | 1d | 2023-07-03 A | 2023-07-03 A | 178 | 100% | 2023-07-03 | 2023-07-03 | 1d | 2023-07-03 | 2023-07-03 |  | SI Design | DBT |  | 5.0 | Paul Pettitt |  | Complete | COMPLETE |  |  |  | Design, Build & Test (PIT) |  |

| ID | WBS | Task | Type | Duration | Start | Finish | Predecessors | Complete | Baseline start | Baseline finish | Baseline duration | Baseline 1 start | Baseline 1 finish | Baseline cost | Responsible | Involved | Text9 | Update Version | MHHS Resource Name | MHHS Programme Phase | Sched Status | RAG | Text29 | Task Status | Milestone ID | Tier |
| --- | --- | --- | --- | --- | --- | --- | --- | --- | --- | --- | --- | --- | --- | --- | --- | --- | --- | --- | --- | --- | --- | --- | --- | --- | --- | --- |
| 180 | 1.3.5.3 | **KnowledgeBase Development** |  | 72d | 2023-06-01 A | 2023-09-08 A |  | 100% | 2023-06-01 | 2023-09-08 | 72d | 2023-06-01 | 2023-09-08 |  | N/A | N/A | DBT | 5.0 | N/A | Design, Build & Test (PIT) |  |  |  |  |  |  |
| 181 | 1.3.5.3.1 | Define Scope of KB |  | 1d | 2023-06-01 A | 2023-06-01 A | 175SS | 100% | 2023-06-01 | 2023-06-01 | 1d | 2023-06-01 | 2023-06-01 |  | SI Design |  | DBT | 5.0 | Paul Pettitt | Design, Build & Test (PIT) | Complete | COMPLETE |  |  |  |  |
| 182 | 1.3.5.3.2 | Capture Existing KB artefacts |  | 20d | 2023-06-02 A | 2023-06-29 A | 181 | 100% | 2023-06-02 | 2023-06-29 | 20d | 2023-06-02 | 2023-06-29 |  | SI Design |  | DBT | 5.0 | Paul Pettitt | Design, Build & Test (PIT) | Complete | COMPLETE |  |  |  |  |
| 183 | 1.3.5.3.3 | Tag artefacts |  | 5d | 2023-06-30 A | 2023-07-06 A | 182 | 100% | 2023-06-30 | 2023-07-06 | 5d | 2023-06-30 | 2023-07-06 |  | SI Design |  | DBT | 5.0 | Paul Pettitt | Design, Build & Test (PIT) | Complete | COMPLETE |  |  |  |  |
| 184 | 1.3.5.3.4 | Develop Participant Interfaces |  | 20d | 2023-07-07 A | 2023-08-03 A | 183 | 100% | 2023-07-07 | 2023-08-03 | 20d | 2023-07-07 | 2023-08-03 |  | SI Design |  | DBT | 5.0 | Paul Pettitt | Design, Build & Test (PIT) | Complete | COMPLETE |  |  |  |  |
| 185 | 1.3.5.3.5 | Promote to Collaboration Portal |  | 21d | 2023-08-04 A | 2023-09-01 A | 184 | 100% | 2023-08-04 | 2023-09-01 | 21d | 2023-08-04 | 2023-09-01 |  | SI Design |  | DBT | 5.0 | Paul Pettitt | Design, Build & Test (PIT) | Complete | COMPLETE |  |  |  |  |
| 186 | 1.3.5.3.6 | Link into FreshDesk |  | 5d | 2023-09-04 A | 2023-09-08 A | 185 | 100% | 2023-09-04 | 2023-09-08 | 5d | 2023-09-04 | 2023-09-08 |  | SI Design |  | DBT | 5.0 | Paul Pettitt | Design, Build & Test (PIT) | Complete | COMPLETE |  |  |  |  |
| 187 | 1.3.6 | **PP Design, Build & Test (DBT)** |  | 605d | 2022-10-31 A | 2025-02-21 A |  | 100% | 2022-10-31 | 2027-07-05 | 495d | 2022-10-31 | 2026-02-16 | -0 | N/A | N/A | DBT | 5.0 | N/A | Design, Build & Test (PIT) |  |  | DAG |  |  |  |
| 188 | 1.3.6.1 | **PP Impact Assessment, Planning & Procurement** |  | 110d | 2022-10-31 A | 2023-03-31 A |  | 100% | 2022-10-31 | 2023-03-31 | 110d | 2022-10-31 | 2023-03-31 |  | N/A | N/A | DBT | 5.0 | N/A | Design, Build & Test (PIT) |  |  |  |  |  |  |
| 189 | 1.3.6.1.1 | **PP Impact Assessment** |  | 67d | 2022-10-31 A | 2023-01-31 A |  | 100% | 2022-10-31 | 2023-01-31 | 67d | 2022-10-31 | 2023-01-31 |  | N/A | N/A | DBT | 5.0 | N/A | Design, Build & Test (PIT) |  |  |  |  |  |  |
| 190 | 1.3.6.1.1.1 | Develop heatmap for impact of MHHS |  | 67d | 2022-10-31 A | 2023-01-31 A | 47 | 100% | 2022-10-31 | 2023-01-31 | 67d | 2022-10-31 | 2023-01-31 |  | PP |  | DBT | 5.0 | PP | Design, Build & Test (PIT) | Complete | COMPLETE |  |  |  |  |
| 191 | 1.3.6.1.1.2 | Develop detailed impact assessment |  | 67d | 2022-10-31 A | 2023-01-31 A | 47 | 100% | 2022-10-31 | 2023-01-31 | 67d | 2022-10-31 | 2023-01-31 |  | PP |  | DBT | 5.0 | PP | Design, Build & Test (PIT) | Complete | COMPLETE |  |  |  |  |
| 192 | 1.3.6.1.2 | **PP Planning** |  | 67d | 2022-10-31 A | 2023-01-31 A |  | 100% | 2022-10-31 | 2023-01-31 | 67d | 2022-10-31 | 2023-01-31 |  | N/A | N/A | DBT | 5.0 | N/A | Design, Build & Test (PIT) |  |  |  |  |  |  |
| 193 | 1.3.6.1.2.1 | Develop detailed short-term plan |  | 23d | 2022-10-31 A | 2022-11-30 A | 47 | 100% | 2022-10-31 | 2022-11-30 | 23d | 2022-10-31 | 2022-11-30 |  | PP |  | DBT | 5.0 | PP | Design, Build & Test (PIT) | Complete | COMPLETE |  |  |  |  |
| 194 | 1.3.6.1.2.2 | Develop overall project plan for implementation |  | 67d | 2022-10-31 A | 2023-01-31 A | 47 | 100% | 2022-10-31 | 2023-01-31 | 67d | 2022-10-31 | 2023-01-31 |  | PP |  | DBT | 5.0 | PP | Design, Build & Test (PIT) | Complete | COMPLETE |  |  |  |  |
| 195 | 1.3.6.1.2.3 | Develop procurement plan |  | 67d | 2022-10-31 A | 2023-01-31 A | 47 | 100% | 2022-10-31 | 2023-01-31 | 67d | 2022-10-31 | 2023-01-31 |  | PP |  | DBT | 5.0 | PP | Design, Build & Test (PIT) | Complete | COMPLETE |  |  |  |  |
| 196 | 1.3.6.1.3 | **PP Software/Service Procurement** |  | 110d | 2022-10-31 A | 2023-03-31 A |  | 100% | 2022-10-31 | 2023-03-31 | 110d | 2022-10-31 | 2023-03-31 |  | N/A | N/A | DBT | 5.0 | N/A | Design, Build & Test (PIT) |  |  |  |  |  |  |
| 197 | 1.3.6.1.3.1 | Run tender process |  | 67d | 2022-10-31 A | 2023-01-31 A | 47 | 100% | 2022-10-31 | 2023-01-31 | 67d | 2022-10-31 | 2023-01-31 |  | PP |  | DBT | 5.0 | PP | Design, Build & Test (PIT) | Complete | COMPLETE |  |  |  |  |
| 198 | 1.3.6.1.3.2 | Select provider & sign commercials |  | 43d | 2023-02-01 A | 2023-03-31 A | 197 | 100% | 2023-02-01 | 2023-03-31 | 43d | 2023-02-01 | 2023-03-31 |  | PP |  | DBT | 5.0 | PP | Design, Build & Test (PIT) | Complete | COMPLETE |  |  |  |  |
| 199 | 1.3.6.2 | **Central Systems DBT** |  | 325d | 2022-10-31 A | 2024-01-26 A |  | 100% | 2022-10-31 | 2024-01-26 | 345d | 2022-10-31 | 2024-05-13 | -0 | N/A | N/A | DBT | 5.0 | N/A | Design, Build & Test (PIT) |  |  | DAG | -316.67 |  |  |
| 200 | 1.3.6.2.1 | **Elexon Central Systems DBT CIT (Entering at Interval 1)** |  | 248d | 2022-10-31 A | 2023-10-11 A |  | 100% | 2022-10-31 | 2023-10-11 | 249d | 2022-10-31 | 2023-09-29 | -0 | N/A | N/A | DBT | 5.0 | N/A | Design, Build & Test (PIT) |  |  | DAG |  |  |  |
| 201 | 1.3.6.2.1.1 | **Design and Build** |  | 235d | 2022-10-31 A | 2023-09-22 A |  | 100% | 2022-10-31 | 2023-09-22 | 240d | 2022-10-31 | 2023-09-29 |  | N/A | N/A | DBT | 5.0 | N/A | Design, Build & Test (PIT) |  |  |  | -259.67 |  |  |
| 202 | 1.3.6.2.1.1.1 | Helix Design and Build |  | 235d | 2022-10-31 A | 2023-09-22 A | 2 | 100% | 2022-10-31 | 2023-09-22 | 240d | 2022-10-31 | 2023-09-29 |  | PP | SI Test | DBT | 5.0 |  | Design, Build & Test (PIT) | Complete | COMPLETE |  |  |  |  |
| 203 | 1.3.6.2.1.2 | **Test Approach & Plan** |  | 235d | 2022-10-31 A | 2023-09-22 A |  | 100% | 2022-10-31 | 2023-09-22 | 235d | 2022-10-31 | 2023-07-21 | -0 | N/A | N/A | DBT | 5.0 | N/A | Design, Build & Test (PIT) |  |  | DAG |  |  |  |
| 204 | 1.3.6.2.1.2.1 | Develop Test Approach & Plan |  | 180d | 2022-10-31 A | 2023-07-07 A |  | 100% | 2022-10-31 | 2023-07-07 | 180d | 2022-10-31 | 2023-07-07 |  | PP | SI Test | DBT | 5.0 |  | Design, Build & Test (PIT) | Complete | COMPLETE |  |  |  |  |
| 205 | 1.3.6.2.1.2.2 | Elexon Central Systems Test Approach & Plan (PIT) submitted to Programme for assurance | milestone | 0d | 2023-07-13 A | 2023-07-13 A | 204FF+4d | 100% | 2023-07-13 | 2023-07-13 | 0d | 2023-07-07 | 2023-07-07 |  | PP | SI Test | DBT | 5.0 |  | Design, Build & Test (PIT) | Complete | COMPLETE | SITAG |  | T3-DB-0029 | T3 |
| 206 | 1.3.6.2.1.2.3 | Elexon Central Systems Test Approach & Plan (PIT) V2 resubmitted to Programme for assurance | milestone, manual | 0d | 2023-07-27 A | 2023-07-27 A | 205FS+9d | 100% | 2023-07-27 | 2023-07-27 | 0d |  |  |  | PP | SI Test | DBT | 5.4 |  | Design, Build & Test (PIT) | Complete | COMPLETE |  |  |  |  |
| 207 | 1.3.6.2.1.2.4 | Elexon Central Systems Test Approach & Plan (PIT) V3 resubmitted to Programme for assurance | milestone | 0d | 2023-08-18 A | 2023-08-18 A | 206FS+17d | 100% | 2023-08-18 | 2023-08-18 | 0d |  |  |  | PP | SI Test | DBT | 5.4 |  | Design, Build & Test (PIT) | Complete | COMPLETE |  |  |  |  |
| 208 | 1.3.6.2.1.2.5 | Elexon Central Systems Test approach and plan MHHS Review Completed | milestone | 0d | 2023-09-22 A | 2023-09-22 A | 207FS+25d | 100% | 2023-09-22 | 2023-09-22 | 0d | 2023-07-10 | 2023-07-21 |  | SI Test | PP | DBT | 5.8 |  | Design, Build & Test (PIT) | Complete | COMPLETE | SITAG |  | T3-DB-0106 | T3 |

| ID | WBS | Task | Type | Duration | Start | Finish | Predecessors | Complete | Baseline start | Baseline finish | Baseline duration | Baseline 1 start | Baseline 1 finish | Constraint | Baseline cost | Responsible | Involved | Text9 | Update Version | MHHS Resource Name | MHHS Programme Phase | Sched Status | RAG | Artefact ID | Milestone ID | Text29 | Tier |
| --- | --- | --- | --- | --- | --- | --- | --- | --- | --- | --- | --- | --- | --- | --- | --- | --- | --- | --- | --- | --- | --- | --- | --- | --- | --- | --- | --- |
| 209 | 1.3.6.2.1.3 | **Test Readiness Report** |  | 16d | 2023-07-28 A | 2023-08-18 A |  | 100% | 2023-07-28 | 2023-08-18 | 51d | 2023-07-21 | 2023-09-29 |  |  | N/A | N/A | DBT | 5.0 | N/A | Design, Build & Test (PIT) |  |  |  |  |  |  |
| 210 | 1.3.6.2.1.3.1 | Test readiness reporting |  | 16d | 2023-07-28 A | 2023-08-18 A | 205FS+10d | 100% | 2023-07-28 | 2023-08-18 | 51d | 2023-07-21 | 2023-09-29 |  |  | PP | 109 | DBT | 5.0 |  | Design, Build & Test (PIT) | Complete | COMPLETE |  |  |  |  |
| 211 | 1.3.6.2.1.4 | **Requirements to test Traceability Matrix (RTTM)** |  | 35d | 2023-08-04 A | 2023-09-22 A |  | 100% | 2023-08-04 | 2023-09-22 | 35d | 2022-10-31 | 2023-08-18 |  | -0 | N/A | N/A | DBT | 5.0 | N/A | Design, Build & Test (PIT) |  |  |  |  |  |  |
| 212 | 1.3.6.2.1.4.1 | Elexon Central Systems RTTM submitted to Programme for assurance | milestone | 0d | 2023-08-04 A | 2023-08-04 A | 205 | 100% | 2023-08-04 | 2023-08-04 | 0d | 2023-08-04 | 2023-08-04 | start no earlier than 2023-04-28 |  | PP | SI Test | DBT | 5.0 |  | Design, Build & Test (PIT) | Complete | COMPLETE | MHHS-ART009 | T3-DB-0030 | SITAG | T3 |
| 213 | 1.3.6.2.1.4.2 | Elexon Central Systems RTTM MHHS Review Completed | milestone | 0d | 2023-09-22 A | 2023-09-22 A | 212FS+35d | 100% | 2023-09-22 | 2023-09-22 | 0d | 2023-08-07 | 2023-08-18 |  |  | SI Test | PP | DBT | 5.8 |  | Design, Build & Test (PIT) | Complete | COMPLETE |  | T3-DB-0107 | SITAG | T3 |
| 214 | 1.3.6.2.1.5 | **Test Scenarios** |  | 35d | 2023-08-04 A | 2023-09-22 A |  | 100% | 2023-08-04 | 2023-09-22 | 35d | 2022-10-31 | 2023-08-18 |  | -0 | N/A | N/A | DBT | 5.0 | N/A | Design, Build & Test (PIT) |  |  |  |  |  |  |
| 215 | 1.3.6.2.1.5.1 | Elexon Central Systems test scenarios submitted to Programme for assurance | milestone | 0d | 2023-08-04 A | 2023-08-04 A | 205 | 100% | 2023-08-04 | 2023-08-04 | 0d | 2023-08-04 | 2023-08-04 |  |  | PP | SI Test | DBT | 5.0 |  | Design, Build & Test (PIT) | Complete | COMPLETE |  | T3-DB-0032 | SITAG | T3 |
| 216 | 1.3.6.2.1.5.2 | Elexon Central Systems Test scenarios MHHS Review Completed | milestone | 0d | 2023-09-22 A | 2023-09-22 A | 215FS+35d | 100% | 2023-09-22 | 2023-09-22 | 0d | 2023-08-07 | 2023-08-18 |  |  | SI Test | PP | DBT | 5.8 |  | Design, Build & Test (PIT) | Complete | COMPLETE |  | T3-DB-0108 | SITAG | T3 |
| 217 | 1.3.6.2.1.6 | **PIT Execution** |  | 38d | 2023-08-21 A | 2023-10-11 A |  | 100% | 2023-08-21 | 2023-10-11 | 248d | 2022-10-31 | 2023-09-29 |  | -0 | N/A | N/A | DBT | 5.0 | N/A | Design, Build & Test (PIT) |  |  |  |  |  |  |
| 218 | 1.3.6.2.1.6.1 | PIT Test Execution Progress Report |  | 18d | 2023-09-04 A | 2023-09-27 A | 210FS+10d | 100% | 2023-09-04 | 2023-09-27 | 235d | 2022-10-31 | 2023-09-22 |  |  | PP | SI Test | DBT | 5.1 |  | Design, Build & Test (PIT) | Complete | COMPLETE |  |  |  |  |
| 219 | 1.3.6.2.1.6.2 | Elexon Central Systems PIT Execution |  | 28d | 2023-08-21 A | 2023-09-27 A | 210 | 100% | 2023-08-21 | 2023-09-27 | 240d | 2022-10-31 | 2023-09-29 |  |  | PP | SI Test | DBT | 5.1 |  | Design, Build & Test (PIT) | Complete | COMPLETE |  |  |  |  |
| 220 | 1.3.6.2.1.6.3 | Elexon Central Systems PIT Completion Report submitted to Programme for assurance | milestone | 0d | 2023-09-27 A | 2023-09-27 A | 219 | 100% | 2023-09-27 | 2023-09-27 | 0d | 2024-01-05 | 2024-01-05 |  |  | PP | SI Test | DBT | 5.8 |  | Design, Build & Test (PIT) | Complete | COMPLETE |  | T3-DB-0109 | SITAG | T3 |
| 221 | 1.3.6.2.1.6.4 | Elexon Central Systems PIT Completion Report MHHS Review Completed | milestone | 0d | 2023-10-11 A | 2023-10-11 A | 213, 216, 218, 220FS+10d, 208 | 100% | 2023-10-11 | 2023-10-11 | 0d |  |  |  |  | SI Test | PP | DBT | 5.8 |  | Design, Build & Test (PIT) | Complete | COMPLETE |  | T3-DB-0110 | SITAG | T3 |
| 222 | 1.3.6.2.2 | **DIP DBT CIT (Entering at Interval 1)** |  | 221d | 2023-01-02 A | 2023-11-06 A |  | 100% | 2023-01-02 | 2023-11-06 | 266d | 2022-10-31 | 2023-09-29 |  | -0 | N/A | N/A | DBT | 5.0 | N/A | Design, Build & Test (PIT) |  |  |  |  |  |  |
| 223 | 1.3.6.2.2.1 | Design |  | 80d | 2023-01-02 A | 2023-04-21 A |  | 100% | 2023-01-02 | 2023-04-21 | 80d | 2023-01-02 | 2023-04-21 | must start on 2023-01-02 |  | PP | SI Design | DBT | 5.0 |  | Design, Build & Test (PIT) | Complete | COMPLETE |  |  |  |  |
| 224 | 1.3.6.2.2.2 | Build |  | 155d | 2023-01-09 A | 2023-08-11 A | 223SS+5d | 100% | 2023-01-09 | 2023-08-11 | 155d | 2023-01-09 | 2023-08-11 |  |  | PP |  | DBT | 5.5 |  | Design, Build & Test (PIT) | Complete | COMPLETE |  |  |  |  |
| 225 | 1.3.6.2.2.3 | **Test Approach & Plan** |  | 9d | 2023-07-07 A | 2023-07-20 A |  | 100% | 2023-07-07 | 2023-07-20 | 190d | 2022-10-31 | 2023-07-21 |  |  | N/A | N/A | DBT | 5.0 | N/A | Design, Build & Test (PIT) |  |  |  |  |  |  |
| 226 | 1.3.6.2.2.3.1 | DIP Test Approach & Plan (PIT) submitted to Programme for assurance | milestone | 0d | 2023-07-07 A | 2023-07-07 A |  | 100% | 2023-07-07 | 2023-07-07 | 0d | 2023-07-07 | 2023-07-07 |  |  | PP | SI Test | DBT | 5.0 |  | Design, Build & Test (PIT) | Complete | COMPLETE | MHHS-ART073 | T3-DB-0026 | SITAG | T3 |
| 227 | 1.3.6.2.2.3.2 | DIP Test Approach & Plan (PIT) MHHS Review Completed | milestone | 0d | 2023-07-20 A | 2023-07-20 A | 226FS+9d | 100% | 2023-07-20 | 2023-07-20 | 10d | 2023-07-10 | 2023-07-21 |  |  | SI Test | PP | DBT | 5.0 |  | Design, Build & Test (PIT) | Complete | COMPLETE |  |  |  |  |
| 228 | 1.3.6.2.2.4 | **PIT Test Readiness Report** |  | 31d | 2023-07-21 A | 2023-09-01 A |  | 100% | 2023-07-21 | 2023-09-01 | 51d | 2023-07-21 | 2023-09-29 |  |  | N/A | N/A | DBT | 5.0 | N/A | Design, Build & Test (PIT) |  |  |  |  |  |  |
| 229 | 1.3.6.2.2.4.1 | Test readiness reporting |  | 31d | 2023-07-21 A | 2023-09-01 A | 226FS+9d | 100% | 2023-07-21 | 2023-09-01 | 51d | 2023-07-21 | 2023-09-29 |  |  | SI Test | 109 | DBT | 5.0 |  | Design, Build & Test (PIT) | Complete | COMPLETE |  |  |  |  |
| 230 | 1.3.6.2.2.5 | **Requirements to test Traceability Matrix (RTTM)** |  | 18d | 2023-08-04 A | 2023-08-30 A |  | 100% | 2023-08-04 | 2023-08-30 | 210d | 2022-10-31 | 2023-08-18 |  |  | N/A | N/A | DBT | 5.0 | N/A | Design, Build & Test (PIT) |  |  |  |  |  |  |
| 231 | 1.3.6.2.2.5.1 | DIP RTTM submitted to Programme for assurance | milestone | 0d | 2023-08-04 A | 2023-08-04 A | 226FS+15d | 100% | 2023-08-04 | 2023-08-04 | 0d | 2023-08-04 | 2023-08-04 |  |  | PP | SI Test | DBT | 5.6 |  | Design, Build & Test (PIT) | Complete | COMPLETE | MHHS-ART009 | T3-DB-0034 | SITAG | T3 |
| 232 | 1.3.6.2.2.5.2 | DIP RTTM MHHS Review Completed | milestone | 0d | 2023-08-30 A | 2023-08-30 A | 231FS+18d | 100% | 2023-08-30 | 2023-08-30 | 10d | 2023-08-07 | 2023-08-18 |  |  | SI Test | PP | DBT | 5.0 |  | Design, Build & Test (PIT) | Complete | COMPLETE |  |  |  |  |

Notes:
- 229: Action: 14/8 - Query from RG - IS this an SI Test deliverable or expected to be a DIP deliverable if so be more specific

| ID | WBS | Task | Type | Duration | Start | Finish | Predecessors | Complete | Baseline start | Baseline finish | Baseline duration | Baseline 1 start | Baseline 1 finish | Constraint | Baseline cost | Responsible | Involved | Text9 | Update Version | MHHS Resource Name | MHHS Programme Phase | Sched Status | RAG | Milestone ID | Text29 | Tier |
| --- | --- | --- | --- | --- | --- | --- | --- | --- | --- | --- | --- | --- | --- | --- | --- | --- | --- | --- | --- | --- | --- | --- | --- | --- | --- | --- |
| 233 | 1.3.6.2.2.6 | **Test Scenarios** |  | 22d | 2023-07-31 A | 2023-08-30 A |  | 100% | 2023-07-31 | 2023-08-30 | 206d | 2022-10-31 | 2023-08-18 |  |  | N/A | N/A | DBT | 5.0 | N/A | Design, Build & Test (PIT) |  |  |  |  |  |
| 234 | 1.3.6.2.2.6.1 | DIP PIT test scenarios submitted to Programme for assurance | milestone | 0d | 2023-07-31 A | 2023-07-31 A | 226FS+15d | 100% | 2023-07-31 | 2023-07-31 | 0d | 2023-08-04 | 2023-08-04 |  |  | PP | SI Test | DBT | 5.0 |  | Design, Build & Test (PIT) | Complete | COMPLETE | T3-DB-0036 | SITAG | T3 |
| 235 | 1.3.6.2.2.6.2 | DIP Test scenarios MHHS Review Completed | milestone | 0d | 2023-08-30 A | 2023-08-30 A | 234FS+22d | 100% | 2023-08-30 | 2023-08-30 | 10d | 2023-08-07 | 2023-08-18 |  |  | SI Test | PP | DBT | 5.0 |  | Design, Build & Test (PIT) | Complete | COMPLETE |  |  |  |
| 236 | 1.3.6.2.2.7 | **PIT execution** |  | 50d | 2023-08-29 A | 2023-11-06 A |  | 100% | 2023-08-29 | 2023-11-06 | 47d | 2022-10-31 | 2023-09-29 |  | -0 | N/A | N/A | DBT | 5.0 | N/A | Design, Build & Test (PIT) |  |  |  |  |  |
| 237 | 1.3.6.2.2.7.1 | PIT Test Execution Progress Report |  | 37d | 2023-09-01 A | 2023-10-23 A | 238FF, 229 | 100% | 2023-09-01 | 2023-10-23 | 37d | 2022-10-31 | 2023-09-22 | start no earlier than 2023-08-29 |  | PP | SI Test | DBT | 5.6 |  | Design, Build & Test (PIT) | Complete | COMPLETE |  |  |  |
| 238 | 1.3.6.2.2.7.2 | PIT Execution (Interim Release 1) |  | 30d | 2023-08-29 A | 2023-10-09 A |  | 100% | 2023-08-29 | 2023-10-09 | 24d | 2022-10-31 | 2023-09-29 | start no earlier than 2023-08-29 |  | PP | SI Test | DBT | 5.6 |  | Design, Build & Test (PIT) | Complete | COMPLETE |  |  |  |
| 239 | 1.3.6.2.2.7.3 | PIT Execution (Interim Release 2) |  | 10d | 2023-10-10 A | 2023-10-23 A | 238 | 100% | 2023-10-10 | 2023-10-23 | 10d |  |  |  |  | PP | SI Test | DBT | 5.6 |  | Design, Build & Test (PIT) | Complete | COMPLETE |  |  |  |
| 240 | 1.3.6.2.2.7.4 | DIP PIT Completion Report (Interim Release 1) submitted to Programme for assurance | milestone | 0d | 2023-10-09 A | 2023-10-09 A | 238 | 100% | 2023-10-09 | 2023-10-09 | 0d | 2024-01-05 | 2024-01-05 |  |  | PP | SI Test | DBT | 5.8 |  | Design, Build & Test (PIT) | Complete | COMPLETE | T3-DB-0111 | SITAG | T3 |
| 241 | 1.3.6.2.2.7.5 | DIP PIT Completion Report (Interim Release 1) MHHS Review Completed | milestone | 0d | 2023-10-23 A | 2023-10-23 A | 240FS+10d | 100% | 2023-10-23 | 2023-10-23 | 0d |  |  |  |  | SI Test | SI Test | DBT | 5.10 |  | Design, Build & Test (PIT) | Complete | COMPLETE | T3-DB-0112 | SITAG | T3 |
| 242 | 1.3.6.2.2.7.6 | DIP PIT Completion Report (Interim Release 2) submitted to Programme for assurance | milestone | 0d | 2023-10-23 A | 2023-10-23 A | 239, 237 | 100% | 2023-10-23 | 2023-10-23 | 0d | 2024-01-05 | 2024-01-05 |  |  | PP | SI Test | DBT | 5.10 |  | Design, Build & Test (PIT) | Complete | COMPLETE | T3-DB-0113 | SITAG | T3 |
| 243 | 1.3.6.2.2.7.7 | DIP PIT Completion Report (Interim Release 2) MHHS Review Completed | milestone | 0d | 2023-11-06 A | 2023-11-06 A | 242FS+10d | 100% | 2023-11-06 | 2023-11-06 | 0d |  |  |  |  | SI Test | SI Test | DBT | 5.14 |  | Design, Build & Test (PIT) | Complete | COMPLETE | T3-DB-0114 | SITAG | T3 |
| 244 | 1.3.6.2.3 | **DCC (DSP) DBT SIT Functional (Entering at SIT Functional)** |  | 325d | 2022-10-31 A | 2024-01-26 A |  | 100% | 2022-10-31 | 2024-01-26 | 345d | 2022-10-31 | 2024-01-05 |  | -0 | N/A | N/A | DBT | 5.18 | N/A | Design, Build & Test (PIT) |  |  |  |  |  |
| 245 | 1.3.6.2.3.1 | Design |  | 67d | 2022-10-31 A | 2023-01-31 A |  | 100% | 2022-10-31 | 2023-01-31 | 67d | 2022-10-31 | 2023-01-31 |  |  | PP | SI Design | DBT | 5.18 |  | Design, Build & Test (PIT) | Complete | COMPLETE |  |  |  |
| 246 | 1.3.6.2.3.2 | **Test Approach & Plan** |  | 20d | 2023-11-17 A | 2023-12-15 A |  | 100% | 2023-11-17 | 2023-12-15 | 20d | 2022-10-31 | 2023-10-27 |  | -0 | N/A | N/A | DBT | 5.18 | N/A | Design, Build & Test (PIT) |  |  |  |  |  |
| 247 | 1.3.6.2.3.2.1 | DCC Test Approach & Plan (PIT) submitted to Programme for assurance | milestone | 0d | 2023-11-17 A | 2023-11-17 A | 245FS+208d | 100% | 2023-11-17 | 2023-11-17 | 0d | 2023-10-13 | 2023-10-13 |  |  | PP | SI Test | DBT | 5.18 |  | Design, Build & Test (PIT) | Complete | COMPLETE | T3-DB-0068 | SITAG | T3 |
| 248 | 1.3.6.2.3.2.2 | DCC Test Approach & Plan (PIT) MHHS Review Completed | milestone | 0d | 2023-12-15 A | 2023-12-15 A | 247FS+20d | 100% | 2023-12-15 | 2023-12-15 | 0d | 2023-10-16 | 2023-10-27 |  |  | SI Test | PP | DBT | 5.18 |  | Design, Build & Test (PIT) | Complete | COMPLETE | T3-DB-0115 | SITAG | T3 |
| 249 | 1.3.6.2.3.3 | **Test Readiness Report** |  | 22d | 2023-12-04 A | 2024-01-02 A |  | 100% | 2023-12-04 | 2024-01-02 | 51d | 2023-10-27 | 2024-01-05 |  |  | N/A | N/A | DBT | 5.18 | N/A | Design, Build & Test (PIT) |  |  |  |  |  |
| 250 | 1.3.6.2.3.3.1 | Test readiness reporting |  | 22d | 2023-12-04 A | 2024-01-02 A | 247FS+10d | 100% | 2023-12-04 | 2024-01-02 | 51d | 2023-10-27 | 2024-01-05 |  |  | PP | 109 | DBT | 5.18 |  | Design, Build & Test (PIT) | Complete | COMPLETE |  |  |  |
| 251 | 1.3.6.2.3.4 | **Requirements to test Traceability Matrix (RTTM)** |  | 30d | 2023-12-15 A | 2024-01-26 A |  | 100% | 2023-12-15 | 2024-01-26 | 30d | 2022-10-31 | 2023-11-24 |  | -0 | N/A | N/A | DBT | 5.18 | N/A | Design, Build & Test (PIT) |  |  |  |  |  |
| 252 | 1.3.6.2.3.4.1 | DCC RTTM submitted to Programme for assurance | milestone | 0d | 2023-12-15 A | 2023-12-15 A | 247FS+20d | 100% | 2023-12-15 | 2023-12-15 | 0d | 2023-11-10 | 2023-11-10 | start no earlier than 2023-04-28 |  | PP | SI Test | DBT | 5.18 |  | Design, Build & Test (PIT) | Complete | COMPLETE | T3-DB-0074 | SITAG | T3 |
| 253 | 1.3.6.2.3.4.2 | DCC RTTM MHHS Review Completed | milestone | 0d | 2024-01-26 A | 2024-01-26 A | 252FS+30d | 100% | 2024-01-26 | 2024-01-26 | 0d | 2023-11-13 | 2023-11-24 |  |  | SI Test | PP | DBT | 5.18 |  | Design, Build & Test (PIT) | Complete | COMPLETE | T3-DB-0116 | SITAG | T3 |
| 254 | 1.3.6.2.3.5 | **Test Scenarios** |  | 30d | 2023-12-15 A | 2024-01-26 A |  | 100% | 2023-12-15 | 2024-01-26 | 30d | 2022-10-31 | 2023-11-24 |  | -0 | N/A | N/A | DBT | 5.18 | N/A | Design, Build & Test (PIT) |  |  |  |  |  |
| 255 | 1.3.6.2.3.5.1 | DCC test scenarios submitted to Programme for assurance | milestone | 0d | 2023-12-15 A | 2023-12-15 A | 247FS+20d | 100% | 2023-12-15 | 2023-12-15 | 0d | 2023-11-10 | 2023-11-10 |  |  | PP | SI Test | DBT | 5.18 |  | Design, Build & Test (PIT) | Complete | COMPLETE | T3-DB-0078 | SITAG | T3 |
| 256 | 1.3.6.2.3.5.2 | DCC Test Scenarios MHHS Review Completed | milestone | 0d | 2024-01-26 A | 2024-01-26 A | 255FS+30d | 100% | 2024-01-26 | 2024-01-26 | 0d | 2023-11-13 | 2023-11-24 |  |  | SI Test | PP | DBT | 5.18 |  | Design, Build & Test (PIT) | Complete | COMPLETE | T3-DB-0117 | SITAG | T3 |

Notes:
- 243: Guidance: 6/10 - LC - Successor should be SIT Component Integration Testing 1 Preparation Complete but not linked as DIP test completion plus 10 day review breaks logic. Decision will be made to proceed without a conclusion of the report review

| ID | WBS | Task | Type | Duration | Start | Finish | Predecessors | Complete | Baseline start | Baseline finish | Baseline duration | Baseline 1 start | Baseline 1 finish | Constraint | Baseline cost | Responsible | Involved | Text9 | Update Version | MHHS Resource Name | MHHS Programme Phase | Sched Status | RAG | Milestone ID | Text29 | Tier | Artefact ID |
| --- | --- | --- | --- | --- | --- | --- | --- | --- | --- | --- | --- | --- | --- | --- | --- | --- | --- | --- | --- | --- | --- | --- | --- | --- | --- | --- | --- |
| 257 | 1.3.6.2.4 | **RECCo (EES) DBT CIT (Entering at Interval 6)** |  | 71d | 2023-10-13 A | 2024-01-19 A |  | 100% | 2023-10-13 | 2024-01-19 | 320d | 2022-10-31 | 2024-01-05 |  | -0 | N/A | N/A | DBT | 5.0 | N/A | Design, Build & Test (PIT) |  |  |  |  |  |  |
| 258 | 1.3.6.2.4.1 | **Test Approach & Plan** |  | 20d | 2023-10-13 A | 2023-11-09 A |  | 100% | 2023-10-13 | 2023-11-09 | 20d | 2022-10-31 | 2023-10-27 |  | -0 | N/A | N/A | DBT | 5.0 | N/A | Design, Build & Test (PIT) |  |  |  |  |  |  |
| 259 | 1.3.6.2.4.1.1 | EES Test Approach & Plan (PIT) submitted to Programme for assurance | milestone | 0d | 2023-10-13 A | 2023-10-13 A |  | 100% | 2023-10-13 | 2023-10-13 | 0d | 2023-10-13 | 2023-10-13 | start no earlier than 2023-10-13 |  | PP | SI Test | DBT | 5.8 |  | Design, Build & Test (PIT) | Complete | COMPLETE | T3-DB-0066 | SITAG | T3 |  |
| 260 | 1.3.6.2.4.1.2 | EES Test approach and plan (PIT) MHHS Review Completed | milestone | 0d | 2023-11-09 A | 2023-11-09 A | 259FS+20d | 100% | 2023-11-09 | 2023-11-09 | 0d | 2023-10-16 | 2023-10-27 |  |  | SI Test | PP | DBT | 5.8 |  | Design, Build & Test (PIT) | Complete | COMPLETE | T3-DB-0119 | SITAG | T3 |  |
| 261 | 1.3.6.2.4.2 | **Test Readiness Report** |  | 10d | 2023-10-27 A | 2023-11-09 A |  | 100% | 2023-10-27 | 2023-11-09 | 51d | 2023-10-27 | 2024-01-05 |  |  | N/A | N/A | DBT | 5.0 | N/A | Design, Build & Test (PIT) |  |  |  |  |  |  |
| 262 | 1.3.6.2.4.2.1 | Test readiness reporting |  | 10d | 2023-10-27 A | 2023-11-09 A | 259FS+10d | 100% | 2023-10-27 | 2023-11-09 | 51d | 2023-10-27 | 2024-01-05 |  |  | PP | 109 | DBT | 5.0 |  | Design, Build & Test (PIT) | Complete | COMPLETE |  |  |  |  |
| 263 | 1.3.6.2.4.3 | **Requirements to test Traceability Matrix (RTTM)** |  | 20d | 2023-11-02 A | 2023-11-30 A |  | 100% | 2023-11-02 | 2023-11-30 | 20d | 2022-10-31 | 2023-11-24 |  | -0 | N/A | N/A | DBT | 5.0 | N/A | Design, Build & Test (PIT) |  |  |  |  |  |  |
| 264 | 1.3.6.2.4.3.1 | EES RTTM submitted to Programme for assurance | milestone | 0d | 2023-11-02 A | 2023-11-02 A | 259FS+15d | 100% | 2023-11-02 | 2023-11-02 | 0d | 2023-11-10 | 2023-11-10 |  |  | PP | SI Test | DBT | 5.8 |  | Design, Build & Test (PIT) | Complete | COMPLETE | T3-DB-0072 | SITAG | T3 | MHHS-ART009 |
| 265 | 1.3.6.2.4.3.2 | EES RTTM MHHS Review Completed | milestone | 0d | 2023-11-30 A | 2023-11-30 A | 264FS+20d | 100% | 2023-11-30 | 2023-11-30 | 0d | 2023-11-13 | 2023-11-24 |  |  | SI Test | PP | DBT | 5.14 |  | Design, Build & Test (PIT) | Complete | COMPLETE | T3-DB-0120 | SITAG | T3 |  |
| 266 | 1.3.6.2.4.4 | **Test Scenarios** |  | 20d | 2023-11-02 A | 2023-11-30 A |  | 100% | 2023-11-02 | 2023-11-30 | 20d | 2022-10-31 | 2023-11-24 |  | -0 | N/A | N/A | DBT | 5.0 | N/A | Design, Build & Test (PIT) |  |  |  |  |  |  |
| 267 | 1.3.6.2.4.4.1 | EES test scenarios submitted to Programme for assurance | milestone | 0d | 2023-11-02 A | 2023-11-02 A | 259FS+15d | 100% | 2023-11-02 | 2023-11-02 | 0d | 2023-11-10 | 2023-11-10 |  |  | PP | SI Test | DBT | 5.8 |  | Design, Build & Test (PIT) | Complete | COMPLETE | T3-DB-0031 | SITAG | T3 |  |
| 268 | 1.3.6.2.4.4.2 | EES Test scenarios MHHS Review Completed | milestone | 0d | 2023-11-30 A | 2023-11-30 A | 267FS+20d | 100% | 2023-11-30 | 2023-11-30 | 0d | 2023-11-13 | 2023-11-24 |  |  | SI Test | PP | DBT | 5.14 |  | Design, Build & Test (PIT) | Complete | COMPLETE | T3-DB-0121 | SITAG | T3 |  |
| 269 | 1.3.6.2.4.5 | **PIT execution** |  | 51d | 2023-11-10 A | 2024-01-19 A |  | 100% | 2023-11-10 | 2024-01-19 | 320d | 2022-10-31 | 2024-01-05 |  | -0 | N/A | N/A | DBT | 5.0 | N/A | Design, Build & Test (PIT) |  |  |  |  |  |  |
| 270 | 1.3.6.2.4.5.1 | PIT Test Execution Progress Report |  | 41d | 2023-11-10 A | 2024-01-05 A | 262 | 100% | 2023-11-10 | 2024-01-05 | 41d | 2022-10-31 | 2023-12-29 |  |  | PP | SI Test | DBT | 5.0 |  | Design, Build & Test (PIT) | Complete | COMPLETE |  |  |  |  |
| 271 | 1.3.6.2.4.5.2 | PIT Execution |  | 41d | 2023-11-10 A | 2024-01-05 A | 267FS+5d | 100% | 2023-11-10 | 2024-01-05 | 310d | 2022-10-31 | 2024-01-05 |  |  | PP | SI Test | DBT | 5.0 |  | Design, Build & Test (PIT) | Complete | COMPLETE |  |  |  |  |
| 272 | 1.3.6.2.4.5.3 | EES PIT Completion Report submitted to Programme for assurance | milestone | 0d | 2024-01-05 A | 2024-01-05 A | 270, 271 | 100% | 2024-01-05 | 2024-01-05 | 0d | 2024-01-05 | 2024-01-05 |  |  | PP | SI Test | DBT | 5.14 |  | Design, Build & Test (PIT) | Complete | COMPLETE | T3-DB-0122 | SITAG | T3 |  |
| 273 | 1.3.6.2.4.5.4 | EES PIT Completion Report MHHS Review Completed | milestone | 0d | 2024-01-19 A | 2024-01-19 A | 260, 265, 268, 272FS+10d | 100% | 2024-01-19 | 2024-01-19 | 0d |  |  |  |  | SI Test | PP | DBT | 5.14 |  | Design, Build & Test (PIT) | Complete | COMPLETE | T3-DB-0123 | SITAG | T3 |  |
| 274 | 1.3.6.2.5 | **Registration Services DBT CIT (Entering at Interval 2)** |  | 70d | 2023-07-28 A | 2023-11-03 A |  | 100% | 2023-07-28 | 2023-11-03 | 70d | 2022-10-31 | 2024-02-28 |  | -0 | N/A | N/A | DBT | 5.0 | N/A | Design, Build & Test (PIT) |  |  |  |  |  |  |
| 275 | 1.3.6.2.5.1 | **Test Approach & Plan** |  | 40d | 2023-07-28 A | 2023-09-22 A |  | 100% | 2023-07-28 | 2023-09-22 | 40d | 2022-10-31 | 2023-08-11 |  | -0 | N/A | N/A | DBT | 5.0 | N/A | Design, Build & Test (PIT) |  |  |  |  |  |  |
| 276 | 1.3.6.2.5.1.1 | Registration Services Test Approach & Plan (PIT) submitted to Programme for assurance | milestone | 0d | 2023-07-28 A | 2023-07-28 A |  | 100% | 2023-07-28 | 2023-07-28 | 0d | 2023-07-28 | 2023-07-28 |  |  | PP | SI Test | DBT | 5.0 |  | Design, Build & Test (PIT) | Complete | COMPLETE | T3-DB-0028 | SITAG | T3 | MHHS-ART073 |
| 277 | 1.3.6.2.5.1.2 | Registration Services Test approach and plan MHHS Review Completed | milestone | 0d | 2023-09-22 A | 2023-09-22 A | 276FS+40d | 100% | 2023-09-22 | 2023-09-22 | 0d | 2023-07-31 | 2023-08-11 |  |  | SI Test | PP | DBT | 5.8 |  | Design, Build & Test (PIT) | Complete | COMPLETE | T3-DB-0124 | SITAG | T3 |  |
| 278 | 1.3.6.2.5.2 | **Test Readiness Report** |  | 20d | 2023-08-14 A | 2023-09-08 A |  | 100% | 2023-08-14 | 2023-09-08 | 51d | 2023-08-11 | 2023-10-20 |  |  | N/A | N/A | DBT | 5.0 | N/A | Design, Build & Test (PIT) |  |  |  |  |  |  |
| 279 | 1.3.6.2.5.2.1 | Test readiness reporting |  | 20d | 2023-08-14 A | 2023-09-08 A | 276FS+10d | 100% | 2023-08-14 | 2023-09-08 | 51d | 2023-08-11 | 2023-10-20 |  |  | PP | 109 | DBT | 5.0 |  | Design, Build & Test (PIT) | Complete | COMPLETE |  |  |  |  |
| 280 | 1.3.6.2.5.3 | **Requirements to test Traceability Matrix (RTTM)** |  | 20d | 2023-09-01 A | 2023-09-29 A |  | 100% | 2023-09-01 | 2023-09-29 | 20d | 2022-10-31 | 2023-09-15 |  | -0 | N/A | N/A | DBT | 5.0 | N/A | Design, Build & Test (PIT) |  |  |  |  |  |  |
| 281 | 1.3.6.2.5.3.1 | Registration Services RTTM submitted to Programme for assurance | milestone | 0d | 2023-09-01 A | 2023-09-01 A | 276FS+15d | 100% | 2023-09-01 | 2023-09-01 | 0d | 2023-09-01 | 2023-09-01 | start no earlier than 2023-04-28 |  | PP | SI Test | DBT | 5.6 |  | Design, Build & Test (PIT) | Complete | COMPLETE | T3-DB-0042 | SITAG | T3 | MHHS-ART009 |
| 282 | 1.3.6.2.5.3.2 | Registration Services RTTM MHHS Review Completed | milestone | 0d | 2023-09-29 A | 2023-09-29 A | 281FS+20d | 100% | 2023-09-29 | 2023-09-29 | 0d | 2023-09-04 | 2023-09-15 |  |  | SI Test | PP | DBT | 5.8 |  | Design, Build & Test (PIT) | Complete | COMPLETE | T3-DB-0125 | SITAG | T3 |  |

| ID | WBS | Task | Type | Duration | Start | Finish | Predecessors | Complete | Baseline start | Baseline finish | Baseline duration | Baseline 1 start | Baseline 1 finish | Constraint | Baseline cost | Responsible | Involved | Text9 | Update Version | MHHS Resource Name | MHHS Programme Phase | Sched Status | RAG | Milestone ID | Text29 | Tier |
| --- | --- | --- | --- | --- | --- | --- | --- | --- | --- | --- | --- | --- | --- | --- | --- | --- | --- | --- | --- | --- | --- | --- | --- | --- | --- | --- |
| 283 | 1.3.6.2.5.4 | **Test Scenarios** |  | 20d | 2023-09-01 A | 2023-09-29 A |  | 100% | 2023-09-01 | 2023-09-29 | 20d | 2022-10-31 | 2023-09-15 |  | -0 | N/A | N/A | DBT | 5.0 | N/A | Design, Build & Test (PIT) |  |  |  |  |  |
| 284 | 1.3.6.2.5.4.1 | Registration Services test scenarios submitted to Programme for assurance | milestone | 0d | 2023-09-01 A | 2023-09-01 A | 276FS+15d | 100% | 2023-09-01 | 2023-09-01 | 0d | 2023-09-01 | 2023-09-01 |  |  | PP | SI Test | DBT | 5.6 |  | Design, Build & Test (PIT) | Complete | COMPLETE | T3-DB-0044 | SITAG | T3 |
| 285 | 1.3.6.2.5.4.2 | Registration Services Test scenarios MHHS Review Completed | milestone | 0d | 2023-09-29 A | 2023-09-29 A | 284FS+20d | 100% | 2023-09-29 | 2023-09-29 | 0d | 2023-09-04 | 2023-09-15 |  |  | SI Test | PP | DBT | 5.8 |  | Design, Build & Test (PIT) | Complete | COMPLETE | T3-DB-0126 | SITAG | T3 |
| 286 | 1.3.6.2.5.5 | **PIT execution** |  | 40d | 2023-09-11 A | 2023-11-03 A |  | 100% | 2023-09-11 | 2023-11-03 | 40d | 2023-01-02 | 2023-10-20 |  | -0 | N/A | N/A | DBT | 5.0 | N/A | Design, Build & Test (PIT) |  |  |  |  |  |
| 287 | 1.3.6.2.5.5.1 | PIT Test Execution Progress Report |  | 33d | 2023-09-11 A | 2023-10-25 A | 279 | 100% | 2023-09-11 | 2023-10-25 | 30d | 2023-01-02 | 2023-10-13 |  |  | PP | SI Test | DBT | 5.0 |  | Design, Build & Test (PIT) | Complete | COMPLETE |  |  |  |
| 288 | 1.3.6.2.5.5.2 | PIT Execution |  | 30d | 2023-09-11 A | 2023-10-20 A | 284FS+5d | 100% | 2023-09-11 | 2023-10-20 | 30d | 2023-01-16 | 2023-10-20 |  |  | PP | SI Test | DBT | 5.0 |  | Design, Build & Test (PIT) | Complete | COMPLETE |  |  |  |
| 289 | 1.3.6.2.5.5.3 | Registration Services PIT (CIT interval 2) Completion Report submitted to Programme for assurance | milestone | 0d | 2023-10-25 A | 2023-10-25 A | 287, 288 | 100% | 2023-10-25 | 2023-10-25 | 0d | 2024-01-05 | 2024-01-05 |  |  | PP | SI Test | DBT | 5.10 |  | Design, Build & Test (PIT) | Complete | COMPLETE | T3-DB-0127 | SITAG | T3 |
| 290 | 1.3.6.2.5.5.4 | Registration Services PIT (CIT interval 2) Completion Report MHHS Review Completed | milestone | 0d | 2023-11-03 A | 2023-11-03 A | 277, 282, 285, 289FS+7d | 100% | 2023-11-03 | 2023-11-03 | 0d |  |  |  |  | SI Test | PP | DBT | 5.11 |  | Design, Build & Test (PIT) | Complete | COMPLETE | T3-DB-0128 | SITAG | T3 |
| 291 | 1.3.6.3 | **SIT Participants DBT** |  | 401d | 2023-08-11 A | 2025-02-21 A |  | 100% | 2023-08-11 | 2024-12-20 | 495d | 2022-10-31 | 2025-03-14 |  | -0 | N/A | N/A | DBT | 5.0 | N/A | Design, Build & Test (PIT) |  |  |  |  |  |
| 292 | 1.3.6.3.1 | **All Data Services DBT CIT (Entering at Interval 3)** |  | 71d | 2023-08-11 A | 2023-11-17 A |  | 100% | 2023-08-11 | 2023-11-17 | 275d | 2022-10-31 | 2023-11-03 |  | -0 | N/A | N/A | DBT | 5.0 | N/A | Design, Build & Test (PIT) |  |  |  |  |  |
| 293 | 1.3.6.3.1.1 | **Test Approach & Plan** |  | 30d | 2023-08-11 A | 2023-09-21 A |  | 100% | 2023-08-11 | 2023-09-21 | 29d | 2022-10-31 | 2023-08-25 |  | -0 | N/A | N/A | DBT | 5.0 | N/A | Design, Build & Test (PIT) |  |  |  |  |  |
| 294 | 1.3.6.3.1.1.1 | All Data Services Test Approach & Plans (PIT) submitted to Programme for assurance | milestone | 0d | 2023-08-11 A | 2023-08-11 A |  | 100% | 2023-08-11 | 2023-08-11 | 0d | 2023-08-11 | 2023-08-11 | start no earlier than 2023-08-11 |  | PP | SI Test | DBT | 5.0 |  | Design, Build & Test (PIT) | Complete | COMPLETE | T3-DB-0038 | SITAG | T3 |
| 295 | 1.3.6.3.1.1.2 | All Data Services Test approach and plans MHHS Review Completed | milestone | 0d | 2023-09-21 A | 2023-09-21 A | 294FS+30d | 100% | 2023-09-21 | 2023-09-21 | 0d | 2023-08-14 | 2023-08-25 |  |  | SI Test | PP | DBT | 5.11 |  | Design, Build & Test (PIT) | Complete | COMPLETE | T3-DB-0129 | SITAG | T3 |
| 296 | 1.3.6.3.1.2 | **Test Readiness Report** |  | 11d | 2023-08-25 A | 2023-09-08 A |  | 100% | 2023-08-25 | 2023-09-08 | 11d | 2023-08-25 | 2023-11-03 |  | -0 | N/A | N/A | DBT | 5.0 | N/A | Design, Build & Test (PIT) |  |  |  |  |  |
| 297 | 1.3.6.3.1.2.1 | Test readiness reporting |  | 11d | 2023-08-25 A | 2023-09-08 A | 294FS+10d | 100% | 2023-08-25 | 2023-09-08 | 11d | 2023-08-25 | 2023-11-03 |  |  | PP | 109 | DBT | 5.0 |  | Design, Build & Test (PIT) | Complete | COMPLETE |  |  |  |
| 298 | 1.3.6.3.1.3 | **Requirements to test Traceability Matrix (RTTM)** |  | 7d | 2023-09-20 A | 2023-09-29 A |  | 100% | 2023-09-20 | 2023-09-29 | 5d | 2022-10-31 | 2023-10-06 |  | -0 | N/A | N/A | DBT | 5.0 | N/A | Design, Build & Test (PIT) |  |  |  |  |  |
| 299 | 1.3.6.3.1.3.1 | All Data Services RTTMs submitted to Programme for assurance | milestone | 0d | 2023-09-20 A | 2023-09-20 A | 294FS+29d | 100% | 2023-09-20 | 2023-09-20 | 0d | 2023-09-22 | 2023-09-22 |  |  | PP | SI Test | DBT | 5.7 |  | Design, Build & Test (PIT) | Complete | COMPLETE | T3-DB-0058 | SITAG | T3 |
| 300 | 1.3.6.3.1.3.2 | All Data Services RTTMs MHHS Review Completed | milestone | 0d | 2023-09-29 A | 2023-09-29 A | 299FS+7d | 100% | 2023-09-29 | 2023-09-29 | 0d | 2023-09-25 | 2023-10-06 |  |  | SI Test | PP | DBT | 5.8 |  | Design, Build & Test (PIT) | Complete | COMPLETE | T3-DB-0130 | SITAG | T3 |
| 301 | 1.3.6.3.1.4 | **Test Scenarios** |  | 6d | 2023-09-20 A | 2023-09-28 A |  | 100% | 2023-09-20 | 2023-09-28 | 4d | 2022-10-31 | 2023-10-06 |  | -0 | N/A | N/A | DBT | 5.0 | N/A | Design, Build & Test (PIT) |  |  |  |  |  |
| 302 | 1.3.6.3.1.4.1 | All Data Services test scenarios' submitted to Programme for assurance | milestone | 0d | 2023-09-20 A | 2023-09-20 A | 294FS+29d | 100% | 2023-09-20 | 2023-09-20 | 0d | 2023-09-22 | 2023-09-22 |  |  | PP | SI Test | DBT | 5.7 |  | Design, Build & Test (PIT) | Complete | COMPLETE | T3-DB-0056 | SITAG | T3 |
| 303 | 1.3.6.3.1.4.2 | All Data Services Test scenarios' MHHS Review Completed | milestone | 0d | 2023-09-28 A | 2023-09-28 A | 302FS+6d | 100% | 2023-09-28 | 2023-09-28 | 0d | 2023-09-25 | 2023-10-06 |  |  | SI Test | PP | DBT | 5.11 |  | Design, Build & Test (PIT) | Complete | COMPLETE | T3-DB-0131 | SITAG | T3 |
| 304 | 1.3.6.3.1.5 | **PIT execution** |  | 50d | 2023-09-11 A | 2023-11-17 A |  | 100% | 2023-09-11 | 2023-11-17 | 275d | 2022-10-31 | 2023-11-03 |  | -0 | N/A | N/A | DBT | 5.0 | N/A | Design, Build & Test (PIT) |  |  |  |  |  |
| 305 | 1.3.6.3.1.5.1 | PIT Test Execution Progress Report |  | 40d | 2023-09-11 A | 2023-11-03 A | 297 | 100% | 2023-09-11 | 2023-11-03 | 260d | 2022-10-31 | 2023-10-27 |  |  | PP | SI Test | DBT | 5.0 |  | Design, Build & Test (PIT) | Complete | COMPLETE |  |  |  |
| 306 | 1.3.6.3.1.5.2 | PIT Execution |  | 27d | 2023-09-28 A | 2023-11-03 A | 302FS+5d | 100% | 2023-09-28 | 2023-11-03 | 265d | 2022-10-31 | 2023-11-03 |  |  | PP | SI Test | DBT | 5.0 |  | Design, Build & Test (PIT) | Complete | COMPLETE |  |  |  |
| 307 | 1.3.6.3.1.5.3 | All Data Services PIT Completion Reports submitted to Programme for assurance | milestone | 0d | 2023-11-03 A | 2023-11-03 A | 305, 306 | 100% | 2023-11-03 | 2023-11-03 | 0d | 2024-01-05 | 2024-01-05 |  |  | PP | SI Test | DBT | 5.11 |  | Design, Build & Test (PIT) | Complete | COMPLETE | T3-DB-0132 | SITAG | T3 |
| 308 | 1.3.6.3.1.5.4 | All Data Services PIT Completion Reports MHHS Review Completed | milestone | 0d | 2023-11-17 A | 2023-11-17 A | 295, 300, 303, 307FS+10d | 100% | 2023-11-17 | 2023-11-17 | 0d |  |  |  |  | SI Test | PP | DBT | 5.13 |  | Design, Build & Test (PIT) | Complete | COMPLETE | T3-DB-0133 | SITAG | T3 |

| ID | WBS | Task | Type | Duration | Start | Finish | Predecessors | Complete | Baseline start | Baseline finish | Baseline duration | Baseline 1 start | Baseline 1 finish | Constraint | Baseline cost | Responsible | Involved | Text9 | Update Version | MHHS Resource Name | MHHS Programme Phase | Sched Status | RAG | Milestone ID | Text29 | Tier | Artefact ID |
| --- | --- | --- | --- | --- | --- | --- | --- | --- | --- | --- | --- | --- | --- | --- | --- | --- | --- | --- | --- | --- | --- | --- | --- | --- | --- | --- | --- |
| 309 | 1.3.6.3.2 | **All Metering Services DBT CIT (Entering at Interval 4)** |  | 70d | 2023-08-25 A | 2023-12-01 A |  | 100% | 2023-08-25 | 2023-12-01 | 285d | 2022-10-31 | 2023-11-17 |  | -0 | N/A | N/A | DBT | 5.0 | N/A | Design, Build & Test (PIT) |  |  |  |  |  |  |
| 310 | 1.3.6.3.2.1 | **Test Approach & Plan** |  | 40d | 2023-08-25 A | 2023-10-20 A |  | 100% | 2023-08-25 | 2023-10-20 | 40d | 2022-10-31 | 2023-09-08 |  | -0 | N/A | N/A | DBT | 5.0 | N/A | Design, Build & Test (PIT) |  |  |  |  |  |  |
| 311 | 1.3.6.3.2.1.1 | All Metering Services Test Approach & Plans (PIT) submitted to Programme for assurance | milestone | 0d | 2023-08-25 A | 2023-08-25 A |  | 100% | 2023-08-25 | 2023-08-25 | 0d | 2023-08-25 | 2023-08-25 |  |  | PP | SI Test | DBT | 5.6 |  | Design, Build & Test (PIT) | Complete | COMPLETE | T3-DB-0040 | SITAG | T3 |  |
| 312 | 1.3.6.3.2.1.2 | All Metering Services Test approach and plans MHHS Review Completed | milestone | 0d | 2023-10-20 A | 2023-10-20 A | 311FS+40d | 100% | 2023-10-20 | 2023-10-20 | 0d | 2023-08-28 | 2023-09-08 |  |  | SI Test | PP | DBT | 5.8 |  | Design, Build & Test (PIT) | Complete | COMPLETE | T3-DB-0134 | SITAG | T3 |  |
| 313 | 1.3.6.3.2.2 | **Test Readiness Report** |  | 11d | 2023-09-11 A | 2023-09-25 A |  | 100% | 2023-09-11 | 2023-09-25 | 51d | 2023-09-08 | 2023-11-17 |  |  | N/A | N/A | DBT | 5.0 | N/A | Design, Build & Test (PIT) |  |  |  |  |  |  |
| 314 | 1.3.6.3.2.2.1 | Test readiness reporting |  | 11d | 2023-09-11 A | 2023-09-25 A | 311FS+10d | 100% | 2023-09-11 | 2023-09-25 | 51d | 2023-09-08 | 2023-11-17 |  |  | PP | 109 | DBT | 5.0 |  | Design, Build & Test (PIT) | Complete | COMPLETE |  |  |  |  |
| 315 | 1.3.6.3.2.3 | **Requirements to test Traceability Matrix (RTTM)** |  | 30d | 2023-09-15 A | 2023-10-27 A |  | 100% | 2023-09-15 | 2023-10-27 | 30d | 2022-10-31 | 2023-09-29 |  | -0 | N/A | N/A | DBT | 5.0 | N/A | Design, Build & Test (PIT) |  |  |  |  |  |  |
| 316 | 1.3.6.3.2.3.1 | All Metering Services RTTMs submitted to Programme for assurance | milestone | 0d | 2023-09-15 A | 2023-09-15 A | 311FS+15d | 100% | 2023-09-15 | 2023-09-15 | 0d | 2023-09-15 | 2023-09-15 |  |  | PP | SI Test | DBT | 5.8 |  | Design, Build & Test (PIT) | Complete | COMPLETE | T3-DB-0048 | SITAG | T3 | MHHS-ART009 |
| 317 | 1.3.6.3.2.3.2 | All Metering Services MHHS Reviews Completed | milestone | 0d | 2023-10-27 A | 2023-10-27 A | 316FS+30d | 100% | 2023-10-27 | 2023-10-27 | 0d | 2023-09-18 | 2023-09-29 |  |  | SI Test | PP | DBT | 5.13 |  | Design, Build & Test (PIT) | Complete | COMPLETE | T3-DB-0135 | SITAG | T3 |  |
| 318 | 1.3.6.3.2.4 | **Test Scenarios** |  | 30d | 2023-09-15 A | 2023-10-27 A |  | 100% | 2023-09-15 | 2023-10-27 | 30d | 2022-10-31 | 2023-09-29 |  | -0 | N/A | N/A | DBT | 5.0 | N/A | Design, Build & Test (PIT) |  |  |  |  |  |  |
| 319 | 1.3.6.3.2.4.1 | All Metering Services test scenarios' submitted to Programme for assurance | milestone | 0d | 2023-09-15 A | 2023-09-15 A | 311FS+15d | 100% | 2023-09-15 | 2023-09-15 | 0d | 2023-09-15 | 2023-09-15 |  |  | PP | SI Test | DBT | 5.8 |  | Design, Build & Test (PIT) | Complete | COMPLETE | T3-DB-0050 | SITAG | T3 |  |
| 320 | 1.3.6.3.2.4.2 | All Metering Services Test scenarios' MHHS Review Completed | milestone | 0d | 2023-10-27 A | 2023-10-27 A | 319FS+30d | 100% | 2023-10-27 | 2023-10-27 | 0d | 2023-09-18 | 2023-09-29 |  |  | SI Test | PP | DBT | 5.13 |  | Design, Build & Test (PIT) | Complete | COMPLETE | T3-DB-0136 | SITAG | T3 |  |
| 321 | 1.3.6.3.2.5 | **PIT execution** |  | 50d | 2023-09-25 A | 2023-12-01 A |  | 100% | 2023-09-25 | 2023-12-01 | 285d | 2022-10-31 | 2023-11-17 |  | -0 | N/A | N/A | DBT | 5.0 | N/A | Design, Build & Test (PIT) |  |  |  |  |  |  |
| 322 | 1.3.6.3.2.5.1 | PIT Test Execution Progress Report |  | 39d | 2023-09-26 A | 2023-11-17 A | 314 | 100% | 2023-09-26 | 2023-11-17 | 39d | 2022-10-31 | 2023-11-10 |  |  | PP | SI Test | DBT | 5.0 |  | Design, Build & Test (PIT) | Complete | COMPLETE |  |  |  |  |
| 323 | 1.3.6.3.2.5.2 | PIT Execution |  | 40d | 2023-09-25 A | 2023-11-17 A | 319FS+5d | 100% | 2023-09-25 | 2023-11-17 | 275d | 2022-10-31 | 2023-11-17 |  |  | PP | SI Test | DBT | 5.0 |  | Design, Build & Test (PIT) | Complete | COMPLETE |  |  |  |  |
| 324 | 1.3.6.3.2.5.3 | All Metering Services PIT Completion Reports submitted to Programme for assurance | milestone | 0d | 2023-11-17 A | 2023-11-17 A | 322, 323 | 100% | 2023-11-17 | 2023-11-17 | 0d | 2024-01-05 | 2024-01-05 |  |  | PP | SI Test | DBT | 5.13 |  | Design, Build & Test (PIT) | Complete | COMPLETE | T3-DB-0137 | SITAG | T3 |  |
| 325 | 1.3.6.3.2.5.4 | All Metering Services PIT Completion Reports MHHS Review Completed | milestone | 0d | 2023-12-01 A | 2023-12-01 A | 312, 317, 320, 324FS+10d | 100% | 2023-12-01 | 2023-12-01 | 0d |  |  |  |  | SI Test | PP | DBT | 5.13 |  | Design, Build & Test (PIT) | Complete | COMPLETE | T3-DB-0138 | SITAG | T3 |  |
| 326 | 1.3.6.3.3 | **All SIT Programme Participants PIT (SIT Functional)** |  | 331d | 2023-11-17 A | 2025-02-21 A |  | 100% | 2023-11-17 | 2024-12-20 | 451d | 2022-12-30 | 2024-02-16 |  | -0 | N/A | N/A | DBT | 5.0 | N/A | Design, Build & Test (PIT) |  |  |  |  |  |  |
| 327 | 1.3.6.3.3.1 | **Test Approach & Plans** |  | 40d | 2023-11-17 A | 2024-01-11 A |  | 100% | 2023-11-17 | 2024-01-11 | 40d | 2022-12-30 | 2023-11-30 |  | -0 | N/A | N/A | DBT | 5.2 | N/A | Design, Build & Test (PIT) |  |  |  |  |  |  |
| 328 | 1.3.6.3.3.1.1 | SIT Functional PIT Test Approach & Plan (PIT) submitted to Programme for assurance | milestone | 0d | 2023-11-17 A | 2023-11-17 A |  | 100% | 2023-11-17 | 2023-11-17 | 0d | 2023-11-16 | 2023-11-16 | start no earlier than 2023-11-17 |  | PP | SI Test | DBT | 5.16 |  | Design, Build & Test (PIT) | Complete | COMPLETE | T3-DB-0093 | SITAG | T3 |  |
| 329 | 1.3.6.3.3.1.2 | All SIT Functional Test approach and plans MHHS Reviews Completed | milestone | 0d | 2024-01-11 A | 2024-01-11 A | 328FS+40d | 100% | 2024-01-11 | 2024-01-11 | 0d | 2023-11-17 | 2023-11-30 |  |  | SI Test | PP | DBT | 5.8 |  | Design, Build & Test (PIT) | Complete | COMPLETE | T3-DB-0139 | SITAG | T3 |  |
| 330 | 1.3.6.3.3.2 | **Test Readiness Reports** |  | 11d | 2023-12-01 A | 2023-12-15 A |  | 100% | 2023-12-01 | 2023-12-15 | 51d | 2023-11-30 | 2024-02-08 |  |  | N/A | N/A | DBT | 5.2 | N/A | Design, Build & Test (PIT) |  |  |  |  |  |  |
| 331 | 1.3.6.3.3.2.1 | Test readiness reporting |  | 11d | 2023-12-01 A | 2023-12-15 A | 328FS+10d | 100% | 2023-12-01 | 2023-12-15 | 51d | 2023-11-30 | 2024-02-08 |  |  | PP | 109 | DBT | 5.2 |  | Design, Build & Test (PIT) | Complete | COMPLETE |  |  |  |  |
| 332 | 1.3.6.3.3.3 | **Requirements to test Traceability Matrices (RTTM)** |  | 30d | 2023-12-07 A | 2024-01-18 A |  | 100% | 2023-12-07 | 2024-01-18 | 30d | 2023-01-06 | 2024-01-05 |  | -0 | N/A | N/A | DBT | 5.2 | N/A | Design, Build & Test (PIT) |  |  |  |  |  |  |
| 333 | 1.3.6.3.3.3.1 | SIT Functional PIT RTTM submitted to Programme for assurance | milestone | 0d | 2023-12-07 A | 2023-12-07 A | 328FS+15d | 100% | 2023-12-07 | 2023-12-07 | 0d | 2023-12-14 | 2023-12-14 |  |  | PP | SI Test | DBT | 5.14 |  | Design, Build & Test (PIT) | Complete | COMPLETE | T3-DB-0091 | SITAG | T3 |  |
| 334 | 1.3.6.3.3.3.2 | All SIT Functional RTTMs MHHS Reviews Completed | milestone | 0d | 2024-01-18 A | 2024-01-18 A | 333FS+30d | 100% | 2024-01-18 | 2024-01-18 | 0d | 2023-12-15 | 2024-01-05 |  |  | SI Test | PP | DBT | 5.14 |  | Design, Build & Test (PIT) | Complete | COMPLETE | T3-DB-0140 | SITAG | T3 |  |

| ID | WBS | Task | Type | Duration | Start | Finish | Predecessors | Complete | Baseline start | Baseline finish | Baseline duration | Baseline 1 start | Baseline 1 finish | Constraint | Baseline cost | Responsible | Involved | Text9 | Update Version | MHHS Resource Name | MHHS Programme Phase | Sched Status | RAG | Milestone ID | Text29 | Tier |
| --- | --- | --- | --- | --- | --- | --- | --- | --- | --- | --- | --- | --- | --- | --- | --- | --- | --- | --- | --- | --- | --- | --- | --- | --- | --- | --- |
| 335 | 1.3.6.3.3.4 | **Test Scenarios** |  | 30d | 2023-12-07 A | 2024-01-18 A |  | 100% | 2023-12-07 | 2024-01-18 | 30d | 2023-01-06 | 2024-01-05 |  | -0 | N/A | N/A | DBT | 5.2 | N/A | Design, Build & Test (PIT) |  |  |  |  |  |
| 336 | 1.3.6.3.3.4.1 | SIT Functional PIT test scenarios submitted to Programme for assurance | milestone | 0d | 2023-12-07 A | 2023-12-07 A | 328FS+15d | 100% | 2023-12-07 | 2023-12-07 | 0d | 2023-12-14 | 2023-12-14 |  |  | PP | SI Test | DBT | 5.14 |  | Design, Build & Test (PIT) | Complete | COMPLETE | T3-DB-0089 | SITAG | T3 |
| 337 | 1.3.6.3.3.4.2 | All SIT Functional Test scenarios' MHHS Reviews Completed | milestone | 0d | 2024-01-18 A | 2024-01-18 A | 336FS+30d | 100% | 2024-01-18 | 2024-01-18 | 0d | 2023-12-15 | 2024-01-05 |  |  | SI Test | PP | DBT | 5.14 |  | Design, Build & Test (PIT) | Complete | COMPLETE | T3-DB-0141 | SITAG | T3 |
| 338 | 1.3.6.3.3.5 | **PIT execution** |  | 51d | 2023-12-15 A | 2024-02-23 A |  | 100% | 2023-12-15 | 2024-02-23 | 301d | 2022-12-30 | 2024-02-09 |  | -0 | N/A | N/A | DBT | 5.0 | N/A | Design, Build & Test (PIT) |  |  |  |  |  |
| 339 | 1.3.6.3.3.5.1 | PIT Test Execution Progress Reports |  | 40d | 2023-12-18 A | 2024-02-09 A | 331 | 100% | 2023-12-18 | 2024-02-09 | 40d | 2022-12-30 | 2024-02-01 |  |  | PP | SI Test | DBT | 5.0 |  | Design, Build & Test (PIT) | Complete | COMPLETE |  |  |  |
| 340 | 1.3.6.3.3.5.2 | PIT Execution |  | 41d | 2023-12-15 A | 2024-02-09 A | 336FS+5d | 100% | 2023-12-15 | 2024-02-09 | 290d | 2022-12-30 | 2024-02-09 |  |  | PP | SI Test | DBT | 5.0 |  | Design, Build & Test (PIT) | Complete | COMPLETE |  |  |  |
| 341 | 1.3.6.3.3.5.3 | All SIT Functional PIT Completion Reports submitted to Programme for Assurance | milestone | 0d | 2024-02-09 A | 2024-02-09 A | 339, 340 | 100% | 2024-02-09 | 2024-02-09 | 0d | 2024-01-05 | 2024-01-05 |  |  | PP | SI Test | DBT | 5.19 |  | Design, Build & Test (PIT) | Complete | COMPLETE | T3-DB-0087 | SITAG | T3 |
| 342 | 1.3.6.3.3.5.4 | All SIT Functional PIT Completion Reports MHHS Review Completed | milestone | 0d | 2024-02-23 A | 2024-02-23 A | 329, 334, 337, 341FS+10d | 100% | 2024-02-23 | 2024-02-23 | 0d |  |  |  |  | SI Test | PP | DBT | 5.19 |  | Design, Build & Test (PIT) | Complete | COMPLETE | T3-DB-0142 | SITAG | T3 |
| 343 | 1.3.6.3.3.6 | **All SIT Programme Participants PIT (SIT Migration)** |  | 71d | 2024-02-16 A | 2024-05-24 A |  | 100% | 2024-02-16 | 2024-05-24 | 301d |  |  |  | -0 | N/A | N/A | DBT | 5.1 | N/A | Design, Build & Test (PIT) |  |  |  |  |  |
| 344 | 1.3.6.3.3.6.1 | **Test Approach & Plans** |  | 40d | 2024-02-16 A | 2024-04-11 A |  | 100% | 2024-02-16 | 2024-04-11 | 40d |  |  |  | -0 | N/A | N/A | DBT | 5.2 | N/A | Design, Build & Test (PIT) |  |  |  |  |  |
| 345 | 1.3.6.3.3.6.1.1 | All SIT Migration PIT Test Approach & Plans submitted to Programme for assurance | milestone | 0d | 2024-02-16 A | 2024-02-16 A |  | 100% | 2024-02-16 | 2024-02-16 | 0d |  |  | start no earlier than 2024-02-16 |  | PP | SI Test | DBT | 5.8 |  | Design, Build & Test (PIT) | Complete | COMPLETE | T3-DB-0143 | SITAG | T3 |
| 346 | 1.3.6.3.3.6.1.2 | All SIT Migration PIT Test approach and plans MHHS Reviews Completed | milestone | 0d | 2024-04-11 A | 2024-04-11 A | 345FS+40d | 100% | 2024-04-11 | 2024-04-11 | 0d |  |  |  |  | SI Test | PP | DBT | 5.23 |  | Design, Build & Test (PIT) | Complete | COMPLETE | T3-DB-0144 | SITAG | T3 |
| 347 | 1.3.6.3.3.6.2 | **Test Readiness Reports** |  | 11d | 2024-03-01 A | 2024-03-15 A |  | 100% | 2024-03-01 | 2024-03-15 | 51d |  |  |  |  | N/A | N/A | DBT | 5.2 | N/A | Design, Build & Test (PIT) |  |  |  |  |  |
| 348 | 1.3.6.3.3.6.2.1 | Test readiness reporting |  | 11d | 2024-03-01 A | 2024-03-15 A | 345FS+10d | 100% | 2024-03-01 | 2024-03-15 | 51d |  |  |  |  | PP | 109 | DBT | 5.2 |  | Design, Build & Test (PIT) | Complete | COMPLETE |  |  |  |
| 349 | 1.3.6.3.3.6.3 | **Requirements to test Traceability Matrices (RTTM)** |  | 30d | 2024-03-07 A | 2024-04-18 A |  | 100% | 2024-03-07 | 2024-04-18 | 30d |  |  |  | -0 | N/A | N/A | DBT | 5.2 | N/A | Design, Build & Test (PIT) |  |  |  |  |  |
| 350 | 1.3.6.3.3.6.3.1 | All SIT Migration PIT RTTMs submitted to Programme for assurance | milestone | 0d | 2024-03-07 A | 2024-03-07 A | 345FS+15d | 100% | 2024-03-07 | 2024-03-07 | 0d |  |  |  |  | PP | SI Test | DBT | 5.23 |  | Design, Build & Test (PIT) | Complete | COMPLETE | T3-DB-0145 | SITAG | T3 |
| 351 | 1.3.6.3.3.6.3.2 | All SIT Migration RTTMs MHHS Reviews Completed | milestone | 0d | 2024-04-18 A | 2024-04-18 A | 350FS+30d | 100% | 2024-04-18 | 2024-04-18 | 0d |  |  |  |  | SI Test | PP | DBT | 5.25 |  | Design, Build & Test (PIT) | Complete | COMPLETE | T3-DB-0146 | SITAG | T3 |
| 352 | 1.3.6.3.3.6.4 | **Test Scenarios** |  | 30d | 2024-03-07 A | 2024-04-18 A |  | 100% | 2024-03-07 | 2024-04-18 | 30d |  |  |  | -0 | N/A | N/A | DBT | 5.2 | N/A | Design, Build & Test (PIT) |  |  |  |  |  |
| 353 | 1.3.6.3.3.6.4.1 | All SIT Migration PIT test scenarios submitted to Programme for assurance | milestone | 0d | 2024-03-07 A | 2024-03-07 A | 345FS+15d | 100% | 2024-03-07 | 2024-03-07 | 0d |  |  |  |  | PP | SI Test | DBT | 5.23 |  | Design, Build & Test (PIT) | Complete | COMPLETE | T3-DB-0147 | SITAG | T3 |
| 354 | 1.3.6.3.3.6.4.2 | All SIT Migration Test scenarios MHHS Reviews Completed | milestone | 0d | 2024-04-18 A | 2024-04-18 A | 353FS+30d | 100% | 2024-04-18 | 2024-04-18 | 0d |  |  |  |  | SI Test | PP | DBT | 5.25 |  | Design, Build & Test (PIT) | Complete | COMPLETE | T3-DB-0148 | SITAG | T3 |
| 355 | 1.3.6.3.3.6.5 | **PIT execution** |  | 51d | 2024-03-15 A | 2024-05-24 A |  | 100% | 2024-03-15 | 2024-05-24 | 301d |  |  |  | -0 | N/A | N/A | DBT | 5.1 | N/A | Design, Build & Test (PIT) |  |  |  |  |  |
| 356 | 1.3.6.3.3.6.5.1 | PIT Test Execution Progress Reports |  | 40d | 2024-03-18 A | 2024-05-10 A | 348 | 100% | 2024-03-18 | 2024-05-10 | 40d |  |  |  |  | PP | SI Test | DBT | 5.1 |  | Design, Build & Test (PIT) | Complete | COMPLETE |  |  |  |
| 357 | 1.3.6.3.3.6.5.2 | PIT Execution |  | 41d | 2024-03-15 A | 2024-05-10 A | 353FS+5d | 100% | 2024-03-15 | 2024-05-10 | 290d |  |  |  |  | PP | SI Test | DBT | 5.1 |  | Design, Build & Test (PIT) | Complete | COMPLETE |  |  |  |
| 358 | 1.3.6.3.3.6.5.3 | All SIT Migration PIT Completion Reports submitted to Programme for assurance | milestone | 0d | 2024-05-10 A | 2024-05-10 A | 356, 357 | 100% | 2024-05-10 | 2024-05-10 | 0d | 2024-01-05 | 2024-01-05 |  |  | PP | SI Test | DBT | 5.8 |  | Design, Build & Test (PIT) | Complete | COMPLETE | T3-DB-0149 | SITAG | T3 |
| 359 | 1.3.6.3.3.6.5.4 | All SIT Migration PIT Completion Reports MHHS Review Completed | milestone | 0d | 2024-05-24 A | 2024-05-24 A | 346, 351, 354, 358FS+10d | 100% | 2024-05-24 | 2024-05-24 | 0d |  |  |  |  | SI Test | PP | DBT | 5.8 |  | Design, Build & Test (PIT) | Complete | COMPLETE | T3-DB-0150 | SITAG | T3 |

| ID | WBS | Task | Type | Duration | Start | Finish | Predecessors | Complete | Baseline start | Baseline finish | Baseline duration | Baseline 1 start | Baseline 1 finish | Constraint | Baseline cost | Responsible | Involved | Text9 | Update Version | MHHS Resource Name | MHHS Programme Phase | Sched Status | RAG | Milestone ID | Text29 | Tier | Guidance |
| --- | --- | --- | --- | --- | --- | --- | --- | --- | --- | --- | --- | --- | --- | --- | --- | --- | --- | --- | --- | --- | --- | --- | --- | --- | --- | --- | --- |
| 360 | 1.3.6.3.3.7 | **All SIT Programme Participants PIT (SIT Non Functional)** |  | 161d | 2024-07-12 A | 2025-02-21 A |  | 100% | 2024-07-12 | 2024-12-20 | 301d |  |  |  | -0 | N/A | N/A | DBT | 6.0 | N/A | Design, Build & Test (PIT) |  |  |  |  |  |  |
| 361 | 1.3.6.3.3.7.1 | **Test Approach & Plan** |  | 41d | 2024-09-27 A | 2024-11-22 A |  | 100% | 2024-09-27 | 2024-11-22 | 40d |  |  |  | -0 | N/A | N/A | DBT | 6.0 | N/A | Design, Build & Test (PIT) |  |  |  |  |  |  |
| 362 | 1.3.6.3.3.7.1.1 | SIT Non-Functional PIT Test Approach & Plan (PIT) submitted to Programme for assurance | milestone | 0d | 2024-09-27 A | 2024-09-27 A |  | 100% | 2024-09-27 | 2024-09-27 | 0d |  |  | start no earlier than 2024-05-10 |  | PP | SI Test | DBT | 6.0 | Roger Robar | Design, Build & Test (PIT) | Complete | COMPLETE | T3-DB-0151 | SITAG | T3 |  |
| 363 | 1.3.6.3.3.7.1.2 | SIT Non-Functional Test approach and plan MHHS Review Completed |  | 1d | 2024-11-21 A | 2024-11-22 A | 362FS+40d | 100% | 2024-11-21 | 2024-11-22 | 0d |  |  |  |  | SI Test | PP | DBT | 6.0 | Roger Robar | Design, Build & Test (PIT) | Complete | COMPLETE | T3-DB-0152 | SITAG | T3 | 6/9/24: Approved at esitag on 26/7/24 |
| 364 | 1.3.6.3.3.7.2 | **Test Readiness Report** |  | 13d | 2024-10-04 A | 2024-10-22 A |  | 100% | 2024-10-04 | 2024-10-22 | 51d |  |  |  |  | N/A | N/A | DBT | 6.0 | N/A | Design, Build & Test (PIT) |  |  |  |  |  |  |
| 365 | 1.3.6.3.3.7.2.1 | Test readiness reporting |  | 13d | 2024-10-04 A | 2024-10-22 A | 362FS+10d | 100% | 2024-10-04 | 2024-10-22 | 51d |  |  |  |  | PP | 109 | DBT | 6.0 |  | Design, Build & Test (PIT) | Complete | COMPLETE |  |  |  |  |
| 366 | 1.3.6.3.3.7.3 | **Requirements to test Traceability Matrix (RTTM)** |  | 20d | 2024-11-01 A | 2024-11-29 A |  | 100% | 2024-11-01 | 2024-11-29 | 30d |  |  |  | -0 | N/A | N/A | DBT | 6.0 | N/A | Design, Build & Test (PIT) |  |  |  |  |  |  |
| 367 | 1.3.6.3.3.7.3.1 | SIT Non-Functional PIT RTTM submitted to Programme for assurance | milestone | 0d | 2024-11-01 A | 2024-11-01 A | 362FS+26d | 100% | 2024-11-01 | 2024-11-01 | 0d |  |  |  |  | PP | SI Test | DBT | 6.0 | Roger Robar | Design, Build & Test (PIT) | Complete | COMPLETE | T3-DB-0153 | SITAG | T3 |  |
| 368 | 1.3.6.3.3.7.3.2 | SIT Non-Functional RTTM MHHS Review Completed | milestone | 0d | 2024-11-29 A | 2024-11-29 A | 367FS+20d | 100% | 2024-11-29 | 2024-11-29 | 0d |  |  | start no earlier than 2024-11-29 |  | SI Test | PP | DBT | 6.0 | Roger Robar | Design, Build & Test (PIT) | Complete | COMPLETE | T3-DB-0154 | SITAG | T3 |  |
| 369 | 1.3.6.3.3.7.4 | **Test Scenarios** |  | 20d | 2024-11-01 A | 2024-11-29 A |  | 100% | 2024-11-01 | 2024-11-29 | 30d |  |  |  | -0 | N/A | N/A | DBT | 6.0 | N/A | Design, Build & Test (PIT) |  |  |  |  |  |  |
| 370 | 1.3.6.3.3.7.4.1 | SIT Non-Functional PIT test scenarios submitted to Programme for assurance | milestone | 0d | 2024-11-01 A | 2024-11-01 A | 362FS+26d | 100% | 2024-11-01 | 2024-11-01 | 0d |  |  |  |  | PP | SI Test | DBT | 6.0 | Roger Robar | Design, Build & Test (PIT) | Complete | COMPLETE | T3-DB-0155 | SITAG | T3 |  |
| 371 | 1.3.6.3.3.7.4.2 | SIT Non-Functional Test scenarios MHHS Review Completed | milestone | 0d | 2024-11-29 A | 2024-11-29 A | 370FS+20d | 100% | 2024-11-29 | 2024-11-29 | 0d |  |  |  |  | SI Test | PP | DBT | 6.0 | Roger Robar | Design, Build & Test (PIT) | Complete | COMPLETE | T3-DB-0156 | SITAG | T3 |  |
| 372 | 1.3.6.3.3.7.5 | **PIT execution** |  | 161d | 2024-07-12 A | 2025-02-21 A |  | 100% | 2024-07-12 | 2024-12-20 | 301d |  |  |  | -0 | N/A | N/A | DBT | 6.0 | N/A | Design, Build & Test (PIT) |  |  |  |  |  |  |
| 373 | 1.3.6.3.3.7.5.1 | PIT Test Execution Progress Report |  | 50d | 2024-07-15 A | 2024-11-21 A | 365 | 100% | 2024-07-15 | 2024-11-21 | 39d |  |  | finish no earlier than 2024-11-21 |  | PP | SI Test | DBT | 6.0 | Roger Robar | Design, Build & Test (PIT) | Complete | COMPLETE |  |  |  |  |
| 374 | 1.3.6.3.3.7.5.2 | PIT Execution |  | 44d | 2024-07-12 A | 2024-11-29 A | 370FS+5d | 100% | 2024-07-12 | 2024-11-29 | 290d |  |  | finish no earlier than 2024-11-29 |  | PP | SI Test | DBT | 6.0 | Roger Robar | Design, Build & Test (PIT) | Complete | COMPLETE |  |  |  |  |
| 375 | 1.3.6.3.3.7.5.3 | SIT Non-Functional PIT Completion Report submitted to Programme for assurance | milestone | 0d | 2024-11-29 A | 2024-11-29 A | 373, 374 | 100% | 2024-11-29 | 2024-11-29 | 0d | 2024-01-05 | 2024-01-05 |  |  | PP | SI Test | DBT | 6.0 | Roger Robar | Design, Build & Test (PIT) | Complete | COMPLETE | T3-DB-0157 | SITAG | T3 |  |
| 376 | 1.3.6.3.3.7.5.4 | SIT Non-Functional PIT Completion Report Theme 1 MHHS Review Completed | milestone | 0d | 2024-12-20 A | 2024-12-20 A | 363, 368, 371, 375FS+15d | 100% | 2024-12-20 | 2024-12-20 | 0d |  |  |  |  | SI Test | PP | DBT | 6.0 | Roger Robar | Design, Build & Test (PIT) | Complete | COMPLETE | T3-DB-0158 | SITAG | T3 |  |
| 377 | 1.3.6.3.3.7.5.5 | SIT Non-Functional PIT Completion Report Theme 2 & 3 MHHS Review Completed | milestone | 0d | 2025-02-21 A | 2025-02-21 A | 363, 368, 371, 375FS+60d | 100% | 2025-02-21 | 2025-02-21 | 0d |  |  |  |  | SI Test |  | DBT | 6.13 |  |  | Complete | COMPLETE | T3-DB-0186 | SITAG | T3 |  |
| 378 | 1.3.6.3.3.8 | **SIT Programme Participants PIT (SIT Operational Theme 1, 2, 3 (Batch 2))** |  | 146d | 2024-07-12 A | 2025-01-31 A |  | 100% | 2024-07-12 | 2024-12-20 | 71d |  |  |  | -0 | N/A | N/A | DBT | 6.0 | N/A | Design, Build & Test (PIT) |  |  |  |  |  |  |
| 379 | 1.3.6.3.3.8.1 | **Test Approach & Plan** |  | 40d | 2024-09-27 A | 2024-11-21 A |  | 100% | 2024-09-27 | 2024-11-21 | 40d |  |  |  | -0 | N/A | N/A | DBT | 6.0 | N/A | Design, Build & Test (PIT) |  |  |  |  |  |  |
| 380 | 1.3.6.3.3.8.1.1 | SIT Operational PIT Test Approach & Plan (PIT) submitted to Programme for assurance | milestone | 0d | 2024-09-27 A | 2024-09-27 A |  | 100% | 2024-09-27 | 2024-09-27 | 0d |  |  | start no earlier than 2024-09-27 |  | PP | SI Test | DBT | 6.0 | Roger Robar | Design, Build & Test (PIT) | Complete | COMPLETE | T3-DB-0159 | SITAG | T3 |  |
| 381 | 1.3.6.3.3.8.1.2 | SIT Operational Test approach and plan MHHS Review Completed | milestone | 0d | 2024-11-21 A | 2024-11-21 A | 380FS+40d | 100% | 2024-11-21 | 2024-11-21 | 0d |  |  |  |  | SI Test | PP | DBT | 6.0 | Roger Robar | Design, Build & Test (PIT) | Complete | COMPLETE | T3-DB-0160 | SITAG | T3 |  |
| 382 | 1.3.6.3.3.8.2 | **Test Readiness Report** |  | 13d | 2024-10-04 A | 2024-10-22 A |  | 100% | 2024-10-04 | 2024-10-22 | 51d |  |  |  |  | N/A | N/A | DBT | 6.0 | N/A | Design, Build & Test (PIT) |  |  |  |  |  |  |
| 383 | 1.3.6.3.3.8.2.1 | Test readiness reporting |  | 13d | 2024-10-04 A | 2024-10-22 A | 380FS+10d | 100% | 2024-10-04 | 2024-10-22 | 51d |  |  |  |  | PP | 109 | DBT | 6.0 |  | Design, Build & Test (PIT) | Complete | COMPLETE |  |  |  |  |

| ID | WBS | Task | Type | Duration | Start | Finish | Predecessors | Complete | Baseline start | Baseline finish | Baseline duration | Baseline 1 start | Baseline 1 finish | Constraint | Baseline cost | Responsible | Involved | Text9 | Update Version | MHHS Resource Name | MHHS Programme Phase | Sched Status | RAG | Milestone ID | Text29 | Tier | Task Status |
| --- | --- | --- | --- | --- | --- | --- | --- | --- | --- | --- | --- | --- | --- | --- | --- | --- | --- | --- | --- | --- | --- | --- | --- | --- | --- | --- | --- |
| 384 | 1.3.6.3.3.8.3 | **Requirements to test Traceability Matrix (RTTM)** |  | 20d | 2024-11-01 A | 2024-11-29 A |  | 100% | 2024-11-01 | 2024-11-29 | 30d |  |  |  | -0 | N/A | N/A | DBT | 6.0 | N/A | Design, Build & Test (PIT) |  |  |  |  |  |  |
| 385 | 1.3.6.3.3.8.3.1 | SIT Operational PIT RTTM submitted to Programme for assurance | milestone | 0d | 2024-11-01 A | 2024-11-01 A | 380FS+26d | 100% | 2024-11-01 | 2024-11-01 | 0d |  |  |  |  | PP | SI Test | DBT | 6.0 | Roger Robar | Design, Build & Test (PIT) | Complete | COMPLETE | T3-DB-0161 | SITAG | T3 |  |
| 386 | 1.3.6.3.3.8.3.2 | SIT Operational RTTM MHHS Review Completed | milestone | 0d | 2024-11-29 A | 2024-11-29 A | 385FS+20d | 100% | 2024-11-29 | 2024-11-29 | 0d |  |  |  |  | SI Test | PP | DBT | 6.0 | Roger Robar | Design, Build & Test (PIT) | Complete | COMPLETE | T3-DB-0162 | SITAG | T3 |  |
| 387 | 1.3.6.3.3.8.4 | **Test Scenarios** |  | 20d | 2024-11-01 A | 2024-11-29 A |  | 100% | 2024-11-01 | 2024-11-29 | 30d |  |  |  | -0 | N/A | N/A | DBT | 6.0 | N/A | Design, Build & Test (PIT) |  |  |  |  |  |  |
| 388 | 1.3.6.3.3.8.4.1 | SIT Operational PIT test scenarios submitted to Programme for assurance | milestone | 0d | 2024-11-01 A | 2024-11-01 A | 380FS+26d | 100% | 2024-11-01 | 2024-11-01 | 0d |  |  |  |  | PP | SI Test | DBT | 6.0 | Roger Robar | Design, Build & Test (PIT) | Complete | COMPLETE | T3-DB-0163 | SITAG | T3 |  |
| 389 | 1.3.6.3.3.8.4.2 | SIT Operational Test scenarios MHHS Review Completed | milestone | 0d | 2024-11-29 A | 2024-11-29 A | 388FS+20d | 100% | 2024-11-29 | 2024-11-29 | 0d |  |  |  |  | SI Test | PP | DBT | 6.0 | Roger Robar | Design, Build & Test (PIT) | Complete | COMPLETE | T3-DB-0164 | SITAG | T3 |  |
| 390 | 1.3.6.3.3.8.5 | **PIT execution** |  | 146d | 2024-07-12 A | 2025-01-31 A |  | 100% | 2024-07-12 | 2024-12-20 | 51d |  |  |  | -0 | N/A | N/A | DBT | 6.0 | N/A | Design, Build & Test (PIT) |  |  |  |  |  |  |
| 391 | 1.3.6.3.3.8.5.1 | PIT Test Execution Progress Report |  | 40d | 2024-07-15 A | 2024-11-21 A | 383 | 100% | 2024-07-15 | 2024-11-21 | 40d |  |  |  |  | PP | SI Test | DBT | 6.0 | Roger Robar | Design, Build & Test (PIT) | Complete | COMPLETE |  |  |  |  |
| 392 | 1.3.6.3.3.8.5.2 | PIT Execution |  | 39d | 2024-07-12 A | 2024-11-29 A | 388 | 100% | 2024-07-12 | 2024-11-29 | 41d |  |  |  |  | PP | SI Test | DBT | 6.0 | Roger Robar | Design, Build & Test (PIT) | Complete | COMPLETE |  |  |  |  |
| 393 | 1.3.6.3.3.8.5.3 | SIT Operational Theme 1, 2, 3 (Batch 2) PIT Completion Report submitted to Programme for assurance | milestone | 0d | 2025-01-14 A | 2025-01-14 A | 391, 392FS+32d | 100% | 2024-11-29 | 2024-11-29 | 0d | 2024-01-05 | 2024-01-05 |  |  | PP | SI Test | DBT | 6.0 | Roger Robar | Design, Build & Test (PIT) | Complete | COMPLETE | T3-DB-0165 | SITAG | T3 |  |
| 394 | 1.3.6.3.3.8.5.4 | SIT Operational Theme 1, 2, 3 (Batch 2) PIT Completion Report MHHS Review Completed | milestone | 0d | 2025-01-31 A | 2025-01-31 A | 381, 386, 389, 393FS+13d | 100% | 2025-01-31 | 2025-01-31 | 0d |  |  |  |  | SI Test | PP | DBT | 6.0 | Roger Robar | Design, Build & Test (PIT) | Complete | COMPLETE | T3-DB-0166 | SITAG | T3 |  |
| 395 | 1.3.6.3.3.9 | **SIT Programme Participants PIT (SIT Operational Theme 3 (Batch 1))** |  | 76d | 2024-09-27 A | 2025-01-10 A |  | 100% | 2024-09-27 | 2025-01-10 | 0d |  |  |  |  | SI Test |  | DBT | 6.17 |  |  |  |  |  |  |  | -814.67 |
| 396 | 1.3.6.3.3.9.1 | **Test Approach & Plan** |  | 40d | 2024-09-27 A | 2024-11-21 A |  | 100% | 2024-09-27 | 2024-11-21 | 0d |  |  |  |  | SI Test |  | DBT | 6.17 | Roger Rober |  |  |  |  |  |  | -814.67 |
| 397 | 1.3.6.3.3.9.1.1 | SIT Operational PIT Test Approach& Plan (PIT) submitted to Programme for assurance | milestone | 0d | 2024-09-27 A | 2024-09-27 A |  | 100% | 2024-09-27 | 2024-09-27 | 0d |  |  | start no earlier than 2024-09-27 |  | SI Test |  | DBT | 6.17 | Roger Rober |  | Complete | COMPLETE |  |  |  |  |
| 398 | 1.3.6.3.3.9.1.2 | SIT Operational Test approach and plan MHHS Review Completed | milestone | 0d | 2024-11-21 A | 2024-11-21 A | 397FS+40d | 100% | 2024-11-21 | 2024-11-21 | 0d |  |  |  |  | SI Test |  | DBT | 6.17 | Roger Rober |  | Complete | COMPLETE |  |  |  |  |
| 399 | 1.3.6.3.3.9.2 | **Test Readiness Report** |  | 13d | 2024-10-04 A | 2024-10-22 A |  | 100% | 2024-10-04 | 2024-10-22 | 0d |  |  |  |  | SI Test |  | DBT | 6.17 | Roger Rober |  |  |  |  |  |  | -814.67 |
| 400 | 1.3.6.3.3.9.2.1 | Test readiness reporting |  | 13d | 2024-10-04 A | 2024-10-22 A | 397FS+5d | 100% | 2024-10-04 | 2024-10-22 | 0d |  |  |  |  | SI Test |  | DBT | 6.17 | Roger Rober |  | Complete | COMPLETE |  |  |  |  |
| 401 | 1.3.6.3.3.9.3 | **Requirements to test Traceability Matrix (RTTM)** |  | 20d | 2024-11-01 A | 2024-11-29 A |  | 100% | 2024-11-01 | 2024-11-29 | 0d |  |  |  |  | SI Test |  | DBT | 6.17 | Roger Rober |  |  |  |  |  |  | -814.67 |
| 402 | 1.3.6.3.3.9.3.1 | SIT Operational PIT RTTM submitted to Programme for assurance | milestone | 0d | 2024-11-01 A | 2024-11-01 A | 397FS+26d | 100% | 2024-11-01 | 2024-11-01 | 0d |  |  |  |  | SI Test |  | DBT | 6.17 | Roger Rober |  | Complete | COMPLETE |  |  |  |  |
| 403 | 1.3.6.3.3.9.3.2 | SIT Operational RTTM MHHS Review Completed | milestone | 0d | 2024-11-29 A | 2024-11-29 A | 402FS+20d | 100% | 2024-11-29 | 2024-11-29 | 0d |  |  |  |  | SI Test |  | DBT | 6.17 | Roger Rober |  | Complete | COMPLETE |  |  |  |  |
| 404 | 1.3.6.3.3.9.4 | **Test Scenarios** |  | 20d | 2024-11-01 A | 2024-11-29 A |  | 100% | 2024-11-01 | 2024-11-29 | 0d |  |  |  |  | SI Test |  | DBT | 6.17 | Roger Rober |  |  |  |  |  |  | -814.67 |
| 405 | 1.3.6.3.3.9.4.1 | SIT Operational PIT test scenarios submitted to Programme for assurance | milestone | 0d | 2024-11-01 A | 2024-11-01 A | 397FS+26d | 100% | 2024-11-01 | 2024-11-01 | 0d |  |  |  |  | SI Test |  | DBT | 6.17 | Roger Rober |  | Complete | COMPLETE |  |  |  |  |
| 406 | 1.3.6.3.3.9.4.2 | SIT Operational Test scenarios MHHS Review Completed | milestone | 0d | 2024-11-29 A | 2024-11-29 A | 405FS+20d | 100% | 2024-11-29 | 2024-11-29 | 0d |  |  |  |  | SI Test |  | DBT | 6.17 | Roger Rober |  | Complete | COMPLETE |  |  |  |  |
| 407 | 1.3.6.3.3.9.5 | **PIT execution** |  | 58d | 2024-10-23 A | 2025-01-10 A |  | 100% | 2024-10-23 | 2025-01-10 | 0d |  |  |  |  | SI Test |  | DBT | 6.17 | Roger Rober |  |  |  |  |  |  | -814.67 |
| 408 | 1.3.6.3.3.9.5.1 | PIT Test Execution Progress Report |  | 40d | 2024-10-23 A | 2024-12-17 A | 400 | 100% | 2024-10-23 | 2024-12-17 | 0d |  |  |  |  | SI Test |  | DBT | 6.17 | Roger Rober |  | Complete | COMPLETE |  |  |  |  |
| 409 | 1.3.6.3.3.9.5.2 | PIT Execution |  | 39d | 2024-11-04 A | 2024-12-26 A | 405 | 100% | 2024-11-04 | 2024-12-26 | 0d |  |  |  |  | SI Test |  | DBT | 6.17 | Roger Rober |  | Complete | COMPLETE |  |  |  |  |
| 410 | 1.3.6.3.3.9.5.3 | SIT Operational Theme 3 (Batch 1) PIT Completion Report submitted to Programme for assurance | milestone | 0d | 2025-01-10 A | 2025-01-10 A | 391, 392FS+30d | 100% | 2025-01-10 | 2025-01-10 | 0d |  |  |  |  | SI Test |  | DBT | 6.17 | Roger Rober |  | Complete | COMPLETE |  |  |  |  |
| 411 | 1.3.6.3.3.9.5.4 | SIT Operational Theme 3 (Batch 1) PIT Completion Report MHHS Review Completed | milestone | 0d | 2025-01-10 A | 2025-01-10 A | 415, 420, 423, 427, 410 | 100% | 2025-01-10 | 2025-01-10 | 0d |  |  |  |  | SI Test |  | DBT | 6.17 | Roger Rober |  | Complete | COMPLETE |  |  |  |  |

| ID | WBS | Task | Type | Duration | Start | Finish | Predecessors | Complete | Baseline start | Baseline finish | Baseline duration | Baseline 1 start | Baseline 1 finish | Constraint | Baseline cost | Responsible | Involved | Text9 | Update Version | MHHS Resource Name | MHHS Programme Phase | Sched Status | RAG | Milestone ID | Text29 | Tier | Artefact ID |
| --- | --- | --- | --- | --- | --- | --- | --- | --- | --- | --- | --- | --- | --- | --- | --- | --- | --- | --- | --- | --- | --- | --- | --- | --- | --- | --- | --- |
| 412 | 1.3.6.3.4 | **All Suppliers DBT CIT (Entering at Interval 5)** |  | 71d | 2023-09-15 A | 2023-12-22 A |  | 100% | 2023-09-15 | 2023-12-22 | 300d | 2022-10-31 | 2025-03-14 |  | -0 | N/A | N/A | DBT | 6.0 | N/A | Design, Build & Test (PIT) |  |  |  |  |  |  |
| 413 | 1.3.6.3.4.1 | **Test Approach & Plan** |  | 20d | 2023-09-15 A | 2023-10-12 A |  | 100% | 2023-09-15 | 2023-10-12 | 19d | 2022-10-31 | 2023-09-29 |  | -0 | N/A | N/A | DBT | 6.0 | N/A | Design, Build & Test (PIT) |  |  |  |  |  |  |
| 414 | 1.3.6.3.4.1.1 | All SIT Suppliers Test Approach & Plans (PIT) submitted to Programme for assurance | milestone | 0d | 2023-09-15 A | 2023-09-15 A |  | 100% | 2023-09-15 | 2023-09-15 | 0d | 2023-09-15 | 2023-09-15 | start no earlier than 2023-09-15 |  | PP | SI Test | DBT | 6.0 |  | Design, Build & Test (PIT) | Complete | COMPLETE | T3-DB-0046 | SITAG | T3 |  |
| 415 | 1.3.6.3.4.1.2 | All SIT Suppliers Test Approach & Plans MHHS Review Completed | milestone | 0d | 2023-10-12 A | 2023-10-12 A | 414FS+20d | 100% | 2023-10-12 | 2023-10-12 | 0d | 2023-09-18 | 2023-09-29 |  |  | SI Test | PP | DBT | 6.0 |  | Design, Build & Test (PIT) | Complete | COMPLETE | T3-DB-0167 | SITAG | T3 |  |
| 416 | 1.3.6.3.4.2 | **Test Readiness Report** |  | 11d | 2023-09-29 A | 2023-10-13 A |  | 100% | 2023-09-29 | 2023-10-13 | 51d | 2023-09-29 | 2023-12-08 |  |  | N/A | N/A | DBT | 6.0 | N/A | Design, Build & Test (PIT) |  |  |  |  |  |  |
| 417 | 1.3.6.3.4.2.1 | Test readiness reporting |  | 11d | 2023-09-29 A | 2023-10-13 A | 414FS+10d | 100% | 2023-09-29 | 2023-10-13 | 51d | 2023-09-29 | 2023-12-08 |  |  | PP | 109 | DBT | 6.0 |  | Design, Build & Test (PIT) | Complete | COMPLETE |  |  |  |  |
| 418 | 1.3.6.3.4.3 | **Requirements to test Traceability Matrix (RTTM)** |  | 20d | 2023-10-06 A | 2023-11-03 A |  | 100% | 2023-10-06 | 2023-11-03 | 21d | 2022-10-31 | 2023-10-20 |  | -0 | N/A | N/A | DBT | 6.0 | N/A | Design, Build & Test (PIT) |  |  |  |  |  |  |
| 419 | 1.3.6.3.4.3.1 | All SIT Suppliers RTTMs submitted to Programme for assurance | milestone | 0d | 2023-10-06 A | 2023-10-06 A | 414FS+16d | 100% | 2023-10-06 | 2023-10-06 | 1d | 2023-10-06 | 2023-10-06 |  |  | PP | SI Test | DBT | 6.0 |  | Design, Build & Test (PIT) | Complete | COMPLETE | T3-DB-0064 | SITAG | T3 | MHHS-ART009 |
| 420 | 1.3.6.3.4.3.2 | All SIT Suppliers RTTMs MHHS Review Completed | milestone | 0d | 2023-11-03 A | 2023-11-03 A | 419FS+20d | 100% | 2023-11-03 | 2023-11-03 | 0d | 2023-10-09 | 2023-10-20 |  |  | SI Test | PP | DBT | 6.0 |  | Design, Build & Test (PIT) | Complete | COMPLETE | T3-DB-0168 | SITAG | T3 |  |
| 421 | 1.3.6.3.4.4 | **Test Scenarios** |  | 20d | 2023-10-05 A | 2023-11-02 A |  | 100% | 2023-10-05 | 2023-11-02 | 20d | 2022-10-31 | 2023-10-20 |  | -0 | N/A | N/A | DBT | 6.0 | N/A | Design, Build & Test (PIT) |  |  |  |  |  |  |
| 422 | 1.3.6.3.4.4.1 | All SIT Suppliers test scenarios' submitted to Programme for assurance | milestone | 0d | 2023-10-05 A | 2023-10-05 A | 414FS+15d | 100% | 2023-10-05 | 2023-10-05 | 0d | 2023-10-06 | 2023-10-06 |  |  | PP | SI Test | DBT | 6.0 |  | Design, Build & Test (PIT) | Complete | COMPLETE | T3-DB-0037 | SITAG | T3 |  |
| 423 | 1.3.6.3.4.4.2 | All SIT Suppliers Test scenarios' MHHS Review Completed | milestone | 0d | 2023-11-02 A | 2023-11-02 A | 422FS+20d | 100% | 2023-11-02 | 2023-11-02 | 0d | 2023-10-09 | 2023-10-20 |  |  | SI Test | PP | DBT | 6.0 |  | Design, Build & Test (PIT) | Complete | COMPLETE | T3-DB-0169 | SITAG | T3 |  |
| 424 | 1.3.6.3.4.5 | **PIT execution** |  | 51d | 2023-10-13 A | 2023-12-22 A |  | 100% | 2023-10-13 | 2023-12-22 | 300d | 2022-10-31 | 2023-12-08 |  | -0 | N/A | N/A | DBT | 6.0 | N/A | Design, Build & Test (PIT) |  |  |  |  |  |  |
| 425 | 1.3.6.3.4.5.1 | PIT Test Execution Progress Report |  | 40d | 2023-10-16 A | 2023-12-08 A | 422FS+5d, 417 | 100% | 2023-10-16 | 2023-12-08 | 40d | 2022-10-31 | 2023-12-01 |  |  | PP | SI Test | DBT | 6.0 |  | Design, Build & Test (PIT) | Complete | COMPLETE |  |  |  |  |
| 426 | 1.3.6.3.4.5.2 | PIT Execution |  | 41d | 2023-10-13 A | 2023-12-08 A | 422FS+5d | 100% | 2023-10-13 | 2023-12-08 | 290d | 2022-10-31 | 2023-12-08 |  |  | PP | SI Test | DBT | 6.0 |  | Design, Build & Test (PIT) | Complete | COMPLETE |  |  |  |  |
| 427 | 1.3.6.3.4.5.3 | All SIT Suppliers PIT Completion Reports submitted to Programme for assurance | milestone | 0d | 2023-12-08 A | 2023-12-08 A | 426, 425 | 100% | 2023-12-08 | 2023-12-08 | 0d | 2024-01-05 | 2024-01-05 |  |  | PP | SI Test | DBT | 6.0 |  | Design, Build & Test (PIT) | Complete | COMPLETE | T3-DB-0170 | SITAG | T3 |  |
| 428 | 1.3.6.3.4.5.4 | All SIT Suppliers PIT Completion Reports MHHS Review Completed | milestone | 0d | 2023-12-22 A | 2023-12-22 A | 427FS+10d, 415, 420, 423 | 100% | 2023-12-22 | 2023-12-22 | 0d |  |  |  |  | SI Test | PP | DBT | 6.0 |  | Design, Build & Test (PIT) | Complete | COMPLETE | T3-DB-0171 | SITAG | T3 |  |
| 429 | 1.3.6.3.5 | **All LDSO Network Operations DBT CIT (Entering at Interval 5)** |  | 71d | 2023-09-15 A | 2023-12-22 A |  | 100% | 2023-09-15 | 2023-12-22 | 310d | 2022-10-31 | 2025-03-14 |  | -0 | N/A | N/A | DBT | 5.0 | N/A | Design, Build & Test (PIT) |  |  |  |  |  |  |
| 430 | 1.3.6.3.5.1 | **Test Approach & Plan** |  | 71d | 2023-09-15 A | 2023-12-22 A |  | 100% | 2023-09-15 | 2023-12-22 | 310d | 2022-10-31 | 2023-08-11 |  | -0 | N/A | N/A | DBT | 5.0 | N/A | Design, Build & Test (PIT) |  |  |  |  |  |  |
| 431 | 1.3.6.3.5.1.1 | All Network Operation Test Approach & Plans (PIT) submitted to Programme for assurance | milestone | 0d | 2023-09-15 A | 2023-09-15 A |  | 100% | 2023-09-15 | 2023-09-15 | 0d | 2023-07-28 | 2023-07-28 | start no earlier than 2023-09-15 |  | PP | SI Test | DBT | 5.8 |  | Design, Build & Test (PIT) | Complete | COMPLETE | T3-DB-0054 | SITAG | T3 |  |
| 432 | 1.3.6.3.5.1.2 | All Network Operation Test Approach & Plans MHHS Review Completed | milestone | 0d | 2023-10-12 A | 2023-10-12 A | 431FS+20d | 100% | 2023-10-12 | 2023-10-12 | 0d | 2023-07-31 | 2023-08-11 |  |  | SI Test | PP | DBT | 5.8 |  | Design, Build & Test (PIT) | Complete | COMPLETE | T3-DB-0172 | SITAG | T3 |  |
| 433 | 1.3.6.3.5.1.3 | **Test Readiness Report** |  | 11d | 2023-09-29 A | 2023-10-13 A |  | 100% | 2023-09-29 | 2023-10-13 | 51d | 2023-08-11 | 2023-10-20 |  |  | N/A | N/A | DBT | 5.0 | N/A | Design, Build & Test (PIT) |  |  |  |  |  |  |
| 434 | 1.3.6.3.5.1.3.1 | Test readiness reporting |  | 11d | 2023-09-29 A | 2023-10-13 A | 431FS+10d | 100% | 2023-09-29 | 2023-10-13 | 51d | 2023-08-11 | 2023-10-20 |  |  | PP | 109 | DBT | 5.0 |  | Design, Build & Test (PIT) | Complete | COMPLETE |  |  |  |  |
| 435 | 1.3.6.3.5.1.4 | **Requirements to test Traceability Matrix (RTTM)** |  | 20d | 2023-10-05 A | 2023-11-02 A |  | 100% | 2023-10-05 | 2023-11-02 | 20d | 2022-10-31 | 2023-09-15 |  | -0 | N/A | N/A | DBT | 5.0 | N/A | Design, Build & Test (PIT) |  |  |  |  |  |  |
| 436 | 1.3.6.3.5.1.4.1 | All Network Operation RTTMs submitted to Programme for assurance | milestone | 0d | 2023-10-05 A | 2023-10-05 A | 431FS+15d | 100% | 2023-10-05 | 2023-10-05 | 0d | 2023-09-01 | 2023-09-01 | start no earlier than 2023-04-28 |  | PP | SI Test | DBT | 5.8 |  | Design, Build & Test (PIT) | Complete | COMPLETE | T3-DB-0062 | SITAG | T3 | MHHS-ART009 |
| 437 | 1.3.6.3.5.1.4.2 | All Network Operation RTTMs MHHS Review Completed | milestone | 0d | 2023-11-02 A | 2023-11-02 A | 436FS+20d | 100% | 2023-11-02 | 2023-11-02 | 0d | 2023-09-04 | 2023-09-15 |  |  | SI Test | PP | DBT | 5.14 |  | Design, Build & Test (PIT) | Complete | COMPLETE | T3-DB-0173 | SITAG | T3 |  |

| ID | WBS | Task | Type | Duration | Start | Finish | Predecessors | Complete | Actual start | Actual finish | Baseline start | Baseline finish | Baseline duration | Baseline 1 start | Baseline 1 finish | Constraint | Baseline cost | Responsible | Involved | Text9 | Update Version | MHHS Resource Name | MHHS Programme Phase | Sched Status | RAG | Milestone ID | Text29 | Tier | Artefact ID |
| --- | --- | --- | --- | --- | --- | --- | --- | --- | --- | --- | --- | --- | --- | --- | --- | --- | --- | --- | --- | --- | --- | --- | --- | --- | --- | --- | --- | --- | --- |
| 438 | 1.3.6.3.5.1.5 | **Test Scenarios** |  | 20d | 2023-10-05 A | 2023-11-02 A |  | 100% |  |  | 2023-10-05 | 2023-11-02 | 20d | 2022-10-31 | 2023-09-15 |  | -0 | N/A | N/A | DBT | 5.0 | N/A | Design, Build & Test (PIT) |  |  |  |  |  |  |
| 439 | 1.3.6.3.5.1.5.1 | All Network Operation test scenarios' submitted to Programme for assurance | milestone | 0d | 2023-10-05 A | 2023-10-05 A | 431FS+15d | 100% |  |  | 2023-10-05 | 2023-10-05 | 0d | 2023-09-01 | 2023-09-01 |  |  | PP | SI Test | DBT | 5.8 |  | Design, Build & Test (PIT) | Complete | COMPLETE | T3-DB-0011 | SITAG | T3 |  |
| 440 | 1.3.6.3.5.1.5.2 | All Network Operation test scenarios' MHHS Review Completed | milestone | 0d | 2023-11-02 A | 2023-11-02 A | 439FS+20d | 100% |  |  | 2023-11-02 | 2023-11-02 | 0d | 2023-09-04 | 2023-09-15 |  |  | SI Test | PP | DBT | 5.14 |  | Design, Build & Test (PIT) | Complete | COMPLETE | T3-DB-0174 | SITAG | T3 |  |
| 441 | 1.3.6.3.5.1.6 | **PIT execution** |  | 51d | 2023-10-13 A | 2023-12-22 A |  | 100% |  |  | 2023-10-13 | 2023-12-22 | 310d | 2022-10-31 | 2024-01-05 |  | -0 | N/A | N/A | DBT | 5.0 | N/A | Design, Build & Test (PIT) |  |  |  |  |  |  |
| 442 | 1.3.6.3.5.1.6.1 | PIT Test Execution Progress Report |  | 40d | 2023-10-16 A | 2023-12-08 A | 439FS+5d, 434 | 100% |  |  | 2023-10-16 | 2023-12-08 | 305d | 2022-10-31 | 2023-12-29 |  |  | PP | SI Test | DBT | 5.0 |  | Design, Build & Test (PIT) | Complete | COMPLETE |  |  |  |  |
| 443 | 1.3.6.3.5.1.6.2 | PIT Execution |  | 41d | 2023-10-13 A | 2023-12-08 A | 439FS+5d | 100% |  |  | 2023-10-13 | 2023-12-08 | 310d | 2022-10-31 | 2024-01-05 |  |  | PP | SI Test | DBT | 5.0 |  | Design, Build & Test (PIT) | Complete | COMPLETE |  |  |  |  |
| 444 | 1.3.6.3.5.1.6.3 | All Network Operation PIT (CIT interval 5) Completion Reports submitted to Programme for assurance | milestone | 0d | 2023-12-08 A | 2023-12-08 A | 443, 442 | 100% |  |  | 2023-12-08 | 2023-12-08 | 0d | 2024-01-05 | 2024-01-05 |  |  | PP | SI Test | DBT | 5.0 |  | Design, Build & Test (PIT) | Complete | COMPLETE | T3-DB-0175 | SITAG | T3 |  |
| 445 | 1.3.6.3.5.1.6.4 | All Network Operation PIT (CIT interval 5) Completion Reports MHHS Review Completed | milestone | 0d | 2023-12-22 A | 2023-12-22 A | 444FS+10d, 432, 437, 440 | 100% |  |  | 2023-12-22 | 2023-12-22 | 0d |  |  |  |  | SI Test | PP | DBT | 5.15 |  | Design, Build & Test (PIT) | Complete | COMPLETE | T3-DB-0176 | SITAG | T3 |  |
| 446 | 1.3.6.3.6 | **All UMSO DBT CIT (Entering at Interval 6)** |  | 81d | 2023-09-29 | 2024-01-19 A |  | 100% | 2023-10-13 |  | 2023-09-29 | 2024-01-19 | 320d | 2022-10-31 | 2024-05-13 |  | -0 | N/A | N/A | DBT | 5.0 | N/A | Design, Build & Test (PIT) |  |  |  |  |  |  |
| 447 | 1.3.6.3.6.1 | **Test Approach & Plan** |  | 20d | 2023-10-13 A | 2023-11-09 A |  | 100% |  |  | 2023-10-13 | 2023-11-09 | 40d | 2022-10-31 | 2023-09-29 |  | -0 | N/A | N/A | DBT | 5.0 | N/A | Design, Build & Test (PIT) |  |  |  |  |  |  |
| 448 | 1.3.6.3.6.1.1 | All UMSO Test Approach & Plans (PIT) submitted to Programme for assurance | milestone | 0d | 2023-10-13 A | 2023-10-13 A |  | 100% |  |  | 2023-10-13 | 2023-10-13 | 0d | 2023-09-15 | 2023-09-15 | start no earlier than 2023-10-13 |  | PP | SI Test | DBT | 5.11 |  | Design, Build & Test (PIT) | Complete | COMPLETE | T3-DB-0052 | SITAG | T3 |  |
| 449 | 1.3.6.3.6.1.2 | All UMSO Test Approach & Plans MHHS Review Completed | milestone | 0d | 2023-11-09 A | 2023-11-09 A | 448FS+20d | 100% |  |  | 2023-11-09 | 2023-11-09 | 0d | 2023-09-18 | 2023-09-29 |  |  | SI Test | PP | DBT | 5.10 |  | Design, Build & Test (PIT) | Complete | COMPLETE | T3-DB-0177 | SITAG | T3 |  |
| 450 | 1.3.6.3.6.2 | **Test Readiness Report** |  | 11d | 2023-09-29 | 2023-10-13 |  | 100% | 2023-10-27 | 2023-11-10 | 2023-09-29 | 2023-10-13 | 11d | 2023-09-29 | 2023-12-08 |  | -0 | N/A | N/A | DBT | 5.0 | N/A | Design, Build & Test (PIT) |  |  |  |  |  |  |
| 451 | 1.3.6.3.6.2.1 | Test readiness reporting |  | 11d | 2023-10-27 A | 2023-11-10 A | 448FS+10d | 100% |  |  | 2023-10-27 | 2023-11-10 | 11d | 2023-09-29 | 2023-12-08 |  |  | PP | 109 | DBT | 5.0 |  | Design, Build & Test (PIT) | Complete | COMPLETE |  |  |  |  |
| 452 | 1.3.6.3.6.3 | **Requirements to test Traceability Matrix (RTTM)** |  | 20d | 2023-10-05 | 2023-11-01 |  | 100% | 2023-11-02 | 2023-11-30 | 2023-10-05 | 2023-11-01 | 20d | 2022-10-31 | 2023-10-20 |  | -0 | N/A | N/A | DBT | 5.0 | N/A | Design, Build & Test (PIT) |  |  |  |  |  |  |
| 453 | 1.3.6.3.6.3.1 | All UMSO RTTMs submitted to Programme for assurance | milestone | 0d | 2023-11-02 A | 2023-11-02 A | 448FS+15d | 100% |  |  | 2023-11-02 | 2023-11-02 | 0d | 2023-10-06 | 2023-10-06 |  |  | PP | SI Test | DBT | 5.12 |  | Design, Build & Test (PIT) | Complete | COMPLETE | T3-DB-0060 | SITAG | T3 | MHHS-ART009 |
| 454 | 1.3.6.3.6.3.2 | All UMSO RTTMs MHHS Review Completed | milestone | 0d | 2023-11-30 A | 2023-11-30 A | 453FS+20d | 100% |  |  | 2023-11-30 | 2023-11-30 | 0d | 2023-10-09 | 2023-10-20 |  |  | SI Test | PP | DBT | 5.12 |  | Design, Build & Test (PIT) | Complete | COMPLETE | T3-DB-0178 | SITAG | T3 |  |
| 455 | 1.3.6.3.6.4 | **Test Scenarios** |  | 20d | 2023-10-05 | 2023-11-01 |  | 100% | 2023-11-02 | 2023-11-30 | 2023-10-05 | 2023-11-01 | 20d | 2022-10-31 | 2023-10-20 |  | -0 | N/A | N/A | DBT | 5.0 | N/A | Design, Build & Test (PIT) |  |  |  |  |  |  |
| 456 | 1.3.6.3.6.4.1 | All UMSO test scenarios' submitted to Programme for assurance | milestone | 0d | 2023-11-02 A | 2023-11-02 A | 448FS+15d | 100% |  |  | 2023-11-02 | 2023-11-02 | 0d | 2023-10-06 | 2023-10-06 |  |  | PP | SI Test | DBT | 5.12 |  | Design, Build & Test (PIT) | Complete | COMPLETE | T3-DB-0025 | SITAG | T3 |  |
| 457 | 1.3.6.3.6.4.2 | All UMSO Test scenarios' MHHS Review Completed | milestone | 0d | 2023-11-30 A | 2023-11-30 A | 456FS+20d | 100% |  |  | 2023-11-30 | 2023-11-30 | 0d | 2023-10-09 | 2023-10-20 |  |  | SI Test | PP | DBT | 5.10 |  | Design, Build & Test (PIT) | Complete | COMPLETE | T3-DB-0179 | SITAG | T3 |  |
| 458 | 1.3.6.3.6.5 | **PIT execution** |  | 51d | 2023-11-10 A | 2024-01-19 A |  | 100% |  |  | 2023-11-10 | 2024-01-19 | 320d | 2022-10-31 | 2023-12-08 |  | -0 | N/A | N/A | DBT | 5.0 | N/A | Design, Build & Test (PIT) |  |  |  |  |  |  |
| 459 | 1.3.6.3.6.5.1 | PIT Test Execution Progress Report |  | 40d | 2023-11-13 A | 2024-01-05 A | 456FS+5d, 451 | 100% |  |  | 2023-11-13 | 2024-01-05 | 40d | 2022-10-31 | 2023-12-01 |  |  | PP | SI Test | DBT | 5.0 |  | Design, Build & Test (PIT) | Complete | COMPLETE |  |  |  |  |
| 460 | 1.3.6.3.6.5.2 | PIT Execution |  | 40d | 2023-11-10 A | 2024-01-04 A | 456FS+5d | 100% |  |  | 2023-11-10 | 2024-01-04 | 290d | 2022-10-31 | 2023-12-08 |  |  | PP | SI Test | DBT | 5.0 |  | Design, Build & Test (PIT) | Complete | COMPLETE |  |  |  |  |
| 461 | 1.3.6.3.6.5.3 | All UMSO PIT (CIT interval 6) Completion Reports submitted to Programme for assurance | milestone | 0d | 2024-01-05 A | 2024-01-05 A | 460, 459 | 100% |  |  | 2024-01-05 | 2024-01-05 | 0d | 2024-01-05 | 2024-01-05 |  |  | PP | SI Test | DBT | 5.10 |  | Design, Build & Test (PIT) | Complete | COMPLETE | T3-DB-0180 | SITAG | T3 |  |
| 462 | 1.3.6.3.6.5.4 | All UMSO PIT (CIT interval 6) Completion Reports MHHS Review Completed | milestone | 0d | 2024-01-19 A | 2024-01-19 A | 449, 454, 457, 461FS+10d | 100% |  |  | 2024-01-19 | 2024-01-19 | 0d |  |  |  |  | SI Test | PP | DBT | 5.10 |  | Design, Build & Test (PIT) | Complete | COMPLETE | T3-DB-0181 | SITAG | T3 |  |

| ID | WBS | Task | Type | Duration | Start | Finish | Predecessors | Complete | Baseline start | Baseline finish | Baseline duration | Baseline 1 start | Baseline 1 finish | Constraint | Responsible | Involved | Text9 | Update Version | MHHS Resource Name | MHHS Programme Phase | Task Status | Sched Status | RAG | Milestone ID | Text29 | Tier | Artefact ID |
| --- | --- | --- | --- | --- | --- | --- | --- | --- | --- | --- | --- | --- | --- | --- | --- | --- | --- | --- | --- | --- | --- | --- | --- | --- | --- | --- | --- |
| 463 | 1.3.7 | **DBT Monitoring and Assurance** |  | 723d | 2022-10-31 A | 2025-08-06 A |  | 100% | 2022-10-31 | 2026-01-20 | 842d | 2022-10-31 | 2026-01-19 |  | N/A | N/A | DBT | 5.0 | N/A | Design, Build & Test (PIT) |  |  |  |  |  |  |  |
| 464 | 1.3.7.1 | **Planning and DBT Progress Monitoring of PPs** |  | 696d | 2022-10-31 A | 2025-06-30 A |  | 100% | 2022-10-31 | 2025-06-30 | 696d | 2022-10-31 | 2025-06-30 |  | N/A | N/A | DBT | 5.0 | N/A | Design, Build & Test (PIT) | M9 |  |  |  |  |  |  |
| 465 | 1.3.7.1.1 | Monitor Non-SIT PPs Planning and DBT1 progress (to inform confirmation of Qualification Testing Tranche participants milestones) |  | 696d | 2022-10-31 A | 2025-06-30 A | 193SS | 100% | 2022-10-31 | 2025-06-30 | 696d | 2022-10-31 | 2025-06-30 |  | Code Bodies | SI Test,PPC | DBT | 5.0 | Nic Farley | Design, Build & Test (PIT) |  | Complete | COMPLETE |  |  |  |  |
| 466 | 1.3.7.2 | **Design Assurance** |  | 713d | 2022-11-14 A | 2025-08-06 A |  | 100% | 2022-11-14 | 2025-08-06 | 713d | 2022-11-14 | 2025-08-06 |  | N/A | N/A | DBT | 5.0 | N/A | Design, Build & Test (PIT) | M9 |  |  |  |  |  |  |
| 467 | 1.3.7.2.1 | **Design Assurance Readiness Assessment Preparation** |  | 39d | 2023-02-28 A | 2023-04-21 A |  | 100% | 2023-02-28 | 2023-04-21 | 39d | 2023-02-28 | 2023-04-21 |  | N/A | N/A | DBT | 5.0 | N/A | Design, Build & Test (PIT) |  |  |  |  |  |  |  |
| 468 | 1.3.7.2.1.1 | Set up FTIG |  | 15d | 2023-04-03 A | 2023-04-21 A |  | 100% | 2023-04-03 | 2023-04-21 | 15d | 2023-04-03 | 2023-04-21 | must start on 2023-04-03 | SI Design |  | DBT | 5.0 | Paul Pettitt | Design, Build & Test (PIT) |  | Complete | COMPLETE |  |  |  |  |
| 469 | 1.3.7.2.1.2 | Produce Draft Questions |  | 10d | 2023-02-28 A | 2023-03-13 A |  | 100% | 2023-02-28 | 2023-03-13 | 10d | 2023-02-28 | 2023-03-13 | must start on 2023-02-28 | SI Design |  | DBT | 5.0 | Paul Pettitt | Design, Build & Test (PIT) |  | Complete | COMPLETE |  |  |  |  |
| 470 | 1.3.7.2.1.3 | Pilot with SRO |  | 1d | 2023-03-14 A | 2023-03-14 A | 469 | 100% | 2023-03-14 | 2023-03-14 | 1d | 2023-03-14 | 2023-03-14 |  | SI Design |  | DBT | 5.0 | Paul Pettitt | Design, Build & Test (PIT) |  | Complete | COMPLETE |  |  |  |  |
| 471 | 1.3.7.2.1.4 | Finalise questions |  | 10d | 2023-03-15 A | 2023-03-28 A | 470 | 100% | 2023-03-15 | 2023-03-28 | 10d | 2023-03-15 | 2023-03-28 |  | SI Design |  | DBT | 5.0 | Paul Pettitt | Design, Build & Test (PIT) |  | Complete | COMPLETE |  |  |  |  |
| 472 | 1.3.7.2.1.5 | Prepare on-line RA tooling |  | 10d | 2023-03-29 A | 2023-04-11 A | 471 | 100% | 2023-03-29 | 2023-04-11 | 10d | 2023-03-29 | 2023-04-11 |  | SI Design |  | DBT | 5.0 | Paul Pettitt | Design, Build & Test (PIT) |  | Complete | COMPLETE |  |  |  |  |
| 473 | 1.3.7.2.1.6 | Prepare webinar content |  | 5d | 2023-03-20 A | 2023-03-24 A | 469FS+4d | 100% | 2023-03-20 | 2023-03-24 | 5d | 2023-03-20 | 2023-03-24 |  | SI Design |  | DBT | 5.0 | Paul Pettitt | Design, Build & Test (PIT) |  | Complete | COMPLETE |  |  |  |  |
| 474 | 1.3.7.2.1.7 | Conduct webinar |  | 1d | 2023-03-30 A | 2023-03-30 A | 473FS+3d | 100% | 2023-03-30 | 2023-03-30 | 1d | 2023-03-30 | 2023-03-30 |  | SI Design | PP | DBT | 5.0 | Paul Pettitt | Design, Build & Test (PIT) |  | Complete | COMPLETE |  |  |  |  |
| 475 | 1.3.7.2.2 | **Participant Design Assurance Approach** |  | 43d | 2022-11-14 A | 2023-01-11 A |  | 100% | 2022-11-14 | 2023-01-11 | 43d | 2022-11-14 | 2023-01-11 |  | N/A | N/A | DBT | 5.0 | N/A | Design, Build & Test (PIT) |  |  |  |  |  |  |  |
| 476 | 1.3.7.2.2.1 | Develop document |  | 20d | 2022-11-14 A | 2022-12-09 A | 47FS+10d | 100% | 2022-11-14 | 2022-12-09 | 20d | 2022-11-14 | 2022-12-09 | start no earlier than 2022-11-14 | SI Design | PP | DBT | 5.0 | Paul Pettitt | Design, Build & Test (PIT) |  | Complete | COMPLETE |  |  |  |  |
| 477 | 1.3.7.2.2.2 | Review document |  | 18d | 2022-12-12 A | 2023-01-04 A | 476 | 100% | 2022-12-12 | 2023-01-04 | 18d | 2022-12-12 | 2023-01-04 |  | PP | SI Design,IPA | DBT | 5.0 | Paul Pettitt | Design, Build & Test (PIT) |  | Complete | COMPLETE |  |  |  |  |
| 478 | 1.3.7.2.2.3 | Participant Design Assurance Approach approved | milestone | 0d | 2023-01-11 A | 2023-01-11 A | 477FF+5d | 100% | 2023-01-11 | 2023-01-11 | 0d | 2023-01-11 | 2023-01-11 |  | SI Design | PP | DBT | 5.0 | Paul Pettitt | Design, Build & Test (PIT) |  | Complete | COMPLETE | T3-DB-0012 | DAG | T3 |  |
| 479 | 1.3.7.2.3 | **Phase 1 - SIT Volunteers (Core Providers)** |  | 145d | 2023-04-10 A | 2023-10-27 A |  | 100% | 2023-04-10 | 2023-10-27 | 145d | 2023-04-10 | 2023-10-27 |  | N/A | N/A | DBT | 5.0 | N/A | Design, Build & Test (PIT) |  |  |  |  |  |  |  |
| 480 | 1.3.7.2.3.1 | Send on-line questionnaire to core capability providers and current SIT volunteers (from Round 3 consultation) |  | 1d | 2023-04-10 A | 2023-04-10 A |  | 100% | 2023-04-10 | 2023-04-10 | 1d | 2023-04-10 | 2023-04-10 | must start on 2023-04-10 | SI Design | PP | DBT | 5.0 | Paul Pettitt | Design, Build & Test (PIT) |  | Complete | COMPLETE |  |  |  |  |
| 481 | 1.3.7.2.3.2 | Participants Provide Responses to questionnaires |  | 15d | 2023-04-11 A | 2023-05-01 A | 480 | 100% | 2023-04-11 | 2023-05-01 | 15d | 2023-04-11 | 2023-05-01 |  | PP |  | DBT | 5.0 | Paul Pettitt | Design, Build & Test (PIT) |  | Complete | COMPLETE |  |  |  |  |
| 482 | 1.3.7.2.3.3 | Assess on-line responses and provided evidence |  | 5d | 2023-05-02 A | 2023-05-08 A | 481 | 100% | 2023-05-02 | 2023-05-08 | 5d | 2023-05-02 | 2023-05-08 |  | SI Design |  | DBT | 5.0 | Paul Pettitt | Design, Build & Test (PIT) |  | Complete | COMPLETE |  |  |  |  |
| 483 | 1.3.7.2.3.4 | Bi-lateral meeting with each responder, to walk and navigate through provided materials |  | 31d | 2023-05-09 A | 2023-06-20 A | 482 | 100% | 2023-05-09 | 2023-06-20 | 31d | 2023-05-09 | 2023-06-20 |  | SI Design | PP | DBT | 5.0 | Paul Pettitt | Design, Build & Test (PIT) |  | Complete | COMPLETE |  |  |  |  |
| 484 | 1.3.7.2.3.5 | Plan for, create and execute deep dive assurance interviews based on agreed priorities (participants, design areas) |  | 62d | 2023-06-07 A | 2023-08-31 A | 483FS-10d | 100% | 2023-06-07 | 2023-08-31 | 62d | 2023-06-07 | 2023-08-01 |  | SI Design |  | DBT | 5.2 | Paul Pettitt | Design, Build & Test (PIT) |  | Complete | COMPLETE |  |  |  |  |
| 485 | 1.3.7.2.3.6 | SI endorsement of participants’ design – assurance reports |  | 43d | 2023-08-02 A | 2023-09-29 A | 484FS-22d | 100% | 2023-08-02 | 2023-09-29 | 43d | 2023-08-02 | 2023-08-15 |  | SI Design |  | DBT | 5.2 | Paul Pettitt | Design, Build & Test (PIT) |  | Complete | COMPLETE |  |  |  |  |
| 486 | 1.3.7.2.3.7 | Post-assurance review of recommendations take-up by assured participants |  | 44d | 2023-08-29 A | 2023-10-27 A | 485SS+19d | 100% | 2023-08-29 | 2023-10-27 | 20d | 2023-08-16 | 2023-10-27 |  | SI Design |  | DBT | 5.2 | Paul Pettitt | Design, Build & Test (PIT) |  | Complete | COMPLETE |  |  |  |  |
| 487 | 1.3.7.2.3.8 | Phase 1 - SIT Volunteers (Core Providers) complete | milestone | 0d | 2023-10-27 A | 2023-10-27 A | 486 | 100% | 2023-10-27 | 2023-10-27 | 0d | 2023-10-27 | 2023-10-27 |  | SI Design |  | DBT | 5.11 | Paul Pettitt | Design, Build & Test (PIT) |  | Complete | COMPLETE | T2-DB-0100 | DAG | T2 | MHHS-ART002 |

| ID | WBS | Task | Type | Duration | Start | Finish | Predecessors | Complete | Actual finish | Baseline start | Baseline finish | Baseline duration | Baseline 1 start | Baseline 1 finish | Constraint | Baseline cost | Responsible | Involved | Text9 | Update Version | MHHS Resource Name | MHHS Programme Phase | Sched Status | RAG | Artefact ID | Milestone ID | Text29 | Tier | Task Status | Future RAG |
| --- | --- | --- | --- | --- | --- | --- | --- | --- | --- | --- | --- | --- | --- | --- | --- | --- | --- | --- | --- | --- | --- | --- | --- | --- | --- | --- | --- | --- | --- | --- |
| 488 | 1.3.7.2.4 | **Phase 2 - SIT all other participants** |  | 143d | 2023-05-08 A | 2023-11-22 A |  | 100% |  | 2023-05-08 | 2023-11-22 | 143d | 2023-05-08 | 2023-11-22 |  |  | N/A | N/A | DBT | 5.0 | N/A | Design, Build & Test (PIT) |  |  |  |  |  |  |  |  |
| 489 | 1.3.7.2.4.1 | Send on-line questionnaire to core capability providers and current SIT volunteers (from Round 3 consultation) |  | 1d | 2023-05-08 A | 2023-05-08 A |  | 100% |  | 2023-05-08 | 2023-05-08 | 1d | 2023-05-08 | 2023-05-08 | must start on 2023-05-08 |  | SI Design | PP | DBT | 5.0 | Paul Pettitt | Design, Build & Test (PIT) | Complete | COMPLETE |  |  |  |  |  |  |
| 490 | 1.3.7.2.4.2 | Participants Provide Responses to questionnaires |  | 15d | 2023-05-09 A | 2023-05-29 A | 489 | 100% |  | 2023-05-09 | 2023-05-29 | 15d | 2023-05-09 | 2023-05-29 |  |  | PP |  | DBT | 5.0 | Paul Pettitt | Design, Build & Test (PIT) | Complete | COMPLETE |  |  |  |  |  |  |
| 491 | 1.3.7.2.4.3 | Assess on-line responses and provided evidence |  | 5d | 2023-05-30 A | 2023-06-05 A | 490 | 100% |  | 2023-05-30 | 2023-06-05 | 5d | 2023-05-30 | 2023-06-05 |  |  | SI Design |  | DBT | 5.0 | Paul Pettitt | Design, Build & Test (PIT) | Complete | COMPLETE |  |  |  |  |  |  |
| 492 | 1.3.7.2.4.4 | Bi-lateral meeting with each responder, to walk and navigate through provided materials |  | 84d | 2023-06-06 A | 2023-09-29 A | 491 | 100% |  | 2023-06-06 | 2023-09-29 | 84d | 2023-06-06 | 2023-07-18 |  |  | SI Design | PP | DBT | 5.2 | Paul Pettitt | Design, Build & Test (PIT) | Complete | COMPLETE |  |  |  |  |  |  |
| 493 | 1.3.7.2.4.5 | Plan for, create and execute deep dive assurance interviews based on agreed priorities (participants, design areas) |  | 69d | 2023-06-27 A | 2023-09-29 A | 492SS+15d | 100% |  | 2023-06-27 | 2023-09-29 | 69d | 2023-07-05 | 2023-08-29 |  |  | SI Design |  | DBT | 5.2 | Paul Pettitt | Design, Build & Test (PIT) | Complete | COMPLETE |  |  |  |  |  |  |
| 494 | 1.3.7.2.4.6 | SI endorsement of participants’ design – assurance reports |  | 54d | 2023-07-18 A | 2023-09-29 A | 493SS+15d | 100% |  | 2023-07-18 | 2023-09-29 | 54d | 2023-08-30 | 2023-09-12 |  |  | SI Design |  | DBT | 5.2 | Paul Pettitt | Design, Build & Test (PIT) | Complete | COMPLETE |  |  |  |  |  |  |
| 495 | 1.3.7.2.4.7 | Post-assurance review of recommendations take-up by assured participants |  | 73d | 2023-08-14 A | 2023-11-22 A | 494SS+19d | 100% |  | 2023-08-14 | 2023-11-22 | 38d | 2023-09-13 | 2023-11-22 |  |  | SI Design |  | DBT | 5.2 | Paul Pettitt | Design, Build & Test (PIT) | Complete | COMPLETE |  |  |  |  |  |  |
| 496 | 1.3.7.2.4.8 | SIT PPs design assurance (excl Migration/Reverse Migration) complete | milestone | 0d | 2023-11-22 A | 2023-11-22 A | 495 | 100% |  | 2023-11-22 | 2023-11-22 | 0d | 2023-11-22 | 2023-11-22 |  |  | SI Design |  | DBT | 5.11 | Paul Pettitt | Design, Build & Test (PIT) | Complete | COMPLETE | MHHS-ART002 | T2-DB-0200 | DAG | T2 |  |  |
| 497 | 1.3.7.2.5 | **Non-SIT PPs design assurance** |  | 445d | 2023-11-23 A | 2025-08-06 A |  | 100% |  | 2023-11-23 | 2025-08-06 | 445d | 2023-11-23 | 2025-08-06 |  |  | N/A | N/A | DBT | 5.0 | N/A | Design, Build & Test (PIT) |  |  |  |  |  |  |  |  |
| 498 | 1.3.7.2.5.1 | Non-SIT PPs design assurance (risk-based sample) |  | 445d | 2023-11-23 A | 2025-08-06 A | 496 | 100% |  | 2023-11-23 | 2025-08-06 | 445d | 2023-11-23 | 2025-08-06 |  |  | SI Design | PPC | DBT | 5.0 | Paul Pettitt | Design, Build & Test (PIT) | Complete | COMPLETE |  |  |  |  |  |  |
| 499 | 1.3.7.3 | **Test Assurance** |  | 629d | 2023-02-01 A | 2025-06-30 A |  | 100% |  | 2023-02-01 | 2025-06-30 | 696d | 2022-10-31 | 2025-06-30 |  |  | N/A | N/A | DBT | 5.0 | N/A | Design, Build & Test (PIT) |  |  |  |  |  |  | M9 |  |
| 500 | 1.3.7.3.1 | Non-SIT PPs test assurance |  | 629d | 2023-02-01 A | 2025-06-30 A |  | 100% |  | 2023-02-01 | 2025-06-30 | 629d | 2023-02-01 | 2025-06-30 |  |  | Code Bodies | PP,PPC,SI Test | DBT | 5.0 | Roger Robar | Design, Build & Test (PIT) | Complete | COMPLETE |  |  |  |  |  |  |
| 501 | 1.3.7.4 | **Pre-Qualification Guidance (PIT Guidance)** |  | 67d | 2022-10-31 A | 2023-01-31 A |  | 100% |  | 2022-10-31 | 2023-01-31 | 67d | 2022-10-31 | 2023-01-31 |  |  | N/A | N/A | DBT | 5.0 | N/A | Design, Build & Test (PIT) |  |  |  |  |  |  |  |  |
| 502 | 1.3.7.4.1 | Develop document (incl. collaboration with code bodies, as required) |  | 56d | 2022-10-31 A | 2023-01-16 A |  | 100% |  | 2022-10-31 | 2023-01-16 | 56d | 2022-10-31 | 2023-01-16 |  |  | SI Test | Code Bodies | DBT | 5.0 |  | Design, Build & Test (PIT) | Complete | COMPLETE |  |  |  |  |  |  |
| 503 | 1.3.7.4.2 | Review, update and agree Pre-Qualification Guidance internally |  | 11d | 2023-01-17 A | 2023-01-31 A | 502 | 100% |  | 2023-01-17 | 2023-01-31 | 11d | 2023-01-17 | 2023-01-31 |  |  | SRO Function | IPA,SI Test | DBT | 5.0 |  | Design, Build & Test (PIT) | Complete | COMPLETE |  |  |  |  |  |  |
| 504 | 1.3.7.5 | **External Programme Dependency Management** |  | 0d | 2022-11-03 A | 2022-11-03 A |  | 100% |  | 2022-11-03 | 2022-11-03 | 0d | 2022-11-03 | 2022-11-03 |  |  | N/A | N/A | DBT | 5.0 | N/A | Design, Build & Test (PIT) |  |  |  |  |  |  |  |  |
| 505 | 1.3.7.5.1 | **SLC47** |  | 0d | 2022-11-03 A | 2022-11-03 A |  | 100% |  | 2022-11-03 | 2022-11-03 | 0d | 2022-11-03 | 2022-11-03 |  |  | N/A | N/A | DBT | 5.0 | N/A | Design, Build & Test (PIT) |  |  |  |  |  |  |  |  |
| 506 | 1.3.7.5.1.1 | SLC47 implementation date | milestone | 0d | 2022-11-03 A | 2022-11-03 A |  | 100% |  | 2022-11-03 | 2022-11-03 | 0d | 2022-11-03 | 2022-11-03 | start no earlier than 2022-11-03 |  | Ofgem |  | DBT | 5.0 |  | Design, Build & Test (PIT) | Complete | COMPLETE |  |  |  |  |  |  |
| 507 | 1.4 | **SYSTEMS INTEGRATION TESTING (SIT)** |  | 910d? | 2022-10-31 A | 2026-04-24 |  | 100% | 2026-08-28 | 2022-10-31 | 2026-04-24 | 841d | 2022-10-31 | 2026-01-19 |  | -0 | N/A | N/A | SIT | 5.0 | N/A | Systems Integration Testing (SIT) |  |  |  |  | SITAG |  |  | 1 Aug 2023 - 30 Sep 2024 |
| 508 | 1.4.1 | **SIT Preparation** |  | 670d? | 2022-10-31 A | 2025-05-23 A |  | 100% |  | 2022-10-31 | 2025-05-16 | 611d | 2022-10-31 | 2025-03-10 |  | -0 | N/A | N/A | SIT | 5.0 | N/A | Systems Integration Testing (SIT) |  |  |  |  | SITAG |  |  |  |
| 509 | 1.4.1.1 | **Test Artefact Development** |  | 472d | 2022-10-31 A | 2024-08-21 A |  | 100% |  | 2022-10-31 | 2024-08-21 | 472d | 2022-10-31 | 2023-09-01 |  | -0 | N/A | N/A | SIT | 5.0 | N/A | Systems Integration Testing (SIT) |  |  |  |  |  |  | M9 |  |
| 510 | 1.4.1.1.1 | **Environment Approach & Plan** |  | 460d | 2022-11-16 A | 2024-08-21 A |  | 100% |  | 2022-11-16 | 2024-08-21 | 460d | 2022-11-16 | 2023-06-30 |  | -0 | N/A | N/A | SIT | 5.0 | N/A | Systems Integration Testing (SIT) |  |  |  |  |  |  |  |  |
| 511 | 1.4.1.1.1.1 | Environment Approach & Plan approved | milestone | 0d | 2022-11-16 A | 2022-11-16 A |  | 100% |  | 2022-11-16 | 2022-11-16 | 0d | 2022-11-16 | 2022-11-16 | start no earlier than 2022-11-16 |  | SI Test | PP | SIT | 5.0 | Simon Berry | Systems Integration Testing (SIT) | Complete | COMPLETE | MHHS-ART139 | T3-TE-0010 | SITAG | T3 |  |  |
| 512 | 1.4.1.1.1.2 | Environment Approach & Plan - Work Off |  | 157d | 2022-11-17 A | 2023-06-23 A | 511FS+1d | 100% |  | 2022-11-17 | 2023-06-23 | 157d | 2022-11-17 | 2023-06-23 |  |  | SI Test | PP | SIT | 5.0 | Simon Berry | Systems Integration Testing (SIT) | Complete | COMPLETE |  |  |  |  |  |  |
| 513 | 1.4.1.1.1.3 | Environment Approach & Plan - Work Off Approved | milestone | 0d | 2023-08-16 A | 2023-08-16 A | 512FS+5d | 100% |  | 2023-08-16 | 2023-08-16 | 0d | 2023-06-30 | 2023-06-30 | start no earlier than 2023-08-16 |  | SI Test | PP | SIT | 5.0 | Simon Berry | Systems Integration Testing (SIT) | Complete | COMPLETE | MHHS-ART139 | T3-TE-0068 | SITAG | T3 |  |  |
| 514 | 1.4.1.1.1.4 | Environment Approach and Plan - SIT Functional | milestone | 0d | 2023-11-20 A | 2023-11-20 A |  | 100% |  | 2023-11-20 | 2023-11-20 | 0d |  |  | start no earlier than 2023-11-20 |  | SI Test | PP | SIT | 5.12 | Simon Berry | Systems Integration Testing (SIT) | Complete | COMPLETE | MHHS-DEL 618 | T3-TE-0090 | SITAG | T3 |  |  |
| 515 | 1.4.1.1.1.5 | Define Approach to Simulator for Non-SIT LDSO | milestone | 0d | 2023-11-15 A | 2023-11-15 A |  | 100% |  | 2023-11-15 | 2023-11-15 | 0d |  |  | start no earlier than 2023-11-15 |  | SI Test | PP | SIT | 5.12 | Simon Berry |  | Complete | COMPLETE |  |  |  |  |  |  |
| 516 | 1.4.1.1.1.6 | Environment Approach and Plan - Non SIT LDSO Testing | milestone | 0d | 2024-04-17 A | 2024-04-17 A |  | 100% |  | 2024-04-17 | 2024-04-17 | 0d |  |  | start no earlier than 2024-04-17 |  | SI Test | PP | SIT | 5.22 | Simon Berry | Systems Integration Testing (SIT) | Complete | COMPLETE | MHHS-DEL 619 | T3-TE-0091 | SITAG/QAG | T3 |  |  |
| 517 | 1.4.1.1.1.7 | Environment Approach and Plan - S and A Testing | milestone | 0d | 2024-07-17 A | 2024-07-17 A |  | 100% |  | 2024-07-17 | 2024-07-17 | 0d |  |  | start no earlier than 2024-07-17 |  | SI Test | PP | SIT | 5.27 | Simon Berry | Systems Integration Testing (SIT) | Complete | COMPLETE | MHHS-DEL 619 | T3-TE-0120 | SITAG/QAG | T3 |  |  |
| 518 | 1.4.1.1.1.8 | Environment Approach and Plan - SIT Non Functional | milestone | 0d | 2024-06-19 A | 2024-06-19 A |  | 100% |  | 2024-06-19 | 2024-06-19 | 0d |  |  | start no earlier than 2024-06-19 |  | SI Test | PP | SIT | 5.27 | Simon Berry | Systems Integration Testing (SIT) | Complete | COMPLETE | MHHS-DEL 620 | T3-TE-0092 | SITAG | T3 |  |  |
| 519 | 1.4.1.1.1.9 | Environment Approach and Plan - Sandbox | milestone | 0d | 2024-08-21 A | 2024-08-21 A |  | 100% |  | 2024-08-21 | 2024-08-21 | 0d |  |  | start no earlier than 2024-08-21 |  | SI Test | PP | SIT | 5.27 | Simon Berry | Systems Integration Testing (SIT) | Complete | COMPLETE | MHHS-DEL 621 | T3-TE-0093 | SITAG/QAG | T3 |  |  |

Notes:
- 508: Action: 11/3: Ask Simon B for the link (line 1312) dip onboarding to non sit ldso
- 510: Action: 16/8 - add to milestone register. Build out detail further
- 511: Action: 25/7 - Simon to provide update
- 512: Action: 25/7 - Simon to provide update
- 513: Action: 25/7 - Simon to provide update
- 514: Action: 16/8 - add to milestone register. Build out detail further
- 516: Action: 16/8 - add to milestone register. Build out detail further
- 517: Action: 16/8 - add to milestone register. Build out detail further
- 518: Action: 16/8 - add to milestone register. Build out detail further
- 519: Action: 16/8 - add to milestone register. Build out detail further

| ID | WBS | Task | Type | Duration | Start | Finish | Predecessors | Complete | Baseline start | Baseline finish | Baseline duration | Baseline 1 start | Baseline 1 finish | Constraint | Baseline cost | Responsible | Involved | Text9 | Update Version | MHHS Resource Name | MHHS Programme Phase | Sched Status | RAG | Task Status | Milestone ID | Text29 | Tier |
| --- | --- | --- | --- | --- | --- | --- | --- | --- | --- | --- | --- | --- | --- | --- | --- | --- | --- | --- | --- | --- | --- | --- | --- | --- | --- | --- | --- |
| 520 | 1.4.1.1.2 | **Overarching Test Scope (for all stages)** |  | 65d | 2022-10-31 A | 2023-01-27 A |  | 100% | 2022-10-31 | 2023-01-27 | 175d | 2022-10-31 | 2023-06-30 |  |  | N/A | N/A | SIT | 5.0 | N/A | Systems Integration Testing (SIT) |  |  |  |  |  |  |
| 521 | 1.4.1.1.2.1 | **Overarching Test Scope (excl. Migration/Reverse Migration, NFT and Ops components)** |  | 65d | 2022-10-31 A | 2023-01-27 A |  | 100% | 2022-10-31 | 2023-01-27 | 65d | 2022-10-31 | 2023-01-27 |  |  | N/A | N/A | SIT | 5.0 | N/A | Systems Integration Testing (SIT) |  |  |  |  |  |  |
| 522 | 1.4.1.1.2.1.1 | Develop document (excl Migration/Reverse Migration, NFT and Ops components) |  | 55d | 2022-10-31 A | 2023-01-13 A | 47 | 100% | 2022-10-31 | 2023-01-13 | 55d | 2022-10-31 | 2023-01-13 |  |  | SI Test |  | SIT | 5.0 |  | Systems Integration Testing (SIT) | Complete | COMPLETE |  |  |  |  |
| 523 | 1.4.1.1.2.1.2 | Review, update & agree document (excl Migration/Reverse Migration, NFT and Ops components) |  | 10d | 2023-01-16 A | 2023-01-27 A | 522 | 100% | 2023-01-16 | 2023-01-27 | 10d | 2023-01-16 | 2023-01-27 |  |  | SI Test | IPA,Code Bodies,PP | SIT | 5.0 |  | Systems Integration Testing (SIT) | Complete | COMPLETE |  |  |  |  |
| 524 | 1.4.1.1.3 | **Configuration and Release Management Approach & Plan** |  | 164d | 2022-11-01 A | 2023-06-16 A |  | 100% | 2022-11-01 | 2023-06-16 | 164d | 2022-11-01 | 2023-04-28 |  |  | N/A | N/A | SIT | 5.0 | N/A | Systems Integration Testing (SIT) |  |  | M9 |  |  |  |
| 525 | 1.4.1.1.3.1 | Develop document |  | 69d | 2022-11-01 A | 2023-06-16 A |  | 100% | 2022-11-01 | 2023-06-16 | 69d | 2022-11-01 | 2023-01-31 | start no earlier than 2022-11-01 |  | SI Test |  | SIT | 5.0 | Simon Berry | Systems Integration Testing (SIT) | Complete | COMPLETE |  |  |  |  |
| 526 | 1.4.1.1.3.2 | Review, update and agree Configuration and Release Management Approach & Plan internally |  | 63d | 2023-02-01 A | 2023-04-28 A | 525 | 100% | 2023-02-01 | 2023-04-28 | 63d | 2023-02-01 | 2023-04-28 |  |  | SRO Function | IPA,SI Test | SIT | 5.0 | Simon Berry | Systems Integration Testing (SIT) | Complete | COMPLETE |  |  |  |  |
| 527 | 1.4.1.1.4 | **Test Data Overarching Approach & Plan** |  | 179d | 2022-11-14 A | 2023-07-20 A |  | 100% | 2022-11-14 | 2023-07-20 | 179d | 2022-11-14 | 2023-05-18 |  |  | N/A | N/A | SIT | 5.0 | N/A | Systems Integration Testing (SIT) |  |  | M9 |  |  |  |
| 528 | 1.4.1.1.4.1 | Develop document |  | 20d | 2022-11-14 A | 2022-12-09 A |  | 100% | 2022-11-14 | 2022-12-09 | 20d | 2022-11-14 | 2022-12-09 | start no earlier than 2022-11-14 |  | SI Test | PP | SIT | 5.0 | Cesar Lopes | Systems Integration Testing (SIT) | Complete | COMPLETE |  |  |  |  |
| 529 | 1.4.1.1.4.2 | Document review and update |  | 155d | 2022-12-12 A | 2023-07-14 A | 528 | 100% | 2022-12-12 | 2023-07-14 | 155d | 2022-12-12 | 2023-05-17 |  |  | PP | SI Test,IPA | SIT | 5.0 | Cesar Lopes | Systems Integration Testing (SIT) | Complete | COMPLETE |  |  |  |  |
| 530 | 1.4.1.1.4.3 | Test Data Overarching Approach & Plan approved by TMAG | milestone | 0d | 2023-07-19 A | 2023-07-19 A | 529FS+3d | 100% | 2023-07-19 | 2023-07-19 | 0d | 2023-05-17 | 2023-05-17 |  |  | SRO Test | PP,IPA,Code Bodies | SIT | 5.0 | Cesar Lopes | Systems Integration Testing (SIT) | Complete | COMPLETE |  | T3-TE-0072 | SITAG | T3 |
| 531 | 1.4.1.1.4.4 | Document publication final version |  | 1d | 2023-07-20 A | 2023-07-20 A | 530 | 100% | 2023-07-20 | 2023-07-20 | 1d | 2023-05-18 | 2023-05-18 |  |  | SI Test |  | SIT | 5.0 | Cesar Lopes | Systems Integration Testing (SIT) | Complete | COMPLETE |  |  |  |  |
| 532 | 1.4.1.1.5 | **Interface Code of Connection (dates subject to DIP Service Provider's plan)** |  | 48d | 2023-03-01 A | 2023-05-05 A |  | 100% | 2023-03-01 | 2023-05-05 | 48d | 2023-03-01 | 2023-05-05 |  |  | N/A | N/A | SIT | 5.0 | N/A | Systems Integration Testing (SIT) |  |  |  |  |  |  |
| 533 | 1.4.1.1.5.1 | Develop Interface Code of Connection with DIP Service Provider |  | 43d | 2023-03-01 A | 2023-04-28 A |  | 100% | 2023-03-01 | 2023-04-28 | 43d | 2023-03-01 | 2023-04-28 | must start on 2023-03-01 |  | DIP Provider | SI Test | SIT | 5.0 |  | Systems Integration Testing (SIT) | Complete | COMPLETE |  |  |  |  |
| 534 | 1.4.1.1.5.2 | Interface Code of Connection approved at SDWG | milestone | 0d | 2023-05-05 A | 2023-05-05 A | 533FS+5d | 100% | 2023-05-05 | 2023-05-05 | 0d | 2023-05-05 | 2023-05-05 |  |  | SI Test | PP | SIT | 5.0 |  | Systems Integration Testing (SIT) | Complete | COMPLETE |  |  |  |  |
| 535 | 1.4.1.1.6 | **Test Traceability** |  | 165d | 2023-06-01 A | 2024-01-17 A |  | 100% | 2023-06-01 | 2024-01-17 | 165d | 2023-06-01 | 2023-09-01 |  | -0 | N/A | N/A | SIT | 5.0 | N/A | Systems Integration Testing (SIT) |  |  |  |  |  |  |
| 536 | 1.4.1.1.6.1 | RTM containing Method Statement Implied Requirements into Azure DevOps |  | 22d | 2023-06-01 A | 2023-06-30 A |  | 100% | 2023-06-01 | 2023-06-30 | 22d | 2023-06-01 | 2023-06-30 | must start on 2023-06-01 |  | SI Test |  | SIT | 5.0 |  | Systems Integration Testing (SIT) | Complete | COMPLETE |  |  |  |  |
| 537 | 1.4.1.1.6.2 | RTM Containing Interface Catalogue Implied Requirements |  | 27d | 2023-06-01 A | 2023-07-07 A |  | 100% | 2023-06-01 | 2023-07-07 | 27d | 2023-06-01 | 2023-07-07 | must start on 2023-06-01 |  | SI Test |  | SIT | 5.0 |  | Systems Integration Testing (SIT) | Complete | COMPLETE |  |  |  |  |
| 538 | 1.4.1.1.6.3 | SIT CIT Full Traceability & Coverage complete |  | 118d | 2023-07-10 A | 2023-12-20 A | 537, 536 | 100% | 2023-07-10 | 2023-12-20 | 110d | 2023-07-10 | 2023-07-28 |  |  | SI Test |  | SIT | 5.0 |  | Systems Integration Testing (SIT) | Complete | COMPLETE |  |  |  |  |
| 539 | 1.4.1.1.6.4 | SIT Functional Full Traceability & Coverage complete |  | 138d | 2023-07-10 A | 2024-01-17 A | 537, 536 | 100% | 2023-07-10 | 2024-01-17 | 138d | 2023-07-10 | 2023-09-01 |  |  | SI Test |  | SIT | 5.0 | Roger Robar | Systems Integration Testing (SIT) | Complete | COMPLETE |  |  |  |  |
| 540 | 1.4.1.2 | **Test Tool Development** |  | 256d? | 2022-10-31 A | 2023-10-23 A |  | 100% | 2022-10-31 | 2023-10-23 | 175d | 2022-10-31 | 2023-06-30 |  |  | N/A | N/A | SIT | 5.0 | N/A | Systems Integration Testing (SIT) |  |  |  |  |  |  |
| 541 | 1.4.1.2.1 | **Test Management Tool** |  | 256d | 2022-10-31 A | 2023-10-23 A |  | 100% | 2022-10-31 | 2023-10-23 | 175d | 2022-10-31 | 2023-06-30 |  |  | N/A | N/A | SIT | 5.0 | N/A | Systems Integration Testing (SIT) |  |  |  |  |  |  |
| 542 | 1.4.1.2.1.1 | **Test Management Tool Implementation** |  | 256d | 2022-10-31 A | 2023-10-23 A |  | 100% | 2022-10-31 | 2023-10-23 | 175d | 2022-10-31 | 2023-06-30 |  |  | N/A | N/A | SIT | 5.0 | N/A | Systems Integration Testing (SIT) |  |  |  |  |  |  |
| 543 | 1.4.1.2.1.1.1 | Requirements identification |  | 40d | 2022-10-31 A | 2022-12-23 A |  | 100% | 2022-10-31 | 2022-12-23 | 40d | 2022-10-31 | 2022-12-23 |  |  | SI DevOps | SI Test | SIT | 5.0 | Simon Berry | Systems Integration Testing (SIT) | Complete | COMPLETE |  |  |  |  |
| 544 | 1.4.1.2.1.1.2 | Development |  | 125d | 2023-01-02 A | 2023-06-23 A | 543FS+5d | 100% | 2023-01-02 | 2023-06-23 | 125d | 2023-01-02 | 2023-06-23 |  |  | SI DevOps | SI Test | SIT | 5.0 | Simon Berry | Systems Integration Testing (SIT) | Complete | COMPLETE |  |  |  |  |
| 545 | 1.4.1.2.1.1.3 | Testing |  | 125d | 2023-01-02 A | 2023-06-23 A | 544FF | 100% | 2023-01-02 | 2023-06-23 | 125d | 2023-01-02 | 2023-06-23 |  |  | SI DevOps | SI Test | SIT | 5.0 | Simon Berry | Systems Integration Testing (SIT) | Complete | COMPLETE |  |  |  |  |
| 546 | 1.4.1.2.1.1.4 | Accept tool | milestone | 0d | 2023-06-23 A | 2023-06-23 A | 545FF | 100% | 2023-06-23 | 2023-06-23 | 0d | 2023-06-23 | 2023-06-23 |  |  | SI DevOps | SI Test | SIT | 5.0 | Simon Berry | Systems Integration Testing (SIT) | Complete | COMPLETE |  |  |  |  |
| 547 | 1.4.1.2.1.1.5 | Implementation |  | 1d | 2023-10-23 A | 2023-10-23 A | 546FS+85d | 100% | 2023-10-23 | 2023-10-23 | 1d | 2023-06-30 | 2023-06-30 |  |  | SI DevOps | PPC | SIT | 5.0 | Simon Berry | Systems Integration Testing (SIT) | Complete | COMPLETE |  |  |  |  |

Notes:
- 524: Action: 1280 DIP available for Onboarding (need to add a link - non sit ldso)

| ID | WBS | Task | Duration | Start | Finish | Predecessors | Complete | Baseline start | Baseline finish | Baseline duration | Baseline 1 start | Baseline 1 finish | Constraint | Responsible | Involved | Text9 | Update Version | MHHS Resource Name | MHHS Programme Phase | Sched Status | RAG | Task Status |
| --- | --- | --- | --- | --- | --- | --- | --- | --- | --- | --- | --- | --- | --- | --- | --- | --- | --- | --- | --- | --- | --- | --- |
| 548 | 1.4.1.2.1.2 | **Test Management Tool User Guide** | 115d | 2023-01-02 A | 2023-06-09 A |  | 100% | 2023-01-02 | 2023-06-09 | 115d | 2023-01-02 | 2023-06-09 |  | N/A | N/A | SIT | 5.0 | N/A | Systems Integration Testing (SIT) |  |  |  |
| 549 | 1.4.1.2.1.2.1 | Develop document | 100d | 2023-01-02 A | 2023-05-19 A | 544SS, 545SS | 100% | 2023-01-02 | 2023-05-19 | 100d | 2023-01-02 | 2023-05-19 | start no earlier than 2023-01-02 | SI DevOps |  | SIT | 5.0 |  | Systems Integration Testing (SIT) | Complete | COMPLETE |  |
| 550 | 1.4.1.2.1.2.2 | Review, update and agree Test Management Tool User Guide internally | 15d | 2023-05-22 A | 2023-06-09 A | 549 | 100% | 2023-05-22 | 2023-06-09 | 15d | 2023-05-22 | 2023-06-09 |  | SRO Function | SI DevOps,SI Test,IPA,PPC | SIT | 5.0 |  | Systems Integration Testing (SIT) | Complete | COMPLETE |  |
| 551 | 1.4.1.2.1.3 | **Test Management Tool Configuration Guide** | 60d | 2023-01-02 A | 2023-03-24 A |  | 100% | 2023-01-02 | 2023-03-24 | 60d | 2023-01-02 | 2023-03-24 |  | N/A | N/A | SIT | 5.0 | N/A | Systems Integration Testing (SIT) |  |  |  |
| 552 | 1.4.1.2.1.3.1 | Develop document | 45d | 2023-01-02 A | 2023-03-03 A | 543 | 100% | 2023-01-02 | 2023-03-03 | 45d | 2023-01-02 | 2023-03-03 | start no earlier than 2023-01-02 | SI DevOps | SI Test,IPA | SIT | 5.0 |  | Systems Integration Testing (SIT) | Complete | COMPLETE |  |
| 553 | 1.4.1.2.1.3.2 | Review, update and agree Test Management Tool Configuration Guide internally | 15d | 2023-03-06 A | 2023-03-24 A | 552 | 100% | 2023-03-06 | 2023-03-24 | 15d | 2023-03-06 | 2023-03-24 |  | SRO Function | SI DevOps,SI Test,IPA | SIT | 5.0 |  | Systems Integration Testing (SIT) | Complete | COMPLETE |  |
| 554 | 1.4.1.2.2 | **Secure Volunteer SIT Participants** | 163d? | 2023-01-31 A | 2023-09-14 A |  | 100% | 2023-01-31 | 2023-09-14 | 0d |  |  |  |  |  | SIT | 6.0 |  |  |  |  | -680.67 |
| 555 | 1.4.1.2.2.1 | PPs decide whether to volunteer to participate in SIT and inform Programme of decision via Round 3 Replan consultation | 1d? | 2023-01-31 A | 2023-01-31 A |  | 100% | 2023-01-31 | 2023-01-31 | 0d |  |  | finish no earlier than 2023-01-31 | SI Test |  | SIT | 6.0 |  |  | Complete | COMPLETE |  |
| 556 | 1.4.1.2.2.2 | Assurance of SIT volunteers' plans (submitted via Round 3 Replan Consultation) | 1d? | 2023-02-14 A | 2023-02-14 A |  | 100% | 2023-02-14 | 2023-02-14 | 0d |  |  | finish no earlier than 2023-02-14 | SI Test |  | SIT | 6.0 |  |  | Complete | COMPLETE |  |
| 557 | 1.4.1.2.2.3 | SIT Participant Volunteers Identified | 1d? | 2023-02-14 A | 2023-02-14 A |  | 100% | 2023-02-14 | 2023-02-14 | 0d |  |  | start no earlier than 2023-02-14 | SI Test |  | SIT | 6.0 |  |  | Complete | COMPLETE |  |
| 558 | 1.4.1.2.2.4 | Engagement with SIT volunteers | 1d? | 2023-05-23 A | 2023-05-23 A |  | 100% | 2023-05-23 | 2023-05-23 | 0d |  |  | finish no earlier than 2023-05-23 | SI Test |  | SIT | 6.0 |  |  | Complete | COMPLETE |  |
| 559 | 1.4.1.2.2.5 | SIT Participants Agreed | 1d? | 2023-05-23 A | 2023-05-23 A |  | 100% | 2023-05-23 | 2023-05-23 | 0d |  |  | start no earlier than 2023-05-23 | SI Test |  | SIT | 6.0 |  |  | Complete | COMPLETE |  |
| 560 | 1.4.1.2.2.6 | **Data Protection Impact Assessment (DPIA)** | 11d? | 2023-06-30 A | 2023-07-14 A |  | 100% | 2023-06-30 | 2023-07-14 | 0d |  |  |  | SI Test |  | SIT | 6.0 |  |  |  |  | -680.67 |
| 561 | 1.4.1.2.2.6.1 | Conduct DPIA on Overall Test Data Approach | 1d? | 2023-06-30 A | 2023-06-30 A |  | 100% | 2023-06-30 | 2023-06-30 | 0d |  |  | finish no earlier than 2023-06-30 | SI Test |  | SIT | 6.0 |  |  | Complete | COMPLETE |  |
| 562 | 1.4.1.2.2.6.2 | Revise Overarching Test Data Approach& plan for DPIA (if required), including engagement with DWG | 1d? | 2023-07-13 A | 2023-07-13 A |  | 100% | 2023-07-13 | 2023-07-13 | 0d |  |  | finish no earlier than 2023-07-13 | SI Test |  | SIT | 6.0 |  |  | Complete | COMPLETE |  |
| 563 | 1.4.1.2.2.6.3 | Review (internal), update and approve revised Overarching Test Data Approach& Plan (if required) | 1d? | 2023-07-14 A | 2023-07-14 A |  | 100% | 2023-07-14 | 2023-07-14 | 0d |  |  | start no earlier than 2023-07-14 | SI Test |  | SIT | 6.0 |  |  | Complete | COMPLETE |  |
| 564 | 1.4.1.2.2.7 | **Data Sharing Agreements** | 30d? | 2023-08-04 A | 2023-09-14 A |  | 100% | 2023-08-04 | 2023-09-14 | 0d |  |  |  | SI Test |  | SIT | 6.0 |  |  |  | COMPLETE | -680.67 |
| 565 | 1.4.1.2.2.7.1 | Produce Data Sharing Agreement for Industry Review | 1d? | 2023-08-04 A | 2023-08-04 A |  | 100% | 2023-08-04 | 2023-08-04 | 0d |  |  | finish no earlier than 2023-08-04 | SI Test |  | SIT | 6.0 |  |  | Complete | COMPLETE |  |
| 566 | 1.4.1.2.2.7.2 | Manage Participant Queries and Contract Agreement Execution | 1d? | 2023-09-14 A | 2023-09-14 A |  | 100% | 2023-09-14 | 2023-09-14 | 0d |  |  | finish no earlier than 2023-09-14 | SI Test |  | SIT | 6.0 |  |  | Complete | COMPLETE |  |
| 567 | 1.4.1.2.2.7.3 | Data Sharing Agreements Complete | 1d? | 2023-09-14 A | 2023-09-14 A |  | 100% | 2023-09-14 | 2023-09-14 | 0d |  |  | start no earlier than 2023-09-14 | SI Test |  | SIT | 6.0 |  |  | Complete | COMPLETE |  |
| 568 | 1.4.1.2.2.8 | **Production Data Cut & Data Obfuscation** | 55d? | 2023-06-19 A | 2023-09-01 A |  | 100% | 2023-06-19 | 2023-09-01 | 0d |  |  |  |  |  | SIT | 6.0 |  |  |  | COMPLETE | -680.67 |
| 569 | 1.4.1.2.2.8.1 | **SI Data Cut Preparation& Infrastructure** | 45d? | 2023-06-19 A | 2023-08-18 A |  | 100% | 2023-06-19 | 2023-08-18 | 0d |  |  |  |  |  | SIT | 6.0 |  |  |  | COMPLETE | -680.67 |
| 570 | 1.4.1.2.2.8.1.1 | SI Data Cut Planning activities (incl. pre-cut and post-cut cleansing and population approach) | 1d? | 2023-06-19 A | 2023-06-19 A |  | 100% | 2023-06-19 | 2023-06-19 | 0d |  |  | finish no earlier than 2023-06-19 | SI Test |  | SIT | 6.0 |  |  | Complete | COMPLETE |  |
| 571 | 1.4.1.2.2.8.1.2 | Set up SI database and transmission structure | 1d? | 2023-08-17 A | 2023-08-17 A |  | 100% | 2023-08-17 | 2023-08-17 | 0d |  |  | finish no earlier than 2023-08-17 | SI Test |  | SIT | 6.0 |  |  | Complete | COMPLETE |  |
| 572 | 1.4.1.2.2.8.1.3 | Mechanism for transfer of data in place | 1d? | 2023-08-18 A | 2023-08-18 A |  | 100% | 2023-08-18 | 2023-08-18 | 0d |  |  | start no earlier than 2023-08-18 | SI Test |  | SIT | 6.0 |  |  | Complete | COMPLETE |  |
| 573 | 1.4.1.2.2.8.1.4 | SI Data Cut Preparation& Infrastructure Complete | 1d? | 2023-08-18 A | 2023-08-18 A |  | 100% | 2023-08-18 | 2023-08-18 | 0d |  |  | start no earlier than 2023-08-18 | SI Test |  | SIT | 6.0 |  |  | Complete | COMPLETE |  |

| ID | WBS | Task | Type | Duration | Start | Finish | Predecessors | Complete | Baseline start | Baseline finish | Baseline duration | Baseline 1 start | Baseline 1 finish | Constraint | Baseline cost | Responsible | Text9 | Task Status | Update Version | RAG | Sched Status | Involved | MHHS Resource Name | MHHS Programme Phase | Milestone ID | Text29 | Tier | Artefact ID |
| --- | --- | --- | --- | --- | --- | --- | --- | --- | --- | --- | --- | --- | --- | --- | --- | --- | --- | --- | --- | --- | --- | --- | --- | --- | --- | --- | --- | --- |
| 574 | 1.4.1.2.2.8.2 | **Production Data Cut** |  | 55d? | 2023-06-19 A | 2023-09-01 A |  | 100% | 2023-06-19 | 2023-09-01 | 0d |  |  |  |  | SI Test | SIT | -680.67 | 6.0 | COMPLETE |  |  |  |  |  |  |  |  |
| 575 | 1.4.1.2.2.8.2.1 | Notification of Production Data Cut issued to relevant participants |  | 1d? | 2023-06-19 A | 2023-06-19 A |  | 100% | 2023-06-19 | 2023-06-19 | 0d |  |  | start no earlier than 2023-06-19 |  | SI Test | SIT |  | 6.0 | COMPLETE | Complete |  |  |  |  |  |  |  |
| 576 | 1.4.1.2.2.8.2.2 | Coordinate relevant participants taking data cut from production systems |  | 1d? | 2023-08-11 A | 2023-08-11 A |  | 100% | 2023-08-11 | 2023-08-11 | 0d |  |  | finish no earlier than 2023-08-11 |  | SI Test | SIT |  | 6.0 | COMPLETE | Complete |  |  |  |  |  |  |  |
| 577 | 1.4.1.2.2.8.2.3 | Production data cut GONG decision |  | 1d? | 2023-08-16 A | 2023-08-16 A |  | 100% | 2023-08-16 | 2023-08-16 | 0d |  |  | start no earlier than 2023-08-16 |  | SI Test | SIT |  | 6.0 | COMPLETE | Complete |  |  |  |  |  |  |  |
| 578 | 1.4.1.2.2.8.2.4 | Relevant participants take data cut from production systems (Saturday 19 August) |  | 1d? | 2023-08-21 A | 2023-08-21 A |  | 100% | 2023-08-21 | 2023-08-21 | 0d |  |  | start no earlier than 2023-08-21 |  | SI Test | SIT |  | 6.0 | COMPLETE | Complete |  |  |  |  |  |  |  |
| 579 | 1.4.1.2.2.8.2.5 | EES transmit request data to SI |  | 1d? | 2023-08-25 A | 2023-08-25 A |  | 100% | 2023-08-25 | 2023-08-25 | 0d |  |  | finish no earlier than 2023-08-25 |  | SI Test | SIT |  | 6.0 | COMPLETE | Complete |  |  |  |  |  |  |  |
| 580 | 1.4.1.2.2.8.2.6 | Check data alignment and integrity of data cut |  | 1d? | 2023-09-01 A | 2023-09-01 A |  | 100% | 2023-09-01 | 2023-09-01 | 0d |  |  | finish no earlier than 2023-09-01 |  | SI Test | SIT |  | 6.0 | COMPLETE | Complete |  |  |  |  |  |  |  |
| 581 | 1.4.1.2.2.8.2.7 | Data cut from relevant participants' production systems completed (Saturday 19 August) |  | 1d? | 2023-08-21 A | 2023-08-21 A |  | 100% | 2023-08-21 | 2023-08-21 | 0d |  |  | start no earlier than 2023-08-21 |  | SI Test | SIT |  | 6.0 | COMPLETE | Complete |  |  |  |  |  |  |  |
| 582 | 1.4.1.2.2.8.2.8 | Production Data Cut Complete |  | 1d? | 2023-08-21 A | 2023-08-21 A |  | 100% | 2023-08-21 | 2023-08-21 | 0d |  |  | start no earlier than 2023-08-21 |  | SI Test | SIT |  | 6.0 | COMPLETE | Complete |  |  |  |  |  |  |  |
| 583 | 1.4.1.3 | **SIT Participation** |  | 147d | 2022-10-31 A | 2023-05-23 A |  | 100% | 2022-10-31 | 2023-05-23 | 147d | 2022-10-31 | 2023-05-23 |  |  | N/A | SIT |  | 5.0 |  |  | N/A | N/A | Systems Integration Testing (SIT) |  |  |  |  |
| 584 | 1.4.1.3.1 | PPs decide whether to volunteer to participate in SIT and inform Programme of decision via Round 3 Replan consultation |  | 67d | 2022-10-31 A | 2023-01-31 A | 34FF | 100% | 2022-10-31 | 2023-01-31 | 67d | 2022-10-31 | 2023-01-31 |  |  | PP | SIT |  | 5.0 | COMPLETE | Complete | SI Test,PMO |  | Systems Integration Testing (SIT) |  |  |  |  |
| 585 | 1.4.1.3.2 | Assurance of SIT volunteers' plans (submitted via Round 3 Replan Consultation) |  | 10d | 2023-02-01 A | 2023-02-14 A | 584, 34 | 100% | 2023-02-01 | 2023-02-14 | 10d | 2023-02-01 | 2023-02-14 |  |  | SI Test | SIT |  | 5.0 | COMPLETE | Complete | PP |  | Systems Integration Testing (SIT) |  |  |  |  |
| 586 | 1.4.1.3.3 | SIT Participant Volunteers Identified | milestone | 0d | 2023-02-14 A | 2023-02-14 A | 585FF | 100% | 2023-02-14 | 2023-02-14 | 0d | 2023-02-14 | 2023-02-14 |  |  | SI Test | SIT |  | 5.0 | COMPLETE | Complete | PP |  | Systems Integration Testing (SIT) | T2-TE-0100 | SITAG | T2 |  |
| 587 | 1.4.1.3.4 | Engagement with SIT volunteers |  | 147d | 2022-10-31 A | 2023-05-23 A |  | 100% | 2022-10-31 | 2023-05-23 | 147d | 2022-10-31 | 2023-05-23 |  |  | SI Test | SIT |  | 5.0 | COMPLETE | Complete | PP |  | Systems Integration Testing (SIT) |  |  |  |  |
| 588 | 1.4.1.3.5 | SIT Participants Agreed | milestone | 0d | 2023-05-23 A | 2023-05-23 A | 587, 622FS-74d | 100% | 2023-05-23 | 2023-05-23 | 0d | 2023-05-23 | 2023-05-23 |  |  | SI Test | SIT |  | 5.0 | COMPLETE | Complete | PP |  | Systems Integration Testing (SIT) | T2-TE-0150 | SITAG | T2 |  |
| 589 | 1.4.1.4 | **SIT Stage-Specific Preparation** |  | 670d? | 2022-10-31 A | 2025-05-23 A |  | 100% | 2022-10-31 | 2025-05-16 | 611d | 2022-10-31 | 2025-03-10 |  | -0 | N/A | SIT |  | 5.0 |  |  | N/A | N/A | Systems Integration Testing (SIT) |  | SITAG |  |  |
| 590 | 1.4.1.4.1 | **SIT Component Integration Preparation** |  | 320d | 2022-10-31 A | 2024-01-19 A |  | 100% | 2022-10-31 | 2024-01-19 | 321d | 2022-10-31 | 2024-01-22 |  | -0 | N/A | SIT |  | 5.0 |  |  | N/A | N/A | Systems Integration Testing (SIT) |  |  |  |  |
| 591 | 1.4.1.4.1.1 | **Test Approach & Plan** |  | 188d | 2022-10-31 A | 2023-07-19 A |  | 100% | 2022-10-31 | 2023-07-19 | 188d | 2022-10-31 | 2023-07-19 |  |  | N/A | SIT |  | 5.0 |  |  | N/A | N/A | Systems Integration Testing (SIT) |  |  |  |  |
| 592 | 1.4.1.4.1.1.1 | Develop document with SITWG |  | 159d | 2022-10-31 A | 2023-06-08 A |  | 100% | 2022-10-31 | 2023-06-08 | 159d | 2022-10-31 | 2023-05-12 |  |  | SI Test | SIT |  | 5.0 | COMPLETE | Complete |  |  | Systems Integration Testing (SIT) |  |  |  |  |
| 593 | 1.4.1.4.1.1.2 | Industry consultation |  | 10d | 2023-06-09 A | 2023-06-22 A | 592 | 100% | 2023-06-09 | 2023-06-22 | 10d |  |  |  |  | PP | SIT |  | 5.1 | COMPLETE | Complete |  |  | Systems Integration Testing (SIT) |  |  |  |  |
| 594 | 1.4.1.4.1.1.3 | Artefact review (via TMAG) and updates |  | 19d | 2023-06-23 A | 2023-07-19 A | 593 | 100% | 2023-06-23 | 2023-07-19 | 19d | 2023-06-09 | 2023-07-06 | finish no earlier than 2023-07-06 |  | SI Test | SIT |  | 5.0 | COMPLETE | Complete | PP,IPA,Code Bodies |  | Systems Integration Testing (SIT) |  |  |  |  |
| 595 | 1.4.1.4.1.1.4 | SIT Component Integration Testing Test Approach & Plan approved | milestone | 0d | 2023-07-19 A | 2023-07-19 A | 594 | 100% | 2023-07-19 | 2023-07-19 | 0d | 2023-07-19 | 2023-07-19 | finish no earlier than 2023-07-19 |  | SI Test | SIT |  | 5.0 | COMPLETE | Complete | PP |  | Systems Integration Testing (SIT) | T3-TE-0012 | SITAG | T3 | MHHS-ART073 |
| 596 | 1.4.1.4.1.2 | **Test Data Approach & Plan** |  | 29d | 2023-06-09 A | 2023-07-19 A |  | 100% | 2023-06-09 | 2023-07-19 | 29d | 2023-06-09 | 2023-07-19 |  |  | N/A | SIT |  | 5.0 |  |  | N/A | N/A | Systems Integration Testing (SIT) |  |  |  |  |
| 597 | 1.4.1.4.1.2.1 | Industry consultation |  | 10d | 2023-06-09 A | 2023-06-22 A | 593SS | 100% | 2023-06-09 | 2023-06-22 | 10d |  |  |  |  | PP | SIT |  | 5.1 | COMPLETE | Complete |  | Cesar Lopes | Systems Integration Testing (SIT) |  |  |  |  |
| 598 | 1.4.1.4.1.2.2 | Artefact review (via TMAG) and updates |  | 19d | 2023-06-23 A | 2023-07-19 A | 597 | 100% | 2023-06-23 | 2023-07-19 | 19d | 2023-06-09 | 2023-07-06 |  |  | SI Test | SIT |  | 5.0 | COMPLETE | Complete | PP | Cesar Lopes | Systems Integration Testing (SIT) |  |  |  |  |
| 599 | 1.4.1.4.1.2.3 | SIT Component Integration Testing Test Data Approach & Plan approved | milestone | 0d | 2023-07-19 A | 2023-07-19 A | 598 | 100% | 2023-07-19 | 2023-07-19 | 0d | 2023-07-19 | 2023-07-19 |  |  | SI Test | SIT |  | 5.0 | COMPLETE | Complete | IPA | Cesar Lopes | Systems Integration Testing (SIT) |  |  |  |  |

| ID | WBS | Task | Type | Duration | Start | Finish | Predecessors | Complete | Baseline start | Baseline finish | Baseline duration | Baseline 1 start | Baseline 1 finish | Constraint | Baseline cost | Responsible | Involved | Text9 | Update Version | MHHS Resource Name | MHHS Programme Phase | Sched Status | RAG | Artefact ID | Milestone ID | Text29 | Tier | Task Status |
| --- | --- | --- | --- | --- | --- | --- | --- | --- | --- | --- | --- | --- | --- | --- | --- | --- | --- | --- | --- | --- | --- | --- | --- | --- | --- | --- | --- | --- |
| 600 | 1.4.1.4.1.3 | **Test scenarios** |  | 173d | 2023-01-02 A | 2023-08-30 A |  | 100% | 2023-01-02 | 2023-08-30 | 173d | 2023-01-02 | 2023-06-02 |  |  | N/A | N/A | SIT | 5.0 | N/A | Systems Integration Testing (SIT) |  |  |  |  |  |  |  |
| 601 | 1.4.1.4.1.3.1 | Development of test scenarios | milestone | 0d | 2023-01-02 A | 2023-01-02 A | 592SS+45d | 100% | 2023-01-02 | 2023-04-28 | 85d | 2023-01-02 | 2023-04-28 |  |  | SI Test | PP, Code Bodies | SIT | 5.0 |  | Systems Integration Testing (SIT) | Complete | COMPLETE |  |  |  |  |  |
| 602 | 1.4.1.4.1.3.2 | Review test scenarios with SIT Working Group |  | 11d | 2023-02-01 A | 2023-02-15 A | 601SS+22d | 100% | 2023-02-01 | 2023-08-09 | 136d | 2023-02-01 | 2023-05-26 |  |  | SI Test | PP, Code Bodies, IPA | SIT | 5.0 |  | Systems Integration Testing (SIT) | Complete | COMPLETE |  |  |  |  |  |
| 603 | 1.4.1.4.1.3.3 | SIT Component Integration Testing Test scenarios approved | milestone | 0d | 2023-08-30 A | 2023-08-30 A | 602FS+15d | 100% | 2023-08-30 | 2023-08-30 | 0d | 2023-06-02 | 2023-06-02 |  |  | SI Test | PP | SIT | 5.6 |  | Systems Integration Testing (SIT) | Complete | COMPLETE | MHHS-ART148 | T3-TE-0014 | SITAG | T3 |  |
| 604 | 1.4.1.4.1.4 | **Test cases** |  | 160d | 2023-05-01 A | 2023-12-08 A |  | 100% | 2023-05-01 | 2023-12-08 | 160d | 2023-05-01 | 2023-09-01 |  |  | N/A | N/A | SIT | 5.6 | N/A | Systems Integration Testing (SIT) |  |  |  |  |  |  |  |
| 605 | 1.4.1.4.1.4.1 | **SI Test cases** |  | 160d | 2023-05-01 A | 2023-12-08 A |  | 100% | 2023-05-01 | 2023-12-08 | 160d | 2023-05-01 | 2023-09-01 |  |  | N/A | N/A | SIT | 5.6 | N/A | Systems Integration Testing (SIT) |  |  |  |  |  |  |  |
| 606 | 1.4.1.4.1.4.1.1 | **Batch 1 (CIT Intervals 1 and 2)** |  | 110d | 2023-05-01 A | 2023-09-29 A |  | 100% | 2023-05-01 | 2023-09-29 | 110d |  |  |  |  | N/A | N/A | SIT | 5.6 | N/A | Systems Integration Testing (SIT) |  |  |  |  |  |  | -290.67 |
| 607 | 1.4.1.4.1.4.1.1.1 | Develop Test cases |  | 100d | 2023-05-01 A | 2023-09-15 A | 601 | 100% | 2023-05-01 | 2023-09-15 | 100d | 2023-05-01 | 2023-07-28 |  |  | SI Test |  | SIT | 5.6 |  | Systems Integration Testing (SIT) | Complete | COMPLETE |  |  |  |  |  |
| 608 | 1.4.1.4.1.4.1.1.2 | Review Test cases with SIT Working Group |  | 9d | 2023-09-18 A | 2023-09-28 A | 607 | 100% | 2023-09-18 | 2023-09-28 | 9d | 2023-05-26 | 2023-08-25 |  |  | SI Test | PP,IPA | SIT | 5.6 |  | Systems Integration Testing (SIT) | Complete | COMPLETE |  |  |  |  |  |
| 609 | 1.4.1.4.1.4.1.1.3 | SIT Component Integration Testing Test cases Batch 1 (CIT Intervals 1 and 2) approved at ETMAG | milestone | 0d | 2023-09-29 A | 2023-09-29 A | 608FS+1d | 100% | 2023-09-29 | 2023-09-29 | 0d | 2023-09-01 | 2023-09-01 |  |  | SI Test | PP | SIT | 5.6 |  | Systems Integration Testing (SIT) | Complete | COMPLETE | MHHS-ART073 | T3-TE-0069 | SITAG | T3 |  |
| 610 | 1.4.1.4.1.4.1.2 | **Batch 2 (CIT Intervals 3 and 4)** |  | 25d | 2023-10-02 A | 2023-11-03 A |  | 100% | 2023-10-02 | 2023-11-03 | 25d |  |  |  |  | N/A | N/A | SIT | 5.6 | N/A | Systems Integration Testing (SIT) |  |  |  |  |  |  | -290.67 |
| 611 | 1.4.1.4.1.4.1.2.1 | Develop Test cases |  | 15d | 2023-10-02 A | 2023-10-20 A | 609 | 100% | 2023-10-02 | 2023-10-20 | 15d | 2023-05-01 | 2023-07-28 |  |  | SI Test |  | SIT | 5.6 |  | Systems Integration Testing (SIT) | Complete | COMPLETE |  |  |  |  |  |
| 612 | 1.4.1.4.1.4.1.2.2 | Review Test cases with SIT Working Group |  | 9d | 2023-10-23 A | 2023-11-02 A | 611 | 100% | 2023-10-23 | 2023-11-02 | 9d | 2023-05-26 | 2023-08-25 |  |  | SI Test | PP,IPA | SIT | 5.6 |  | Systems Integration Testing (SIT) | Complete | COMPLETE |  |  |  |  |  |
| 613 | 1.4.1.4.1.4.1.2.3 | SIT Component Integration Testing Test cases Batch 2 (CIT Intervals 3 and 4) approved at ETMAG | milestone | 0d | 2023-11-03 A | 2023-11-03 A | 612FS+1d | 100% | 2023-11-03 | 2023-11-03 | 0d | 2023-09-01 | 2023-09-01 |  |  | SI Test | PP | SIT | 5.11 |  | Systems Integration Testing (SIT) | Complete | COMPLETE |  | T3-TE-0104 | SITAG | T3 |  |
| 614 | 1.4.1.4.1.4.1.3 | **Batch 3 (CIT Intervals 5 and 6)** |  | 25d | 2023-11-03 A | 2023-12-08 A |  | 100% | 2023-11-03 | 2023-12-08 | 25d |  |  |  |  | N/A | N/A | SIT | 5.6 | N/A | Systems Integration Testing (SIT) |  |  |  |  |  |  | -290.67 |
| 615 | 1.4.1.4.1.4.1.3.1 | Develop Test cases |  | 15d | 2023-11-03 A | 2023-11-24 A | 613 | 100% | 2023-11-03 | 2023-11-24 | 15d | 2023-05-01 | 2023-07-28 |  |  | SI Test |  | SIT | 5.6 |  | Systems Integration Testing (SIT) | Complete | COMPLETE |  |  |  |  |  |
| 616 | 1.4.1.4.1.4.1.3.2 | Review Test cases with SIT Working Group |  | 9d | 2023-11-27 A | 2023-12-07 A | 615 | 100% | 2023-11-27 | 2023-12-07 | 9d | 2023-05-26 | 2023-08-25 |  |  | SI Test | PP,IPA | SIT | 5.6 |  | Systems Integration Testing (SIT) | Complete | COMPLETE |  |  |  |  |  |
| 617 | 1.4.1.4.1.4.1.3.3 | SIT Component Integration Testing Test cases Batch 3 (CIT Intervals 5 and 6) approved at ETMAG | milestone | 0d | 2023-12-08 A | 2023-12-08 A | 616FS+1d | 100% | 2023-12-08 | 2023-12-08 | 0d | 2023-09-01 | 2023-09-01 |  |  | SI Test | PP | SIT | 5.14 |  | Systems Integration Testing (SIT) | Complete | COMPLETE |  | T3-TE-0105 | SITAG | T3 |  |
| 618 | 1.4.1.4.1.5 | **CIT Interval 1 Preparation** |  | 283d | 2022-11-16 A | 2023-12-15 A |  | 100% | 2022-11-16 | 2023-12-15 | 278d | 2022-11-16 | 2023-10-23 |  | -0 | N/A | N/A | SIT | 5.6 | N/A | Systems Integration Testing (SIT) |  |  |  |  |  |  |  |
| 619 | 1.4.1.4.1.5.1 | **Environments (SIT A)** |  | 246d | 2022-11-16 A | 2023-10-25 A |  | 100% | 2022-11-16 | 2023-10-25 | 239d | 2022-11-16 | 2023-10-06 |  |  | N/A | N/A | SIT | 5.0 | N/A | Systems Integration Testing (SIT) |  |  |  |  |  |  |  |
| 620 | 1.4.1.4.1.5.1.1 | PPs register PKI Officers and request PKI certificates |  | 5d | 2023-10-09 A | 2023-10-13 A |  | 100% | 2023-10-09 | 2023-10-13 | 5d | 2023-08-28 | 2023-09-01 | start no earlier than 2023-10-09 |  | PP | DIP Provider | SIT | 5.5 | Simon Berry | Systems Integration Testing (SIT) | Complete | COMPLETE |  |  |  |  |  |
| 621 | 1.4.1.4.1.5.1.2 | PPs register PKI Officers and request PKI certificates Complete - Interval 1 | milestone | 0d | 2023-10-25 A | 2023-10-25 A | 620FS+8d | 100% | 2023-10-25 | 2023-10-25 | 0d |  |  |  |  | PP | DIP Provider | SIT | 5.10 | Simon Berry | Systems Integration Testing (SIT) | Complete | COMPLETE |  | T3-TE-0094 | SITAG | T3 |  |
| 622 | 1.4.1.4.1.5.1.3 | PP SIT A environment preparation (incl. security certificates and security compliance) |  | 238d | 2022-11-16 A | 2023-10-13 A | 511 | 100% | 2022-11-16 | 2023-10-13 | 208d | 2022-11-16 | 2023-09-01 |  |  | PP | SI Test | SIT | 5.8 | Simon Berry | Systems Integration Testing (SIT) | Complete | COMPLETE |  |  |  |  |  |
| 623 | 1.4.1.4.1.5.1.4 | SI coordinate SIT Participants' SIT A environment preparation |  | 238d | 2022-11-16 A | 2023-10-13 A | 622SS | 100% | 2022-11-16 | 2023-10-13 | 208d | 2022-11-16 | 2023-09-01 |  |  | SI Test | PP | SIT | 5.8 | Simon Berry | Systems Integration Testing (SIT) | Complete | COMPLETE |  |  |  |  |  |
| 624 | 1.4.1.4.1.5.1.5 | PP submit self-declaration of environment preparation complete (incl. security certificates and security compliance) to Programme for assurance | milestone | 0d | 2023-10-13 A | 2023-10-13 A | 622FF | 100% | 2023-10-13 | 2023-10-13 | 0d | 2023-09-01 | 2023-09-01 | start no earlier than 2023-10-13 |  | PP | SI Test | SIT | 5.8 | Simon Berry | Systems Integration Testing (SIT) | Complete | COMPLETE |  |  |  |  |  |
| 625 | 1.4.1.4.1.5.1.6 | SI assure PPs' self-declaration of environment preparation complete (incl. security certificates and security compliance) |  | 5d | 2023-10-16 A | 2023-10-20 A | 624FF+5d | 100% | 2023-10-16 | 2023-10-20 | 5d | 2023-09-04 | 2023-09-08 |  |  | SI Test | PP | SIT | 5.8 | Simon Berry | Systems Integration Testing (SIT) | Complete | COMPLETE |  |  |  |  |  |
| 626 | 1.4.1.4.1.5.1.7 | SIT Participants' SIT A environments ready to start connectivity proving CIT Interval 1 | milestone | 0d | 2023-09-01 A | 2023-09-01 A | 624SS | 100% | 2023-09-01 | 2023-09-01 | 0d | 2023-09-01 | 2023-09-01 |  |  | PP | PP,IPA | SIT | 5.6 | Simon Berry | Systems Integration Testing (SIT) | Complete | COMPLETE | MHHS-ART139 | T3-TE-0019 | SITAG | T3 |  |
| 627 | 1.4.1.4.1.5.1.8 | PP SIT A environment connectivity proving |  | 10d | 2023-09-04 A | 2023-09-15 A | 626 | 100% | 2023-09-04 | 2023-09-15 | 20d | 2023-09-04 | 2023-09-29 |  |  | PP | SI Test | SIT | 5.8 | Simon Berry | Systems Integration Testing (SIT) | Complete | COMPLETE |  |  |  |  |  |
| 628 | 1.4.1.4.1.5.1.9 | SI coordinate SIT Participants' SIT A environment connectivity proving |  | 10d | 2023-09-04 A | 2023-09-15 A | 627SS | 100% | 2023-09-04 | 2023-09-15 | 20d | 2023-09-04 | 2023-09-29 |  |  | SI Test | PP | SIT | 5.8 | Simon Berry | Systems Integration Testing (SIT) | Complete | COMPLETE |  |  |  |  |  |
| 629 | 1.4.1.4.1.5.1.10 | PP deployment of MHHS solution code to SIT A environments |  | 10d | 2023-09-25 A | 2023-10-06 A | 670FF | 100% | 2023-09-25 | 2023-10-06 | 10d | 2023-09-18 | 2023-09-29 |  |  | PP | SI Test | SIT | 5.0 | Simon Berry | Systems Integration Testing (SIT) | Complete | COMPLETE |  |  |  |  |  |
| 630 | 1.4.1.4.1.5.1.11 | SI coordinate deployment of MHHS solution code to SIT Participants' SIT A environments |  | 10d | 2023-09-25 A | 2023-10-06 A | 670FF | 100% | 2023-09-25 | 2023-10-06 | 10d | 2023-09-18 | 2023-09-29 |  |  | SI Test | PP | SIT | 5.0 | Simon Berry | Systems Integration Testing (SIT) | Complete | COMPLETE |  |  |  |  |  |
| 631 | 1.4.1.4.1.5.1.12 | PP submit evidence of SIT A environment connectivity proving and code deployment completion to Programme for assurance |  | 30d | 2023-09-04 A | 2023-10-13 A | 627SS | 100% | 2023-09-04 | 2023-10-13 | 20d | 2023-09-04 | 2023-09-29 |  |  | PP | SI Test | SIT | 5.8 | Simon Berry | Systems Integration Testing (SIT) | Complete | COMPLETE |  |  |  |  |  |
| 632 | 1.4.1.4.1.5.1.13 | SI assurance of SIT Participants' SIT A environment connectivity proving and code deployment completion |  | 25d | 2023-09-18 A | 2023-10-20 A | 631FF+5d | 100% | 2023-09-18 | 2023-10-20 | 25d | 2023-09-04 | 2023-10-06 |  |  | SI Test | PP | SIT | 5.8 | Simon Berry | Systems Integration Testing (SIT) | Complete | COMPLETE |  |  |  |  |  |

Notes:
- 609: Guidance: 18/8 - needs to finish on 29/9 for ETWAG / Action: 18/8 - needs to finish on 29/9 for ETWAG. Update Milestone register after approval
- 613: Guidance: 18/8 - needs to finish on 3/11 for ETWAG / Action: 18/8 - needs to finish on 29/9 for ETWAG
- 617: Guidance: 28/11 - Red because TMAG date has moved from 8/12 to 20/12 due to reduction in Dec TMAGs. No impact. No action

| ID | WBS | Task | Type | Duration | Start | Finish | Predecessors | Complete | Baseline start | Baseline finish | Baseline duration | Baseline cost | Responsible | Involved | Text9 | Task Status | Update Version | MHHS Resource Name | MHHS Programme Phase | Sched Status | RAG | Action | Milestone ID | Text29 | Tier | Artefact ID |
| --- | --- | --- | --- | --- | --- | --- | --- | --- | --- | --- | --- | --- | --- | --- | --- | --- | --- | --- | --- | --- | --- | --- | --- | --- | --- | --- |
| 633 | 1.4.1.4.1.5.2 | **Test Data - ISD Creation** |  | 9d | 2023-08-22 A | 2023-09-01 A |  | 100% | 2023-08-22 | 2023-09-01 | 9d |  | N/A | N/A | SIT | -275.67 | 5.5 | N/A | Systems Integration Testing (SIT) |  |  |  |  |  |  |  |
| 634 | 1.4.1.4.1.5.2.1 | Set-up Market Participants and DIP ID Data |  | 8d | 2023-08-22 A | 2023-08-31 A |  | 100% | 2023-08-22 | 2023-08-31 | 8d |  | SI Test Data | SI Test, DIP, Helix | SIT |  | 5.5 | Cesar Lopes | Systems Integration Testing (SIT) | Complete | COMPLETE |  |  |  |  |  |
| 635 | 1.4.1.4.1.5.2.2 | Distribute ISD Data to Participants |  | 1d | 2023-09-01 A | 2023-09-01 A | 634 | 100% | 2023-09-01 | 2023-09-01 | 1d |  | SI Test Data | SI Test, DIP, Helix | SIT |  | 5.5 | Cesar Lopes | Systems Integration Testing (SIT) | Complete | COMPLETE |  |  |  |  |  |
| 636 | 1.4.1.4.1.5.2.3 | Test Data - ISD Creation Complete | milestone | 0d | 2023-09-01 A | 2023-09-01 A | 635 | 100% | 2023-09-01 | 2023-09-01 | 0d |  | SI Test Data | SI Test, DIP, Helix | SIT |  | 5.5 | Cesar Lopes | Systems Integration Testing (SIT) | Complete | COMPLETE | 3/8 - add as t3 milestones. Awaiting approval at TMAG | T3-TE-0083 | SITAG | T3 |  |
| 637 | 1.4.1.4.1.5.3 | **Test Data - SFTP Onboarding** |  | 70d | 2023-08-21 A | 2023-11-24 A |  | 100% | 2023-08-21 | 2023-11-24 | 70d | -0 | N/A | N/A | SIT | -275.67 | 5.5 | N/A | Systems Integration Testing (SIT) |  |  |  |  |  |  |  |
| 638 | 1.4.1.4.1.5.3.1 | Create Containers and Keys for Participants |  | 3d | 2023-08-21 A | 2023-08-23 A |  | 100% | 2023-08-21 | 2023-08-23 | 3d |  | SI Test Data | SI Test | SIT |  | 5.5 | Cesar Lopes | Systems Integration Testing (SIT) | Complete | COMPLETE |  |  |  |  |  |
| 639 | 1.4.1.4.1.5.3.2 | Share SFTP Access with Participants |  | 5d | 2023-08-24 A | 2023-08-30 A | 638 | 100% | 2023-08-24 | 2023-08-30 | 5d |  | SI Test Data | SI Test, PP | SIT |  | 5.5 | Cesar Lopes | Systems Integration Testing (SIT) | Complete | COMPLETE |  |  |  |  |  |
| 640 | 1.4.1.4.1.5.3.3 | Test SFTP Connectivity |  | 5d | 2023-08-31 A | 2023-09-06 A | 639 | 100% | 2023-08-31 | 2023-09-06 | 5d |  | SI Test Data | SI Test, PP | SIT |  | 5.5 | Cesar Lopes | Systems Integration Testing (SIT) | Complete | COMPLETE |  |  |  |  |  |
| 641 | 1.4.1.4.1.5.3.4 | Test Data - SFTP Onboarding Complete | milestone | 0d | 2023-11-24 A | 2023-11-24 A | 640FS+57d | 100% | 2023-11-24 | 2023-11-24 | 0d |  | SI Test Data | SI Test, PP | SIT |  | 5.13 | Cesar Lopes | Systems Integration Testing (SIT) | Complete | COMPLETE |  | T3-TE-0084 | SITAG | T3 |  |
| 642 | 1.4.1.4.1.5.4 | **Test Data - Provide Sample Files** |  | 10d | 2023-08-21 A | 2023-09-01 A |  | 100% | 2023-08-21 | 2023-09-01 | 10d |  | N/A | N/A | SIT | -275.67 | 5.5 | N/A | Systems Integration Testing (SIT) |  |  |  |  |  |  |  |
| 643 | 1.4.1.4.1.5.4.1 | Generate Sample Files off IF Messages |  | 8d | 2023-08-21 A | 2023-08-30 A |  | 100% | 2023-08-21 | 2023-08-30 | 8d |  | SI Test Data | SI Test | SIT |  | 5.5 | Cesar Lopes | Systems Integration Testing (SIT) | Complete | COMPLETE |  |  |  |  |  |
| 644 | 1.4.1.4.1.5.4.2 | Transmit Sample Files off IF Messages to Participants (More detail needs to be planned for a POC) |  | 2d | 2023-08-31 A | 2023-09-01 A | 643 | 100% | 2023-08-31 | 2023-09-01 | 2d |  | SI Test Data | SI Test | SIT |  | 5.5 | Cesar Lopes | Systems Integration Testing (SIT) | Complete | COMPLETE |  |  |  |  |  |
| 645 | 1.4.1.4.1.5.4.3 | Test Data - Provide Sample Files Complete | milestone | 0d | 2023-09-01 A | 2023-09-01 A | 644 | 100% | 2023-09-01 | 2023-09-01 | 0d |  | SI Test Data | SI Test | SIT |  | 5.5 | Cesar Lopes | Systems Integration Testing (SIT) | Complete | COMPLETE | 3/8 - add as t3 milestones. Awaiting approval at TMAG | T3-TE-0085 | SITAG | T3 |  |
| 646 | 1.4.1.4.1.5.5 | **Test Data - Detailed SIT Data Load Guidance** |  | 65d | 2023-09-07 A | 2023-12-06 A |  | 100% | 2023-09-07 | 2023-12-06 | 62d | -0 | N/A | N/A | SIT | -275.67 | 5.5 | N/A | Systems Integration Testing (SIT) |  |  |  |  |  |  |  |
| 647 | 1.4.1.4.1.5.5.1 | Document Guidance |  | 21d | 2023-09-07 A | 2023-10-05 A | 645FS+3d | 100% | 2023-09-07 | 2023-10-05 | 16d |  | SI Test Data | SI Test | SIT |  | 5.9 | Cesar Lopes | Systems Integration Testing (SIT) | Complete | COMPLETE |  |  |  |  |  |
| 648 | 1.4.1.4.1.5.5.2 | Provide Guidance to PPs |  | 1d | 2023-10-06 A | 2023-10-06 A | 647 | 100% | 2023-10-06 | 2023-10-06 | 1d |  | SI Test Data | SI Test | SIT |  | 5.9 | Cesar Lopes | Systems Integration Testing (SIT) | Complete | COMPLETE |  |  |  |  |  |
| 649 | 1.4.1.4.1.5.5.3 | Test Data - Detailed SIT Functional Data Load Guidance Complete | milestone | 0d | 2023-12-06 A | 2023-12-06 A | 648FS+43d | 100% | 2023-12-06 | 2023-12-06 | 0d |  | SI Test Data | SI Test | SIT |  | 5.13 | Michael Inije | Systems Integration Testing (SIT) | Complete | COMPLETE |  | T3-TE-0095 | SITAG | T3 | MHHS-DEL 1545 |
| 650 | 1.4.1.4.1.5.6 | **Test Data - Population of Data Items for Testing Guidance - Draft** |  | 80d | 2023-08-17 A | 2023-12-06 A |  | 100% | 2023-08-17 | 2023-12-06 | 77d | -0 | N/A | N/A | SIT | -275.67 | 5.5 | N/A | Systems Integration Testing (SIT) |  |  |  |  |  |  |  |
| 651 | 1.4.1.4.1.5.6.1 | Document Guidance - Draft |  | 11d | 2023-08-17 A | 2023-08-31 A | 840 | 100% | 2023-08-17 | 2023-08-31 | 11d |  | SI Test Data | SI Test | SIT |  | 5.6 | Cesar Lopes | Systems Integration Testing (SIT) | Complete | COMPLETE |  |  |  |  |  |
| 652 | 1.4.1.4.1.5.6.2 | Provide Guidance to PPs - Draft |  | 1d | 2023-09-01 A | 2023-09-01 A | 651 | 100% | 2023-09-01 | 2023-09-01 | 1d |  | SI Test Data | SI Test | SIT |  | 5.6 | Cesar Lopes | Systems Integration Testing (SIT) | Complete | COMPLETE |  |  |  |  |  |
| 653 | 1.4.1.4.1.5.6.3 | Test Data - Population of Data Items for Testing Guidance - Draft Complete | milestone | 0d | 2023-12-06 A | 2023-12-06 A | 652FS+68d | 100% | 2023-12-06 | 2023-12-06 | 0d |  | SI Test Data | SI Test | SIT |  | 5.13 | Michael Inije | Systems Integration Testing (SIT) | Complete | COMPLETE |  | T3-TE-0096 | SITAG | T3 | MHHS-DEL 816 |
| 654 | 1.4.1.4.1.5.7 | **Test Data - Population of Data Items for Testing Guidance - Final** |  | 87d | 2023-08-17 A | 2023-12-15 A |  | 100% | 2023-08-17 | 2023-12-15 | 45d |  | N/A | N/A | SIT | -275.67 | 5.5 | N/A | Systems Integration Testing (SIT) |  |  |  |  |  |  |  |
| 655 | 1.4.1.4.1.5.7.1 | Update Document Guidance With PPS Feedback |  | 81d | 2023-08-17 A | 2023-12-07 A | 651SS | 100% | 2023-08-17 | 2023-12-07 | 44d |  | SI Test Data | SI Test | SIT |  | 5.5 | Michael Inije | Systems Integration Testing (SIT) | Complete | COMPLETE |  |  |  |  |  |
| 656 | 1.4.1.4.1.5.7.2 | Provide Final Guidance to PPs |  | 1d | 2023-12-08 A | 2023-12-08 A | 655 | 100% | 2023-12-08 | 2023-12-08 | 1d |  | SI Test Data | SI Test | SIT |  | 5.5 | Michael Inije | Systems Integration Testing (SIT) | Complete | COMPLETE |  |  |  |  |  |
| 657 | 1.4.1.4.1.5.7.3 | Test Data - Population of Data Items for Testing Guidance - Final Complete | milestone | 0d | 2023-12-15 A | 2023-12-15 A | 656FS+5d | 100% | 2023-12-15 | 2023-12-15 | 0d |  | SI Test Data | SI Test | SIT |  | 5.14 | Michael Inije | Systems Integration Testing (SIT) | Complete | COMPLETE |  | T3-TE-0097 | SITAG | T3 | MHHS-DEL 816 |

| ID | WBS | Task | Type | Duration | Start | Finish | Predecessors | Complete | Baseline start | Baseline finish | Baseline duration | Baseline 1 start | Baseline 1 finish | Constraint | Baseline cost | Responsible | Involved | Text9 | Update Version | MHHS Resource Name | MHHS Programme Phase | Sched Status | RAG | Artefact ID | Milestone ID | Text29 | Tier |
| --- | --- | --- | --- | --- | --- | --- | --- | --- | --- | --- | --- | --- | --- | --- | --- | --- | --- | --- | --- | --- | --- | --- | --- | --- | --- | --- | --- |
| 658 | 1.4.1.4.1.5.8 | **Test Data (SIT A) Interval 1** |  | 40d | 2023-09-04 A | 2023-10-27 A |  | 100% | 2023-09-04 | 2023-10-27 | 20d | 2023-09-04 | 2023-09-29 |  |  | N/A | N/A | SIT | 5.0 | N/A | Systems Integration Testing (SIT) |  |  |  |  |  |  |
| 659 | 1.4.1.4.1.5.8.1 | Run data allocation |  | 4d | 2023-09-04 A | 2023-09-07 A | 599, 636 | 100% | 2023-09-04 | 2023-09-07 | 4d | 2023-09-04 | 2023-09-07 |  |  | SI Test |  | SIT | 5.0 | Cesar Lopes | Systems Integration Testing (SIT) | Complete | COMPLETE |  |  |  |  |
| 660 | 1.4.1.4.1.5.8.2 | Cleanse, anonymise and populate data post cut |  | 4d | 2023-09-08 A | 2023-09-13 A | 659 | 100% | 2023-09-08 | 2023-09-13 | 4d | 2023-09-08 | 2023-09-13 |  |  | SI Test |  | SIT | 5.0 | Cesar Lopes | Systems Integration Testing (SIT) | Complete | COMPLETE |  |  |  |  |
| 661 | 1.4.1.4.1.5.8.3 | Transmit data sets to PPs |  | 3d | 2023-09-15 A | 2023-09-19 A | 660 | 100% | 2023-09-15 | 2023-09-19 | 1d | 2023-09-14 | 2023-09-15 |  |  | SI Test |  | SIT | 5.0 | Cesar Lopes | Systems Integration Testing (SIT) | Complete | COMPLETE |  |  |  |  |
| 662 | 1.4.1.4.1.5.8.4 | PP - Load test data to test environments |  | 7d | 2023-09-20 A | 2023-09-28 A | 661, 645 | 100% | 2023-09-20 | 2023-09-28 | 5d | 2023-09-18 | 2023-09-22 |  |  | PP |  | SIT | 5.0 | Cesar Lopes | Systems Integration Testing (SIT) | Complete | COMPLETE |  |  |  |  |
| 663 | 1.4.1.4.1.5.8.5 | PP Check data integrity on test environment |  | 1d | 2023-09-29 A | 2023-09-29 A | 662 | 100% | 2023-09-29 | 2023-09-29 | 5d | 2023-09-25 | 2023-09-29 |  |  | PP |  | SIT | 5.0 | Cesar Lopes | Systems Integration Testing (SIT) | Complete | COMPLETE |  |  |  |  |
| 664 | 1.4.1.4.1.5.8.6 | PP submit self-declaration to Programme to confirm loading & verification of test data | milestone | 0d | 2023-09-29 A | 2023-09-29 A | 663FF | 100% | 2023-09-29 | 2023-09-29 | 0d | 2023-09-29 | 2023-09-29 |  |  | PP | SI Test | SIT | 5.0 | Cesar Lopes | Systems Integration Testing (SIT) | Complete | COMPLETE |  |  |  |  |
| 665 | 1.4.1.4.1.5.8.7 | Test Data (SIT A) Interval 1 Complete | milestone | 0d | 2023-10-27 A | 2023-10-27 A | 664FS+20d | 100% | 2023-10-27 | 2023-10-27 | 0d |  |  |  |  | SI Test | PP | SIT | 5.10 | Cesar Lopes | Systems Integration Testing (SIT) | Complete | COMPLETE | MHHS-ART148/169 | T3-TE-0073 | SITAG | T3 |
| 666 | 1.4.1.4.1.5.9 | **Other Preparation** |  | 45d | 2023-07-03 A | 2023-09-01 A |  | 100% | 2023-07-03 | 2023-09-01 | 45d | 2023-07-03 | 2023-09-01 |  |  | N/A | N/A | SIT | 5.0 | N/A | Systems Integration Testing (SIT) |  |  |  |  |  |  |
| 667 | 1.4.1.4.1.5.9.1 | Onboarding of Test Participants to Test Management Tool (Azure DevOps) |  | 45d | 2023-07-03 A | 2023-09-01 A | 626SF | 100% | 2023-07-03 | 2023-09-01 | 45d | 2023-07-03 | 2023-09-01 |  |  | SI Test | PP | SIT | 5.0 |  | Systems Integration Testing (SIT) | Complete | COMPLETE |  |  |  |  |
| 668 | 1.4.1.4.1.5.9.2 | Test Management Tool onboarding |  | 45d | 2023-07-03 A | 2023-09-01 A | 626SF | 100% | 2023-07-03 | 2023-09-01 | 45d | 2023-07-03 | 2023-09-01 |  |  | PP | SI Test | SIT | 5.0 |  | Systems Integration Testing (SIT) | Complete | COMPLETE |  |  |  |  |
| 669 | 1.4.1.4.1.5.10 | **SIT Component Integration Test Readiness Report** |  | 28d | 2023-09-14 A | 2023-10-23 A |  | 100% | 2023-09-14 | 2023-10-23 | 9d | 2023-09-11 | 2023-10-20 |  |  | N/A | N/A | SIT | 5.6 | N/A | Systems Integration Testing (SIT) |  |  |  |  |  |  |
| 670 | 1.4.1.4.1.5.10.1 | PP submit Test Readiness Report to Programme for assurance | milestone | 0d | 2023-10-20 A | 2023-10-20 A | 668, 609, 665 | 100% | 2023-10-20 | 2023-10-20 | 0d | 2023-09-29 | 2023-09-29 | start no earlier than 2023-10-09 |  | PP | SI Test | SIT | 5.6 |  | Systems Integration Testing (SIT) | Complete | COMPLETE |  |  |  |  |
| 671 | 1.4.1.4.1.5.10.2 | SI assure Test Participants' Test Readiness Reports |  | 1d | 2023-10-23 A | 2023-10-23 A | 670SS | 100% | 2023-10-23 | 2023-10-23 | 5d | 2023-10-02 | 2023-10-06 |  |  | SI Test | PP,IPA | SIT | 5.6 |  | Systems Integration Testing (SIT) | Complete | COMPLETE |  |  |  |  |
| 672 | 1.4.1.4.1.5.10.3 | SI develop Overarching SIT Component Integration Test Readiness Report |  | 23d | 2023-09-14 A | 2023-10-16 A | 595FS+40d | 100% | 2023-09-14 | 2023-10-16 | 4d | 2023-09-11 | 2023-10-06 |  |  | SI Test |  | SIT | 5.6 |  | Systems Integration Testing (SIT) | Complete | COMPLETE |  |  |  |  |
| 673 | 1.4.1.4.1.5.10.4 | Artefact review (via TMAG) and updates |  | 4d | 2023-10-17 A | 2023-10-20 A | 672 | 100% | 2023-10-17 | 2023-10-20 | 5d | 2023-10-09 | 2023-10-20 |  |  | SI Test | PP,IPA | SIT | 5.6 |  | Systems Integration Testing (SIT) | Complete | COMPLETE |  |  |  |  |
| 674 | 1.4.1.4.1.5.11 | SIT Component Integration Testing 1 Preparation Complete (incl. approval of SI SIT Component Integration Test Readiness Report) | milestone | 0d | 2023-10-27 A | 2023-10-27 A | 673FS+1d, 670, 626, 668, 665, 227, 232, 221, 241, 242, 671 | 100% | 2023-10-27 | 2023-10-27 | 0d | 2023-10-23 | 2023-10-23 |  |  | SI Test | PP,IPA | SIT | 5.11 |  | Systems Integration Testing (SIT) | Complete | COMPLETE | MHHS-ART071 | T2-TE-0250 | SITAG | T2 |
| 675 | 1.4.1.4.1.6 | **CIT Interval 2 Preparation** |  | 103d | 2023-07-03 A | 2023-11-22 A |  | 100% | 2023-07-03 | 2023-11-22 | 95d | 2022-11-16 | 2023-11-06 |  | -0 | N/A | N/A | SIT | 5.0 | N/A | Systems Integration Testing (SIT) |  |  |  |  |  |  |
| 676 | 1.4.1.4.1.6.1 | **Environments (SIT A)** |  | 43d | 2023-09-22 A | 2023-11-22 A |  | 100% | 2023-09-22 | 2023-11-22 | 35d | 2022-11-16 | 2023-10-27 |  | -0 | N/A | N/A | SIT | 5.0 | N/A | Systems Integration Testing (SIT) |  |  |  |  |  |  |
| 677 | 1.4.1.4.1.6.1.1 | SIT Participants' SIT A environments ready to start connectivity proving CIT Interval 2 | milestone | 0d | 2023-09-22 A | 2023-09-22 A |  | 100% | 2023-09-22 | 2023-09-22 | 0d | 2023-09-22 | 2023-09-22 |  |  | PP | PP,IPA | SIT | 5.6 | Simon Berry | Systems Integration Testing (SIT) | Complete | COMPLETE | MHHS-ART139 | T3-TE-0020 | SITAG | T3 |
| 678 | 1.4.1.4.1.6.1.2 | Programme Participants Ready to Start Connectivity Proving | milestone | 0d | 2023-09-22 A | 2023-09-22 A |  | 100% | 2023-09-22 | 2023-09-22 | 0d |  |  | finish no earlier than 2023-09-22 |  | PP |  | SIT | 5.10 | Simon Berry | Systems Integration Testing (SIT) | Complete | COMPLETE |  |  |  |  |
| 679 | 1.4.1.4.1.6.1.3 | Internal Connectivity Proving Phase |  | 10d | 2023-09-25 A | 2023-10-06 A | 678 | 100% | 2023-09-25 | 2023-10-06 | 10d |  |  |  |  | PP |  | SIT | 5.10 | Simon Berry | Systems Integration Testing (SIT) | Complete | COMPLETE |  |  |  |  |
| 680 | 1.4.1.4.1.6.1.4 | Internal Connectivity Proving Phase Complete | milestone | 0d | 2023-10-06 A | 2023-10-06 A | 679 | 100% | 2023-10-06 | 2023-10-06 | 0d |  |  | start no earlier than 2023-10-06 |  | PP |  | SIT | 5.10 | Simon Berry | Systems Integration Testing (SIT) | Complete | COMPLETE |  |  |  |  |
| 681 | 1.4.1.4.1.6.1.5 | DIP Onboarding Activity (1. PKI Officers and Certificates, 2. Set-up Validation, 3. End Point Creation, 4. Controlled Smoke Test ) |  | 28d | 2023-10-16 A | 2023-11-22 A | 680FS+5d | 100% | 2023-10-16 | 2023-11-22 | 20d |  |  |  |  | PP |  | SIT | 5.10 | Simon Berry | Systems Integration Testing (SIT) | Complete | COMPLETE |  |  |  |  |
| 682 | 1.4.1.4.1.6.1.6 | DIP Onboarding Complete | milestone | 0d | 2023-11-22 A | 2023-11-22 A | 681 | 100% | 2023-11-22 | 2023-11-22 | 0d |  |  |  |  | PP |  | SIT | 5.10 | Simon Berry | Systems Integration Testing (SIT) | Complete | COMPLETE |  |  |  |  |
| 683 | 1.4.1.4.1.6.1.7 | PPs Register PKI Officers and request PKI certificates Complete - Interval 2 | milestone | 0d | 2023-11-22 A | 2023-11-22 A | 682 | 100% | 2023-11-22 | 2023-11-22 | 0d |  |  |  |  | PP | DIP Provider | SIT | 5.15 | Simon Berry | Systems Integration Testing (SIT) | Complete | COMPLETE |  | T3-TE-0098 | SITAG | T3 |
| 684 | 1.4.1.4.1.6.1.8 | PP Code Deployment | milestone | 0d | 2023-10-20 A | 2023-10-20 A |  | 100% | 2023-10-20 | 2023-10-20 | 0d |  |  | start no earlier than 2023-10-20 |  | PP |  | SIT | 5.10 | Simon Berry | Systems Integration Testing (SIT) | Complete | COMPLETE |  |  |  |  |

Notes:
- 665: Action: 28/7: CH: Needs to be set-up as a reporting milestone. 31/7: Check with Cesar if has been approved so can be baselined
- 669: Action: 21/8 - Rework with Lee
- 671: Action: 21/8 - Rework with Lee
- 672: Action: 21/8 - Rework with Lee
- 673: Action: 21/8 - Rework with Lee

| ID | WBS | Task | Type | Duration | Start | Finish | Predecessors | Complete | Baseline start | Baseline finish | Baseline duration | Baseline 1 start | Baseline 1 finish | Constraint | Baseline cost | Responsible | Involved | Text9 | Update Version | MHHS Resource Name | MHHS Programme Phase | Sched Status | RAG | Artefact ID | Milestone ID | Text29 | Tier |
| --- | --- | --- | --- | --- | --- | --- | --- | --- | --- | --- | --- | --- | --- | --- | --- | --- | --- | --- | --- | --- | --- | --- | --- | --- | --- | --- | --- |
| 685 | 1.4.1.4.1.6.2 | **Test Data (SIT A) Interval 2** |  | 43d | 2023-09-20 A | 2023-11-17 A |  | 100% | 2023-09-20 | 2023-11-17 | 25d | 2023-09-18 | 2023-10-20 |  |  | N/A | N/A | SIT | 5.0 | N/A | Systems Integration Testing (SIT) |  |  |  |  |  |  |
| 686 | 1.4.1.4.1.6.2.1 | Run data allocation |  | 7d | 2023-09-20 A | 2023-09-28 A | 662SS | 100% | 2023-09-20 | 2023-09-28 | 5d | 2023-09-18 | 2023-09-22 |  |  | SI Test |  | SIT | 5.0 | Cesar Lopes | Systems Integration Testing (SIT) | Complete | COMPLETE |  |  |  |  |
| 687 | 1.4.1.4.1.6.2.2 | Cleanse and populate data post cut |  | 2d | 2023-09-29 A | 2023-10-02 A | 686 | 100% | 2023-09-29 | 2023-10-02 | 5d | 2023-09-25 | 2023-09-29 |  |  | SI Test |  | SIT | 5.0 | Cesar Lopes | Systems Integration Testing (SIT) | Complete | COMPLETE |  |  |  |  |
| 688 | 1.4.1.4.1.6.2.3 | Transmit data sets to PPs |  | 1d | 2023-10-03 A | 2023-10-03 A | 687 | 100% | 2023-10-03 | 2023-10-03 | 2d | 2023-10-02 | 2023-10-03 |  |  | SI Test |  | SIT | 5.0 | Cesar Lopes | Systems Integration Testing (SIT) | Complete | COMPLETE |  |  |  |  |
| 689 | 1.4.1.4.1.6.2.4 | PP - Load test data to test environments |  | 33d | 2023-10-04 A | 2023-11-17 A | 688 | 100% | 2023-10-04 | 2023-11-17 | 8d | 2023-10-04 | 2023-10-13 |  |  | PP |  | SIT | 5.0 | Cesar Lopes | Systems Integration Testing (SIT) | Complete | COMPLETE |  |  |  |  |
| 690 | 1.4.1.4.1.6.2.5 | PP Check data integrity on test environment |  | 15d | 2023-10-23 A | 2023-11-17 A | 689FF | 100% | 2023-10-23 | 2023-11-17 | 5d | 2023-10-16 | 2023-10-20 |  |  | PP |  | SIT | 5.0 | Cesar Lopes | Systems Integration Testing (SIT) | Complete | COMPLETE |  |  |  |  |
| 691 | 1.4.1.4.1.6.2.6 | PP submit self-declaration to Programme to confirm loading & verification of test data | milestone | 0d | 2023-11-17 A | 2023-11-17 A | 690FF | 100% | 2023-11-17 | 2023-11-17 | 0d | 2023-10-20 | 2023-10-20 |  |  | PP | SI Test | SIT | 5.0 | Cesar Lopes | Systems Integration Testing (SIT) | Complete | COMPLETE |  |  |  |  |
| 692 | 1.4.1.4.1.6.2.7 | Test Data (SIT A) Interval 2 Complete | milestone | 0d | 2023-11-17 A | 2023-11-17 A | 691 | 100% | 2023-11-17 | 2023-11-17 | 0d |  |  |  |  | SI Test | PP | SIT | 5.12 | Cesar Lopes | Systems Integration Testing (SIT) | Complete | COMPLETE | MHHS-ART148/169 | T3-TE-0074 | SITAG | T3 |
| 693 | 1.4.1.4.1.6.3 | **Other Preparation** |  | 87d | 2023-07-03 A | 2023-10-31 A |  | 100% | 2023-07-03 | 2023-10-31 | 87d | 2023-07-03 | 2023-09-22 |  | -0 | N/A | N/A | SIT | 5.0 | N/A | Systems Integration Testing (SIT) |  |  |  |  |  |  |
| 694 | 1.4.1.4.1.6.3.1 | Onboarding of Test Participants to Test Management Tool (Azure DevOps) |  | 60d | 2023-07-03 A | 2023-09-22 A | 677SF | 100% | 2023-07-03 | 2023-09-22 | 60d | 2023-07-03 | 2023-09-22 |  |  | SI Test | PP | SIT | 5.0 |  | Systems Integration Testing (SIT) | Complete | COMPLETE |  |  |  |  |
| 695 | 1.4.1.4.1.6.3.2 | Test Management Tool onboarding |  | 27d | 2023-09-25 A | 2023-10-31 A | 694 | 100% | 2023-09-25 | 2023-10-31 | 27d | 2023-07-03 | 2023-09-22 |  |  | PP | SI Test | SIT | 5.0 | Simon Berry | Systems Integration Testing (SIT) | Complete | COMPLETE |  |  |  |  |
| 696 | 1.4.1.4.1.6.4 | **SIT Component Integration Test Readiness Report** |  | 25d | 2023-10-02 A | 2023-11-03 A |  | 100% | 2023-10-02 | 2023-11-03 | 25d | 2023-10-02 | 2023-11-03 |  |  | N/A | N/A | SIT | 5.0 | N/A | Systems Integration Testing (SIT) |  |  |  |  |  |  |
| 697 | 1.4.1.4.1.6.4.1 | PP submit Test Readiness Report to Programme for assurance | milestone | 0d | 2023-10-25 A | 2023-10-25 A | 609FS+18d | 100% | 2023-10-25 | 2023-10-25 | 0d | 2023-10-20 | 2023-10-20 |  |  | PP | SI Test | SIT | 5.0 |  | Systems Integration Testing (SIT) | Complete | COMPLETE |  |  |  |  |
| 698 | 1.4.1.4.1.6.4.2 | SI assure Test Participants' Test Readiness Reports |  | 2d | 2023-10-26 A | 2023-10-27 A | 697 | 100% | 2023-10-26 | 2023-10-27 | 5d | 2023-10-23 | 2023-10-27 |  |  | SI Test | PP,IPA | SIT | 5.0 |  | Systems Integration Testing (SIT) | Complete | COMPLETE |  |  |  |  |
| 699 | 1.4.1.4.1.6.4.3 | SI develop Overarching SIT Component Integration Test Readiness Report |  | 20d | 2023-10-02 A | 2023-10-27 A | 698FF | 100% | 2023-10-02 | 2023-10-27 | 20d | 2023-10-02 | 2023-10-27 |  |  | SI Test |  | SIT | 5.0 |  | Systems Integration Testing (SIT) | Complete | COMPLETE |  |  |  |  |
| 700 | 1.4.1.4.1.6.4.4 | Artefact review (via TMAG) and updates |  | 5d | 2023-10-30 A | 2023-11-03 A | 699 | 100% | 2023-10-30 | 2023-11-03 | 5d | 2023-10-30 | 2023-11-03 |  |  | SI Test | PP,IPA | SIT | 5.0 |  | Systems Integration Testing (SIT) | Complete | COMPLETE |  |  |  |  |
| 701 | 1.4.1.4.1.6.5 | SIT Component Integration Testing 2 Preparation Complete (incl. approval of SI SIT Component Integration Test Readiness Report) | milestone | 0d | 2023-11-06 A | 2023-11-06 A | 695, 700FS+1d, 677, 290 | 100% | 2023-11-06 | 2023-11-06 | 0d | 2023-11-06 | 2023-11-06 |  |  | SI Test | PP,IPA | SIT | 5.11 |  | Systems Integration Testing (SIT) | Complete | COMPLETE | MHHS-ART071 | T2-TE-0300 | SITAG | T2 |
| 702 | 1.4.1.4.1.7 | **CIT Interval 3 Preparation** |  | 54d | 2023-10-03 A | 2023-12-15 A |  | 100% | 2023-10-03 | 2023-12-15 | 91d | 2022-11-16 | 2023-11-20 |  | -0 | N/A | N/A | SIT | 5.0 | N/A | Systems Integration Testing (SIT) |  |  |  |  |  |  |
| 703 | 1.4.1.4.1.7.1 | **PIT Test Completion Report (incl. evidence)** |  | 26d | 2023-10-13 A | 2023-11-17 A |  | 100% | 2023-10-13 | 2023-11-17 | 21d | 2023-10-13 | 2023-11-10 |  |  | N/A | N/A | SIT | 5.0 | N/A | Systems Integration Testing (SIT) |  |  |  |  |  |  |
| 704 | 1.4.1.4.1.7.1.1 | Submit draft PIT Test Completion Report (incl. evidence) and submit to Programme for assurance |  | 11d | 2023-10-13 A | 2023-10-27 A |  | 100% | 2023-10-13 | 2023-10-27 | 1d | 2023-10-13 | 2023-10-13 | must start on 2023-10-13 |  | PP | SI Test | SIT | 5.0 |  | Systems Integration Testing (SIT) | Complete | COMPLETE |  |  |  |  |
| 705 | 1.4.1.4.1.7.1.2 | Finalise PIT Test Completion Report (incl. evidence) |  | 5d | 2023-10-30 A | 2023-11-03 A | 704 | 100% | 2023-10-30 | 2023-11-03 | 15d | 2023-10-16 | 2023-11-03 |  |  | PP | SI Test | SIT | 5.0 |  | Systems Integration Testing (SIT) | Complete | COMPLETE |  |  |  |  |
| 706 | 1.4.1.4.1.7.1.3 | PP PIT Completion Report (excl. Migration/Reverse Migration) submitted to Programme for assurance CIT Interval 3 | milestone | 0d | 2023-11-03 A | 2023-11-03 A | 705, 79, 95 | 100% | 2023-11-03 | 2023-11-03 | 0d | 2023-11-03 | 2023-11-03 |  |  | PP | SI Test | SIT | 5.11 |  | Systems Integration Testing (SIT) | Complete | COMPLETE |  | T3-DB-0017 | SITAG | T3 |
| 707 | 1.4.1.4.1.7.1.4 | PP Final PIT Completion Reports assured by SI |  | 10d | 2023-11-06 A | 2023-11-17 A | 706 | 100% | 2023-11-06 | 2023-11-17 | 5d | 2023-11-06 | 2023-11-10 |  |  | SI Test | PP | SIT | 5.0 |  | Systems Integration Testing (SIT) | Complete | COMPLETE |  |  |  |  |
| 708 | 1.4.1.4.1.7.2 | **Environments (SIT A)** |  | 51d | 2023-10-06 A | 2023-12-15 A |  | 100% | 2023-10-06 | 2023-12-15 | 26d | 2022-11-16 | 2023-11-10 |  | -0 | N/A | N/A | SIT | 5.0 | N/A | Systems Integration Testing (SIT) |  |  |  |  |  |  |
| 709 | 1.4.1.4.1.7.2.1 | Programme Participants Ready to Start Connectivity Proving | milestone | 0d | 2023-10-06 A | 2023-10-06 A |  | 100% | 2023-10-06 | 2023-10-06 | 0d |  |  | start no earlier than 2023-10-06 |  | PP | PP.SI Test | SIT | 5.10 | Simon Berry | Systems Integration Testing (SIT) | Complete | COMPLETE |  |  |  |  |
| 710 | 1.4.1.4.1.7.2.2 | SIT Participants' SIT A environments ready to start connectivity proving CIT Interval 3 | milestone | 0d | 2023-10-06 A | 2023-10-06 A | 709 | 100% | 2023-10-06 | 2023-10-06 | 0d | 2023-10-06 | 2023-10-06 |  |  | PP | PP,SI Test | SIT | 5.10 | Simon Berry | Systems Integration Testing (SIT) | Complete | COMPLETE | MHHS-ART139 | T3-TE-0021 | SITAG | T3 |
| 711 | 1.4.1.4.1.7.2.3 | Internal Connectivity Proving Phase |  | 10d | 2023-10-09 A | 2023-10-20 A | 709FS+1d | 100% | 2023-10-09 | 2023-10-20 | 10d |  |  |  |  | PP | PP,SI Test | SIT | 5.10 | Simon Berry | Systems Integration Testing (SIT) | Complete | COMPLETE |  |  |  |  |
| 712 | 1.4.1.4.1.7.2.4 | Internal Connectivity Proving Phase Complete | milestone | 0d | 2023-10-20 A | 2023-10-20 A | 711 | 100% | 2023-10-20 | 2023-10-20 | 0d |  |  |  |  | PP | PP,SI Test | SIT | 5.10 | Simon Berry | Systems Integration Testing (SIT) | Complete | COMPLETE |  |  |  |  |
| 713 | 1.4.1.4.1.7.2.5 | DIP Onboarding Activity (1. PKI Officers and Certificates, 2. Set-up Validation, 3. End Point Creation, 4. Controlled Smoke Test ) |  | 35d | 2023-10-30 A | 2023-12-15 A | 712FS+5d | 100% | 2023-10-30 | 2023-12-15 | 10d |  |  |  |  | PP | PP,DIP Provider | SIT | 5.10 | Simon Berry | Systems Integration Testing (SIT) | Complete | COMPLETE |  |  |  |  |
| 714 | 1.4.1.4.1.7.2.6 | DIP Onboarding Complete | milestone | 0d | 2023-12-15 A | 2023-12-15 A | 713 | 100% | 2023-12-15 | 2023-12-15 | 0d |  |  |  |  | PP | PP,DIP Provider | SIT | 5.10 | Simon Berry | Systems Integration Testing (SIT) | Complete | COMPLETE |  |  |  |  |
| 715 | 1.4.1.4.1.7.2.7 | PPs Register PKI Officers and Request PKI certificates Complete - Interval 3 | milestone | 0d | 2023-12-15 A | 2023-12-15 A | 714FF | 100% | 2023-12-15 | 2023-12-15 | 0d | 2023-10-02 | 2023-10-06 |  |  | PP | PP,DIP Provider | SIT | 5.13 | Simon Berry | Systems Integration Testing (SIT) | Complete | COMPLETE |  | T3-TE-0099 | SITAG | T3 |
| 716 | 1.4.1.4.1.7.2.8 | PP Code Deployment | milestone | 0d | 2023-11-10 A | 2023-11-10 A | 712FS+15d | 100% | 2023-11-10 | 2023-11-10 | 0d |  |  | start no earlier than 2023-10-20 |  | PP | PP | SIT | 5.10 | Simon Berry | Systems Integration Testing (SIT) | Complete | COMPLETE |  |  |  |  |

Notes:
- 692: Action: 28/7: CH: Needs to be set-up as a reporting milestone. 31/7: Check with Cesar if has been approved so can be baselined
- 710: Action: 30/8 - lee said date is 30/10

| ID | WBS | Task | Type | Duration | Start | Finish | Predecessors | Complete | Baseline start | Baseline finish | Baseline duration | Baseline 1 start | Baseline 1 finish | Constraint | Baseline cost | Responsible | Involved | Text9 | Update Version | MHHS Resource Name | MHHS Programme Phase | Sched Status | RAG | Artefact ID | Milestone ID | Text29 | Tier |
| --- | --- | --- | --- | --- | --- | --- | --- | --- | --- | --- | --- | --- | --- | --- | --- | --- | --- | --- | --- | --- | --- | --- | --- | --- | --- | --- | --- |
| 717 | 1.4.1.4.1.7.3 | **Test Data (SIT A) Interval 3** |  | 34d | 2023-10-03 A | 2023-11-17 A |  | 100% | 2023-10-03 | 2023-11-17 | 25d | 2023-10-02 | 2023-11-03 |  |  | N/A | N/A | SIT | 5.0 | N/A | Systems Integration Testing (SIT) |  |  |  |  |  |  |
| 718 | 1.4.1.4.1.7.3.1 | Run data allocation |  | 4d | 2023-10-03 A | 2023-10-06 A | 688SS | 100% | 2023-10-03 | 2023-10-06 | 5d | 2023-10-02 | 2023-10-06 |  |  | SI Test |  | SIT | 5.0 | Cesar Lopes | Systems Integration Testing (SIT) | Complete | COMPLETE |  |  |  |  |
| 719 | 1.4.1.4.1.7.3.2 | Cleanse and populate data post cut |  | 5d | 2023-10-09 A | 2023-10-13 A | 718 | 100% | 2023-10-09 | 2023-10-13 | 5d | 2023-10-09 | 2023-10-13 |  |  | SI Test |  | SIT | 5.0 | Cesar Lopes | Systems Integration Testing (SIT) | Complete | COMPLETE |  |  |  |  |
| 720 | 1.4.1.4.1.7.3.3 | Transmit data sets to PPs |  | 2d | 2023-10-16 A | 2023-10-17 A | 719 | 100% | 2023-10-16 | 2023-10-17 | 2d | 2023-10-16 | 2023-10-17 |  |  | SI Test |  | SIT | 5.0 | Cesar Lopes | Systems Integration Testing (SIT) | Complete | COMPLETE |  |  |  |  |
| 721 | 1.4.1.4.1.7.3.4 | PP - Load test data to test environments |  | 8d | 2023-10-18 A | 2023-10-27 A | 720 | 100% | 2023-10-18 | 2023-10-27 | 8d | 2023-10-18 | 2023-10-27 |  |  | PP |  | SIT | 5.0 | Cesar Lopes | Systems Integration Testing (SIT) | Complete | COMPLETE |  |  |  |  |
| 722 | 1.4.1.4.1.7.3.5 | PP Check data integrity on test environment |  | 15d | 2023-10-30 A | 2023-11-17 A | 721 | 100% | 2023-10-30 | 2023-11-17 | 5d | 2023-10-30 | 2023-11-03 |  |  | PP |  | SIT | 5.0 | Cesar Lopes | Systems Integration Testing (SIT) | Complete | COMPLETE |  |  |  |  |
| 723 | 1.4.1.4.1.7.3.6 | PP submit self-declaration to Programme to confirm loading & verification of test data | milestone | 0d | 2023-11-17 A | 2023-11-17 A | 722FF | 100% | 2023-11-17 | 2023-11-17 | 0d | 2023-11-03 | 2023-11-03 |  |  | PP | SI Test | SIT | 5.0 | Cesar Lopes | Systems Integration Testing (SIT) | Complete | COMPLETE |  |  |  |  |
| 724 | 1.4.1.4.1.7.3.7 | Test Data (SIT A) Interval 3 Complete | milestone | 0d | 2023-11-17 A | 2023-11-17 A | 723 | 100% | 2023-11-17 | 2023-11-17 | 0d |  |  |  |  | SI Test | PP | SIT | 5.13 | Cesar Lopes | Systems Integration Testing (SIT) | Complete | COMPLETE | MHHS-ART148/169 | T3-TE-0075 | SITAG | T3 |
| 725 | 1.4.1.4.1.7.4 | **Other Preparation** |  | 25d | 2023-10-16 A | 2023-11-17 A |  | 100% | 2023-10-16 | 2023-11-17 | 60d | 2023-07-17 | 2023-10-06 |  |  | N/A | N/A | SIT | 5.0 | N/A | Systems Integration Testing (SIT) |  |  |  |  |  |  |
| 726 | 1.4.1.4.1.7.4.1 | Onboarding of Test Participants to Test Management Tool (Azure DevOps) |  | 25d | 2023-10-16 A | 2023-11-17 A |  | 100% | 2023-10-16 | 2023-11-17 | 60d | 2023-07-17 | 2023-10-06 | start no earlier than 2023-10-16 |  | SI Test | PP | SIT | 5.0 | Simon Berry | Systems Integration Testing (SIT) | Complete | COMPLETE |  |  |  |  |
| 727 | 1.4.1.4.1.7.4.2 | Test Management Tool onboarding |  | 25d | 2023-10-16 A | 2023-11-17 A |  | 100% | 2023-10-16 | 2023-11-17 | 60d | 2023-07-17 | 2023-10-06 | start no earlier than 2023-10-16 |  | PP | SI Test | SIT | 5.0 | Simon Berry | Systems Integration Testing (SIT) | Complete | COMPLETE |  |  |  |  |
| 728 | 1.4.1.4.1.7.5 | **SIT Component Integration Test Readiness Report** |  | 25d | 2023-10-16 A | 2023-11-17 A |  | 100% | 2023-10-16 | 2023-11-17 | 25d | 2023-10-16 | 2023-11-17 |  |  | N/A | N/A | SIT | 5.0 | N/A | Systems Integration Testing (SIT) |  |  |  |  |  |  |
| 729 | 1.4.1.4.1.7.5.1 | PP submit Test Readiness Report to Programme for assurance | milestone | 0d | 2023-11-03 A | 2023-11-03 A | 613 | 100% | 2023-11-03 | 2023-11-03 | 0d | 2023-11-03 | 2023-11-03 |  |  | PP | SI Test | SIT | 5.0 |  | Systems Integration Testing (SIT) | Complete | COMPLETE |  |  |  |  |
| 730 | 1.4.1.4.1.7.5.2 | SI assure Test Participants' Test Readiness Reports |  | 5d | 2023-11-06 A | 2023-11-10 A | 729FF+5d | 100% | 2023-11-06 | 2023-11-10 | 5d | 2023-11-06 | 2023-11-10 |  |  | SI Test | PP,IPA | SIT | 5.0 |  | Systems Integration Testing (SIT) | Complete | COMPLETE |  |  |  |  |
| 731 | 1.4.1.4.1.7.5.3 | SI develop Overarching SIT Component Integration Test Readiness Report |  | 20d | 2023-10-16 A | 2023-11-10 A | 730FF | 100% | 2023-10-16 | 2023-11-10 | 20d | 2023-10-16 | 2023-11-10 |  |  | SI Test |  | SIT | 5.0 |  | Systems Integration Testing (SIT) | Complete | COMPLETE |  |  |  |  |
| 732 | 1.4.1.4.1.7.5.4 | Artefact review (via TMAG) and updates |  | 5d | 2023-11-13 A | 2023-11-17 A | 731 | 100% | 2023-11-13 | 2023-11-17 | 5d | 2023-11-13 | 2023-11-17 |  |  | SI Test | PP,IPA | SIT | 5.0 |  | Systems Integration Testing (SIT) | Complete | COMPLETE |  |  |  |  |
| 733 | 1.4.1.4.1.7.6 | SIT Component Integration Testing 3 Preparation Complete (incl. approval of SI SIT Component Integration Test Readiness Report) | milestone | 0d | 2023-11-20 A | 2023-11-20 A | 732FS+1d, 706, 710, 729, 727, 724, 308 | 100% | 2023-11-20 | 2023-11-20 | 0d | 2023-11-20 | 2023-11-20 |  |  | SI Test | PP,IPA | SIT | 5.12 |  | Systems Integration Testing (SIT) | Complete | COMPLETE | MHHS-ART071 | T2-TE-0350 | SITAG | T2 |
| 734 | 1.4.1.4.1.8 | **CIT Interval 4 Preparation** |  | 36d | 2023-10-16 A | 2023-12-04 A |  | 100% | 2023-10-16 | 2023-12-04 | 36d | 2022-11-16 | 2023-12-04 |  | -0 | N/A | N/A | SIT | 5.0 | N/A | Systems Integration Testing (SIT) |  |  |  |  |  |  |
| 735 | 1.4.1.4.1.8.1 | **PIT Test Completion Report (incl. evidence)** |  | 21d | 2023-10-27 A | 2023-11-24 A |  | 100% | 2023-10-27 | 2023-11-24 | 21d | 2023-10-27 | 2023-11-24 |  |  | N/A | N/A | SIT | 5.0 | N/A | Systems Integration Testing (SIT) |  |  |  |  |  |  |
| 736 | 1.4.1.4.1.8.1.1 | Submit draft PIT Test Completion Report (incl. evidence) and submit to Programme for assurance |  | 1d | 2023-10-27 A | 2023-10-27 A |  | 100% | 2023-10-27 | 2023-10-27 | 1d | 2023-10-27 | 2023-10-27 | must start on 2023-10-27 |  | PP | SI Test | SIT | 5.0 |  | Systems Integration Testing (SIT) | Complete | COMPLETE |  |  |  |  |
| 737 | 1.4.1.4.1.8.1.2 | Finalise PIT Test Completion Report (incl. evidence) |  | 15d | 2023-10-30 A | 2023-11-17 A | 736 | 100% | 2023-10-30 | 2023-11-17 | 15d | 2023-10-30 | 2023-11-17 |  |  | PP | SI Test | SIT | 5.0 |  | Systems Integration Testing (SIT) | Complete | COMPLETE |  |  |  |  |
| 738 | 1.4.1.4.1.8.1.3 | PP PIT Completion Report (excl. Migration/Reverse Migration) submitted to Programme for assurance CIT Interval 4 | milestone | 0d | 2023-11-17 A | 2023-11-17 A | 737, 79, 95 | 100% | 2023-11-17 | 2023-11-17 | 0d | 2023-11-17 | 2023-11-17 |  |  | PP | SI Test | SIT | 5.13 |  | Systems Integration Testing (SIT) | Complete | COMPLETE |  | T3-DB-0019 | SITAG | T3 |
| 739 | 1.4.1.4.1.8.1.4 | PP Final PIT Completion Reports assured by SI |  | 5d | 2023-11-20 A | 2023-11-24 A | 738 | 100% | 2023-11-20 | 2023-11-24 | 5d | 2023-11-20 | 2023-11-24 |  |  | SI Test | PP | SIT | 5.0 |  | Systems Integration Testing (SIT) | Complete | COMPLETE |  |  |  |  |
| 740 | 1.4.1.4.1.8.2 | **Environments (SIT A)** |  | 25d | 2023-10-23 A | 2023-11-24 A |  | 100% | 2023-10-23 | 2023-11-24 | 25d | 2022-11-16 | 2023-11-24 |  | -0 | N/A | N/A | SIT | 5.0 | N/A | Systems Integration Testing (SIT) |  |  |  |  |  |  |
| 741 | 1.4.1.4.1.8.2.1 | Programme Participants Ready to Start Connectivity Proving | milestone | 0d | 2023-10-23 A | 2023-10-23 A |  | 100% | 2023-10-23 | 2023-10-23 | 0d |  |  | start no earlier than 2023-10-23 |  | PP |  | SIT | 5.10 | Simon Berry | Systems Integration Testing (SIT) | Complete | COMPLETE |  |  |  |  |
| 742 | 1.4.1.4.1.8.2.2 | SIT Participants' SIT A environments ready to start connectivity proving CIT Interval 4 | milestone | 0d | 2023-10-23 A | 2023-10-23 A | 741 | 100% | 2023-10-23 | 2023-10-23 | 0d | 2023-10-20 | 2023-10-20 |  |  | PP | PP,IPA | SIT | 5.10 | Simon Berry | Systems Integration Testing (SIT) | Complete | COMPLETE | MHHS-ART139 | T3-TE-0022 | SITAG | T3 |
| 743 | 1.4.1.4.1.8.2.3 | Internal Connectivity Proving Phase |  | 10d | 2023-10-23 A | 2023-11-03 A | 742 | 100% | 2023-10-23 | 2023-11-03 | 10d |  |  |  |  | PP |  | SIT | 5.10 | Simon Berry | Systems Integration Testing (SIT) | Complete | COMPLETE |  |  |  |  |
| 744 | 1.4.1.4.1.8.2.4 | Internal Connectivity Proving Phase Complete | milestone | 0d | 2023-11-03 A | 2023-11-03 A | 743 | 100% | 2023-11-03 | 2023-11-03 | 0d |  |  |  |  | PP |  | SIT | 5.10 | Simon Berry | Systems Integration Testing (SIT) | Complete | COMPLETE |  |  |  |  |
| 745 | 1.4.1.4.1.8.2.5 | DIP Onboarding Activity (1. PKI Officers and Certificates, 2. Set-up Validation, 3. End Point Creation, 4. Controlled Smoke Test ) |  | 10d | 2023-11-13 A | 2023-11-24 A | 744FS+5d | 100% | 2023-11-13 | 2023-11-24 | 10d |  |  |  |  | PP |  | SIT | 5.10 | Simon Berry | Systems Integration Testing (SIT) | Complete | COMPLETE |  |  |  |  |
| 746 | 1.4.1.4.1.8.2.6 | DIP Onboarding Complete | milestone | 0d | 2023-11-24 A | 2023-11-24 A | 745 | 100% | 2023-11-24 | 2023-11-24 | 0d |  |  |  |  | PP |  | SIT | 5.10 | Simon Berry | Systems Integration Testing (SIT) | Complete | COMPLETE |  |  |  |  |
| 747 | 1.4.1.4.1.8.2.7 | PPs register PKI Officers and Request PKI Certificates Complete - Interval 4 | milestone | 0d | 2023-11-24 A | 2023-11-24 A | 746 | 100% | 2023-11-24 | 2023-11-24 | 0d |  |  |  |  | PP | DIP Provider | SIT | 5.16 | Simon Berry | Systems Integration Testing (SIT) | Complete | COMPLETE |  | T3-TE-0100 | SITAG | T3 |
| 748 | 1.4.1.4.1.8.2.8 | PP Code Deployment | milestone | 0d | 2023-11-17 A | 2023-11-17 A |  | 100% | 2023-11-17 | 2023-11-17 | 0d |  |  | start no earlier than 2023-11-17 |  | PP |  | SIT | 5.10 | Simon Berry | Systems Integration Testing (SIT) | Complete | COMPLETE |  |  |  |  |

Notes:
- 724: Action: 28/7: CH: Needs to be set-up as a reporting milestone. 31/7: Check with Cesar if has been approved so can be baselined

| ID | WBS | Task | Type | Duration | Start | Finish | Predecessors | Complete | Baseline start | Baseline finish | Baseline duration | Baseline 1 start | Baseline 1 finish | Constraint | Baseline cost | Responsible | Involved | Text9 | Update Version | MHHS Resource Name | MHHS Programme Phase | Sched Status | RAG | Artefact ID | Milestone ID | Text29 | Tier |
| --- | --- | --- | --- | --- | --- | --- | --- | --- | --- | --- | --- | --- | --- | --- | --- | --- | --- | --- | --- | --- | --- | --- | --- | --- | --- | --- | --- |
| 749 | 1.4.1.4.1.8.3 | **Test Data (SIT A) Interval 4** |  | 30d | 2023-10-23 A | 2023-12-01 A |  | 100% | 2023-10-23 | 2023-12-01 | 25d | 2023-10-16 | 2023-11-17 |  |  | N/A | N/A | SIT | 5.0 | N/A | Systems Integration Testing (SIT) |  |  |  |  |  |  |
| 750 | 1.4.1.4.1.8.3.1 | Run data allocation |  | 5d | 2023-10-23 A | 2023-10-27 A | 719FS+5d | 100% | 2023-10-23 | 2023-10-27 | 5d | 2023-10-16 | 2023-10-20 |  |  | SI Test |  | SIT | 5.0 | Cesar Lopes | Systems Integration Testing (SIT) | Complete | COMPLETE |  |  |  |  |
| 751 | 1.4.1.4.1.8.3.2 | Cleanse and populate data post cut |  | 2d | 2023-10-30 A | 2023-10-31 A | 750 | 100% | 2023-10-30 | 2023-10-31 | 5d | 2023-10-23 | 2023-10-27 |  |  | SI Test |  | SIT | 5.0 | Cesar Lopes | Systems Integration Testing (SIT) | Complete | COMPLETE |  |  |  |  |
| 752 | 1.4.1.4.1.8.3.3 | Transmit data sets to PPs |  | 5d | 2023-11-01 A | 2023-11-07 A | 751 | 100% | 2023-11-01 | 2023-11-07 | 2d | 2023-10-30 | 2023-10-31 |  |  | SI Test |  | SIT | 5.0 | Cesar Lopes | Systems Integration Testing (SIT) | Complete | COMPLETE |  |  |  |  |
| 753 | 1.4.1.4.1.8.3.4 | PP - Load test data to test environments |  | 5d | 2023-11-08 A | 2023-11-14 A | 752 | 100% | 2023-11-08 | 2023-11-14 | 8d | 2023-11-01 | 2023-11-10 |  |  | PP |  | SIT | 5.0 | Cesar Lopes | Systems Integration Testing (SIT) | Complete | COMPLETE |  |  |  |  |
| 754 | 1.4.1.4.1.8.3.5 | PP Check data integrity on test environment |  | 13d | 2023-11-15 A | 2023-12-01 A | 753 | 100% | 2023-11-15 | 2023-12-01 | 5d | 2023-11-13 | 2023-11-17 |  |  | PP |  | SIT | 5.0 | Michael Inije | Systems Integration Testing (SIT) | Complete | COMPLETE |  |  |  |  |
| 755 | 1.4.1.4.1.8.3.6 | PP submit self-declaration to Programme to confirm loading & verification of test data | milestone | 0d | 2023-12-01 A | 2023-12-01 A | 754FF | 100% | 2023-12-01 | 2023-12-01 | 0d | 2023-11-17 | 2023-11-17 |  |  | PP | SI Test | SIT | 5.0 | Michael Inije | Systems Integration Testing (SIT) | Complete | COMPLETE |  |  |  |  |
| 756 | 1.4.1.4.1.8.3.7 | Test Data (SIT A) Interval 4 Complete | milestone | 0d | 2023-12-01 A | 2023-12-01 A | 755 | 100% | 2023-12-01 | 2023-12-01 | 0d |  |  |  |  | SI Test | PP | SIT | 5.13 | Michael Inije | Systems Integration Testing (SIT) | Complete | COMPLETE | MHHS-ART148/169 | T3-TE-0076 | SITAG | T3 |
| 757 | 1.4.1.4.1.8.4 | **Other Preparation** |  | 25d | 2023-10-30 A | 2023-12-01 A |  | 100% | 2023-10-30 | 2023-12-01 | 25d | 2023-07-31 | 2023-10-20 |  | -0 | N/A | N/A | SIT | 5.0 | N/A | Systems Integration Testing (SIT) |  |  |  |  |  |  |
| 758 | 1.4.1.4.1.8.4.1 | Onboarding of Test Participants to Test Management Tool (Azure DevOps) |  | 25d | 2023-10-30 A | 2023-12-01 A |  | 100% | 2023-10-30 | 2023-12-01 | 25d | 2023-07-31 | 2023-10-20 | start no earlier than 2023-10-30 |  | SI Test | PP | SIT | 5.0 | Simon Berry | Systems Integration Testing (SIT) | Complete | COMPLETE |  |  |  |  |
| 759 | 1.4.1.4.1.8.4.2 | Test Management Tool onboarding |  | 25d | 2023-10-30 A | 2023-12-01 A |  | 100% | 2023-10-30 | 2023-12-01 | 25d | 2023-07-31 | 2023-10-20 | start no earlier than 2023-10-30 |  | PP | SI Test | SIT | 5.0 | Simon Berry | Systems Integration Testing (SIT) | Complete | COMPLETE |  |  |  |  |
| 760 | 1.4.1.4.1.8.5 | **SIT Component Integration Test Readiness Report** |  | 27d | 2023-10-16 A | 2023-11-21 A |  | 100% | 2023-10-16 | 2023-11-21 | 25d | 2023-10-30 | 2023-12-01 |  |  | N/A | N/A | SIT | 5.0 | N/A | Systems Integration Testing (SIT) |  |  |  |  |  |  |
| 761 | 1.4.1.4.1.8.5.1 | PP submit Test Readiness Report to Programme for assurance | milestone | 0d | 2023-11-03 A | 2023-11-03 A | 613 | 100% | 2023-11-03 | 2023-11-03 | 0d | 2023-11-17 | 2023-11-17 |  |  | PP | SI Test | SIT | 5.0 |  | Systems Integration Testing (SIT) | Complete | COMPLETE |  |  |  |  |
| 762 | 1.4.1.4.1.8.5.2 | SI assure Test Participants' Test Readiness Reports |  | 5d | 2023-11-06 A | 2023-11-10 A | 761FF+5d | 100% | 2023-11-06 | 2023-11-10 | 5d | 2023-11-20 | 2023-11-24 |  |  | SI Test | PP,IPA | SIT | 5.0 |  | Systems Integration Testing (SIT) | Complete | COMPLETE |  |  |  |  |
| 763 | 1.4.1.4.1.8.5.3 | SI develop Overarching SIT Component Integration Test Readiness Report |  | 20d | 2023-10-16 A | 2023-11-10 A | 762FF | 100% | 2023-10-16 | 2023-11-10 | 20d | 2023-10-30 | 2023-11-24 |  |  | SI Test |  | SIT | 5.0 |  | Systems Integration Testing (SIT) | Complete | COMPLETE |  |  |  |  |
| 764 | 1.4.1.4.1.8.5.4 | Artefact review (via SITAG) and updates |  | 7d | 2023-11-13 A | 2023-11-21 A | 763 | 100% | 2023-11-13 | 2023-11-21 | 5d | 2023-11-27 | 2023-12-01 |  |  | SI Test | PP,IPA | SIT | 5.0 |  | Systems Integration Testing (SIT) | Complete | COMPLETE |  |  |  |  |
| 765 | 1.4.1.4.1.8.6 | SIT Component Integration Testing 4 Preparation Complete (incl. approval of SI SIT Component Integration Test Readiness Report) | milestone | 0d | 2023-12-04 A | 2023-12-04 A | 764FS+2d, 738, 742, 761, 756, 325FS+1d | 100% | 2023-12-04 | 2023-12-04 | 0d | 2023-12-04 | 2023-12-04 |  |  | SI Test | PP,IPA | SIT | 5.13 |  | Systems Integration Testing (SIT) | Complete | COMPLETE | MHHS-ART071 | T2-TE-0400 | SITAG | T2 |
| 766 | 1.4.1.4.1.9 | **CIT Interval 5 Preparation** |  | 53d | 2023-11-01 A | 2024-01-12 A |  | 100% | 2023-11-01 | 2024-01-12 | 55d | 2022-11-16 | 2024-01-08 |  | -0 | N/A | N/A | SIT | 5.0 | N/A | Systems Integration Testing (SIT) |  |  |  |  |  |  |
| 767 | 1.4.1.4.1.9.1 | **PIT Test Completion Report (incl. evidence)** |  | 21d | 2023-11-17 A | 2023-12-15 A |  | 100% | 2023-11-17 | 2023-12-15 | 21d | 2023-11-17 | 2023-12-15 |  |  | N/A | N/A | SIT | 5.0 | N/A | Systems Integration Testing (SIT) |  |  |  |  |  |  |
| 768 | 1.4.1.4.1.9.1.1 | Submit draft PIT Test Completion Report (incl. evidence) and submit to Programme for assurance |  | 1d | 2023-11-17 A | 2023-11-17 A |  | 100% | 2023-11-17 | 2023-11-17 | 1d | 2023-11-17 | 2023-11-17 | must start on 2023-11-17 |  | PP | SI Test | SIT | 5.0 | Lee Cox | Systems Integration Testing (SIT) | Complete | COMPLETE |  |  |  |  |
| 769 | 1.4.1.4.1.9.1.2 | Finalise PIT Test Completion Report (incl. evidence) |  | 15d | 2023-11-20 A | 2023-12-08 A | 768 | 100% | 2023-11-20 | 2023-12-08 | 15d | 2023-11-20 | 2023-12-08 |  |  | PP | SI Test | SIT | 5.0 | Lee Cox | Systems Integration Testing (SIT) | Complete | COMPLETE |  |  |  |  |
| 770 | 1.4.1.4.1.9.1.3 | PP PIT Completion Report (excl. Migration/Reverse Migration) submitted to Programme for assurance CIT Interval 5 | milestone | 0d | 2023-12-08 A | 2023-12-08 A | 769, 79, 95 | 100% | 2023-12-08 | 2023-12-08 | 0d | 2023-12-08 | 2023-12-08 |  |  | PP | SI Test | SIT | 5.14 | Lee Cox | Systems Integration Testing (SIT) | Complete | COMPLETE |  | T3-DB-0021 | SITAG | T3 |
| 771 | 1.4.1.4.1.9.1.4 | PP Final PIT Completion Reports assured by SI |  | 5d | 2023-12-11 A | 2023-12-15 A | 770 | 100% | 2023-12-11 | 2023-12-15 | 5d | 2023-12-11 | 2023-12-15 |  |  | SI Test | PP | SIT | 5.0 | Lee Cox | Systems Integration Testing (SIT) | Complete | COMPLETE |  |  |  |  |
| 772 | 1.4.1.4.1.9.2 | **Environments (SIT A)** |  | 21d | 2023-11-10 A | 2023-12-08 A |  | 100% | 2023-11-10 | 2023-12-08 | 21d | 2022-11-16 | 2023-12-15 |  | -0 | N/A | N/A | SIT | 5.0 | N/A | Systems Integration Testing (SIT) |  |  |  |  |  |  |
| 773 | 1.4.1.4.1.9.2.1 | Programme Participants Ready to Start Connectivity Proving | milestone | 0d | 2023-11-10 A | 2023-11-10 A |  | 100% | 2023-11-10 | 2023-11-10 | 0d |  |  | start no earlier than 2023-11-10 |  | PP |  | SIT | 5.10 | Simon Berry | Systems Integration Testing (SIT) | Complete | COMPLETE |  |  |  |  |
| 774 | 1.4.1.4.1.9.2.2 | SIT Participants' SIT A environments ready to start connectivity proving CIT Interval 5 | milestone | 0d | 2023-11-10 A | 2023-11-10 A | 773 | 100% | 2023-11-10 | 2023-11-10 | 0d | 2023-11-10 | 2023-11-10 |  |  | PP | PP,IPA | SIT | 5.6 | Simon Berry | Systems Integration Testing (SIT) | Complete | COMPLETE | MHHS-ART139 | T3-TE-0023 | SITAG | T3 |
| 775 | 1.4.1.4.1.9.2.3 | Internal Connectivity Proving Phase |  | 10d | 2023-11-13 A | 2023-11-24 A | 773FS+1d | 100% | 2023-11-13 | 2023-11-24 | 10d |  |  |  |  | PP |  | SIT | 5.10 | Simon Berry | Systems Integration Testing (SIT) | Complete | COMPLETE |  |  |  |  |
| 776 | 1.4.1.4.1.9.2.4 | Internal Connectivity Proving Phase Complete | milestone | 0d | 2023-11-24 A | 2023-11-24 A | 775 | 100% | 2023-11-24 | 2023-11-24 | 0d |  |  |  |  | PP |  | SIT | 5.10 | Simon Berry | Systems Integration Testing (SIT) | Complete | COMPLETE |  |  |  |  |
| 777 | 1.4.1.4.1.9.2.5 | DIP Onboarding Activity (1. PKI Officers and Certificates, 2. Set-up Validation, 3. End Point Creation, 4. Controlled Smoke Test ) |  | 10d | 2023-11-27 A | 2023-12-08 A | 776 | 100% | 2023-11-27 | 2023-12-08 | 10d |  |  |  |  | PP |  | SIT | 5.10 | Simon Berry | Systems Integration Testing (SIT) | Complete | COMPLETE |  |  |  |  |
| 778 | 1.4.1.4.1.9.2.6 | DIP Onboarding Complete | milestone | 0d | 2023-12-08 A | 2023-12-08 A | 777 | 100% | 2023-12-08 | 2023-12-08 | 0d |  |  |  |  | PP |  | SIT | 5.10 | Simon Berry | Systems Integration Testing (SIT) | Complete | COMPLETE |  |  |  |  |
| 779 | 1.4.1.4.1.9.2.7 | PPs register PKI Officers and Request PKI Certificates Complete - Interval 5 | milestone | 0d | 2023-12-08 A | 2023-12-08 A | 778 | 100% | 2023-12-08 | 2023-12-08 | 0d | 2023-11-06 | 2023-11-10 |  |  | PP | DIP Provider | SIT | 5.17 | Simon Berry | Systems Integration Testing (SIT) | Complete | COMPLETE |  | T3-TE-0101 | SITAG | T3 |
| 780 | 1.4.1.4.1.9.2.8 | PP Code Deployment | milestone | 0d | 2023-12-08 A | 2023-12-08 A | 779 | 100% | 2023-12-08 | 2023-12-08 | 0d |  |  | start no earlier than 2023-10-20 |  | PP |  | SIT | 5.10 | Simon Berry | Systems Integration Testing (SIT) | Complete | COMPLETE |  |  |  |  |

| ID | WBS | Task | Type | Duration | Start | Finish | Predecessors | Complete | Baseline start | Baseline finish | Baseline duration | Baseline 1 start | Baseline 1 finish | Constraint | Baseline cost | Responsible | Involved | Text9 | Update Version | MHHS Resource Name | MHHS Programme Phase | Sched Status | RAG | Artefact ID | Milestone ID | Text29 | Tier |
| --- | --- | --- | --- | --- | --- | --- | --- | --- | --- | --- | --- | --- | --- | --- | --- | --- | --- | --- | --- | --- | --- | --- | --- | --- | --- | --- | --- |
| 781 | 1.4.1.4.1.9.3 | **Test Data (SIT A) Interval 5** |  | 33d | 2023-11-01 A | 2023-12-15 A |  | 100% | 2023-11-01 | 2023-12-15 | 30d | 2023-10-30 | 2023-12-08 |  |  | N/A | N/A | SIT | 5.0 | N/A | Systems Integration Testing (SIT) |  |  |  |  |  |  |
| 782 | 1.4.1.4.1.9.3.1 | Run data allocation |  | 5d | 2023-11-01 A | 2023-11-07 A | 752SS | 100% | 2023-11-01 | 2023-11-07 | 10d | 2023-10-30 | 2023-11-10 |  |  | SI Test |  | SIT | 5.0 | Cesar Lopes | Systems Integration Testing (SIT) | Complete | COMPLETE |  |  |  |  |
| 783 | 1.4.1.4.1.9.3.2 | Cleanse and populate data post cut |  | 8d | 2023-11-08 A | 2023-11-17 A | 782 | 100% | 2023-11-08 | 2023-11-17 | 5d | 2023-11-13 | 2023-11-17 |  |  | SI Test |  | SIT | 5.0 | Cesar Lopes | Systems Integration Testing (SIT) | Complete | COMPLETE |  |  |  |  |
| 784 | 1.4.1.4.1.9.3.3 | Transmit data sets to PPs |  | 2d | 2023-11-20 A | 2023-11-21 A | 783 | 100% | 2023-11-20 | 2023-11-21 | 2d | 2023-11-20 | 2023-11-21 |  |  | SI Test |  | SIT | 5.0 | Cesar Lopes | Systems Integration Testing (SIT) | Complete | COMPLETE |  |  |  |  |
| 785 | 1.4.1.4.1.9.3.4 | PP - Load test data to test environments |  | 8d | 2023-11-22 A | 2023-12-01 A | 784 | 100% | 2023-11-22 | 2023-12-01 | 8d | 2023-11-22 | 2023-12-01 |  |  | PP |  | SIT | 5.0 | Michael Inije | Systems Integration Testing (SIT) | Complete | COMPLETE |  |  |  |  |
| 786 | 1.4.1.4.1.9.3.5 | PP Check data integrity on test environment |  | 10d | 2023-12-04 A | 2023-12-15 A | 785 | 100% | 2023-12-04 | 2023-12-15 | 5d | 2023-12-04 | 2023-12-08 |  |  | PP |  | SIT | 5.0 | Michael Inije | Systems Integration Testing (SIT) | Complete | COMPLETE |  |  |  |  |
| 787 | 1.4.1.4.1.9.3.6 | PP submit self-declaration to Programme to confirm loading & verification of test data | milestone | 0d | 2023-12-15 A | 2023-12-15 A | 786FF | 100% | 2023-12-15 | 2023-12-15 | 0d | 2023-12-08 | 2023-12-08 |  |  | PP | SI Test | SIT | 5.0 | Michael Inije | Systems Integration Testing (SIT) | Complete | COMPLETE |  |  |  |  |
| 788 | 1.4.1.4.1.9.3.7 | Test Data (SIT A) Interval 5 Complete | milestone | 0d | 2023-12-15 A | 2023-12-15 A | 787 | 100% | 2023-12-15 | 2023-12-15 | 0d |  |  |  |  | SI Test | PP | SIT | 5.14 | Michael Inije | Systems Integration Testing (SIT) | Complete | COMPLETE | MHHS-ART148/169 | T3-TE-0077 | SITAG | T3 |
| 789 | 1.4.1.4.1.9.4 | **Other Preparation** |  | 40d | 2023-11-20 A | 2024-01-12 A |  | 100% | 2023-11-20 | 2024-01-12 | 40d | 2023-08-21 | 2023-11-10 |  | -0 | N/A | N/A | SIT | 5.0 | N/A | Systems Integration Testing (SIT) |  |  |  |  |  |  |
| 790 | 1.4.1.4.1.9.4.1 | Onboarding of Test Participants to Test Management Tool (Azure DevOps) |  | 40d | 2023-11-20 A | 2024-01-12 A |  | 100% | 2023-11-20 | 2024-01-12 | 40d | 2023-08-21 | 2023-11-10 | start no earlier than 2023-11-20 |  | SI Test | PP | SIT | 5.0 | Simon Berry | Systems Integration Testing (SIT) | Complete | COMPLETE |  |  |  |  |
| 791 | 1.4.1.4.1.9.4.2 | Test Management Tool onboarding |  | 36d | 2023-11-20 A | 2024-01-08 A |  | 100% | 2023-11-20 | 2024-01-08 | 36d | 2023-08-21 | 2023-11-10 | start no earlier than 2023-11-20 |  | PP | SI Test | SIT | 5.0 | Simon Berry | Systems Integration Testing (SIT) | Complete | COMPLETE |  |  |  |  |
| 792 | 1.4.1.4.1.9.5 | **SIT Component Integration Test Readiness Report** |  | 35d | 2023-11-20 A | 2024-01-05 A |  | 100% | 2023-11-20 | 2024-01-05 | 35d | 2023-11-20 | 2024-01-05 |  |  | N/A | N/A | SIT | 5.0 | N/A | Systems Integration Testing (SIT) |  |  |  |  |  |  |
| 793 | 1.4.1.4.1.9.5.1 | PP submit Test Readiness Report to Programme for assurance | milestone | 0d | 2023-12-08 A | 2023-12-08 A | 617 | 100% | 2023-12-08 | 2023-12-08 | 0d | 2023-12-08 | 2023-12-08 |  |  | PP | SI Test | SIT | 5.0 | Lee Cox | Systems Integration Testing (SIT) | Complete | COMPLETE |  |  |  |  |
| 794 | 1.4.1.4.1.9.5.2 | SI assure Test Participants' Test Readiness Reports |  | 5d | 2023-12-11 A | 2023-12-15 A | 793FF+5d | 100% | 2023-12-11 | 2023-12-15 | 5d | 2023-12-11 | 2023-12-15 |  |  | SI Test | PP,IPA | SIT | 5.0 | Lee Cox | Systems Integration Testing (SIT) | Complete | COMPLETE |  |  |  |  |
| 795 | 1.4.1.4.1.9.5.3 | SI develop Overarching SIT Component Integration Test Readiness Report |  | 20d | 2023-11-20 A | 2023-12-15 A | 794FF | 100% | 2023-11-20 | 2023-12-15 | 20d | 2023-11-20 | 2023-12-15 |  |  | SI Test |  | SIT | 5.0 | Lee Cox | Systems Integration Testing (SIT) | Complete | COMPLETE |  |  |  |  |
| 796 | 1.4.1.4.1.9.5.4 | Artefact review (via SITAG) and updates |  | 15d | 2023-12-18 A | 2024-01-05 A | 795 | 100% | 2023-12-18 | 2024-01-05 | 15d | 2023-12-18 | 2024-01-05 |  |  | SI Test | PP,IPA | SIT | 5.0 | Lee Cox | Systems Integration Testing (SIT) | Complete | COMPLETE |  |  |  |  |
| 797 | 1.4.1.4.1.9.6 | SIT Component Integration Testing 5 Preparation Complete (incl. approval of SI SIT Component Integration Test Readiness Report) | milestone | 0d | 2024-01-08 A | 2024-01-08 A | 796FS+1d, 770, 774, 791, 793, 788, 445, 428 | 100% | 2024-01-08 | 2024-01-08 | 0d | 2024-01-08 | 2024-01-08 |  |  | SI Test | PP,IPA | SIT | 5.15 |  | Systems Integration Testing (SIT) | Complete | COMPLETE | MHHS-ART071 | T2-TE-0450 | SITAG | T2 |
| 798 | 1.4.1.4.1.10 | **CIT Interval 6 Preparation** |  | 45d | 2023-11-20 A | 2024-01-19 A |  | 100% | 2023-11-20 | 2024-01-19 | 46d | 2022-11-16 | 2024-01-22 |  | -0 | N/A | N/A | SIT | 5.0 | N/A | Systems Integration Testing (SIT) |  |  |  |  |  |  |
| 799 | 1.4.1.4.1.10.1 | **PIT Test Completion Report (incl. evidence)** |  | 31d | 2023-12-01 A | 2024-01-12 A |  | 100% | 2023-12-01 | 2024-01-12 | 31d | 2023-12-01 | 2024-01-12 |  |  | N/A | N/A | SIT | 5.0 | N/A | Systems Integration Testing (SIT) |  |  |  |  |  |  |
| 800 | 1.4.1.4.1.10.1.1 | Submit draft PIT Test Completion Report (incl. evidence) and submit to Programme for assurance |  | 1d | 2023-12-01 A | 2023-12-01 A |  | 100% | 2023-12-01 | 2023-12-01 | 1d | 2023-12-01 | 2023-12-01 | must start on 2023-12-01 |  | PP | SI Test | SIT | 5.0 |  | Systems Integration Testing (SIT) | Complete | COMPLETE |  |  |  |  |
| 801 | 1.4.1.4.1.10.1.2 | Finalise PIT Test Completion Report (incl. evidence) |  | 25d | 2023-12-04 A | 2024-01-05 A | 800 | 100% | 2023-12-04 | 2024-01-05 | 25d | 2023-12-04 | 2024-01-05 |  |  | PP | SI Test | SIT | 5.0 |  | Systems Integration Testing (SIT) | Complete | COMPLETE |  |  |  |  |
| 802 | 1.4.1.4.1.10.1.3 | PP PIT Completion Report (excl. Migration/Reverse Migration) submitted to Programme for assurance CIT Interval 6 | milestone | 0d | 2024-01-05 A | 2024-01-05 A | 801, 79, 95, 247, 252, 255 | 100% | 2024-01-05 | 2024-01-05 | 0d | 2024-01-05 | 2024-01-05 |  |  | PP | SI Test | SIT | 5.19 |  | Systems Integration Testing (SIT) | Complete | COMPLETE |  | T3-DB-0023 | SITAG | T3 |
| 803 | 1.4.1.4.1.10.1.4 | PP Final PIT Completion Reports assured by SI |  | 5d | 2024-01-08 A | 2024-01-12 A | 802 | 100% | 2024-01-08 | 2024-01-12 | 5d | 2024-01-08 | 2024-01-12 |  |  | SI Test | PP | SIT | 5.19 |  | Systems Integration Testing (SIT) | Complete | COMPLETE |  |  |  |  |
| 804 | 1.4.1.4.1.10.2 | **Environments (SIT A)** |  | 30d | 2023-11-24 A | 2024-01-05 A |  | 100% | 2023-11-24 | 2024-01-05 | 30d | 2022-11-16 | 2024-01-05 |  | -0 | N/A | N/A | SIT | 5.0 | N/A | Systems Integration Testing (SIT) |  |  |  |  |  |  |
| 805 | 1.4.1.4.1.10.2.1 | Programme Participants Ready to Start Connectivity Proving | milestone | 0d | 2023-11-24 A | 2023-11-24 A |  | 100% | 2023-11-24 | 2023-11-24 | 0d |  |  | start no earlier than 2023-11-24 |  | PP |  | SIT | 5.10 | Simon Berry | Systems Integration Testing (SIT) | Complete | COMPLETE |  |  |  |  |
| 806 | 1.4.1.4.1.10.2.2 | SIT Participants' SIT A environments ready to start connectivity proving CIT Interval 6 | milestone | 0d | 2023-11-24 A | 2023-11-24 A | 805 | 100% | 2023-11-24 | 2023-11-24 | 0d | 2023-11-24 | 2023-11-24 |  |  | PP | PP,IPA | SIT | 5.6 | Simon Berry | Systems Integration Testing (SIT) | Complete | COMPLETE | MHHS-ART139 | T3-TE-0024 | SITAG | T3 |
| 807 | 1.4.1.4.1.10.2.3 | Internal Connectivity Proving Phase |  | 10d | 2023-11-27 A | 2023-12-08 A | 806FS+1d | 100% | 2023-11-27 | 2023-12-08 | 10d |  |  |  |  | PP |  | SIT | 5.10 | Simon Berry | Systems Integration Testing (SIT) | Complete | COMPLETE |  |  |  |  |
| 808 | 1.4.1.4.1.10.2.4 | Internal Connectivity Proving Phase Complete | milestone | 0d | 2023-12-08 A | 2023-12-08 A | 807 | 100% | 2023-12-08 | 2023-12-08 | 0d |  |  |  |  | PP |  | SIT | 5.10 | Simon Berry | Systems Integration Testing (SIT) | Complete | COMPLETE |  |  |  |  |
| 809 | 1.4.1.4.1.10.2.5 | DIP Onboarding Activity (1. PKI Officers and Certificates, 2. Set-up Validation, 3. End Point Creation, 4. Controlled Smoke Test ) |  | 5d | 2023-12-04 A | 2023-12-08 A | 806FS+6d | 100% | 2023-12-04 | 2023-12-08 | 5d |  |  |  |  | PP |  | SIT | 5.10 | Simon Berry | Systems Integration Testing (SIT) | Complete | COMPLETE |  |  |  |  |
| 810 | 1.4.1.4.1.10.2.6 | DIP Onboarding Complete | milestone | 0d | 2023-12-08 A | 2023-12-08 A | 809 | 100% | 2023-12-08 | 2023-12-08 | 0d |  |  |  |  | PP |  | SIT | 5.10 | Simon Berry | Systems Integration Testing (SIT) | Complete | COMPLETE |  |  |  |  |
| 811 | 1.4.1.4.1.10.2.7 | PPs register PKI Officers and Request PKI Certificates Complete - Interval 6 | milestone | 0d | 2023-12-08 A | 2023-12-08 A | 810 | 100% | 2023-12-08 | 2023-12-08 | 0d | 2023-11-20 | 2023-11-24 | start no earlier than 2023-12-08 |  | PP | DIP Provider | SIT | 5.17 | Simon Berry | Systems Integration Testing (SIT) | Complete | COMPLETE |  | T3-TE-0102 | SITAG | T3 |
| 812 | 1.4.1.4.1.10.2.8 | PP Code Deployment | milestone | 0d | 2024-01-05 A | 2024-01-05 A |  | 100% | 2024-01-05 | 2024-01-05 | 0d |  |  | start no earlier than 2024-01-05 |  | PP |  | SIT | 5.10 | Simon Berry | Systems Integration Testing (SIT) | Complete | COMPLETE |  |  |  |  |

Notes:
- 788: Action: 28/7: CH: Needs to be set-up as a reporting milestone. 31/7: Check with Cesar if has been approved so can be baselined

| ID | WBS | Task | Type | Duration | Start | Finish | Predecessors | Complete | Baseline start | Baseline finish | Baseline duration | Baseline 1 start | Baseline 1 finish | Constraint | Baseline cost | Responsible | Involved | Text9 | Update Version | MHHS Resource Name | MHHS Programme Phase | Sched Status | RAG | Artefact ID | Milestone ID | Text29 | Tier |
| --- | --- | --- | --- | --- | --- | --- | --- | --- | --- | --- | --- | --- | --- | --- | --- | --- | --- | --- | --- | --- | --- | --- | --- | --- | --- | --- | --- |
| 813 | 1.4.1.4.1.10.3 | **Test Data (SIT A) Interval 6** |  | 25d | 2023-11-20 A | 2023-12-22 A |  | 100% | 2023-11-20 | 2023-12-22 | 25d | 2023-11-20 | 2023-12-22 |  |  | N/A | N/A | SIT | 5.0 | N/A | Systems Integration Testing (SIT) |  |  |  |  |  |  |
| 814 | 1.4.1.4.1.10.3.1 | Run data allocation |  | 10d | 2023-11-20 A | 2023-12-01 A | 784SS | 100% | 2023-11-20 | 2023-12-01 | 5d | 2023-11-20 | 2023-11-24 |  |  | SI Test |  | SIT | 5.0 | Michael Inije | Systems Integration Testing (SIT) | Complete | COMPLETE |  |  |  |  |
| 815 | 1.4.1.4.1.10.3.2 | Cleanse and populate data post cut |  | 1d | 2023-12-04 A | 2023-12-04 A | 814 | 100% | 2023-12-04 | 2023-12-04 | 5d | 2023-11-27 | 2023-12-01 |  |  | SI Test |  | SIT | 5.0 | Michael Inije | Systems Integration Testing (SIT) | Complete | COMPLETE |  |  |  |  |
| 816 | 1.4.1.4.1.10.3.3 | Transmit data sets to PPs |  | 1d | 2023-12-05 A | 2023-12-05 A | 815 | 100% | 2023-12-05 | 2023-12-05 | 2d | 2023-12-04 | 2023-12-05 |  |  | SI Test |  | SIT | 5.0 | Michael Inije | Systems Integration Testing (SIT) | Complete | COMPLETE |  |  |  |  |
| 817 | 1.4.1.4.1.10.3.4 | PP - Load test data to test environments |  | 8d | 2023-12-06 A | 2023-12-15 A | 816 | 100% | 2023-12-06 | 2023-12-15 | 8d | 2023-12-06 | 2023-12-15 |  |  | PP |  | SIT | 5.0 | Michael Inije | Systems Integration Testing (SIT) | Complete | COMPLETE |  |  |  |  |
| 818 | 1.4.1.4.1.10.3.5 | PP Check data integrity on test environment |  | 5d | 2023-12-18 A | 2023-12-22 A | 817 | 100% | 2023-12-18 | 2023-12-22 | 5d | 2023-12-18 | 2023-12-22 |  |  | PP |  | SIT | 5.0 | Michael Inije | Systems Integration Testing (SIT) | Complete | COMPLETE |  |  |  |  |
| 819 | 1.4.1.4.1.10.3.6 | PP submit self-declaration to Programme to confirm loading & verification of test data | milestone | 0d | 2023-12-22 A | 2023-12-22 A | 818FF | 100% | 2023-12-22 | 2023-12-22 | 0d | 2023-12-22 | 2023-12-22 |  |  | PP | SI Test | SIT | 5.0 | Michael Inije | Systems Integration Testing (SIT) | Complete | COMPLETE |  |  |  |  |
| 820 | 1.4.1.4.1.10.3.7 | Test Data (SIT A) Interval 6 Complete | milestone | 0d | 2023-12-22 A | 2023-12-22 A | 819 | 100% | 2023-12-22 | 2023-12-22 | 0d |  |  |  |  | SI Test | PP | SIT | 5.5 | Michael Inije | Systems Integration Testing (SIT) | Complete | COMPLETE | MHHS-ART148/169 | T3-TE-0078 | SITAG | T3 |
| 821 | 1.4.1.4.1.10.4 | **Other Preparation** |  | 31d | 2023-12-04 A | 2024-01-15 A |  | 100% | 2023-12-04 | 2024-01-15 | 31d | 2023-09-04 | 2023-11-24 |  | -0 | N/A | N/A | SIT | 5.0 | N/A | Systems Integration Testing (SIT) |  |  |  |  |  |  |
| 822 | 1.4.1.4.1.10.4.1 | Onboarding of Test Participants to Test Management Tool (Azure DevOps) |  | 31d | 2023-12-04 A | 2024-01-15 A |  | 100% | 2023-12-04 | 2024-01-15 | 31d | 2023-09-04 | 2023-11-24 | start no earlier than 2023-12-04 |  | SI Test | PP | SIT | 5.0 | Simon Berry | Systems Integration Testing (SIT) | Complete | COMPLETE |  |  |  |  |
| 823 | 1.4.1.4.1.10.4.2 | Test Management Tool onboarding |  | 31d | 2023-12-04 A | 2024-01-15 A |  | 100% | 2023-12-04 | 2024-01-15 | 31d | 2023-09-04 | 2023-11-24 | start no earlier than 2023-12-04 |  | PP | SI Test | SIT | 5.0 | Simon Berry | Systems Integration Testing (SIT) | Complete | COMPLETE |  |  |  |  |
| 824 | 1.4.1.4.1.10.5 | **SIT Component Integration Test Readiness Report** |  | 25d | 2023-11-20 A | 2023-12-22 A |  | 100% | 2023-11-20 | 2023-12-22 | 25d | 2023-12-18 | 2024-01-19 |  |  | N/A | N/A | SIT | 5.0 | N/A | Systems Integration Testing (SIT) |  |  |  |  |  |  |
| 825 | 1.4.1.4.1.10.5.1 | PP submit Test Readiness Report to Programme for assurance | milestone | 0d | 2023-12-08 A | 2023-12-08 A | 617 | 100% | 2023-12-08 | 2023-12-08 | 0d | 2024-01-05 | 2024-01-05 |  |  | PP | SI Test | SIT | 5.0 |  | Systems Integration Testing (SIT) | Complete | COMPLETE |  |  |  |  |
| 826 | 1.4.1.4.1.10.5.2 | SI assure Test Participants' Test Readiness Reports |  | 5d | 2023-12-11 A | 2023-12-15 A | 825FF+5d | 100% | 2023-12-11 | 2023-12-15 | 5d | 2024-01-08 | 2024-01-12 |  |  | SI Test | PP,IPA | SIT | 5.0 |  | Systems Integration Testing (SIT) | Complete | COMPLETE |  |  |  |  |
| 827 | 1.4.1.4.1.10.5.3 | SI develop Overarching SIT Component Integration Test Readiness Report |  | 20d | 2023-11-20 A | 2023-12-15 A | 826FF | 100% | 2023-11-20 | 2023-12-15 | 20d | 2023-12-18 | 2024-01-12 |  |  | SI Test |  | SIT | 5.0 |  | Systems Integration Testing (SIT) | Complete | COMPLETE |  |  |  |  |
| 828 | 1.4.1.4.1.10.5.4 | Artefact review (via TMAG) and updates |  | 5d | 2023-12-18 A | 2023-12-22 A | 827 | 100% | 2023-12-18 | 2023-12-22 | 5d | 2024-01-15 | 2024-01-19 |  |  | SI Test | PP,IPA | SIT | 5.0 |  | Systems Integration Testing (SIT) | Complete | COMPLETE |  |  |  |  |
| 829 | 1.4.1.4.1.10.6 | SIT Component Integration Testing 6 Preparation Complete (incl. approval of SI SIT Component Integration Test Readiness Report) | milestone | 0d | 2024-01-19 A | 2024-01-19 A | 828FS+1d, 802, 806, 823, 825, 820, 273, 462 | 100% | 2024-01-19 | 2024-01-19 | 0d | 2024-01-22 | 2024-01-22 |  |  | SI Test | PP,IPA | SIT | 5.15 |  | Systems Integration Testing (SIT) | Complete | COMPLETE | MHHS-ART071 | T2-TE-0500 | SITAG | T2 |
| 830 | 1.4.1.4.2 | **SIT Functional Preparation** |  | 595d? | 2022-10-31 A | 2025-02-07 A |  | 100% | 2022-10-31 | 2025-04-07 | 520d | 2022-10-31 | 2024-03-01 |  | -0 | N/A | N/A | SIT | 5.0 | N/A | Systems Integration Testing (SIT) |  |  |  |  | SITAG |  |
| 831 | 1.4.1.4.2.1 | Environment Approach and Plan - SIT Functional |  | 1d? | 2023-11-20 A | 2023-11-20 A |  | 100% | 2023-11-20 | 2023-11-20 | 0d |  |  | start no earlier than 2023-11-20 |  | SI Test |  | SIT | 6.0 |  |  | Complete | COMPLETE |  |  |  |  |
| 832 | 1.4.1.4.2.2 | **Test Approach & Plan** |  | 208d | 2022-10-31 A | 2023-08-16 A |  | 100% | 2022-10-31 | 2023-08-16 | 208d | 2022-10-31 | 2023-08-16 |  |  | N/A | N/A | SIT | 5.0 | N/A | Systems Integration Testing (SIT) |  |  |  |  |  |  |
| 833 | 1.4.1.4.2.2.1 | Develop document with SITWG |  | 179d | 2022-10-31 A | 2023-07-06 A |  | 100% | 2022-10-31 | 2023-07-06 | 179d | 2022-10-31 | 2023-07-06 | finish no earlier than 2023-07-06 |  | SI Test |  | SIT | 5.0 |  | Systems Integration Testing (SIT) | Complete | COMPLETE |  |  |  |  |
| 834 | 1.4.1.4.2.2.2 | Industry Consultation |  | 10d | 2023-07-07 A | 2023-07-20 A | 833 | 100% | 2023-07-07 | 2023-07-20 | 10d |  |  |  |  | PP |  | SIT | 5.1 |  | Systems Integration Testing (SIT) | Complete | COMPLETE |  |  |  |  |
| 835 | 1.4.1.4.2.2.3 | Artefact review (via TMAG) and updates |  | 19d | 2023-07-21 A | 2023-08-16 A | 834 | 100% | 2023-07-21 | 2023-08-16 | 19d | 2023-07-07 | 2023-08-03 | finish no earlier than 2023-08-03 |  | SI Test | PP,IPA,Code Bodies | SIT | 5.5 |  | Systems Integration Testing (SIT) | Complete | COMPLETE |  |  |  |  |
| 836 | 1.4.1.4.2.2.4 | SIT Functional Test Approach & Plan approved | milestone | 0d | 2023-08-16 A | 2023-08-16 A |  | 100% | 2023-08-16 | 2023-08-16 | 0d | 2023-08-16 | 2023-08-16 | finish no earlier than 2023-08-16 |  | SI Test | PP | SIT | 5.0 |  | Systems Integration Testing (SIT) | Complete | COMPLETE | MHHS-ART073 | T3-TE-0013 | SITAG | T3 |

Notes:
- 820: Action: 28/7: CH: Needs to be set-up as a reporting milestone. 31/7: Check with Cesar if has been approved so can be baselined

| ID | WBS | Task | Type | Duration | Start | Finish | Predecessors | Complete | Baseline start | Baseline finish | Baseline duration | Baseline 1 start | Baseline 1 finish | Constraint | Baseline cost | Responsible | Involved | Text9 | Update Version | MHHS Resource Name | MHHS Programme Phase | Sched Status | RAG | Artefact ID | Milestone ID | Text29 | Tier | Action | Guidance | Task Status |
| --- | --- | --- | --- | --- | --- | --- | --- | --- | --- | --- | --- | --- | --- | --- | --- | --- | --- | --- | --- | --- | --- | --- | --- | --- | --- | --- | --- | --- | --- | --- |
| 837 | 1.4.1.4.2.3 | **Test Data Approach & Plan** |  | 29d | 2023-07-07 A | 2023-08-16 A |  | 100% | 2023-07-07 | 2023-08-16 | 29d | 2023-07-07 | 2023-08-16 |  |  | N/A | N/A | SIT | 5.0 | N/A | Systems Integration Testing (SIT) |  |  |  |  |  |  |  |  |  |
| 838 | 1.4.1.4.2.3.1 | Industry Consultation |  | 10d | 2023-07-07 A | 2023-07-20 A | 834SS | 100% | 2023-07-07 | 2023-07-20 | 10d |  |  |  |  | PP |  | SIT | 5.1 | Cesar Lopes | Systems Integration Testing (SIT) | Complete | COMPLETE |  |  |  |  |  |  |  |
| 839 | 1.4.1.4.2.3.2 | Artefact review (via TMAG) and updates |  | 19d | 2023-07-21 A | 2023-08-16 A | 838 | 100% | 2023-07-21 | 2023-08-16 | 19d | 2023-07-07 | 2023-08-03 |  |  | SI Test |  | SIT | 5.5 | Cesar Lopes | Systems Integration Testing (SIT) | Complete | COMPLETE |  |  |  |  |  |  |  |
| 840 | 1.4.1.4.2.3.3 | SIT Functional Testing Test Data Approach & Plan approved | milestone | 0d | 2023-08-16 A | 2023-08-16 A | 839 | 100% | 2023-08-16 | 2023-08-16 | 0d | 2023-08-16 | 2023-08-16 |  |  | SI Test | PP,IPA | SIT | 5.5 | Cesar Lopes | Systems Integration Testing (SIT) | Complete | COMPLETE |  |  |  |  |  |  |  |
| 841 | 1.4.1.4.2.4 | **Test scenarios** |  | 298d | 2023-01-02 A | 2024-02-21 A |  | 100% | 2023-01-02 | 2024-02-21 | 298d | 2023-01-02 | 2023-06-02 |  | -0 | N/A | N/A | SIT | 5.0 | N/A | Systems Integration Testing (SIT) |  |  |  |  |  |  |  |  |  |
| 842 | 1.4.1.4.2.4.1 | Development of test scenarios |  | 85d | 2023-01-02 A | 2023-04-28 A | 833SS+45d | 100% | 2023-01-02 | 2023-04-28 | 85d | 2023-01-02 | 2023-04-28 |  |  | SI Test | PP, Code Bodies | SIT | 5.0 |  | Systems Integration Testing (SIT) | Complete | COMPLETE |  |  |  |  |  |  |  |
| 843 | 1.4.1.4.2.4.2 | Review test scenarios with SIT Working Group |  | 65d | 2023-08-17 A | 2023-11-15 A | 842FS+78d | 100% | 2023-08-17 | 2023-11-15 | 65d | 2023-02-01 | 2023-05-26 |  |  | SI Test | PP, Code Bodies, IPA | SIT | 5.0 |  | Systems Integration Testing (SIT) | Complete | COMPLETE |  |  |  |  |  |  |  |
| 844 | 1.4.1.4.2.4.3 | SIT Functional Testing Test scenarios (themes 1-5) approved | milestone | 0d | 2023-12-08 A | 2023-12-08 A | 843FS+17d | 100% | 2023-12-08 | 2023-12-08 | 0d | 2023-06-02 | 2023-06-02 |  |  | SI Test | PP | SIT | 5.14 |  | Systems Integration Testing (SIT) | Complete | COMPLETE | MMHS-ART073 | T3-TE-0015 | SITAG | T3 |  |  |  |
| 845 | 1.4.1.4.2.4.4 | SIT Functional Testing Test scenarios (themes 6,7,9) approved | milestone | 0d | 2024-01-17 A | 2024-01-17 A | 844FS+28d | 100% | 2024-01-17 | 2024-01-17 | 0d | 2023-06-02 | 2023-06-02 |  |  | SI Test | PP | SIT | 5.16 |  | Systems Integration Testing (SIT) | Complete | COMPLETE | MMHS-ART073 | T3-TE-0106 | SITAG | T3 |  |  |  |
| 846 | 1.4.1.4.2.4.5 | SIT Functional Testing Test scenarios (theme 8) approved | milestone | 0d | 2024-02-21 A | 2024-02-21 A | 845FS+25d | 100% | 2024-02-21 | 2024-02-21 | 0d | 2023-06-02 | 2023-06-02 |  |  | SI Test | PP | SIT | 5.14 |  | Systems Integration Testing (SIT) | Complete | COMPLETE | MMHS-ART073 | T3-TE-0107 | SITAG | T3 |  |  |  |
| 847 | 1.4.1.4.2.5 | **Test cases** |  | 465d? | 2023-05-01 A | 2025-02-07 A |  | 100% | 2023-05-01 | 2025-02-07 | 213d | 2023-05-01 | 2023-09-01 |  |  | N/A | N/A | SIT | 5.0 | N/A | Systems Integration Testing (SIT) |  |  |  |  |  |  | 25/7 - needs to be replanned |  |  |
| 848 | 1.4.1.4.2.5.1 | **SI Test cases** |  | 213d | 2023-05-01 A | 2024-02-21 A |  | 100% | 2023-05-01 | 2024-02-21 | 213d | 2023-05-01 | 2023-09-01 |  |  | N/A | N/A | SIT | 5.0 | N/A | Systems Integration Testing (SIT) |  |  |  |  |  |  | 25/7 - needs to be replanned |  |  |
| 849 | 1.4.1.4.2.5.1.1 | Development of Test cases |  | 150d | 2023-05-01 A | 2023-11-24 A | 842 | 100% | 2023-05-01 | 2023-11-24 | 150d | 2023-05-01 | 2023-07-28 |  |  | SI Test |  | SIT | 5.0 |  | Systems Integration Testing (SIT) | Complete | COMPLETE |  |  |  |  | 25/7 - needs to be replanned |  |  |
| 850 | 1.4.1.4.2.5.1.2 | Review Test cases with SIT Working Group |  | 78d | 2023-09-25 A | 2024-01-10 A | 849SS+105d | 100% | 2023-09-25 | 2024-01-10 | 78d | 2023-05-26 | 2023-08-25 |  |  | SI Test | PP,IPA | SIT | 5.0 |  | Systems Integration Testing (SIT) | Complete | COMPLETE |  |  |  |  | 25/7 - needs to be replanned |  |  |
| 851 | 1.4.1.4.2.5.1.3 | SIT Functional Testing Test Cases (themes 1-5) approved | milestone | 0d | 2024-01-17 A | 2024-01-17 A | 850FS+5d | 100% | 2024-01-17 | 2024-01-17 | 0d | 2023-09-01 | 2023-09-01 |  |  | SI Test | PP | SIT | 5.14 |  | Systems Integration Testing (SIT) | Complete | COMPLETE | MHHS-ART140 | T3-TE-0070 | SITAG | T3 |  | 2/1/24 - Approved at Dec TMAG |  |
| 852 | 1.4.1.4.2.5.1.4 | SIT Functional Testing Test cases (themes 6,7,9) approved | milestone | 0d | 2024-01-17 A | 2024-01-17 A | 851 | 100% | 2024-01-17 | 2024-01-17 | 0d | 2023-09-01 | 2023-09-01 |  |  | SI Test | PP | SIT | 5.14 |  | Systems Integration Testing (SIT) | Complete | COMPLETE | MHHS-ART140 | T3-TE-0108 | SITAG | T3 |  |  |  |
| 853 | 1.4.1.4.2.5.1.5 | SIT Functional Testing Test cases (theme 8) approved | milestone | 0d | 2024-02-21 A | 2024-02-21 A | 852FS+25d | 100% | 2024-02-21 | 2024-02-21 | 0d | 2023-09-01 | 2023-09-01 |  |  | SI Test | PP | SIT | 5.14 |  | Systems Integration Testing (SIT) | Complete | COMPLETE | MHHS-ART140 | T3-TE-0109 | SITAG | T3 |  |  |  |
| 854 | 1.4.1.4.2.5.2 | **SIT Functional Programme RTTM** |  | 74d? | 2024-07-29 A | 2024-11-07 A |  | 100% | 2024-07-29 | 2024-10-11 | 0d |  |  |  |  | SI Test |  | SIT | 6.0 | Kevin Davis |  |  |  |  |  | SITAG |  |  |  | -687.67 |
| 855 | 1.4.1.4.2.5.2.1 | **RTTM Development** |  | 30d? | 2024-07-29 A | 2024-09-06 A |  | 100% | 2024-07-29 | 2024-09-20 | 0d |  |  |  |  | SI Test |  | SIT | 6.0 | Kevin Davis |  |  |  |  |  | SITAG |  |  |  | -693.67 |
| 856 | 1.4.1.4.2.5.2.1.1 | Development of Manual SIT Functional RTTM |  | 30d? | 2024-07-29 A | 2024-09-06 A |  | 100% | 2024-07-29 | 2024-09-06 | 0d |  |  | start no earlier than 2024-07-29 |  | SI Test |  | SIT | 6.0 | Kevin Davis |  | Complete | COMPLETE |  |  | SITAG |  |  |  |  |
| 857 | 1.4.1.4.2.5.2.1.2 | Manual SIT Functional RTTM Complete | milestone | 0d? | 2024-09-06 A | 2024-09-06 A | 856 | 100% | 2024-09-06 | 2024-09-06 | 0d |  |  | start no earlier than 2024-07-29 |  | SI Test |  | SIT | 6.0 | Kevin Davis |  | Complete | COMPLETE |  |  | SITAG |  |  |  |  |
| 858 | 1.4.1.4.2.5.2.2 | **Gap analysis** |  | 54d? | 2024-08-26 A | 2024-11-07 A |  | 100% | 2024-08-26 | 2024-10-11 | 0d |  |  |  |  | SI Test |  | SIT | 6.0 | Kevin Davis |  |  |  |  |  | SITAG |  |  |  | -693.67 |
| 859 | 1.4.1.4.2.5.2.2.1 | Identify gaps in test case coverage following RTTM review |  | 20d? | 2024-08-26 A | 2024-09-20 A |  | 100% | 2024-08-26 | 2024-09-20 | 0d |  |  |  |  | SI Test |  | SIT | 6.0 | Kevin Davis |  | Complete | COMPLETE |  |  | SITAG |  |  |  |  |
| 860 | 1.4.1.4.2.5.2.2.2 | Address gaps in test case coverage following RTTM review |  | 25d | 2024-09-09 A | 2024-10-11 A | 859SS+10d | 100% | 2024-09-09 | 2024-10-04 | 0d |  |  |  |  | SI Test |  | SIT | 6.0 | Kevin Davis |  | Complete | COMPLETE |  |  | SITAG |  |  |  |  |
| 861 | 1.4.1.4.2.5.2.2.3 | Gap analysis complete | milestone | 0d | 2024-10-11 A | 2024-10-11 A | 860 | 100% | 2024-10-11 | 2024-10-11 | 0d |  |  |  |  | SI Test |  | SIT | 6.11 | Kevin Davis |  | Complete | COMPLETE |  |  | SITAG |  |  |  |  |
| 862 | 1.4.1.4.2.5.2.2.4 | Test Script updates identified |  | 1d? | 2024-10-14 A | 2024-10-14 A | 861 | 100% | 2024-10-14 | 2024-10-14 | 0d |  |  |  |  | SI Test |  | SIT | 6.11 | Kevin Davis |  | Complete | COMPLETE |  |  | SITAG |  |  |  |  |
| 863 | 1.4.1.4.2.5.2.2.5 | Test Scripts updates |  | 1d | 2024-10-15 A | 2024-10-15 A | 862 | 100% | 2024-10-15 | 2024-10-15 | 0d |  |  |  |  | SI Test |  | SIT | 6.11 | Kevin Davis |  | Complete | COMPLETE |  |  | SITAG |  |  |  |  |
| 864 | 1.4.1.4.2.5.2.2.6 | RTTM Updated Additional Static RTTM WBS items |  | 10d | 2024-10-14 A | 2024-10-25 A | 862FS-1d | 100% | 2024-10-14 | 2024-10-25 | 0d |  |  |  |  | SI Test |  | SIT | 6.11 | Kevin Davis |  | Complete | COMPLETE |  |  | SITAG |  |  |  |  |
| 865 | 1.4.1.4.2.5.2.2.7 | Removal of de-scoped TCs from the RTTMs |  | 5d | 2024-10-21 A | 2024-10-25 A | 864FS-5d | 100% | 2024-10-21 | 2024-10-25 | 0d |  |  |  |  | SI Test |  | SIT | 6.11 | Kevin Davis |  | Complete | COMPLETE |  |  | SITAG |  |  |  |  |
| 866 | 1.4.1.4.2.5.2.2.8 | Update and stabilisation of all TC ADO IDs |  | 14d | 2024-10-21 A | 2024-11-07 A | 864FS-5d | 100% | 2024-10-21 | 2024-10-25 | 0d |  |  |  |  | SI Test |  | SIT | 6.12 | Kevin Davis |  | Complete | COMPLETE |  |  | SITAG |  |  |  |  |
| 867 | 1.4.1.4.2.5.2.2.9 | Addition and integration of Role tags to reqs in the Role RTTMs |  | 5d | 2024-10-21 A | 2024-10-25 A | 864FS-5d | 100% | 2024-10-21 | 2024-10-25 | 0d |  |  |  |  | SI Test |  | SIT | 6.11 | Kevin Davis |  | Complete | COMPLETE |  |  | SITAG |  |  |  |  |
| 868 | 1.4.1.4.2.5.2.2.10 | Update of the RTTM All sheet (porting of the individual RTTMs) |  | 7d | 2024-10-24 A | 2024-11-01 A | 864FS-2d | 100% | 2024-10-24 | 2024-10-25 | 0d |  |  |  |  | SI Test |  | SIT | 6.11 | Kevin Davis |  | Complete | COMPLETE |  |  | SITAG |  |  |  |  |
| 869 | 1.4.1.4.2.5.2.2.11 | Define Additional ADO Tags |  | 1d | 2024-10-23 A | 2024-10-23 A | 864FS-3d | 100% | 2024-10-23 | 2024-10-23 | 0d |  |  |  |  | SI Test |  | SIT | 6.11 | Kevin Davis |  | Complete | COMPLETE |  |  | SITAG |  |  |  |  |
| 870 | 1.4.1.4.2.5.2.2.12 | Functional RTTM ready for import into ADO | milestone | 0d | 2024-11-01 A | 2024-11-01 A | 868 | 100% | 2024-10-25 | 2024-10-25 | 0d |  |  |  |  | SI Test |  | SIT | 6.11 | Kevin Davis |  | Complete | COMPLETE |  |  | SITAG |  |  |  |  |
| 871 | 1.4.1.4.2.5.2.2.13 | Further Interative Deepdive on the requirements to testcase mapping |  | 9d | 2024-10-21 A | 2024-10-31 A | 868FS-10d | 100% | 2024-10-21 | 2024-10-31 | 0d |  |  |  |  | SI Test |  | SIT | 6.11 | Kevin Davis |  | Complete | COMPLETE |  |  | SITAG |  |  |  |  |
| 872 | 1.4.1.4.2.5.2.2.14 | Internal review |  | 5d | 2024-10-21 A | 2024-10-25 A | 871FS-9d | 100% | 2024-11-01 | 2024-11-05 | 0d |  |  |  |  | SI Test |  | SIT | 6.11 | Kevin Davis |  | Complete | COMPLETE |  |  | SITAG |  |  |  |  |
| 873 | 1.4.1.4.2.5.2.2.15 | Issue Static RTTM to Code Bodies |  | 1d? | 2024-10-29 A | 2024-10-29 A | 872FS+1d | 100% | 2024-11-06 | 2024-11-06 | 0d |  |  |  |  | SI Test |  | SIT | 6.11 | Kevin Davis |  | Complete | COMPLETE |  |  | SITAG |  |  |  |  |
| 874 | 1.4.1.4.2.5.2.2.16 | Code Body Acceptance of RTTM |  | 5d | 2024-10-30 A | 2024-11-05 A | 873 | 100% | 2024-11-07 | 2024-11-13 | 0d |  |  |  |  | Code Bodies |  | SIT | 6.11 | Kevin Davis |  | Complete | COMPLETE |  |  | SITAG |  |  |  |  |

| ID | WBS | Task | Type | Duration | Start | Finish | Predecessors | Complete | Baseline start | Baseline finish | Baseline duration | Constraint | Responsible | Text9 | Task Status | Update Version | MHHS Resource Name | Text29 | Sched Status | RAG | Milestone ID | Tier |
| --- | --- | --- | --- | --- | --- | --- | --- | --- | --- | --- | --- | --- | --- | --- | --- | --- | --- | --- | --- | --- | --- | --- |
| 875 | 1.4.1.4.2.5.3 | **Cycle 3 Test Evidence Capturing Approach** |  | 25d? | 2024-09-16 A | 2024-10-18 A |  | 100% | 2024-09-16 | 2024-10-18 | 0d |  | SI Test | SIT | -692.67 | 6.0 | Ankur Pande | SITAG |  |  |  |  |
| 876 | 1.4.1.4.2.5.3.1 | Define guiding principles and proof of concept |  | 10d | 2024-09-16 A | 2024-09-27 A |  | 100% | 2024-09-16 | 2024-09-27 | 0d | start no earlier than 2024-09-16 | SI Test | SIT |  | 6.0 | Ankur Pande | SITAG | Complete | COMPLETE |  |  |
| 877 | 1.4.1.4.2.5.3.2 | Draft proposed test evidence capturing approach |  | 3d | 2024-09-30 A | 2024-10-02 A | 876 | 100% | 2024-09-30 | 2024-10-02 | 0d |  | SI Test | SIT |  | 6.0 | Ankur Pande | SITAG | Complete | COMPLETE |  |  |
| 878 | 1.4.1.4.2.5.3.3 | SRO review |  | 5d | 2024-10-03 A | 2024-10-09 A | 877 | 100% | 2024-10-03 | 2024-10-09 | 0d |  | SI Test | SIT |  | 6.0 | Ankur Pande | SITAG | Complete | COMPLETE |  |  |
| 879 | 1.4.1.4.2.5.3.4 | Present proposed approach |  | 1d? | 2024-10-11 A | 2024-10-11 A | 878FS+1d | 100% | 2024-10-11 | 2024-10-11 | 0d |  | SI Test | SIT |  | 6.0 | Ankur Pande | SITAG | Complete | COMPLETE |  |  |
| 880 | 1.4.1.4.2.5.3.5 | Incorporate feedback |  | 4d | 2024-10-14 A | 2024-10-17 A | 879 | 100% | 2024-10-14 | 2024-10-17 | 0d |  | SI Test | SIT |  | 6.0 | Ankur Pande | SITAG | Complete | COMPLETE |  |  |
| 881 | 1.4.1.4.2.5.3.6 | Publish proposed approach ahead of Cycle 3 start |  | 1d? | 2024-10-18 A | 2024-10-18 A | 880 | 100% | 2024-10-18 | 2024-10-18 | 0d |  | SI Test | SIT |  | 6.0 | Ankur Pande | SITAG | Complete | COMPLETE |  |  |
| 882 | 1.4.1.4.2.5.4 | **DITL Cycle 3 Pack Development** |  | 8d? | 2024-10-08 A | 2024-10-17 A |  | 100% | 2024-10-08 | 2024-10-17 | 0d |  | SI Test | SIT | 6.33 | 6.0 | Dom Mooney | SITAG | No BL |  |  |  |
| 883 | 1.4.1.4.2.5.4.1 | Programme Cycle 2 Retro |  | 1d? | 2024-10-08 A | 2024-10-08 A |  | 100% | 2024-10-08 | 2024-10-08 | 0d | start no earlier than 2024-10-08 | SI Test | SIT |  | 6.0 | Dom Mooney | SITAG | Complete | COMPLETE |  |  |
| 884 | 1.4.1.4.2.5.4.2 | Post-retro DITL Changes |  | 3d | 2024-10-09 A | 2024-10-11 A | 883 | 100% | 2024-10-09 | 2024-10-11 | 0d |  | SI Test | SIT |  | 6.0 | Dom Mooney | SITAG | Complete | COMPLETE |  |  |
| 885 | 1.4.1.4.2.5.4.3 | SRO Review |  | 2d | 2024-10-14 A | 2024-10-15 A | 884 | 100% | 2024-10-14 | 2024-10-15 | 0d |  | SI Test | SIT |  | 6.0 | Dom Mooney | SITAG | Complete | COMPLETE |  |  |
| 886 | 1.4.1.4.2.5.4.4 | Post-SRO Review Changes |  | 1d? | 2024-10-16 A | 2024-10-16 A | 885 | 100% | 2024-10-16 | 2024-10-16 | 0d |  | SI Test | SIT |  | 6.0 | Dom Mooney | SITAG | Complete | COMPLETE |  |  |
| 887 | 1.4.1.4.2.5.4.5 | Publish Cycle 3 DITL / Cycle 3 DITL Online Sessions for SIT PPs |  | 1d? | 2024-10-17 A | 2024-10-17 A | 886 | 100% | 2024-10-17 | 2024-10-17 | 0d |  | SI Test, PPs | SIT |  | 6.0 | Dom Mooney | SITAG | Complete | COMPLETE |  |  |
| 888 | 1.4.1.4.2.5.5 | **Test Script Exit Points** |  | 85d | 2024-10-14 A | 2025-02-07 A |  | 100% | 2024-10-14 | 2025-02-07 | 0d |  | SI Test | SIT | -694.67 | 6.0 | Kevin Davis | SITAG |  |  |  |  |
| 889 | 1.4.1.4.2.5.5.1 | Implement exit points for Sprint 5 |  | 5d | 2024-10-14 A | 2024-10-18 A | 881FS-5d | 100% | 2024-10-14 | 2024-10-18 | 0d |  | SI Test | SIT |  | 6.0 | Kevin Davis | SITAG | Complete | COMPLETE |  |  |
| 890 | 1.4.1.4.2.5.5.2 | Identify exit points for Sprint 6 |  | 5d | 2024-11-07 A | 2024-11-13 A | 1513SS | 100% | 2024-10-21 | 2024-10-25 | 0d |  | SI Test | SIT |  | 6.0 | Kevin Davis | SITAG | Complete | COMPLETE |  |  |
| 891 | 1.4.1.4.2.5.5.3 | Identify exit points for Sprint 7 |  | 5d | 2024-11-08 A | 2024-11-14 A | 1514SS | 100% | 2024-11-04 | 2024-11-08 | 0d | start no earlier than 2024-11-08 | SI Test | SIT |  | 6.0 | Kevin Davis | SITAG | Complete | COMPLETE |  |  |
| 892 | 1.4.1.4.2.5.5.4 | Identify exit points for Sprint 8 |  | 5d | 2024-11-18 A | 2024-11-22 A | 1515SS | 100% | 2024-11-18 | 2024-11-22 | 0d |  | SI Test | SIT |  | 6.0 | Kevin Davis | SITAG | Complete | COMPLETE |  |  |
| 893 | 1.4.1.4.2.5.5.5 | Identify exit points for Sprint 9 |  | 5d | 2024-12-02 A | 2024-12-06 A | 1516SS | 100% | 2024-12-02 | 2024-12-06 | 0d |  | SI Test | SIT |  | 6.0 | Kevin Davis | SITAG | Complete | COMPLETE |  |  |
| 894 | 1.4.1.4.2.5.5.6 | Identify exit points for Sprint 10 |  | 5d | 2024-12-23 A | 2024-12-27 A | 1517SS | 100% | 2024-12-23 | 2024-12-27 | 0d |  | SI Test | SIT |  | 6.0 | Kevin Davis | SITAG | Complete | COMPLETE |  |  |
| 895 | 1.4.1.4.2.5.5.7 | Identify exit points for Sprint 11 |  | 5d | 2025-01-06 A | 2025-01-10 A | 1518SS | 100% | 2025-01-06 | 2025-01-10 | 0d |  | SI Test | SIT |  | 6.0 | Kevin Davis | SITAG | Complete | COMPLETE |  |  |
| 896 | 1.4.1.4.2.5.5.8 | Identify exit points for Sprint 12 |  | 5d | 2025-01-20 A | 2025-01-24 A | 1519SS | 100% | 2025-01-20 | 2025-01-24 | 0d |  | SI Test | SIT |  | 6.0 | Kevin Davis | SITAG | Complete | COMPLETE |  |  |
| 897 | 1.4.1.4.2.5.5.9 | Identify exit points for Sprint 13 |  | 5d | 2025-02-03 A | 2025-02-07 A | 1520SS | 100% | 2025-02-03 | 2025-02-07 | 0d |  | SI Test | SIT |  | 6.0 | Kevin Davis | SITAG | Complete | COMPLETE |  |  |
| 898 | 1.4.1.4.2.5.5.10 | Exit point identified and evidence capture flags updated | milestone | 0d | 2025-02-07 A | 2025-02-07 A | 897 | 100% | 2025-02-07 | 2025-02-07 | 0d |  | SI Test | SIT |  | 6.13 | Kevin Davis | SITAG | Complete | COMPLETE | T3-TE-0125 | T3 |

| ID | WBS | Task | Type | Duration | Start | Finish | Predecessors | Complete | Baseline start | Baseline finish | Baseline duration | Baseline 1 start | Baseline 1 finish | Constraint | Baseline cost | Responsible | Involved | Text9 | Update Version | MHHS Resource Name | MHHS Programme Phase | Text29 | Task Status | Sched Status | RAG | Action | Milestone ID | Tier | Artefact ID |
| --- | --- | --- | --- | --- | --- | --- | --- | --- | --- | --- | --- | --- | --- | --- | --- | --- | --- | --- | --- | --- | --- | --- | --- | --- | --- | --- | --- | --- | --- |
| 899 | 1.4.1.4.2.6 | **Environments (SIT-Staging)** |  | 10d | 2023-12-04 A | 2023-12-15 A |  | 100% | 2023-12-04 | 2023-12-15 | 323d | 2022-11-16 | 2024-02-09 |  |  | N/A | N/A | SIT | 5.0 | N/A | Systems Integration Testing (SIT) | SITAG |  |  |  |  |  |  |  |
| 900 | 1.4.1.4.2.6.1 | **SIT Functional pre-requisites** |  | 10d | 2023-12-04 A | 2023-12-15 A |  | 100% | 2023-12-04 | 2023-12-15 | 10d |  |  |  |  | N/A | N/A | SIT | 5.3 | N/A | Systems Integration Testing (SIT) | SITAG |  |  |  |  |  |  |  |
| 901 | 1.4.1.4.2.6.1.1 | **DCC** |  | 10d | 2023-12-04 A | 2023-12-15 A |  | 100% | 2023-12-04 | 2023-12-15 | 10d |  |  |  |  | N/A | N/A | SIT | 5.3 | N/A | Systems Integration Testing (SIT) | SITAG | -254.67 |  |  |  |  |  |  |
| 902 | 1.4.1.4.2.6.1.1.1 | **CSS** |  | 10d | 2023-12-04 A | 2023-12-15 A |  | 100% | 2023-12-04 | 2023-12-15 | 10d |  |  |  |  | N/A | N/A | SIT | 5.3 | N/A | Systems Integration Testing (SIT) | SITAG | -254.67 |  |  |  |  |  |  |
| 903 | 1.4.1.4.2.6.1.1.1.1 | SIT participants have requested DCC CSS PKI certificates for access to UIT-B environment |  | 10d | 2023-12-04 A | 2023-12-15 A |  | 100% | 2023-12-04 | 2023-12-15 | 10d |  |  | start no earlier than 2023-12-04 |  | SIT Participants (Suppliers & Third Parties) | PP | SIT | 5.3 | Simon Berry | Systems Integration Testing (SIT) | SITAG |  | Complete | COMPLETE |  |  |  |  |
| 904 | 1.4.1.4.2.6.1.1.1.2 | SIT participants have received DCC CSS PKI certificates for UIT-B environment | milestone | 0d | 2023-12-15 A | 2023-12-15 A | 903 | 100% | 2023-12-15 | 2023-12-15 | 0d |  |  |  |  | SIT Participants (Suppliers & Third Parties) | PP | SIT | 5.5 | Simon Berry | Systems Integration Testing (SIT) | SITAG |  | Complete | COMPLETE | 7/8 - added as a T3 milestone. Awaiting approval at TMAG | T3-TE-0088 | T3 |  |
| 905 | 1.4.1.4.2.6.1.1.2 | **DSP** |  | 10d | 2023-12-04 A | 2023-12-15 A |  | 100% | 2023-12-04 | 2023-12-15 | 10d |  |  |  |  | N/A | N/A | SIT | 5.3 | N/A | Systems Integration Testing (SIT) | SITAG | -254.67 |  |  |  |  |  |  |
| 906 | 1.4.1.4.2.6.1.1.2.1 | SIT participants have requested DCC DSP PKI certificates for access to UIT-B environment |  | 10d | 2023-12-04 A | 2023-12-15 A |  | 100% | 2023-12-04 | 2023-12-15 | 10d |  |  | start no earlier than 2023-12-04 |  | PPs in SDS Market Role | PP | SIT | 5.3 | Simon Berry | Systems Integration Testing (SIT) | SITAG |  | Complete | COMPLETE |  |  |  |  |
| 907 | 1.4.1.4.2.6.1.1.2.2 | SIT participants have received DCC DSP PKI certificates for UIT-B environment | milestone | 0d | 2023-12-15 A | 2023-12-15 A | 906 | 100% | 2023-12-15 | 2023-12-15 | 0d |  |  |  |  | PPs in SDS Market Role | PP | SIT | 5.5 | Simon Berry | Systems Integration Testing (SIT) | SITAG |  | Complete | COMPLETE | 7/8 - added as a T3 milestone. Awaiting approval at TMAG | T3-TE-0089 | T3 |  |
| 908 | 1.4.1.4.2.7 | **Stand up SIT A Environment** |  | 25d | 2024-02-05 A | 2024-03-08 A |  | 100% | 2024-02-05 | 2024-03-08 | 25d | 2024-02-05 | 2024-02-09 |  |  | N/A | N/A | SIT | 6.0 | N/A | Systems Integration Testing (SIT) | SITAG |  |  |  |  |  |  |  |
| 909 | 1.4.1.4.2.7.1 | **SIT Functional Connectivity Proving** |  | 15d | 2024-02-12 A | 2024-03-01 A |  | 100% | 2024-02-12 | 2024-03-01 | 20d |  |  |  |  | N/A | N/A | SIT | 5.5 | N/A | Systems Integration Testing (SIT) | SITAG | -288.67 |  |  |  |  |  |  |
| 910 | 1.4.1.4.2.7.1.1 | SIT Functional Connectivity Proving Period |  | 15d | 2024-02-12 A | 2024-03-01 A |  | 100% | 2024-02-12 | 2024-03-01 | 20d |  |  | start no earlier than 2024-01-08 |  | SI Test | PP | SIT | 5.19 | Simon Berry | Systems Integration Testing (SIT) | SITAG |  | Complete | COMPLETE |  |  |  |  |
| 911 | 1.4.1.4.2.7.1.2 | SIT Functional Connectivity Proving Complete | milestone | 0d | 2024-03-01 A | 2024-03-01 A | 910 | 100% | 2024-03-01 | 2024-03-01 | 0d |  |  | start no earlier than 2024-03-01 |  | SI Test | PP | SIT | 5.19 | Simon Berry | Systems Integration Testing (SIT) | SITAG |  | Complete | COMPLETE |  | T3-TE-0103 | T3 |  |
| 912 | 1.4.1.4.2.7.2 | **PP Environments (SIT A)** |  | 25d | 2024-02-05 A | 2024-03-08 A |  | 100% | 2024-02-05 | 2024-03-08 | 5d | 2024-02-05 | 2024-02-09 |  |  | N/A | N/A | SIT | 5.0 | N/A | Systems Integration Testing (SIT) | SITAG |  |  |  |  |  |  |  |
| 913 | 1.4.1.4.2.7.2.1 | Deployment of MHHS solution code to SIT A environments |  | 25d | 2024-02-05 A | 2024-03-08 A |  | 100% | 2024-02-05 | 2024-03-08 | 5d | 2024-02-05 | 2024-02-09 | start no earlier than 2024-02-05 |  | PP | SI Test | SIT | 5.0 | Simon Berry | Systems Integration Testing (SIT) | SITAG |  | Complete | COMPLETE |  |  |  |  |
| 914 | 1.4.1.4.2.7.3 | **SI Environments (SIT A)** |  | 25d | 2024-02-05 A | 2024-03-08 A |  | 100% | 2024-02-05 | 2024-03-08 | 5d | 2024-02-05 | 2024-02-09 |  |  | N/A | N/A | SIT | 5.0 | N/A | Systems Integration Testing (SIT) | SITAG |  |  |  |  |  |  |  |
| 915 | 1.4.1.4.2.7.3.1 | Coordinate deployment of MHHS solution code to SIT Participants' SIT A environments |  | 25d | 2024-02-05 A | 2024-03-08 A | 913SS | 100% | 2024-02-05 | 2024-03-08 | 5d | 2024-02-05 | 2024-02-09 |  |  | SI Test | PP | SIT | 5.0 | Simon Berry | Systems Integration Testing (SIT) | SITAG |  | Complete | COMPLETE |  |  |  |  |
| 916 | 1.4.1.4.2.8 | **Test data (SIT A)** |  | 221d? | 2023-12-18 A | 2024-10-21 A |  | 100% | 2023-12-18 | 2025-04-07 | 225d |  |  |  | -0 | N/A | N/A | SIT | 5.4 | N/A | Systems Integration Testing (SIT) | SITAG | -269.67 |  |  |  |  |  |  |
| 917 | 1.4.1.4.2.8.1 | **Cycle 1 Test data (SIT A)** |  | 55d | 2023-12-18 A | 2024-03-01 A |  | 100% | 2023-12-18 | 2024-03-01 | 55d |  |  |  | -0 | N/A | N/A | SIT | 5.4 | N/A | Systems Integration Testing (SIT) | SITAG | -269.67 |  |  |  |  |  |  |
| 918 | 1.4.1.4.2.8.1.1 | Prepare, Generate and Allocate Test Data |  | 28d | 2023-12-18 A | 2024-01-24 A | 649, 657 | 100% | 2023-12-18 | 2024-01-24 | 28d |  |  | start no earlier than 2023-12-11 |  | SI Test Data |  | SIT | 5.14 | Michael Inije | Systems Integration Testing (SIT) | SITAG |  | Complete | COMPLETE |  |  |  |  |
| 919 | 1.4.1.4.2.8.1.2 | Transmit Data Sets to PPs |  | 4d | 2024-01-26 A | 2024-01-31 A | 918FS+1d | 100% | 2024-01-26 | 2024-01-31 | 2d |  |  |  |  | SI Test Data |  | SIT | 5.14 | Michael Inije | Systems Integration Testing (SIT) | SITAG |  | Complete | COMPLETE |  |  |  |  |
| 920 | 1.4.1.4.2.8.1.3 | PP's Iterative load and data integrity check |  | 22d | 2024-02-01 A | 2024-03-01 A | 919 | 100% | 2024-02-01 | 2024-03-01 | 10d |  |  |  |  | PP |  | SIT | 5.14 | Michael Inije | Systems Integration Testing (SIT) | SITAG |  | Complete | COMPLETE |  |  |  |  |
| 921 | 1.4.1.4.2.8.1.4 | Cycle 1 - PP's confirmation that test data is ready for SIT Functional | milestone | 0d | 2024-03-01 A | 2024-03-01 A | 920 | 100% | 2024-03-01 | 2024-03-01 | 0d |  |  |  |  | SI Test Data |  | SIT | 5.18 | Michael Inije | Systems Integration Testing (SIT) | SITAG |  | Complete | COMPLETE | 2/8 - added as a T3 milestone. Awaiting approval at TMAG | T3-TE-0079 | T3 | MHHS-ART140 MHHS-ART169 |
| 922 | 1.4.1.4.2.8.2 | **Cycle 2 Test data (inc. Settlement Data) (SIT A)** |  | 57d | 2024-03-28 A | 2024-06-14 A |  | 100% | 2024-03-28 | 2024-06-14 | 47d |  |  |  | -0 | N/A | N/A | SIT | 6.0 | N/A | Systems Integration Testing (SIT) | SITAG |  |  |  |  |  |  |  |
| 923 | 1.4.1.4.2.8.2.1 | Prepare, Generate and Allocate Test Data |  | 31d | 2024-03-28 A | 2024-05-09 A | 921FS+18d | 100% | 2024-03-28 | 2024-05-09 | 31d |  |  |  |  | SI Test Data |  | SIT | 5.14 | Michael Inije | Systems Integration Testing (SIT) | SITAG |  | Complete | COMPLETE |  |  |  |  |
| 924 | 1.4.1.4.2.8.2.2 | Transmit Data Sets to PPs |  | 3d | 2024-05-10 A | 2024-05-14 A | 923 | 100% | 2024-05-10 | 2024-05-14 | 3d |  |  |  |  | SI Test Data |  | SIT | 5.14 | Michael Inije | Systems Integration Testing (SIT) | SITAG |  | Complete | COMPLETE |  |  |  |  |
| 925 | 1.4.1.4.2.8.2.3 | PP's Iterative load and data integrity check |  | 13d | 2024-05-15 A | 2024-05-31 A | 924 | 100% | 2024-05-15 | 2024-05-31 | 13d |  |  |  |  | PP |  | SIT | 5.14 | Michael Inije | Systems Integration Testing (SIT) | SITAG |  | Complete | COMPLETE |  |  |  |  |
| 926 | 1.4.1.4.2.8.2.4 | Cycle 2 - PP's confirmation that test data is ready for SIT Functional | milestone | 0d | 2024-06-14 A | 2024-06-14 A | 925FS+10d | 100% | 2024-06-14 | 2024-06-14 | 0d |  |  |  |  | SI Test Data |  | SIT | 5.27 | Michael Inije | Systems Integration Testing (SIT) | SITAG |  | Complete | COMPLETE | 2/8 - added as a T3 milestone. Awaiting approval at TMAG | T3-TE-0080 | T3 | MHHS-ART140 MHHS-ART169 |

| ID | WBS | Task | Duration | Start | Finish | Predecessors | Complete | Baseline start | Baseline finish | Baseline duration | Baseline 1 start | Baseline 1 finish | Constraint | Baseline cost | Responsible | Involved | Text9 | Update Version | MHHS Resource Name | MHHS Programme Phase | Text29 | Sched Status | RAG | Milestone ID | Tier |
| --- | --- | --- | --- | --- | --- | --- | --- | --- | --- | --- | --- | --- | --- | --- | --- | --- | --- | --- | --- | --- | --- | --- | --- | --- | --- |
| 927 | 1.4.1.4.2.8.3 | **Cycle 3 Test data (SIT A) (2)** | 71d? | 2024-07-15 A | 2024-10-21 A |  | 100% | 2024-07-15 | 2024-10-21 | 41d |  |  |  | -0 | N/A | N/A | SIT | 5.4 | N/A | Systems Integration Testing (SIT) | SITAG |  |  |  |  |
| 928 | 1.4.1.4.2.8.3.1 | Cycle 3 data requirments analysis - check Cycle 2 data for gaps Check blocked test cases | 10d? | 2024-07-15 A | 2024-07-26 A |  | 100% | 2024-07-15 | 2024-07-26 | 0d |  |  | finish no earlier than 2024-07-26 |  | SI Test Data |  | SIT | 6.0 | Michael Inije |  | SITAG | Complete | COMPLETE |  |  |
| 929 | 1.4.1.4.2.8.3.2 | Provide DCC with MPANS for deletion secure file with password | 1d? | 2024-08-12 A | 2024-08-12 A |  | 100% | 2024-08-12 | 2024-08-12 | 0d |  |  |  |  | SI Test Data |  | SIT | 6.0 | Michael Inije |  | SITAG | Complete | COMPLETE |  |  |
| 930 | 1.4.1.4.2.8.3.3 | Receive MPANS from DCC to exclude | 1d? | 2024-08-09 A | 2024-08-09 A |  | 100% | 2024-08-09 | 2024-08-09 | 0d |  |  |  |  | SI Test Data |  | SIT | 6.0 | Michael Inije |  | SITAG | Complete | COMPLETE |  |  |
| 931 | 1.4.1.4.2.8.3.4 | Exclude MPANS from allocation | 1d | 2024-08-16 A | 2024-08-16 A |  | 100% | 2024-08-16 | 2024-08-16 | 0d |  |  |  |  | SI Test Data |  | SIT | 6.0 | Michael Inije |  | SITAG | Complete | COMPLETE |  |  |
| 932 | 1.4.1.4.2.8.3.5 | Allocate Cycle 3 MPANS | 16d? | 2024-08-06 A | 2024-08-27 A |  | 100% | 2024-08-06 | 2024-08-27 | 0d |  |  |  |  | SI Test Data |  | SIT | 6.0 | Michael Inije |  | SITAG | Complete | COMPLETE |  |  |
| 933 | 1.4.1.4.2.8.3.6 | Generate Cycle 3 Data | 2d? | 2024-08-27 A | 2024-08-28 A |  | 100% | 2024-08-27 | 2024-08-28 | 0d |  |  |  |  | SI Test Data |  | SIT | 6.0 | Michael Inije |  | SITAG | Complete | COMPLETE |  |  |
| 934 | 1.4.1.4.2.8.3.7 | Check data prior to sending to DCC | 5d? | 2024-08-22 A | 2024-08-28 A |  | 100% | 2024-08-22 | 2024-08-28 | 0d |  |  |  |  | SI Test Data |  | SIT | 6.0 | Michael Inije |  | SITAG | Complete | COMPLETE |  |  |
| 935 | 1.4.1.4.2.8.3.8 | Share Cycle 3 MPAN data with DCC | 1d? | 2024-08-29 A | 2024-08-29 A |  | 100% | 2024-08-29 | 2024-08-29 | 0d |  |  |  |  | SI Test Data |  | SIT | 6.0 | Michael Inije |  | SITAG | Complete | COMPLETE |  |  |
| 936 | 1.4.1.4.2.8.3.9 | DCC - load data and create registration Id's for Cycle 3 data | 13d? | 2024-08-27 A | 2024-09-12 A |  | 100% | 2024-08-27 | 2024-09-12 | 0d |  |  |  |  | DCC |  | SIT | 6.0 | Michael Inije |  | SITAG | Complete | COMPLETE |  |  |
| 937 | 1.4.1.4.2.8.3.10 | Add registration ID's to Cycle 3 Data | 2d? | 2024-09-12 A | 2024-09-13 A |  | 100% | 2024-09-12 | 2024-09-13 | 0d |  |  |  |  | SI Test Data |  | SIT | 6.0 | Michael Inije |  | SITAG | Complete | COMPLETE |  |  |
| 938 | 1.4.1.4.2.8.3.11 | Share subset of data with St Cls for data load | 2d? | 2024-09-12 A | 2024-09-13 A |  | 100% | 2024-09-12 | 2024-09-13 | 0d |  |  |  |  | SI Test Data |  | SIT | 6.0 | Michael Inije |  | SITAG | Complete | COMPLETE |  |  |
| 939 | 1.4.1.4.2.8.3.12 | St Clements to run test with Subset of data - MPRS business process checks including Import/Export MPANS | 5d? | 2024-09-16 A | 2024-09-20 A |  | 100% | 2024-09-16 | 2024-09-20 | 0d |  |  |  |  | SCS |  | SIT | 6.0 | Michael Inije |  | SITAG | Complete | COMPLETE |  |  |
| 940 | 1.4.1.4.2.8.3.13 | Send Cycle 3 data to partcipants for early sight of data | 3d? | 2024-09-25 A | 2024-09-27 A |  | 100% | 2024-09-25 | 2024-09-27 | 0d |  |  |  |  | SI Test Data |  | SIT | 6.0 | Michael Inije |  | SITAG | Complete | COMPLETE |  |  |
| 941 | 1.4.1.4.2.8.3.14 | St Clements MPRS data load bulk files for Cycle 3 | 15d? | 2024-09-23 A | 2024-10-11 A |  | 100% | 2024-09-23 | 2024-10-11 | 0d |  |  |  |  | SCS |  | SIT | 6.0 | Michael Inije |  | SITAG | Complete | COMPLETE |  |  |
| 942 | 1.4.1.4.2.8.3.15 | New MPAN creation and load through DCC and St Clements | 1d? | 2024-10-11 A | 2024-10-11 A |  | 100% | 2024-10-11 | 2024-10-11 | 0d |  |  | start no earlier than 2024-10-11 |  | SI Test Data |  | SIT | 6.0 | Michael Inije |  | SITAG | Complete | COMPLETE |  |  |
| 943 | 1.4.1.4.2.8.3.16 | Share files with PP's and central parties | 1d | 2024-10-11 A | 2024-10-11 A |  | 100% | 2024-10-11 | 2024-10-11 | 0d |  |  | start no earlier than 2024-10-11 |  | SI Test Data |  | SIT | 6.0 | Michael Inije |  | SITAG | Complete | COMPLETE |  |  |
| 944 | 1.4.1.4.2.8.3.17 | Avanade to load data | 6d | 2024-10-14 A | 2024-10-21 A |  | 100% | 2024-10-14 | 2024-10-21 | 0d |  |  | start no earlier than 2024-10-14 |  | DIP Provider |  | SIT | 6.0 | Michael Inije |  | SITAG | Complete | COMPLETE |  |  |
| 945 | 1.4.1.4.2.8.3.18 | Helix to load data | 6d | 2024-10-14 A | 2024-10-21 A |  | 100% | 2024-10-14 | 2024-10-21 | 0d |  |  | start no earlier than 2024-10-14 |  | Helix |  | SIT | 6.0 | Michael Inije |  | SITAG | Complete | COMPLETE |  |  |
| 946 | 1.4.1.4.2.8.3.19 | PP's and central parties to load all Cycle 3 data | 6d | 2024-10-14 A | 2024-10-21 A |  | 100% | 2024-10-14 | 2024-10-21 | 0d |  |  | start no earlier than 2024-10-14 |  | PPs |  | SIT | 6.0 | Michael Inije |  | SITAG | Complete | COMPLETE |  |  |
| 947 | 1.4.1.4.2.8.3.20 | All parties to finalise data load | 1d? | 2024-10-21 A | 2024-10-21 A |  | 100% | 2024-10-21 | 2024-10-21 | 0d |  |  | start no earlier than 2024-10-21 |  | SI Data |  | SIT | 6.0 | Michael Inije |  | SITAG | Complete | COMPLETE | T3-TE-0081 | T3 |
| 948 | 1.4.1.4.2.9 | **SIT Functional Test Readiness Report** | 45d | 2024-01-01 A | 2024-03-01 A |  | 100% | 2024-01-01 | 2024-03-01 | 44d | 2024-01-01 | 2024-02-23 |  | -0 | N/A | N/A | SIT | 5.0 | N/A | Systems Integration Testing (SIT) | SITAG |  |  |  |  |
| 949 | 1.4.1.4.2.9.1 | **PP SIT Functional Test Readiness Report** | 44d | 2024-01-01 A | 2024-02-29 A |  | 100% | 2024-01-01 | 2024-02-29 | 44d | 2024-01-01 | 2024-02-09 |  | -0 | N/A | N/A | SIT | 5.0 | N/A | Systems Integration Testing (SIT) | SITAG |  |  |  |  |
| 950 | 1.4.1.4.2.9.1.1 | Develop draft Test Readiness Report and submit to Programme for assurance | 21d | 2024-01-01 A | 2024-01-29 A |  | 100% | 2024-01-01 | 2024-01-29 | 20d | 2024-01-01 | 2024-01-29 | start no earlier than 2024-01-01 |  | PP | SI Test | SIT | 5.0 |  | Systems Integration Testing (SIT) | SITAG | Complete | COMPLETE |  |  |
| 951 | 1.4.1.4.2.9.1.2 | Placing Reliance Stage 2 Review | 34d | 2024-01-15 A | 2024-02-29 A | 950SS+10d | 100% | 2024-01-15 | 2024-02-29 | 34d |  |  |  |  | SI Test | PP | SIT | 5.12 |  | Systems Integration Testing (SIT) | SITAG | Complete | COMPLETE |  |  |
| 952 | 1.4.1.4.2.9.1.3 | Finalise Test Readiness Report and submit to Programme for assurance | 9d | 2024-01-30 A | 2024-02-09 A | 950 | 100% | 2024-01-30 | 2024-02-09 | 10d | 2024-01-29 | 2024-02-09 |  |  | PP | SI Test | SIT | 5.0 |  | Systems Integration Testing (SIT) | SITAG | Complete | COMPLETE |  |  |

| ID | WBS | Task | Type | Duration | Start | Finish | Predecessors | Complete | Baseline start | Baseline finish | Baseline duration | Baseline 1 start | Baseline 1 finish | Constraint | Baseline cost | Responsible | Involved | Text9 | Update Version | MHHS Resource Name | MHHS Programme Phase | Text29 | Sched Status | RAG | Milestone ID | Tier | Artefact ID | Task Status |
| --- | --- | --- | --- | --- | --- | --- | --- | --- | --- | --- | --- | --- | --- | --- | --- | --- | --- | --- | --- | --- | --- | --- | --- | --- | --- | --- | --- | --- |
| 953 | 1.4.1.4.2.9.2 | **SI SIT Functional Test Readiness Report** |  | 40d | 2024-01-01 A | 2024-02-23 A |  | 100% | 2024-01-01 | 2024-02-23 | 40d | 2024-01-01 | 2024-02-23 |  |  | N/A | N/A | SIT | 5.0 | N/A | Systems Integration Testing (SIT) | SITAG |  |  |  |  |  |  |
| 954 | 1.4.1.4.2.9.2.1 | Assure Test Participants' Test Readiness Reports |  | 35d | 2024-01-01 A | 2024-02-16 A | 950SS, 952FF+5d | 100% | 2024-01-01 | 2024-02-16 | 35d | 2024-01-01 | 2024-02-16 |  |  | SI Test | PP,IPA | SIT | 5.0 |  | Systems Integration Testing (SIT) | SITAG | Complete | COMPLETE |  |  |  |  |
| 955 | 1.4.1.4.2.9.2.2 | Develop Overarching SIT Functional Test Readiness Report |  | 20d | 2024-01-22 A | 2024-02-16 A | 954FF | 100% | 2024-01-22 | 2024-02-16 | 20d | 2024-01-22 | 2024-02-16 |  |  | SI Test |  | SIT | 5.0 |  | Systems Integration Testing (SIT) | SITAG | Complete | COMPLETE |  |  |  |  |
| 956 | 1.4.1.4.2.9.2.3 | Artefact review (via TMAG) and updates |  | 5d | 2024-02-19 A | 2024-02-23 A | 955 | 100% | 2024-02-19 | 2024-02-23 | 5d | 2024-02-19 | 2024-02-23 |  |  | SI Test | PP,IPA | SIT | 5.0 |  | Systems Integration Testing (SIT) | SITAG | Complete | COMPLETE |  |  |  |  |
| 957 | 1.4.1.4.2.9.3 | SIT Functional Testing Preparation Complete | milestone | 0d | 2024-03-01 A | 2024-03-01 A | 956FF+5d, 836, 342, 951, 844, 851, 921 | 100% | 2024-03-01 | 2024-03-01 | 0d | 2024-03-01 | 2024-03-01 |  |  | SI Test | PP,IPA | SIT | 5.0 |  | Systems Integration Testing (SIT) | SITAG | Complete | COMPLETE | T2-TE-0550 | T2 |  |  |
| 958 | 1.4.1.4.3 | **SIT Migration Testing Preparation** |  | 595d? | 2022-10-31 A | 2025-02-07 A |  | 100% | 2022-10-31 | 2024-10-04 | 420d | 2022-11-16 | 2024-06-03 |  | -0 | N/A | N/A | SIT | 5.21 | N/A | Systems Integration Testing (SIT) | SITAG |  |  |  |  |  |  |
| 959 | 1.4.1.4.3.1 | **Test Approach & Plan** |  | 75d | 2023-09-07 A | 2023-12-20 A |  | 100% | 2023-09-07 | 2023-12-20 | 75d | 2023-09-07 | 2023-12-20 |  | -0 | N/A | N/A | SIT | 5.0 |  | Systems Integration Testing (SIT) | SITAG |  |  |  |  |  |  |
| 960 | 1.4.1.4.3.1.1 | Develop document with SITWG |  | 32d | 2023-09-07 A | 2023-10-20 A | 3066 | 100% | 2023-09-07 | 2023-10-20 | 25d | 2023-09-07 | 2023-10-11 | finish no earlier than 2023-10-11 |  | SI Test |  | SIT | 5.0 |  | Systems Integration Testing (SIT) | SITAG | Complete | COMPLETE |  |  |  |  |
| 961 | 1.4.1.4.3.1.2 | Draft document review with Code Bodies |  | 8d | 2023-10-23 A | 2023-11-01 A | 960 | 100% | 2023-10-23 | 2023-11-01 | 10d | 2023-10-12 | 2023-10-25 |  |  | SI Test | Code Bodies | SIT | 5.0 |  | Systems Integration Testing (SIT) | SITAG | Complete | COMPLETE |  |  |  |  |
| 962 | 1.4.1.4.3.1.3 | Industry Consultation |  | 10d | 2023-11-02 A | 2023-11-15 A | 961 | 100% | 2023-11-02 | 2023-11-15 | 10d |  |  |  |  | PP |  | SIT | 5.1 |  | Systems Integration Testing (SIT) | SITAG | Complete | COMPLETE |  |  |  |  |
| 963 | 1.4.1.4.3.1.4 | Artefact review (via TMAG) and updates |  | 25d | 2023-11-16 A | 2023-12-20 A | 962 | 100% | 2023-11-16 | 2023-12-20 | 30d | 2023-10-26 | 2023-12-20 |  |  | SI Test | PP,IPA,Code Bodies | SIT | 5.0 |  | Systems Integration Testing (SIT) | SITAG | Complete | COMPLETE |  |  |  |  |
| 964 | 1.4.1.4.3.1.5 | SIT Migration Testing Test Approach & Plan approved | milestone | 0d | 2023-12-20 A | 2023-12-20 A | 963 | 100% | 2023-12-20 | 2023-12-20 | 1d | 2023-12-20 | 2023-12-20 | finish no earlier than 2023-12-20 |  | SI Test | PP | SIT | 5.14 |  | Systems Integration Testing (SIT) | SITAG | Complete | COMPLETE | T3-TE-0018 | T3 | MHHS-ART073 |  |
| 965 | 1.4.1.4.3.2 | **Test Data Approach & Plan** |  | 35d | 2023-11-02 A | 2023-12-20 A |  | 100% | 2023-11-02 | 2023-12-20 | 35d | 2023-10-26 | 2023-12-20 |  | -0 | N/A | N/A | SIT | 5.0 | N/A | Systems Integration Testing (SIT) | SITAG |  |  |  |  |  |  |
| 966 | 1.4.1.4.3.2.1 | Industry Consultation |  | 10d | 2023-11-02 A | 2023-11-15 A | 962SS | 100% | 2023-11-02 | 2023-11-15 | 10d |  |  |  |  | PP |  | SIT | 5.1 | PP | Systems Integration Testing (SIT) | SITAG | Complete | COMPLETE |  |  |  |  |
| 967 | 1.4.1.4.3.2.2 | Artefact review (via TMAG) and updates |  | 25d | 2023-11-16 A | 2023-12-20 A | 966 | 100% | 2023-11-16 | 2023-12-20 | 30d | 2023-10-26 | 2023-12-20 |  |  | SI Test Data |  | SIT | 5.0 | Michael Inije | Systems Integration Testing (SIT) | SITAG | Complete | COMPLETE |  |  |  |  |
| 968 | 1.4.1.4.3.2.3 | SIT Migration Test Data Test Approach & Plan approved | milestone | 0d | 2023-12-20 A | 2023-12-20 A | 967 | 100% | 2023-12-20 | 2023-12-20 | 0d | 2023-12-20 | 2023-12-20 |  |  | SI Test Data | PP,IPA | SIT | 5.14 | Michael Inije | Systems Integration Testing (SIT) | SITAG | Complete | COMPLETE |  |  |  |  |
| 969 | 1.4.1.4.3.3 | **Test scenarios & Test Cases** |  | 297d? | 2023-12-21 A | 2025-02-07 A |  | 100% | 2023-12-21 | 2024-10-04 | 65d | 2023-07-24 | 2024-01-17 |  | -0 | N/A | N/A | SIT | 5.16 | N/A | Systems Integration Testing (SIT) | SITAG |  |  |  |  |  |  |
| 970 | 1.4.1.4.3.3.1 | **Theme 1** |  | 65d | 2023-12-21 A | 2024-03-20 A |  | 100% | 2023-12-21 | 2024-03-20 | 65d |  |  |  | -0 | N/A | N/A | SIT | 5.16 | N/A | Systems Integration Testing (SIT) | SITAG |  |  |  |  |  | -448.67 |
| 971 | 1.4.1.4.3.3.1.1 | Develop Test Scenarios & Test Cases |  | 25d | 2023-12-21 A | 2024-01-24 A | 964 | 100% | 2023-12-21 | 2024-01-24 | 25d |  |  |  |  | SI Test | SI Test, PP | SIT | 5.16 |  |  | SITAG | Complete | COMPLETE |  |  |  |  |
| 972 | 1.4.1.4.3.3.1.2 | Industry Review Workshop |  | 1d | 2024-01-25 A | 2024-01-25 A | 971 | 100% | 2024-01-25 | 2024-01-25 | 1d |  |  |  |  | SI Test, PP | SI Test, PP | SIT | 5.16 |  |  | SITAG | Complete | COMPLETE |  |  |  |  |
| 973 | 1.4.1.4.3.3.1.3 | Industry Consultation Review |  | 6d | 2024-02-05 A | 2024-02-12 A | 972FS+6d | 100% | 2024-02-05 | 2024-02-12 | 6d |  |  |  |  | SI Test, PP | SI Test, PP | SIT | 5.16 |  |  | SITAG | Complete | COMPLETE |  |  |  |  |
| 974 | 1.4.1.4.3.3.1.4 | Review with SIT Working Group |  | 5d | 2024-02-29 A | 2024-03-06 A | 973FS+12d | 100% | 2024-02-29 | 2024-03-06 | 5d |  |  |  |  | SI Test, PP | SI Test, PP | SIT | 5.19 |  |  | SITAG | Complete | COMPLETE |  |  |  |  |
| 975 | 1.4.1.4.3.3.1.5 | SIT Migration Test scenarios & Test Cases Approved - Theme 1 | milestone | 0d | 2024-03-20 A | 2024-03-20 A | 974FS+10d | 100% | 2024-03-20 | 2024-03-20 | 0d |  |  |  |  | SI Test | SI Test, PP | SIT | 5.21 |  | Systems Integration Testing (SIT) | SITAG | Complete | COMPLETE | T3-TE-0110 | T3 |  |  |
| 976 | 1.4.1.4.3.3.2 | **Theme 2** |  | 85d | 2023-12-21 A | 2024-04-17 A |  | 100% | 2023-12-21 | 2024-04-17 | 85d |  |  |  | -0 | N/A | N/A | SIT | 5.16 | N/A | Systems Integration Testing (SIT) | SITAG |  |  |  |  |  | -448.67 |
| 977 | 1.4.1.4.3.3.2.1 | Develop Test Scenarios & Test Cases |  | 40d | 2023-12-21 A | 2024-02-14 A | 964 | 100% | 2023-12-21 | 2024-02-14 | 40d |  |  |  |  | SI Test | SI Test, PP | SIT | 5.16 |  |  | SITAG | Complete | COMPLETE |  |  |  |  |
| 978 | 1.4.1.4.3.3.2.2 | Industry Review Workshop |  | 1d | 2024-02-15 A | 2024-02-15 A | 977 | 100% | 2024-02-15 | 2024-02-15 | 1d |  |  |  |  | SI Test, PP | SI Test, PP | SIT | 5.16 |  |  | SITAG | Complete | COMPLETE |  |  |  |  |
| 979 | 1.4.1.4.3.3.2.3 | Industry Consultation Review |  | 6d | 2024-02-26 A | 2024-03-04 A | 978FS+6d | 100% | 2024-02-26 | 2024-03-04 | 6d |  |  |  |  | SI Test, PP | SI Test, PP | SIT | 5.19 |  |  | SITAG | Complete | COMPLETE |  |  |  |  |
| 980 | 1.4.1.4.3.3.2.4 | Review with SIT Working Group |  | 5d | 2024-03-28 A | 2024-04-03 A | 979FS+17d | 100% | 2024-03-28 | 2024-04-03 | 5d |  |  |  |  | SI Test, PP | SI Test, PP | SIT | 5.16 |  |  | SITAG | Complete | COMPLETE |  |  |  |  |
| 981 | 1.4.1.4.3.3.2.5 | SIT Migration Test scenarios & Test Cases Approved - Theme 2 | milestone | 0d | 2024-04-17 A | 2024-04-17 A | 980FS+10d | 100% | 2024-04-17 | 2024-04-17 | 0d |  |  |  |  | SI Test | SI Test, PP | SIT | 5.22 |  | Systems Integration Testing (SIT) | SITAG | Complete | COMPLETE | T3-TE-0111 | T3 |  |  |

| ID | WBS | Task | Type | Duration | Start | Finish | Predecessors | Complete | Baseline start | Baseline finish | Baseline duration | Constraint | Baseline cost | Responsible | Involved | Text9 | Task Status | Update Version | MHHS Resource Name | MHHS Programme Phase | Text29 | Sched Status | RAG | Milestone ID | Tier |
| --- | --- | --- | --- | --- | --- | --- | --- | --- | --- | --- | --- | --- | --- | --- | --- | --- | --- | --- | --- | --- | --- | --- | --- | --- | --- |
| 982 | 1.4.1.4.3.3.3 | **Theme 3** |  | 85d | 2023-12-21 A | 2024-04-17 A |  | 100% | 2023-12-21 | 2024-04-17 | 85d |  | -0 | N/A | N/A | SIT | -448.67 | 5.16 | N/A | Systems Integration Testing (SIT) | SITAG |  |  |  |  |
| 983 | 1.4.1.4.3.3.3.1 | Develop Test Scenarios & Test Cases |  | 55d | 2023-12-21 A | 2024-03-06 A | 964 | 100% | 2023-12-21 | 2024-03-06 | 55d |  |  | SI Test | SI Test, PP | SIT |  | 5.19 |  |  | SITAG | Complete | COMPLETE |  |  |
| 984 | 1.4.1.4.3.3.3.2 | Industry Review Workshop |  | 1d | 2024-03-07 A | 2024-03-07 A | 983 | 100% | 2024-03-07 | 2024-03-07 | 1d |  |  | SI Test, PP | SI Test, PP | SIT |  | 5.16 |  |  | SITAG | Complete | COMPLETE |  |  |
| 985 | 1.4.1.4.3.3.3.3 | Industry Consultation Review |  | 6d | 2024-03-13 A | 2024-03-20 A | 984FS+3d | 100% | 2024-03-13 | 2024-03-20 | 6d |  |  | SI Test, PP | SI Test, PP | SIT |  | 5.16 |  |  | SITAG | Complete | COMPLETE |  |  |
| 986 | 1.4.1.4.3.3.3.4 | Review with SIT Working Group |  | 5d | 2024-03-28 A | 2024-04-03 A | 985FS+5d | 100% | 2024-03-28 | 2024-04-03 | 5d |  |  | SI Test, PP | SI Test, PP | SIT |  | 5.16 |  |  | SITAG | Complete | COMPLETE |  |  |
| 987 | 1.4.1.4.3.3.3.5 | SIT Migration Test scenarios & Test Cases Approved - Theme 3 | milestone | 0d | 2024-04-17 A | 2024-04-17 A | 986FS+10d | 100% | 2024-04-17 | 2024-04-17 | 0d |  |  | SI Test | SI Test, PP | SIT |  | 5.22 |  | Systems Integration Testing (SIT) | SITAG | Complete | COMPLETE | T3-TE-0112 | T3 |
| 988 | 1.4.1.4.3.3.4 | **RTTM Development** |  | 17d | 2024-08-29 A | 2024-09-20 A |  | 100% | 2024-08-29 | 2024-10-04 | 0d |  |  | SI Test |  | SIT | -693.67 | 6.0 | Ankur Pande |  | SITAG |  |  |  |  |
| 989 | 1.4.1.4.3.3.4.1 | Develop Manual SIT Migration RTTM |  | 17d | 2024-08-29 A | 2024-09-20 A |  | 100% | 2024-08-29 | 2024-09-20 | 0d | start no earlier than 2024-08-29 |  | SI Test |  | SIT |  | 6.0 | Ankur Pande |  | SITAG | Complete | COMPLETE |  |  |
| 990 | 1.4.1.4.3.3.4.2 | Manual SIT Migration RTTM Complete | milestone | 0d | 2024-09-20 A | 2024-09-20 A | 989 | 100% | 2024-09-20 | 2024-09-20 | 0d |  |  | SI Test |  | SIT |  | 6.0 | Ankur Pande |  | SITAG | Complete | COMPLETE |  |  |
| 991 | 1.4.1.4.3.3.5 | **Gap analysis** |  | 107d? | 2024-09-12 A | 2025-02-07 A |  | 100% | 2024-09-12 | 2024-10-04 | 0d |  |  | SI Test |  | SIT | -693.67 | 6.0 | Ankur Pande |  | SITAG |  |  |  |  |
| 992 | 1.4.1.4.3.3.5.1 | Identify gaps in test case coverage following RTTM review. |  | 12d | 2024-09-12 A | 2024-09-27 A | 989SS+10d | 100% | 2024-09-12 | 2024-09-27 | 0d |  |  | SI Test |  | SIT |  | 6.0 | Ankur Pande |  | SITAG | Complete | COMPLETE |  |  |
| 993 | 1.4.1.4.3.3.5.2 | Address gaps in test case coverage following RTTM review. |  | 17d | 2024-09-19 A | 2024-10-11 A | 992SS+5d | 100% | 2024-09-19 | 2024-10-04 | 0d |  |  | SI Test |  | SIT |  | 6.0 | Ankur Pande |  | SITAG | Complete | COMPLETE |  |  |
| 994 | 1.4.1.4.3.3.5.3 | Gap analysis complete | milestone | 0d? | 2024-10-11 A | 2024-10-11 A | 993 | 100% | 2024-10-04 | 2024-10-04 | 0d |  |  | SI Test |  | SIT |  | 6.0 | Ankur Pande |  | SITAG | Complete | COMPLETE |  |  |
| 995 | 1.4.1.4.3.3.5.4 | Test Script updates identified |  | 1d? | 2024-10-14 A | 2024-10-14 A | 994 | 100% | 2024-10-14 | 2024-10-14 | 0d |  |  | SI Test |  | SIT |  | 6.11 | Ankur Pande |  | SITAG | Complete | COMPLETE |  |  |
| 996 | 1.4.1.4.3.3.5.5 | Test Scripts updates |  | 16d? | 2024-10-14 A | 2024-11-04 A | 995FS-1d | 100% | 2024-10-14 | 2024-11-04 | 0d |  |  | SI Test |  | SIT |  | 6.11 | Ankur Pande |  | SITAG | Complete | COMPLETE |  |  |
| 997 | 1.4.1.4.3.3.5.6 | RTTM Updated |  | 1d? | 2024-10-29 A | 2024-10-29 A | 996FS-5d | 100% | 2024-10-29 | 2024-10-29 | 0d |  |  | SI Test |  | SIT |  | 6.11 | Ankur Pande |  | SITAG | Complete | COMPLETE |  |  |
| 998 | 1.4.1.4.3.3.5.7 | Removal of de-scoped TCs from the RTTMs |  | 2d | 2024-10-31 A | 2024-11-01 A | 996FS-3d | 100% | 2024-10-31 | 2024-11-01 | 0d |  |  | SI Test |  | SIT |  | 6.11 | Ankur Pande |  | SITAG | Complete | COMPLETE |  |  |
| 999 | 1.4.1.4.3.3.5.8 | Update and stabilisation of all TC ADO IDs |  | 2d | 2024-10-31 A | 2024-11-01 A | 996FS-3d | 100% | 2024-10-31 | 2024-11-01 | 0d |  |  | SI Test |  | SIT |  | 6.11 | Ankur Pande |  | SITAG | Complete | COMPLETE |  |  |
| 1000 | 1.4.1.4.3.3.5.9 | Addition and integration of Role tags to reqs in the Role RTTMs |  | 3d | 2024-10-30 A | 2024-11-01 A | 996FS-4d | 100% | 2024-10-30 | 2024-11-01 | 0d |  |  | SI Test |  | SIT |  | 6.11 | Ankur Pande |  | SITAG | Complete | COMPLETE |  |  |
| 1001 | 1.4.1.4.3.3.5.10 | Update of the RTTM All sheet (porting of the individual RTTMs) |  | 2d | 2024-10-31 A | 2024-11-01 A | 996FS-3d | 100% | 2024-10-31 | 2024-11-01 | 0d |  |  | SI Test |  | SIT |  | 6.11 | Ankur Pande |  | SITAG | Complete | COMPLETE |  |  |
| 1002 | 1.4.1.4.3.3.5.11 | ADO IDs corrected |  | 1d? | 2024-11-04 A | 2024-11-04 A | 1001 | 100% | 2024-11-04 | 2024-11-04 | 0d | start no earlier than 2024-10-16 |  | SI Test |  | SIT |  | 6.11 | Ankur Pande |  | SITAG | Complete | COMPLETE |  |  |
| 1003 | 1.4.1.4.3.3.5.12 | Migration RTTM ready for import into ADO | milestone | 0d | 2024-11-04 A | 2024-11-04 A | 1002 | 100% | 2024-11-04 | 2024-11-04 | 0d |  |  | SI Test |  | SIT |  | 6.11 | Ankur Pande |  | SITAG | Complete | COMPLETE |  |  |
| 1004 | 1.4.1.4.3.3.5.13 | Issue Static RTTM to Code Bodies |  | 1d? | 2024-11-05 A | 2024-11-05 A | 1003 | 100% | 2024-11-05 | 2024-11-05 | 0d |  |  | SI Test |  | SIT |  | 6.11 | Ankur Pande |  | SITAG | Complete | COMPLETE |  |  |
| 1005 | 1.4.1.4.3.3.5.14 | Implement Code Bodies feedback on RTTM |  | 6d | 2024-11-06 A | 2024-11-13 A | 1004 | 100% | 2024-11-06 | 2024-11-13 | 0d |  |  | SI Test |  | SIT |  | 6.12 | Ankur Pande |  | SITAG | Complete | COMPLETE |  |  |
| 1006 | 1.4.1.4.3.3.5.15 | Code Body Acceptance of RTTM | milestone | 0d | 2024-11-13 A | 2024-11-13 A | 1004, 1005 | 100% | 2024-11-06 | 2024-11-13 | 0d |  |  | SI Test |  | SIT |  | 6.11 | Ankur Pande |  | SITAG | Complete | COMPLETE |  |  |

| ID | WBS | Task | Type | Duration | Start | Finish | Predecessors | Complete | Actual start | Baseline start | Baseline finish | Baseline duration | Constraint | Responsible | Text9 | Task Status | Update Version | MHHS Resource Name | Text29 | Sched Status | RAG | Milestone ID | Tier |
| --- | --- | --- | --- | --- | --- | --- | --- | --- | --- | --- | --- | --- | --- | --- | --- | --- | --- | --- | --- | --- | --- | --- | --- |
| 1007 | 1.4.1.4.3.3.5.16 | **ADO Clean-up** |  | 17d? | 2024-10-24 | 2024-11-15 A |  | 100% | 2024-10-25 | 2024-10-24 | 2024-11-15 | 0d |  | SI Test | SIT | -727.67 | 6.11 | Heath Thomas | SITAG |  |  |  |  |
| 1008 | 1.4.1.4.3.3.5.16.1 | Theme alignment |  | 1d? | 2024-10-28 A | 2024-10-28 A |  | 100% |  | 2024-10-28 | 2024-10-28 | 0d | start no earlier than 2024-10-28 | SI Test | SIT |  | 6.11 | Heath Thomas | SITAG | Complete | COMPLETE |  |  |
| 1009 | 1.4.1.4.3.3.5.16.2 | Understand Additional suffix Fields in ADO as defined by Kevin |  | 1d? | 2024-10-25 A | 2024-10-25 A |  | 100% |  | 2024-10-25 | 2024-10-25 | 0d | finish no earlier than 2024-10-25 | SI Test | SIT |  | 6.11 | Heath Thomas | SITAG | Complete | COMPLETE |  |  |
| 1010 | 1.4.1.4.3.3.5.16.3 | Correct Missing Test Case References |  | 1d? | 2024-10-28 A | 2024-10-28 A |  | 100% |  | 2024-10-28 | 2024-10-28 | 0d | start no earlier than 2024-10-28 | SI Test | SIT |  | 6.11 | Heath Thomas | SITAG | Complete | COMPLETE |  |  |
| 1011 | 1.4.1.4.3.3.5.16.4 | Load Functional RTTMs into ADO |  | 1d? | 2024-10-28 A | 2024-10-28 A |  | 100% |  | 2024-10-28 | 2024-10-28 | 0d | start no earlier than 2024-10-28 | SI Test | SIT |  | 6.11 | Heath Thomas | SITAG | Complete | COMPLETE |  |  |
| 1012 | 1.4.1.4.3.3.5.16.5 | Load Migration RTTMs into ADO |  | 1d? | 2024-11-06 A | 2024-11-06 A |  | 100% |  | 2024-11-06 | 2024-11-06 | 0d | start no earlier than 2024-11-06 | SI Test | SIT |  | 6.11 | Heath Thomas | SITAG | Complete | COMPLETE |  |  |
| 1013 | 1.4.1.4.3.3.5.16.6 | Confirm Missing fields in ADO are resolved |  | 1d? | 2024-11-07 A | 2024-11-07 A |  | 100% |  | 2024-11-07 | 2024-11-07 | 0d | finish no earlier than 2024-11-07 | SI Test | SIT |  | 6.11 | Heath Thomas | SITAG | Complete | COMPLETE |  |  |
| 1014 | 1.4.1.4.3.3.5.16.7 | Reload Functional RTTM into ADO |  | 1d? | 2024-11-07 A | 2024-11-07 A |  | 100% |  | 2024-11-07 | 2024-11-07 | 0d | start no earlier than 2024-11-07 | SI Test | SIT |  | 6.11 | Heath Thomas | SITAG | Complete | COMPLETE |  |  |
| 1015 | 1.4.1.4.3.3.5.16.8 | **ADO Design Documentation** |  | 10d? | 2024-11-04 | 2024-11-15 A |  | 100% | 2024-11-15 | 2024-11-04 | 2024-11-15 | 0d |  | SI Test | SIT | -727.67 | 6.11 | Heath Thomas | SITAG |  |  |  |  |
| 1016 | 1.4.1.4.3.3.5.16.8.1 | Produce ADO high Level Design and Data Model |  | 1d? | 2024-11-15 A | 2024-11-15 A |  | 100% |  | 2024-11-15 | 2024-11-15 | 0d | finish no earlier than 2024-11-15 | SI Test | SIT |  | 6.11 | Heath Thomas | SITAG | Complete | COMPLETE |  |  |
| 1017 | 1.4.1.4.3.3.5.16.8.2 | Produce Report derivation document |  | 1d? | 2024-11-15 A | 2024-11-15 A |  | 100% |  | 2024-11-15 | 2024-11-15 | 0d | finish no earlier than 2024-11-15 | SI Test | SIT |  | 6.11 | Heath Thomas | SITAG | Complete | COMPLETE |  |  |
| 1018 | 1.4.1.4.3.3.5.17 | **Test Case Rationalisation (Functional + Migration)** |  | 67d | 2024-11-07 A | 2025-02-07 A |  | 100% |  | 2024-11-07 | 2024-12-20 | 0d |  | SI Test | SIT | -727.67 | 6.11 | Roger Robar | SITAG |  |  |  |  |
| 1019 | 1.4.1.4.3.3.5.17.1 | Internal preliminary rationalisation workshop 1 |  | 1d | 2024-11-07 A | 2024-11-07 A | 1004FS+1d | 100% |  | 2024-11-07 | 2024-11-07 | 0d |  | SI Test | SIT |  | 6.11 | Roger Robar | SITAG | Complete | COMPLETE |  |  |
| 1020 | 1.4.1.4.3.3.5.17.2 | Baseline RTTMs | milestone | 0d | 2024-11-13 A | 2024-11-13 A | 1006, 874 | 100% |  | 2024-11-13 | 2024-11-13 | 0d |  | SI Test | SIT |  | 6.11 | Roger Robar | SITAG | Complete | COMPLETE |  |  |
| 1021 | 1.4.1.4.3.3.5.17.3 | Baseline test cases | milestone | 0d | 2024-11-13 A | 2024-11-13 A | 1006 | 100% |  | 2024-11-13 | 2024-11-13 | 0d |  | SI Test | SIT |  | 6.11 | Roger Robar | SITAG | Complete | COMPLETE |  |  |
| 1022 | 1.4.1.4.3.3.5.17.4 | Produce requirements / test case analysis doc |  | 1d | 2024-11-14 A | 2024-11-14 A | 1021 | 100% |  | 2024-11-14 | 2024-11-14 | 0d |  | SI Test | SIT |  | 6.11 | Roger Robar | SITAG | Complete | COMPLETE |  |  |
| 1023 | 1.4.1.4.3.3.5.17.5 | Internal finalisation rationalisation workshop 2 |  | 13d | 2024-11-15 A | 2024-12-03 A | 1022 | 100% |  | 2024-11-15 | 2024-12-03 | 0d |  | SI Test | SIT |  | 6.17 | Roger Robar | SITAG | Complete | COMPLETE |  |  |
| 1024 | 1.4.1.4.3.3.5.17.6 | SRO walkthrough |  | 1d | 2024-12-04 A | 2024-12-04 A | 1023 | 100% |  | 2024-12-04 | 2024-12-04 | 0d |  | SI Test | SIT |  | 6.17 | Roger Robar | SITAG | Complete | COMPLETE |  |  |
| 1025 | 1.4.1.4.3.3.5.17.7 | Code Bodies walkthrough |  | 1d | 2024-12-04 A | 2024-12-04 A | 1023 | 100% |  | 2024-12-04 | 2024-12-04 | 0d |  | SI Test | SIT |  | 6.17 | Roger Robar | SITAG | Complete | COMPLETE |  |  |
| 1026 | 1.4.1.4.3.3.5.17.8 | Send invites to PPs for walkthrough |  | 1d | 2024-12-04 A | 2024-12-04 A | 1025FS-1d | 100% |  | 2024-12-04 | 2024-12-04 | 0d |  | SI Test | SIT |  | 6.17 | Roger Robar | SITAG | Complete | COMPLETE |  |  |
| 1027 | 1.4.1.4.3.3.5.17.9 | PP walkthrough |  | 1d | 2024-12-17 A | 2024-12-17 A | 1026FS+8d | 100% |  | 2024-12-17 | 2024-12-17 | 0d |  | SI Test | SIT |  | 6.17 | Roger Robar | SITAG | Complete | COMPLETE |  |  |
| 1028 | 1.4.1.4.3.3.5.17.10 | Update requirements / test case analysis doc |  | 29d | 2024-12-05 A | 2025-01-14 A | 1026 | 100% |  | 2024-12-05 | 2025-01-14 | 0d |  | SI Test | SIT |  | 6.17 | Roger Robar | SITAG | Complete | COMPLETE |  |  |
| 1029 | 1.4.1.4.3.3.5.17.11 | SITWG Paper Day | milestone | 0d | 2025-01-14 A | 2025-01-14 A | 1028 | 100% |  | 2025-01-14 | 2025-01-14 | 0d |  | SI Test | SIT |  | 6.17 | Roger Robar | SITAG | Complete | COMPLETE |  |  |
| 1030 | 1.4.1.4.3.3.5.17.12 | SITWG recommendation on requirements / test case analysis doc | milestone | 0d | 2025-01-21 A | 2025-01-21 A | 1029FS+5d | 100% |  | 2025-01-21 | 2025-01-21 | 0d |  | SI Test | SIT |  | 6.17 | Roger Robar | SITAG | Complete | COMPLETE |  |  |
| 1031 | 1.4.1.4.3.3.5.17.13 | Issue to SITAG / SITAG paper day | milestone | 0d | 2025-01-22 A | 2025-01-22 A | 1030FS+1d | 100% |  | 2025-01-22 | 2025-01-22 | 0d |  | SI Test | SIT |  | 6.17 | Roger Robar | SITAG | Complete | COMPLETE |  |  |
| 1032 | 1.4.1.4.3.3.5.17.14 | Prepare ADO update |  | 6d | 2025-01-22 A | 2025-01-29 A | 1030 | 100% |  | 2025-01-22 | 2025-01-29 | 0d |  | SI Test | SIT |  | 6.17 | Roger Robar | SITAG | Complete | COMPLETE |  |  |
| 1033 | 1.4.1.4.3.3.5.17.15 | Sign off by SITAG | milestone | 0d | 2025-01-29 A | 2025-01-29 A | 1031FS+5d | 100% |  | 2025-01-29 | 2025-01-29 | 0d |  | SI Test | SIT |  | 6.17 | Roger Robar | SITAG | Complete | COMPLETE |  |  |
| 1034 | 1.4.1.4.3.3.5.17.16 | Update ADO |  | 7d | 2025-01-30 A | 2025-02-07 A | 1033 | 100% |  | 2025-01-30 | 2025-02-07 | 0d |  | SI Test | SIT |  | 6.17 | Roger Robar | SITAG | Complete | COMPLETE |  |  |
| 1035 | 1.4.1.4.3.3.5.17.17 | Update all ADO reporting |  | 7d | 2025-01-30 A | 2025-02-07 A | 1033 | 100% |  | 2025-01-30 | 2025-02-07 | 0d |  | SI Test | SIT |  | 6.17 | Roger Robar | SITAG | Complete | COMPLETE |  |  |
| 1036 | 1.4.1.4.3.3.5.17.18 | Update test cases |  | 7d | 2025-01-30 A | 2025-02-07 A | 1033 | 100% |  | 2025-01-30 | 2025-02-07 | 0d |  | SI Test | SIT |  | 6.17 | Roger Robar | SITAG | Complete | COMPLETE |  |  |
| 1037 | 1.4.1.4.3.3.5.17.19 | Update RTTM |  | 7d | 2025-01-30 A | 2025-02-07 A | 1033 | 100% |  | 2025-01-30 | 2025-02-07 | 0d |  | SI Test | SIT |  | 6.17 | Roger Robar | SITAG | Complete | COMPLETE |  |  |
| 1038 | 1.4.1.4.3.3.5.17.20 | Update master test case spreadsheet |  | 7d | 2025-01-30 A | 2025-02-07 A | 1033 | 100% |  | 2025-01-30 | 2025-02-07 | 0d |  | SI Test | SIT |  | 6.17 | Roger Robar | SITAG | Complete | COMPLETE |  |  |
| 1039 | 1.4.1.4.3.3.5.17.21 | Test Case Rationalisation complete | milestone | 0d | 2025-02-07 A | 2025-02-07 A | 1034, 1035, 1033, 1036, 1037, 1038 | 100% |  | 2025-02-07 | 2025-02-07 | 0d |  | SI Test | SIT |  | 6.17 | Roger Robar | SITAG | Complete | COMPLETE | T3-TE-0141 | T3 |

| ID | WBS | Task | Type | Duration | Start | Finish | Predecessors | Complete | Baseline start | Baseline finish | Baseline duration | Baseline 1 start | Baseline 1 finish | Constraint | Baseline cost | Responsible | Involved | Text9 | Update Version | MHHS Resource Name | MHHS Programme Phase | Text29 | Sched Status | RAG | Milestone ID | Tier | Artefact ID | Guidance |
| --- | --- | --- | --- | --- | --- | --- | --- | --- | --- | --- | --- | --- | --- | --- | --- | --- | --- | --- | --- | --- | --- | --- | --- | --- | --- | --- | --- | --- |
| 1040 | 1.4.1.4.3.4 | **Environments (SIT B)** |  | 435d | 2022-10-31 A | 2024-06-28 A |  | 100% | 2022-10-31 | 2024-06-28 | 420d | 2022-11-16 | 2024-05-13 |  | -0 | N/A | N/A | SIT | 5.0 | N/A | Systems Integration Testing (SIT) | SITAG |  |  |  |  |  |  |
| 1041 | 1.4.1.4.3.4.1 | **PP Environments (SIT B)** |  | 41d | 2024-05-03 A | 2024-06-28 A |  | 100% | 2024-05-03 | 2024-06-28 | 26d | 2022-11-16 | 2024-05-13 |  | -0 | N/A | N/A | SIT | 5.0 | N/A | Systems Integration Testing (SIT) | SITAG |  |  |  |  |  |  |
| 1042 | 1.4.1.4.3.4.1.1 | PP Environments available | milestone | 0d | 2024-05-03 A | 2024-05-03 A | 511 | 100% | 2024-05-03 | 2024-05-03 | 0d | 2022-11-16 | 2024-04-01 | start no earlier than 2024-05-03 |  | PP | SI Test | SIT | 5.21 | Simon Berry | Systems Integration Testing (SIT) | SITAG | Complete | COMPLETE |  |  |  |  |
| 1043 | 1.4.1.4.3.4.1.2 | PP Onboarding / Smoke test |  | 35d | 2024-05-13 A | 2024-06-28 A | 1042FS+6d | 100% | 2024-05-13 | 2024-06-28 | 20d | 2022-11-16 | 2024-04-01 |  |  | PP | SI Test | SIT | 5.21 | Simon Berry | Systems Integration Testing (SIT) | SITAG | Complete | COMPLETE |  |  |  |  |
| 1044 | 1.4.1.4.3.4.1.3 | DTN Connectivity Proving Complete |  | 5d | 2024-06-10 A | 2024-06-14 A | 1042FS+26d | 100% | 2024-06-10 | 2024-06-14 | 0d | 2024-04-15 | 2024-04-26 |  |  | PP | SI Test | SIT | 5.21 | Simon Berry | Systems Integration Testing (SIT) | SITAG | Complete | COMPLETE |  |  |  |  |
| 1045 | 1.4.1.4.3.4.1.4 | PP Code Deployment | milestone | 0d | 2024-06-14 A | 2024-06-14 A | 1044 | 100% | 2024-06-14 | 2024-06-14 | 0d | 2024-04-29 | 2024-05-13 |  |  | PP | SI Test | SIT | 5.21 | Simon Berry | Systems Integration Testing (SIT) | SITAG | Complete | COMPLETE |  |  |  |  |
| 1046 | 1.4.1.4.3.4.2 | **SI Environments (SIT B)** |  | 425d | 2022-10-31 A | 2024-06-14 A |  | 100% | 2022-10-31 | 2024-06-14 | 420d | 2022-11-16 | 2024-05-10 |  | -0 | N/A | N/A | SIT | 5.0 | N/A | Systems Integration Testing (SIT) | SITAG |  |  |  |  |  |  |
| 1047 | 1.4.1.4.3.4.2.1 | Coordinate SIT Participants' SIT B environment preparation |  | 420d | 2022-10-31 A | 2024-06-07 A |  | 100% | 2022-10-31 | 2024-06-07 | 420d | 2022-11-16 | 2024-04-01 |  |  | SI Test | PP | SIT | 5.21 | Simon Berry | Systems Integration Testing (SIT) | SITAG | Complete | COMPLETE |  |  |  |  |
| 1048 | 1.4.1.4.3.4.2.2 | Assure PPs' self-declaration of environment preparation complete (incl. security certificates and security compliance) | milestone | 0d | 2024-06-07 A | 2024-06-07 A | 1047 | 100% | 2024-06-07 | 2024-06-07 | 0d | 2022-11-16 | 2024-03-29 |  |  | SI Test | PP | SIT | 5.21 | Simon Berry | Systems Integration Testing (SIT) | SITAG | Complete | COMPLETE |  |  |  |  |
| 1049 | 1.4.1.4.3.4.2.3 | SIT Participants' SIT B environments ready to start connectivity proving (incl. certificates and security compliance) | milestone | 0d | 2024-06-05 A | 2024-06-05 A | 1042FS+24d | 100% | 2024-06-05 | 2024-06-05 | 0d | 2024-04-01 | 2024-04-01 |  |  | SI Test | PP,IPA | SIT | 5.26 | Simon Berry | Systems Integration Testing (SIT) | SITAG | Complete | COMPLETE | T3-TE-0033 | T3 |  |  |
| 1050 | 1.4.1.4.3.4.2.4 | Coordinate SIT Participants' SIT B environment connectivity proving |  | 2d | 2024-06-06 A | 2024-06-07 A | 1049 | 100% | 2024-06-06 | 2024-06-07 | 19d | 2024-04-01 | 2024-04-26 |  |  | SI Test | PP | SIT | 5.21 | Simon Berry | Systems Integration Testing (SIT) | SITAG | Complete | COMPLETE |  |  |  |  |
| 1051 | 1.4.1.4.3.4.2.5 | Coordinate deployment of MHHS solution code to SIT Participants' SIT B environments | milestone | 0d | 2024-06-14 A | 2024-06-14 A | 1045 | 100% | 2024-06-14 | 2024-06-14 | 4d | 2024-04-15 | 2024-04-26 |  |  | SI Test | PP | SIT | 5.21 | Simon Berry | Systems Integration Testing (SIT) | SITAG | Complete | COMPLETE |  |  |  |  |
| 1052 | 1.4.1.4.3.5 | **SIT Migration Test Readiness Report** |  | 44d | 2024-04-02 A | 2024-05-31 A |  | 100% | 2024-04-02 | 2024-05-31 | 44d | 2024-04-02 | 2024-05-27 |  | -0 | N/A | N/A | SIT | 5.0 | N/A | Systems Integration Testing (SIT) | SITAG |  |  |  |  |  |  |
| 1053 | 1.4.1.4.3.5.1 | **PP SIT Migration Test Readiness Report** |  | 44d | 2024-04-02 A | 2024-05-31 A |  | 100% | 2024-04-02 | 2024-05-31 | 44d | 2024-04-02 | 2024-05-13 |  | -0 | N/A | N/A | SIT | 5.0 | N/A | Systems Integration Testing (SIT) | SITAG |  |  |  |  |  |  |
| 1054 | 1.4.1.4.3.5.1.1 | Develop draft Test Readiness Report and submit to Programme for assurance |  | 20d | 2024-04-02 A | 2024-04-29 A |  | 100% | 2024-04-02 | 2024-04-29 | 20d | 2024-04-02 | 2024-04-30 | start no earlier than 2024-04-02 |  | PP | SI Test | SIT | 5.0 |  | Systems Integration Testing (SIT) | SITAG | Complete | COMPLETE |  |  |  |  |
| 1055 | 1.4.1.4.3.5.1.2 | Placing Reliance Stage 2 Review |  | 35d | 2024-04-15 A | 2024-05-31 A | 1054SS+9d | 100% | 2024-04-15 | 2024-05-31 | 35d |  |  |  |  | SI Test | PP | SIT | 5.12 |  | Systems Integration Testing (SIT) | SITAG | Complete | COMPLETE |  |  |  |  |
| 1056 | 1.4.1.4.3.5.1.3 | Finalise Test Readiness Report and submit to Programme for assurance |  | 10d | 2024-04-30 A | 2024-05-13 A | 1054 | 100% | 2024-04-30 | 2024-05-13 | 10d | 2024-04-30 | 2024-05-13 |  |  | PP | SI Test | SIT | 5.0 |  | Systems Integration Testing (SIT) | SITAG | Complete | COMPLETE |  |  |  |  |
| 1057 | 1.4.1.4.3.5.2 | **SI SIT Migration Test Readiness Report** |  | 40d | 2024-04-02 A | 2024-05-27 A |  | 100% | 2024-04-02 | 2024-05-27 | 40d | 2024-04-02 | 2024-05-27 |  |  | N/A | N/A | SIT | 5.0 | N/A | Systems Integration Testing (SIT) | SITAG |  |  |  |  |  |  |
| 1058 | 1.4.1.4.3.5.2.1 | Assure Test Participants' Test Readiness Reports |  | 35d | 2024-04-02 A | 2024-05-20 A | 1054SS, 1056FF+5d | 100% | 2024-04-02 | 2024-05-20 | 35d | 2024-04-02 | 2024-05-20 |  |  | SI Test | PP,IPA | SIT | 5.0 |  | Systems Integration Testing (SIT) | SITAG | Complete | COMPLETE |  |  |  |  |
| 1059 | 1.4.1.4.3.5.2.2 | Develop Overarching SIT Migration Test Readiness Report |  | 20d | 2024-04-23 A | 2024-05-20 A | 1058FF | 100% | 2024-04-23 | 2024-05-20 | 20d | 2024-04-23 | 2024-05-20 |  |  | SI Test |  | SIT | 5.0 |  | Systems Integration Testing (SIT) | SITAG | Complete | COMPLETE |  |  |  |  |
| 1060 | 1.4.1.4.3.5.2.3 | Artefact review (via SITAG) and updates |  | 5d | 2024-05-21 A | 2024-05-27 A | 1059 | 100% | 2024-05-21 | 2024-05-27 | 5d | 2024-05-21 | 2024-05-27 |  |  | SI Test | PP,IPA | SIT | 5.0 |  | Systems Integration Testing (SIT) | SITAG | Complete | COMPLETE |  |  |  |  |
| 1061 | 1.4.1.4.3.6 | SIT Migration Testing Preparation Complete | milestone | 0d | 2024-06-03 A | 2024-06-03 A | 1060FF+5d, 964, 359, 1055, 975, 981, 987 | 100% | 2024-06-03 | 2024-06-03 | 0d | 2024-06-03 | 2024-06-03 |  |  | SI Test | PP,IPA | SIT | 5.0 |  | Systems Integration Testing (SIT) | SITAG | Complete | COMPLETE | T2-TE-0650 | T2 |  |  |
| 1062 | 1.4.1.4.4 | **SIT Non-Functional Preparation** |  | 347d? | 2023-11-30 A | 2025-03-28 A |  | 100% | 2023-11-30 | 2025-03-14 | 193d | 2023-07-03 | 2024-08-26 |  | -0 | N/A | N/A | SIT | 5.0 | N/A | Systems Integration Testing (SIT) | SITAG |  |  |  |  |  |  |
| 1063 | 1.4.1.4.4.1 | **Test Approach & Plan** |  | 120d | 2023-11-30 A | 2024-05-15 A |  | 100% | 2023-11-30 | 2024-05-15 | 120d | 2023-11-30 | 2024-03-20 |  | -0 | N/A | N/A | SIT | 5.0 | N/A | Systems Integration Testing (SIT) | SITAG |  |  |  |  |  |  |
| 1064 | 1.4.1.4.4.1.1 | Develop document with SITWG |  | 67d | 2023-11-30 A | 2024-03-01 A |  | 100% | 2023-11-30 | 2024-03-01 | 67d | 2023-11-30 | 2024-01-10 | must start on 2023-11-30 |  | SI Test |  | SIT | 5.0 |  | Systems Integration Testing (SIT) | SITAG | Complete | COMPLETE |  |  |  |  |
| 1065 | 1.4.1.4.4.1.2 | Draft document review with Code Bodies |  | 10d | 2024-03-04 A | 2024-03-15 A | 1064 | 100% | 2024-03-04 | 2024-03-15 | 10d | 2024-01-11 | 2024-01-24 |  |  | SI Test | Code Bodies | SIT | 5.0 |  | Systems Integration Testing (SIT) | SITAG | Complete | COMPLETE |  |  |  |  |
| 1066 | 1.4.1.4.4.1.3 | Industry Consultation |  | 10d | 2024-03-18 A | 2024-03-29 A | 1065 | 100% | 2024-03-18 | 2024-03-29 | 10d |  |  |  |  | PP |  | SIT | 5.1 |  | Systems Integration Testing (SIT) | SITAG | Complete | COMPLETE |  |  |  |  |
| 1067 | 1.4.1.4.4.1.4 | Industry Assurance Review |  | 5d | 2024-04-11 A | 2024-04-17 A | 1066FS+8d | 100% | 2024-04-11 | 2024-04-17 | 5d |  |  |  |  |  |  | SIT | 5.16 |  |  | SITAG | Complete | COMPLETE |  |  |  |  |
| 1068 | 1.4.1.4.4.1.5 | SIT Non-Functional Testing Test Approach & Plan approved | milestone | 0d | 2024-05-15 A | 2024-05-15 A | 1067FS+20d | 100% | 2024-05-15 | 2024-05-15 | 0d | 2024-03-20 | 2024-03-20 |  |  | SI Test | PP | SIT | 5.30 | Roger Robar | Systems Integration Testing (SIT) | SITAG | Complete | COMPLETE | T3-TE-0026 | T3 | MHHS-ART073 | 30/7/24: Approved at esitag on 26/7/24 |

| ID | WBS | Task | Type | Duration | Start | Finish | Predecessors | Complete | Actual finish | Baseline start | Baseline finish | Baseline duration | Baseline 1 start | Baseline 1 finish | Constraint | Baseline cost | Responsible | Involved | Text9 | Update Version | MHHS Resource Name | MHHS Programme Phase | Text29 | Sched Status | RAG | Milestone ID | Tier | Task Status | Guidance |
| --- | --- | --- | --- | --- | --- | --- | --- | --- | --- | --- | --- | --- | --- | --- | --- | --- | --- | --- | --- | --- | --- | --- | --- | --- | --- | --- | --- | --- | --- |
| 1069 | 1.4.1.4.4.2 | **Test Data Approach & Plan** |  | 41d | 2024-03-20 A | 2024-05-15 A |  | 100% |  | 2024-03-20 | 2024-05-15 | 41d | 2024-01-25 | 2024-03-20 |  | -0 | N/A | N/A | SIT | 5.0 | N/A | Systems Integration Testing (SIT) | SITAG |  |  |  |  |  |  |
| 1070 | 1.4.1.4.4.2.1 | Industry Consultation |  | 14d | 2024-03-20 A | 2024-04-08 A | 1066SS+2d | 100% |  | 2024-03-20 | 2024-04-08 | 14d |  |  |  |  | PP |  | SIT | 5.1 | Michael Inije | Systems Integration Testing (SIT) | SITAG | Complete | COMPLETE |  |  |  |  |
| 1071 | 1.4.1.4.4.2.2 | Artefact review (via SITAG) and updates |  | 27d | 2024-04-09 A | 2024-05-15 A | 1070 | 100% |  | 2024-04-09 | 2024-05-15 | 27d | 2024-01-25 | 2024-03-13 |  |  | SI Test |  | SIT | 5.0 | Michael Inije | Systems Integration Testing (SIT) | SITAG | Complete | COMPLETE |  |  |  |  |
| 1072 | 1.4.1.4.4.2.3 | SIT Non-Functional Testing Test Data Approach & Plan approved | milestone | 0d | 2024-05-15 A | 2024-05-15 A | 1068FF, 1071 | 100% |  | 2024-05-15 | 2024-05-15 | 0d | 2024-03-20 | 2024-03-20 |  |  | SI Test | PP,IPA | SIT | 5.24 | Michael Inije | Systems Integration Testing (SIT) | SITAG | Complete | COMPLETE | T3-TE-0113 | T3 |  |  |
| 1073 | 1.4.1.4.4.3 | **Test scenarios & Test Cases** |  | 98d? | 2024-03-04 A | 2024-07-17 |  | 100% | 2024-09-18 | 2024-03-04 | 2024-07-17 | 123d | 2023-07-24 | 2024-01-17 |  | -0 | N/A | N/A | SIT | 5.21 | N/A | Systems Integration Testing (SIT) | SITAG |  |  |  |  |  |  |
| 1074 | 1.4.1.4.4.3.1 | **Theme 1** |  | 78d | 2024-03-04 A | 2024-06-19 A |  | 100% |  | 2024-03-04 | 2024-06-19 | 78d |  |  |  | -0 | N/A | N/A | SIT | 5.21 | N/A | Systems Integration Testing (SIT) | SITAG |  |  |  |  | -448.67 |  |
| 1075 | 1.4.1.4.4.3.1.1 | Develop Test Scenarios & Test Cases |  | 33d | 2024-03-04 A | 2024-04-17 A | 1064 | 100% |  | 2024-03-04 | 2024-04-17 | 33d |  |  |  |  | SI Test | SI Test, PP | SIT | 5.21 |  |  | SITAG | Complete | COMPLETE |  |  |  |  |
| 1076 | 1.4.1.4.4.3.1.2 | Industry Review Workshop |  | 1d | 2024-04-18 A | 2024-04-18 A | 1075 | 100% |  | 2024-04-18 | 2024-04-18 | 1d |  |  |  |  | SI Test, PP | SI Test, PP | SIT | 5.21 |  |  | SITAG | Complete | COMPLETE |  |  |  |  |
| 1077 | 1.4.1.4.4.3.1.3 | Industry Consultation Review |  | 7d | 2024-05-02 A | 2024-05-10 A | 1076FS+9d | 100% |  | 2024-05-02 | 2024-05-10 | 7d |  |  |  |  | SI Test, PP | SI Test, PP | SIT | 5.21 |  |  | SITAG | Complete | COMPLETE |  |  |  |  |
| 1078 | 1.4.1.4.4.3.1.4 | Review with NFT Working Group |  | 5d | 2024-05-31 A | 2024-06-06 A | 1077FS+14d | 100% |  | 2024-05-31 | 2024-06-06 | 5d |  |  |  |  | SI Test, PP | SI Test, PP | SIT | 5.21 |  |  | SITAG | Complete | COMPLETE |  |  |  |  |
| 1079 | 1.4.1.4.4.3.1.5 | SIT NFT Scenarios & Test Cases Approved - Theme 1 | milestone | 0d | 2024-06-19 A | 2024-06-19 A | 1078FS+9d | 100% |  | 2024-06-19 | 2024-06-19 | 0d |  |  |  |  | SI Test | SI Test, PP | SIT | 5.30 | Roger Robar | Systems Integration Testing (SIT) | SITAG | Complete | COMPLETE | T3-TE-0114 | T3 |  | 30/7/24: Approved at esitag on 26/7/24 |
| 1080 | 1.4.1.4.4.3.2 | **Theme 2** |  | 98d | 2024-03-04 A | 2024-07-17 A |  | 100% |  | 2024-03-04 | 2024-07-17 | 98d |  |  |  |  | N/A | N/A | SIT | 5.21 | N/A | Systems Integration Testing (SIT) | SITAG |  |  |  |  | -448.67 |  |
| 1081 | 1.4.1.4.4.3.2.1 | Develop Test Scenarios & Test Cases |  | 53d | 2024-03-04 A | 2024-05-15 A | 1064 | 100% |  | 2024-03-04 | 2024-05-15 | 53d |  |  |  |  | SI Test | SI Test, PP | SIT | 5.21 |  |  | SITAG | Complete | COMPLETE |  |  |  |  |
| 1082 | 1.4.1.4.4.3.2.2 | Industry Review Workshop |  | 1d | 2024-05-16 A | 2024-05-16 A | 1081 | 100% |  | 2024-05-16 | 2024-05-16 | 1d |  |  |  |  | SI Test, PP | SI Test, PP | SIT | 5.21 |  |  | SITAG | Complete | COMPLETE |  |  |  |  |
| 1083 | 1.4.1.4.4.3.2.3 | Industry Consultation Review |  | 7d | 2024-05-20 A | 2024-05-28 A | 1082FS+1d | 100% |  | 2024-05-20 | 2024-05-28 | 7d |  |  |  |  | SI Test, PP | SI Test, PP | SIT | 5.21 |  |  | SITAG | Complete | COMPLETE |  |  |  |  |
| 1084 | 1.4.1.4.4.3.2.4 | Review with NFT Working Group |  | 5d | 2024-06-28 A | 2024-07-04 A | 1083FS+22d | 100% |  | 2024-06-28 | 2024-07-04 | 5d |  |  |  |  | SI Test, PP | SI Test, PP | SIT | 5.21 |  |  | SITAG | Complete | COMPLETE |  |  |  |  |
| 1085 | 1.4.1.4.4.3.2.5 | SIT NFT Scenarios & Test Cases Approved - Theme 2 | milestone | 0d | 2024-07-17 A | 2024-07-17 A | 1084FS+9d | 100% |  | 2024-07-17 | 2024-07-17 | 0d |  |  |  |  | SI Test | SI Test, PP | SIT | 5.22 |  | Systems Integration Testing (SIT) | SITAG | Complete | COMPLETE | T3-TE-0115 | T3 |  |  |
| 1086 | 1.4.1.4.4.3.3 | **Theme 3** |  | 98d? | 2024-03-04 A | 2024-07-17 |  | 100% | 2024-09-18 | 2024-03-04 | 2024-07-17 | 123d |  |  |  | -0 | N/A | N/A | SIT | 6.0 | N/A | Systems Integration Testing (SIT) | SITAG |  |  |  |  | -448.67 |  |
| 1087 | 1.4.1.4.4.3.3.1 | Develop Test Scenarios & Test Cases |  | 63d | 2024-03-04 A | 2024-05-29 A | 1064 | 100% |  | 2024-03-04 | 2024-05-29 | 63d |  |  |  |  | SI Test | SI Test, PP | SIT | 6.0 |  |  | SITAG | Complete | COMPLETE |  |  |  |  |
| 1088 | 1.4.1.4.4.3.3.2 | Industry Review Workshop |  | 1d | 2024-05-30 A | 2024-05-30 A | 1087 | 100% |  | 2024-05-30 | 2024-05-30 | 1d |  |  |  |  | SI Test, PP | SI Test, PP | SIT | 6.0 |  |  | SITAG | Complete | COMPLETE |  |  |  |  |
| 1089 | 1.4.1.4.4.3.3.3 | Industry Consultation Review |  | 6d | 2024-06-10 A | 2024-06-17 A | 1088FS+6d | 100% |  | 2024-06-10 | 2024-06-17 | 6d |  |  |  |  | SI Test, PP | SI Test, PP | SIT | 6.0 |  |  | SITAG | Complete | COMPLETE |  |  |  |  |
| 1090 | 1.4.1.4.4.3.3.4 | Review with NFT Working Group |  | 5d | 2024-06-28 A | 2024-07-04 A | 1089FS+8d | 100% |  | 2024-06-28 | 2024-07-04 | 30d |  |  |  |  | SI Test, PP | SI Test, PP | SIT | 6.0 | Roger Robar |  | SITAG | Complete | COMPLETE |  |  |  |  |
| 1091 | 1.4.1.4.4.3.3.5 | SIT NFT Scenarios & Test Cases Approved - Theme 3 | milestone | 0d | 2024-09-18 A | 2024-09-18 A | 1090FS+9d | 100% |  | 2024-09-18 | 2024-09-18 | 0d |  |  | start no earlier than 2024-09-18 |  | SI Test | SI Test, PP | SIT | 5.30 | Roger Robar | Systems Integration Testing (SIT) | SITAG | Complete | COMPLETE | T3-TE-0116 | T3 |  | 31/7/24: baseline date change approved at esitag on 26/7/24 |
| 1092 | 1.4.1.4.4.4 | **SIT NFT Programme RTTM** |  | 45d | 2024-09-18 A | 2024-11-19 A |  | 100% |  | 2024-09-18 | 2024-10-16 | 0d |  |  |  |  | SI Test |  | SIT | 6.11 | David O'Riordan |  | SITAG |  |  |  |  | -197.67 |  |
| 1093 | 1.4.1.4.4.4.1 | Develop Manual SIT NFT RTTM |  | 30d | 2024-09-18 A | 2024-10-29 A | 1091 | 100% |  | 2024-09-18 | 2024-10-29 | 0d |  |  |  |  | SI Test |  | SIT | 6.11 | David O'Riordan |  | SITAG | Complete | COMPLETE |  |  |  |  |
| 1094 | 1.4.1.4.4.4.2 | LDP peer review |  | 10d | 2024-10-30 A | 2024-11-12 A | 1093 | 100% |  | 2024-10-30 | 2024-11-12 | 0d |  |  |  |  | SI Test |  | SIT | 6.11 | David O'Riordan |  | SITAG | Complete | COMPLETE |  |  |  |  |
| 1095 | 1.4.1.4.4.4.3 | Review with SRO |  | 5d | 2024-11-13 A | 2024-11-19 A | 1094 | 100% |  | 2024-11-13 | 2024-11-19 | 0d |  |  |  |  | SI Test |  | SIT | 6.11 | David O'Riordan |  | SITAG | Complete | COMPLETE |  |  |  |  |
| 1096 | 1.4.1.4.4.4.4 | DIP Manager / Code Bodies / Full SRO to review |  | 5d | 2024-11-13 A | 2024-11-19 A | 1094 | 100% |  | 2024-11-13 | 2024-11-19 | 0d |  |  |  |  | SI Test |  | SIT | 6.12 | David O'Riordan |  | SITAG | Complete | COMPLETE |  |  |  |  |
| 1097 | 1.4.1.4.4.4.5 | DIP Manager / Code Bodies / Full SRO acceptance of RTTM | milestone | 0d | 2024-11-19 A | 2024-11-19 A | 1096 | 100% |  | 2024-11-19 | 2024-11-19 | 0d |  |  |  |  | SI Test |  | SIT | 6.16 | David O'Riordan |  | SITAG | Complete | COMPLETE |  |  |  |  |
| 1098 | 1.4.1.4.4.4.6 | Manual SIT NFT RTTM Complete | milestone | 0d | 2024-11-19 A | 2024-11-19 A | 1095, 1096 | 100% |  | 2024-11-19 | 2024-11-19 | 0d |  |  |  |  | SI Test |  | SIT | 6.11 | David O'Riordan |  | SITAG | Complete | COMPLETE |  |  |  |  |

| ID | WBS | Task | Type | Duration | Start | Finish | Predecessors | Complete | Baseline start | Baseline finish | Baseline duration | Baseline 1 start | Baseline 1 finish | Constraint | Baseline cost | Responsible | Text9 | Task Status | Update Version | Sched Status | MHHS Resource Name | Text29 | RAG | Involved | MHHS Programme Phase | Action |
| --- | --- | --- | --- | --- | --- | --- | --- | --- | --- | --- | --- | --- | --- | --- | --- | --- | --- | --- | --- | --- | --- | --- | --- | --- | --- | --- |
| 1099 | 1.4.1.4.4.5 | **NFT (Theme 1, 2 and 3) DITL** |  | 18d | 2025-02-03 A | 2025-02-26 A |  | 100% | 2024-10-08 | 2024-10-17 | 0d |  |  |  |  | SI Test | SIT | 6.33 | 6.15 | No BL | David O'Riordan | SITAG |  |  |  |  |
| 1100 | 1.4.1.4.4.5.1 | DITL Development |  | 10d | 2025-02-03 A | 2025-02-14 A |  | 100% | 2025-02-03 | 2025-02-14 | 0d |  |  | start no earlier than 2025-02-03 |  | SI Test | SIT |  | 6.15 | Complete | David O'Riordan | SITAG | COMPLETE |  |  |  |
| 1101 | 1.4.1.4.4.5.2 | SRO Review |  | 5d | 2025-02-17 A | 2025-02-21 A | 1100 | 100% | 2025-02-17 | 2025-02-21 | 0d |  |  |  |  | SI Test | SIT |  | 6.15 | Complete | David O'Riordan | SITAG | COMPLETE |  |  |  |
| 1102 | 1.4.1.4.4.5.3 | Post-SRO Review Changes |  | 3d | 2025-02-24 A | 2025-02-26 A | 1101 | 100% | 2025-02-24 | 2025-02-26 | 0d |  |  |  |  | SI Test | SIT |  | 6.15 | Complete | David O'Riordan | SITAG | COMPLETE |  |  |  |
| 1103 | 1.4.1.4.4.5.4 | Programme DITL walkthrough with PPs on Theme 1, 2 and 3 | milestone | 0d | 2025-02-26 A | 2025-02-26 A | 1102 | 100% | 2025-02-26 | 2025-02-26 | 0d |  |  |  |  | SI Test | SIT |  | 6.15 | Complete | David O'Riordan | SITAG | COMPLETE |  |  |  |
| 1104 | 1.4.1.4.4.6 | **NFT Performance Tool Theme 1 Setup** |  | 268d? | 2024-03-04 A | 2025-03-12 A |  | 100% | 2024-03-04 | 2025-01-10 | 0d |  |  |  |  | SI Test | SIT | -205.67 | 6.1 |  | David O'Riordan | SITAG |  |  |  |  |
| 1105 | 1.4.1.4.4.6.1 | Theme 1 injection tool initial POC |  | 85d? | 2024-03-04 A | 2024-06-28 A |  | 100% | 2024-03-04 | 2024-06-28 | 0d |  |  |  |  | SI Test | SIT |  | 6.1 | Complete | David O'Riordan | SITAG | COMPLETE |  |  |  |
| 1106 | 1.4.1.4.4.6.2 | Theme 1 injection tool configuration and validation against DIP SIM (IR7.1) |  | 38d | 2024-07-01 A | 2024-08-21 A | 1105 | 100% | 2024-07-01 | 2024-08-21 | 0d |  |  |  |  | SI Test | SIT |  | 6.1 | Complete | David O'Riordan | SITAG | COMPLETE |  |  |  |
| 1107 | 1.4.1.4.4.6.3 | Theme 1 injection tool configuration and validation against DIP SIM (IR8.1) |  | 29d | 2024-08-22 A | 2024-10-01 A | 1106 | 100% | 2024-08-22 | 2024-10-01 | 0d |  |  |  |  | SI Test | SIT |  | 6.1 | Complete | David O'Riordan | SITAG | COMPLETE |  |  |  |
| 1108 | 1.4.1.4.4.6.4 | Theme 1 injection tool configuration and validation againast UIT DIP (IR8.1) |  | 11d | 2024-10-02 A | 2024-10-16 A | 1107 | 100% | 2024-10-02 | 2024-10-16 | 0d |  |  |  |  | SI Test | SIT |  | 6.1 | Complete | David O'Riordan | SITAG | COMPLETE |  |  |  |
| 1109 | 1.4.1.4.4.6.5 | Theme 1 injection tool configuration and validation against SIT-B DIP (IR8.4) |  | 3d? | 2025-03-10 A | 2025-03-12 A | 1557FS+10d | 100% | 2025-01-06 | 2025-01-08 | 0d |  |  |  |  | SI Test | SIT |  | 6.1 | Complete | David O'Riordan | SITAG | COMPLETE |  |  |  |
| 1110 | 1.4.1.4.4.7 | **Environments (SIT B)** |  | 134d | 2024-08-27 A | 2025-02-28 A |  | 100% | 2024-08-27 | 2025-01-03 | 0d | 2024-07-30 | 2024-08-05 |  | -0 | N/A | SIT |  | 5.0 |  | Heath Thomas | SITAG |  | N/A | Systems Integration Testing (SIT) |  |
| 1111 | 1.4.1.4.4.7.1 | **PP Environments (SIT B)** |  | 0d | 2024-08-27 A | 2024-08-27 A |  | 100% | 2024-08-27 | 2024-08-27 | 0d | 2024-07-30 | 2024-08-05 |  | -0 | N/A | SIT |  | 5.0 |  | Heath Thomas | SITAG |  | N/A | Systems Integration Testing (SIT) |  |
| 1112 | 1.4.1.4.4.7.1.1 | Deployment of MHHS solution code to SIT B environments | milestone | 0d | 2024-08-27 A | 2024-08-27 A |  | 100% | 2024-08-27 | 2024-08-27 | 0d | 2024-07-30 | 2024-08-05 | start no earlier than 2024-08-27 |  | PP | SIT |  | 5.21 | Complete | Heath Thomas | SITAG | COMPLETE | SI Test | Systems Integration Testing (SIT) | 26/3/24: Lee said change to SB and align to IR7 |
| 1113 | 1.4.1.4.4.7.2 | **SI Environments (SIT B)** |  | 0d | 2024-08-27 A | 2024-08-27 A |  | 100% | 2024-08-27 | 2024-08-27 | 0d | 2024-07-30 | 2024-08-05 |  | -0 | N/A | SIT |  | 5.0 |  | Heath Thomas | SITAG |  | N/A | Systems Integration Testing (SIT) |  |
| 1114 | 1.4.1.4.4.7.2.1 | Coordinate deployment of MHHS solution code to SIT Participants' SIT B environments | milestone | 0d | 2024-08-27 A | 2024-08-27 A | 1112SS | 100% | 2024-08-27 | 2024-08-27 | 0d | 2024-07-30 | 2024-08-05 |  |  | SI Test | SIT |  | 5.21 | Complete | Heath Thomas | SITAG | COMPLETE | PP | Systems Integration Testing (SIT) |  |
| 1115 | 1.4.1.4.4.7.3 | **Helix and Avanade Environments Upscale** |  | 5d | 2025-02-24 A | 2025-02-28 A |  | 100% | 2024-12-23 | 2025-01-03 | 0d |  |  |  |  | SI Test | SIT | -686.67 | 6.0 |  | Heath Thomas | SITAG |  |  |  |  |
| 1116 | 1.4.1.4.4.7.3.1 | Environment Uplift Window (Technical Check) |  | 5d | 2025-02-24 A | 2025-02-28 A | 1557 | 100% | 2025-02-24 | 2025-02-28 | 0d |  |  |  |  | SI Test | SIT |  | 6.19 | Complete | Heath Thomas | SITAG | COMPLETE |  |  |  |
| 1117 | 1.4.1.4.4.8 | **SIT Non-Functional Execution Model** |  | 42d | 2025-01-20 A | 2025-03-18 A |  | 100% | 2025-01-20 | 2025-02-12 | 0d |  |  |  |  | SI Test | SIT | -778.67 | 6.15 |  | David O'Riordan | SITAG |  |  |  |  |
| 1118 | 1.4.1.4.4.8.1 | **Theme 1** |  | 22d | 2025-01-20 A | 2025-02-18 A |  | 100% | 2025-01-20 | 2025-02-12 | 0d |  |  |  |  | SI Test | SIT | -778.67 | 6.15 |  | David O'Riordan | SITAG |  |  |  |  |
| 1119 | 1.4.1.4.4.8.1.1 | Develop execution model Theme 1 |  | 3d | 2025-01-20 A | 2025-01-22 A |  | 100% | 2025-01-20 | 2025-01-22 | 0d |  |  | start no earlier than 2025-01-20 |  | SI Test | SIT |  | 6.15 | Complete | David O'Riordan | SITAG | COMPLETE |  |  |  |
| 1120 | 1.4.1.4.4.8.1.2 | SRO provide feedback |  | 5d | 2025-01-23 A | 2025-01-29 A | 1119 | 100% | 2025-01-23 | 2025-01-29 | 0d |  |  |  |  | SI Test | SIT |  | 6.15 | Complete | David O'Riordan | SITAG | COMPLETE |  |  |  |
| 1121 | 1.4.1.4.4.8.1.3 | Address SRO feedback on execution model |  | 2d | 2025-01-30 A | 2025-01-31 A | 1120 | 100% | 2025-01-30 | 2025-01-31 | 0d |  |  |  |  | SI Test | SIT |  | 6.15 | Complete | David O'Riordan | SITAG | COMPLETE |  |  |  |
| 1122 | 1.4.1.4.4.8.1.4 | Finalise execution model |  | 3d | 2025-02-03 A | 2025-02-05 A | 1121 | 100% | 2025-02-03 | 2025-02-05 | 0d |  |  |  |  | SI Test | SIT |  | 6.15 | Complete | David O'Riordan | SITAG | COMPLETE |  |  |  |
| 1123 | 1.4.1.4.4.8.1.5 | NFTWG paper day | milestone | 0d | 2025-02-11 A | 2025-02-11 A | 1122FS+4d | 100% | 2025-02-05 | 2025-02-05 | 0d |  |  |  |  | SI Test | SIT |  | 6.17 | Complete | David O'Riordan | SITAG | COMPLETE |  |  |  |
| 1124 | 1.4.1.4.4.8.1.6 | NFTWG update on execution model | milestone | 0d | 2025-02-18 A | 2025-02-18 A | 1123FS+5d | 100% | 2025-02-18 | 2025-02-18 | 0d |  |  |  |  | SI Test | SIT |  | 6.17 | Complete | David O'Riordan | SITAG | COMPLETE |  |  |  |

| ID | WBS | Task | Type | Duration | Start | Finish | Predecessors | Complete | Baseline start | Baseline finish | Baseline duration | Baseline 1 start | Baseline 1 finish | Constraint | Baseline cost | Responsible | Text9 | Task Status | Update Version | MHHS Resource Name | Text29 | Sched Status | RAG | Involved | MHHS Programme Phase | Tier | Milestone ID |
| --- | --- | --- | --- | --- | --- | --- | --- | --- | --- | --- | --- | --- | --- | --- | --- | --- | --- | --- | --- | --- | --- | --- | --- | --- | --- | --- | --- |
| 1125 | 1.4.1.4.4.8.2 | **Theme 2 & 3** |  | 42d | 2025-01-20 A | 2025-03-18 A |  | 100% | 2025-01-20 | 2025-02-12 | 0d |  |  |  |  | SI Test | SIT | -778.67 | 6.15 | David O'Riordan | SITAG |  |  |  |  |  |  |
| 1126 | 1.4.1.4.4.8.2.1 | Develop execution model Theme 2 & 3 |  | 3d | 2025-01-20 A | 2025-01-22 A |  | 100% | 2025-01-20 | 2025-01-22 | 0d |  |  | start no earlier than 2025-01-20 |  | SI Test | SIT |  | 6.15 | David O'Riordan | SITAG | Complete | COMPLETE |  |  |  |  |
| 1127 | 1.4.1.4.4.8.2.2 | SRO provide feedback |  | 5d | 2025-01-23 A | 2025-01-29 A | 1126 | 100% | 2025-01-23 | 2025-01-29 | 0d |  |  |  |  | SI Test | SIT |  | 6.15 | David O'Riordan | SITAG | Complete | COMPLETE |  |  |  |  |
| 1128 | 1.4.1.4.4.8.2.3 | Address SRO feedback on execution model |  | 2d | 2025-01-30 A | 2025-01-31 A | 1127 | 100% | 2025-01-30 | 2025-01-31 | 0d |  |  |  |  | SI Test | SIT |  | 6.15 | David O'Riordan | SITAG | Complete | COMPLETE |  |  |  |  |
| 1129 | 1.4.1.4.4.8.2.4 | Finalise execution model |  | 3d | 2025-02-03 A | 2025-02-05 A | 1128 | 100% | 2025-02-03 | 2025-02-05 | 0d |  |  |  |  | SI Test | SIT |  | 6.15 | David O'Riordan | SITAG | Complete | COMPLETE |  |  |  |  |
| 1130 | 1.4.1.4.4.8.2.5 | NFTWG paper day | milestone | 0d | 2025-03-11 A | 2025-03-11 A | 1129FS+24d | 100% | 2025-03-11 | 2025-03-11 | 0d |  |  |  |  | SI Test | SIT |  | 6.17 | David O'Riordan | SITAG | Complete | COMPLETE |  |  |  |  |
| 1131 | 1.4.1.4.4.8.2.6 | NFTWG update on execution model | milestone | 0d | 2025-03-18 A | 2025-03-18 A | 1130FS+5d | 100% | 2025-03-18 | 2025-03-18 | 0d |  |  |  |  | SI Test | SIT |  | 6.17 | David O'Riordan | SITAG | Complete | COMPLETE |  |  |  |  |
| 1132 | 1.4.1.4.4.9 | **SIT Non-Functional Progress reporting** |  | 22d | 2025-01-23 A | 2025-02-21 A |  | 100% | 2024-12-30 | 2025-01-24 | 0d |  |  |  |  | SI Test | SIT | -778.67 | 6.14 | David O'Riordan | SITAG |  |  |  |  |  |  |
| 1133 | 1.4.1.4.4.9.1 | Determine reporting methodology |  | 2d | 2025-01-23 A | 2025-01-24 A | 1119, 1126 | 100% | 2025-01-23 | 2025-01-24 | 0d |  |  |  |  | SI Test | SIT |  | 6.14 | David O'Riordan | SITAG | Complete | COMPLETE |  |  |  |  |
| 1134 | 1.4.1.4.4.9.2 | Implement reporting |  | 20d | 2025-01-27 A | 2025-02-21 A | 1133, 836, 376, 1079, 1085, 1091 | 100% | 2025-01-27 | 2025-02-14 | 0d | 2024-08-26 | 2024-08-26 |  |  | SI Test | SIT |  | 6.14 | David O'Riordan | SITAG | Complete | COMPLETE | PP,IPA | Systems Integration Testing (SIT) | T2 |  |
| 1135 | 1.4.1.4.4.10 | **SIT Non-Functional Test Readiness Report** |  | 48d | 2025-01-21 A | 2025-03-28 A |  | 100% | 2024-06-25 | 2025-03-07 | 44d | 2024-06-25 | 2024-08-19 |  | -0 | N/A | SIT |  | 5.0 | David O'Riordan | SITAG |  |  | N/A | Systems Integration Testing (SIT) |  |  |
| 1136 | 1.4.1.4.4.10.1 | **SIT Non-Functional Theme 1 Overarching Test Readiness Report** |  | 29d | 2025-01-21 A | 2025-02-28 A |  | 100% | 2024-06-25 | 2025-01-10 | 40d | 2024-06-25 | 2024-08-19 |  |  | N/A | SIT |  | 6.17 | David O'Riordan | SITAG |  |  | N/A | Systems Integration Testing (SIT) |  |  |
| 1137 | 1.4.1.4.4.10.1.1 | Develop Overarching SIT Non-Functional Theme 1 Overarching Test Readiness Report |  | 11d | 2025-01-21 A | 2025-02-04 A | 376 | 100% | 2025-01-21 | 2025-02-04 | 20d | 2024-07-16 | 2024-08-12 | finish no earlier than 2025-02-04 |  | SI Test | SIT |  | 6.17 | David O'Riordan | SITAG | Complete | COMPLETE |  | Systems Integration Testing (SIT) |  |  |
| 1138 | 1.4.1.4.4.10.1.2 | SRO review |  | 5d | 2025-02-05 A | 2025-02-11 A | 1137 | 100% | 2025-02-05 | 2025-02-11 | 0d |  |  | finish no earlier than 2025-02-10 |  | SI Test | SIT |  | 6.17 | David O'Riordan | SITAG | Complete | COMPLETE |  |  |  |  |
| 1139 | 1.4.1.4.4.10.1.3 | NFTWG paper day | milestone | 0d | 2025-02-11 A | 2025-02-11 A | 1138 | 100% | 2025-02-11 | 2025-02-11 | 0d |  |  | finish no earlier than 2025-02-11 |  | SI Test | SIT |  | 6.17 | David O'Riordan | SITAG | Complete | COMPLETE |  |  |  |  |
| 1140 | 1.4.1.4.4.10.1.4 | NFTWG review the Non-Functional Theme 1 Overarching Test Readiness Report | milestone | 0d | 2025-02-18 A | 2025-02-18 A | 1139FS+5d | 100% | 2025-02-18 | 2025-02-18 | 0d |  |  |  |  | SI Test | SIT |  | 6.17 | David O'Riordan | SITAG | Complete | COMPLETE |  |  |  |  |
| 1141 | 1.4.1.4.4.10.1.5 | Update Non-Functional Theme 1 Overarching Test Readiness Report following SRO / NFTWG feedback |  | 6d | 2025-02-19 A | 2025-02-26 A | 1138, 1140 | 100% | 2025-02-19 | 2025-02-26 | 0d |  |  | finish no earlier than 2025-02-26 |  | SI Test | SIT |  | 6.17 | David O'Riordan | SITAG | Complete | COMPLETE |  |  |  |  |
| 1142 | 1.4.1.4.4.10.1.6 | FTIG Recommendation | milestone | 0d | 2025-02-21 A | 2025-02-21 A | 1140FS+3d | 100% | 2025-02-21 | 2025-02-21 | 0d |  |  |  |  | SI Test | SIT |  | 6.17 | David O'Riordan |  | Complete | COMPLETE |  |  |  |  |
| 1143 | 1.4.1.4.4.10.1.7 | eSITAG paper day | milestone | 0d | 2025-02-26 A | 2025-02-26 A | 1141 | 100% | 2025-02-26 | 2025-02-26 | 0d |  |  | finish no earlier than 2025-02-21 |  | SI Test | SIT |  | 6.17 | David O'Riordan | SITAG | Complete | COMPLETE |  |  |  |  |
| 1144 | 1.4.1.4.4.10.1.8 | eSITAG approve Non-Functional Theme 1 Overarching Test Readiness Report | milestone | 0d | 2025-02-28 A | 2025-02-28 A | 1388 | 100% | 2025-02-28 | 2025-02-28 | 0d |  |  |  |  | SI Test | SIT |  | 6.17 | David O'Riordan | SITAG | Complete | COMPLETE |  |  | T3 | T3-TE-0190 |
| 1145 | 1.4.1.4.4.10.2 | **SIT Non-Functional Overarching Test Readiness Report Theme 2 & 3** |  | 28d | 2025-02-18 A | 2025-03-28 A |  | 100% | 2025-02-18 | 2025-03-28 | 0d |  |  |  |  | SI Test | SIT | -779.67 | 6.17 | David O'Riordan | SITAG |  |  |  |  |  |  |
| 1146 | 1.4.1.4.4.10.2.1 | Develop Overarching SIT Non-Functional Overarching Test Readiness Report Theme 2 & 3 |  | 11d | 2025-02-18 A | 2025-03-04 A |  | 100% | 2025-02-18 | 2025-03-04 | 0d |  |  | finish no earlier than 2025-03-04 |  | SI Test | SIT |  | 6.17 | David O'Riordan | SITAG | Complete | COMPLETE |  |  |  |  |
| 1147 | 1.4.1.4.4.10.2.2 | SRO review |  | 5d | 2025-03-05 A | 2025-03-11 A | 1146SS | 100% | 2025-03-05 | 2025-03-11 | 0d |  |  | start no earlier than 2025-03-05 |  | SI Test | SIT |  | 6.17 | David O'Riordan | SITAG | Complete | COMPLETE |  |  |  |  |
| 1148 | 1.4.1.4.4.10.2.3 | NFTWG paper day | milestone | 0d | 2025-03-11 A | 2025-03-11 A | 1147 | 100% | 2025-03-11 | 2025-03-11 | 0d |  |  | finish no earlier than 2025-03-11 |  | SI Test | SIT |  | 6.17 | David O'Riordan | SITAG | Complete | COMPLETE |  |  |  |  |
| 1149 | 1.4.1.4.4.10.2.4 | NFTWG review the Non-Functional Overarching Test Readiness Report Theme 2 & 3 | milestone | 0d | 2025-03-18 A | 2025-03-18 A | 1148FS+5d | 100% | 2025-03-18 | 2025-03-18 | 0d |  |  | finish no earlier than 2025-03-18 |  | SI Test | SIT |  | 6.17 | David O'Riordan | SITAG | Complete | COMPLETE |  |  |  |  |
| 1150 | 1.4.1.4.4.10.2.5 | Update Non-Functional Overarching Test Readiness Report Theme 2 & 3 following SRO / NFTWG feedback |  | 6d | 2025-03-19 A | 2025-03-26 A | 1147, 1149 | 100% | 2025-03-19 | 2025-03-26 | 0d |  |  |  |  | SI Test | SIT |  | 6.17 | David O'Riordan | SITAG | Complete | COMPLETE |  |  |  |  |
| 1151 | 1.4.1.4.4.10.2.6 | GLIG Recommendation | milestone | 0d | 2025-03-21 A | 2025-03-21 A | 1149FS+3d | 100% | 2025-03-21 | 2025-03-21 | 0d |  |  |  |  | SI Test | SIT |  | 6.17 | David O'Riordan |  | Complete | COMPLETE |  |  |  |  |
| 1152 | 1.4.1.4.4.10.2.7 | eSITAG paper day | milestone | 0d | 2025-03-26 A | 2025-03-26 A | 1150, 1151 | 100% | 2025-03-26 | 2025-03-26 | 0d |  |  | start no earlier than 2025-03-21 |  | SI Test | SIT |  | 6.17 | David O'Riordan | SITAG | Complete | COMPLETE |  |  |  |  |
| 1153 | 1.4.1.4.4.10.2.8 | eSITAG approve Non-Functional Overarching Test Readiness Report Theme 2 & 3 | milestone | 0d | 2025-03-28 A | 2025-03-28 A | 1152, 1389FS-1d, 1390 | 100% | 2025-03-28 | 2025-03-28 | 0d |  |  |  |  | SI Test | SIT |  | 6.17 | David O'Riordan | SITAG | Complete | COMPLETE |  |  | T3 | T3-TE-0191 |
| 1154 | 1.4.1.4.4.11 | SIT Non-Functional Testing Preparation Complete Theme 1 | milestone | 0d | 2025-02-28 A | 2025-02-28 A | 1388 | 100% | 2025-02-28 | 2025-02-28 | 0d |  |  | start no earlier than 2025-02-28 |  | SI Test | SIT |  | 6.15 | David O'Riordan | SITAG | Complete | COMPLETE |  |  | T2 | T2-TE-0700 |
| 1155 | 1.4.1.4.4.12 | SIT Non-Functional Testing Preparation Complete Theme 2 & 3 | milestone | 0d | 2025-03-28 A | 2025-03-28 A | 377FS+5d, 1389, 1390, 1131, 1134, 1109, 1103, 1098 | 100% | 2025-03-28 | 2025-03-28 | 0d |  |  |  |  | SI Test | SIT |  | 6.15 | David O'Riordan | SITAG | Complete | COMPLETE |  |  | T2 | T2-TE-1100 |

| ID | WBS | Task | Type | Duration | Start | Finish | Predecessors | Complete | Actual start | Baseline start | Baseline finish | Baseline duration | Baseline 1 start | Baseline 1 finish | Constraint | Baseline cost | Responsible | Involved | Text9 | Update Version | MHHS Resource Name | MHHS Programme Phase | Text29 | Sched Status | RAG | Artefact ID | Milestone ID | Tier | Task Status | Guidance |
| --- | --- | --- | --- | --- | --- | --- | --- | --- | --- | --- | --- | --- | --- | --- | --- | --- | --- | --- | --- | --- | --- | --- | --- | --- | --- | --- | --- | --- | --- | --- |
| 1156 | 1.4.1.4.5 | **SIT Operational Preparation** |  | 670d? | 2022-10-31 | 2025-05-23 A |  | 100% | 2024-02-01 | 2024-02-01 | 2025-01-31 | 283d | 2023-08-03 | 2025-03-10 |  | -0 | N/A | N/A | SIT | 5.0 | N/A | Systems Integration Testing (SIT) | SITAG |  |  |  |  |  |  |  |
| 1157 | 1.4.1.4.5.1 | **Test Approach & Plan** |  | 75d | 2024-02-01 A | 2024-05-15 A |  | 100% |  | 2024-02-01 | 2024-05-15 | 75d | 2024-02-01 | 2024-05-15 |  | -0 | N/A | N/A | SIT | 5.0 | N/A | Systems Integration Testing (SIT) | SITAG |  |  |  |  |  |  |  |
| 1158 | 1.4.1.4.5.1.1 | Develop document with SITWG |  | 25d | 2024-02-01 A | 2024-03-06 A |  | 100% |  | 2024-02-01 | 2024-03-06 | 25d | 2024-02-01 | 2024-03-06 | must start on 2024-02-01 |  | SI Test |  | SIT | 5.0 | Steve Evans | Systems Integration Testing (SIT) | SITAG | Complete | COMPLETE |  |  |  |  |  |
| 1159 | 1.4.1.4.5.1.2 | Draft document review with Code Bodies |  | 4d | 2024-03-21 A | 2024-03-26 A | 1158FS+10d | 100% |  | 2024-03-21 | 2024-03-26 | 10d | 2024-03-07 | 2024-03-20 |  |  | SI Test | Code Bodies | SIT | 5.0 | Steve Evans | Systems Integration Testing (SIT) | SITAG | Complete | COMPLETE |  |  |  |  |  |
| 1160 | 1.4.1.4.5.1.3 | Industry Consultation |  | 10d | 2024-03-27 A | 2024-04-09 A | 1159 | 100% |  | 2024-03-27 | 2024-04-09 | 10d |  |  |  |  | PP |  | SIT | 5.1 | Steve Evans | Systems Integration Testing (SIT) | SITAG | Complete | COMPLETE |  |  |  |  |  |
| 1161 | 1.4.1.4.5.1.4 | Artefact review (via SITAG) and updates |  | 26d | 2024-04-10 A | 2024-05-15 A | 1160 | 100% |  | 2024-04-10 | 2024-05-15 | 30d | 2024-03-21 | 2024-05-15 |  |  | SI Test | PP,IPA,Code Bodies | SIT | 5.0 | Steve Evans | Systems Integration Testing (SIT) | SITAG | Complete | COMPLETE |  |  |  |  |  |
| 1162 | 1.4.1.4.5.1.5 | SIT Operational Testing Test Approach & Plan approved | milestone | 0d | 2024-05-15 A | 2024-05-15 A | 1161 | 100% |  | 2024-05-15 | 2024-05-15 | 0d | 2024-05-15 | 2024-05-15 |  |  | SI Test | PP | SIT | 5.24 | Steve Evans | Systems Integration Testing (SIT) | SITAG | Complete | COMPLETE | MHHS-ART073 | T3-TE-0029 | T3 |  |  |
| 1163 | 1.4.1.4.5.2 | **Test Data Approach & Plan** |  | 36d | 2024-03-27 A | 2024-05-15 A |  | 100% |  | 2024-03-27 | 2024-05-15 | 36d | 2024-03-21 | 2024-05-15 |  | -0 | N/A | N/A | SIT | 5.0 | N/A | Systems Integration Testing (SIT) | SITAG |  |  |  |  |  |  |  |
| 1164 | 1.4.1.4.5.2.1 | Industry Consultation |  | 10d | 2024-03-27 A | 2024-04-09 A | 1160SS | 100% |  | 2024-03-27 | 2024-04-09 | 10d |  |  |  |  | PP |  | SIT | 5.1 | Michael Inije | Systems Integration Testing (SIT) | SITAG | Complete | COMPLETE |  |  |  |  |  |
| 1165 | 1.4.1.4.5.2.2 | Artefact review (via SITAG) and updates |  | 26d | 2024-04-10 A | 2024-05-15 A | 1164 | 100% |  | 2024-04-10 | 2024-05-15 | 26d | 2024-03-21 | 2024-05-15 |  |  | SI Test |  | SIT | 5.0 | Michael Inije | Systems Integration Testing (SIT) | SITAG | Complete | COMPLETE |  |  |  |  |  |
| 1166 | 1.4.1.4.5.2.3 | SIT Operational Testing Test Data Approach & Plan approved | milestone | 0d | 2024-05-15 A | 2024-05-15 A | 1165 | 100% |  | 2024-05-15 | 2024-05-15 | 0d | 2024-05-15 | 2024-05-15 |  |  | SI Test | PP,IPA | SIT | 5.0 | Michael Inije | Systems Integration Testing (SIT) | SITAG | Complete | COMPLETE |  |  |  |  |  |
| 1167 | 1.4.1.4.5.3 | **Theme 1 & 2 Test Cases Approved** |  | 108d | 2024-04-10 A | 2024-09-06 A |  | 100% |  | 2024-04-10 | 2025-01-31 | 116d | 2023-07-24 | 2024-01-17 |  | -0 | N/A | N/A | SIT | 6.18 | Michael Inije | Systems Integration Testing (SIT) | SITAG |  |  |  |  |  |  |  |
| 1168 | 1.4.1.4.5.3.1 | **Theme 1** |  | 108d | 2024-04-10 A | 2024-09-06 A |  | 100% |  | 2024-04-10 | 2024-09-06 | 96d |  |  |  | -0 | N/A | N/A | SIT | 6.0 | Michael Inije | Systems Integration Testing (SIT) | SITAG |  |  |  |  |  | -448.67 |  |
| 1169 | 1.4.1.4.5.3.1.1 | Develop Test Scenarios & Test Cases |  | 53d | 2024-04-10 A | 2024-06-21 A | 1160 | 100% |  | 2024-04-10 | 2024-06-21 | 16d |  |  |  |  | SI Test | SI Test, PP | SIT | 6.0 | Michael Inije |  | SITAG | Complete | COMPLETE |  |  |  |  |  |
| 1170 | 1.4.1.4.5.3.1.2 | Industry Review Workshop |  | 1d | 2024-06-24 A | 2024-06-24 A | 1169 | 100% |  | 2024-06-24 | 2024-06-24 | 1d |  |  |  |  | SI Test, PP | SI Test, PP | SIT | 6.0 | Michael Inije |  | SITAG | Complete | COMPLETE |  |  |  |  |  |
| 1171 | 1.4.1.4.5.3.1.3 | Industry Consultation Review |  | 6d | 2024-07-02 A | 2024-07-09 A | 1170FS+17d | 100% |  | 2024-07-02 | 2024-07-09 | 6d |  |  |  |  | SI Test, PP | SI Test, PP | SIT | 6.0 | Michael Inije |  | SITAG | Complete | COMPLETE |  |  |  |  |  |
| 1172 | 1.4.1.4.5.3.1.4 | Review with SIT Working Group |  | 5d | 2024-08-19 A | 2024-08-23 A | 1171FS+16d | 100% |  | 2024-08-19 | 2024-08-23 | 5d |  |  |  |  | SI Test, PP | SI Test, PP | SIT | 6.0 | Michael Inije |  | SITAG | Complete | COMPLETE |  |  |  |  |  |
| 1173 | 1.4.1.4.5.3.1.5 | SIT Operational Scenarios & Test Cases Approved - Theme 1 | milestone | 0d | 2024-09-06 A | 2024-09-06 A | 1172FS+10d | 100% |  | 2024-09-06 | 2024-09-06 | 0d |  |  | start no earlier than 2024-09-06 |  | SI Test | SI Test, PP | SIT | 6.0 | Michael Inije | Systems Integration Testing (SIT) | SITAG | Complete | COMPLETE |  | T3-TE-0117 | T3 |  | 31/7/24: baseline date change approved at esitag on 26/7/24 |
| 1174 | 1.4.1.4.5.3.2 | **Theme 2** |  | 107d | 2024-04-10 A | 2024-09-06 A |  | 100% |  | 2024-04-10 | 2024-09-06 | 71d |  |  |  |  | N/A | N/A | SIT | 6.0 | Michael Inije | Systems Integration Testing (SIT) | SITAG |  |  |  |  |  | -448.67 |  |
| 1175 | 1.4.1.4.5.3.2.1 | Develop Test Scenarios & Test Cases |  | 53d | 2024-04-10 A | 2024-06-21 A | 1160 | 100% |  | 2024-04-10 | 2024-06-21 | 31d |  |  | finish no earlier than 2024-06-21 |  | SI Test | SI Test, PP | SIT | 6.0 | Michael Inije |  | SITAG | Complete | COMPLETE |  |  |  |  |  |
| 1176 | 1.4.1.4.5.3.2.2 | Industry Review Workshop |  | 1d | 2024-06-24 A | 2024-06-24 A | 1175 | 100% |  | 2024-06-24 | 2024-06-24 | 1d |  |  |  |  | SI Test, PP | SI Test, PP | SIT | 6.0 | Michael Inije |  | SITAG | Complete | COMPLETE |  |  |  |  |  |
| 1177 | 1.4.1.4.5.3.2.3 | Industry Consultation Review |  | 6d | 2024-07-02 A | 2024-07-09 A | 1176FS+7d | 100% |  | 2024-07-02 | 2024-07-09 | 6d |  |  |  |  | SI Test, PP | SI Test, PP | SIT | 6.0 | Michael Inije |  | SITAG | Complete | COMPLETE |  |  |  |  |  |
| 1178 | 1.4.1.4.5.3.2.4 | Review with SIT Working Group |  | 5d | 2024-08-19 A | 2024-08-23 A | 1177FS+11d | 100% |  | 2024-08-19 | 2024-08-23 | 5d |  |  |  |  | SI Test, PP | SI Test, PP | SIT | 6.0 | Michael Inije |  | SITAG | Complete | COMPLETE |  |  |  |  |  |
| 1179 | 1.4.1.4.5.3.2.5 | SIT Operational Scenarios & Test Cases Approved - Theme 2 | milestone | 0d | 2024-09-06 A | 2024-09-06 A | 1178FS+10d | 100% |  | 2024-09-06 | 2024-09-06 | 0d |  |  |  |  | SI Test | SI Test, PP | SIT | 6.0 | Michael Inije | Systems Integration Testing (SIT) | SITAG | Complete | COMPLETE |  | T3-TE-0118 | T3 |  |  |

| ID | WBS | Task | Type | Duration | Start | Finish | Predecessors | Complete | Actual start | Baseline start | Baseline finish | Baseline duration | Baseline 1 start | Baseline 1 finish | Constraint | Baseline cost | Responsible | Involved | Text9 | Update Version | MHHS Resource Name | MHHS Programme Phase | Text29 | Sched Status | RAG | Task Status | Milestone ID | Tier |
| --- | --- | --- | --- | --- | --- | --- | --- | --- | --- | --- | --- | --- | --- | --- | --- | --- | --- | --- | --- | --- | --- | --- | --- | --- | --- | --- | --- | --- |
| 1180 | 1.4.1.4.5.4 | **Environments (SIT B)** |  | 0d | 2024-10-07 A | 2024-10-07 A |  | 100% |  | 2024-10-07 | 2024-10-07 | 0d | 2024-09-03 | 2024-09-09 |  | -0 | N/A | N/A | SIT | 5.31 | Heath Thomas | Systems Integration Testing (SIT) | SITAG |  |  |  |  |  |
| 1181 | 1.4.1.4.5.4.1 | **PP Environments (SIT B)** |  | 0d | 2024-10-07 A | 2024-10-07 A |  | 100% |  | 2024-10-07 | 2024-10-07 | 0d | 2024-09-03 | 2024-09-09 |  | -0 | N/A | N/A | SIT | 5.31 | Heath Thomas | Systems Integration Testing (SIT) | SITAG |  |  |  |  |  |
| 1182 | 1.4.1.4.5.4.1.1 | Deployment of MHHS solution code to SIT B environments | milestone | 0d | 2024-10-07 A | 2024-10-07 A | 141 | 100% |  | 2024-10-07 | 2024-10-07 | 0d | 2024-09-03 | 2024-09-09 | start no earlier than 2024-08-27 |  | PP | SI Test | SIT | 5.31 | Heath Thomas | Systems Integration Testing (SIT) | SITAG | Complete | COMPLETE |  |  |  |
| 1183 | 1.4.1.4.5.4.2 | **SI Environments (SIT B)** |  | 0d | 2024-10-07 A | 2024-10-07 A |  | 100% |  | 2024-10-07 | 2024-10-07 | 0d | 2024-09-03 | 2024-09-09 |  | -0 | N/A | N/A | SIT | 5.31 | Heath Thomas | Systems Integration Testing (SIT) | SITAG |  |  |  |  |  |
| 1184 | 1.4.1.4.5.4.2.1 | Coordinate deployment of MHHS solution code to SIT Participants' SIT B environments | milestone | 0d | 2024-10-07 A | 2024-10-07 A | 1182SS | 100% |  | 2024-10-07 | 2024-10-07 | 0d | 2024-09-03 | 2024-09-09 |  |  | SI Test | PP | SIT | 5.31 | Heath Thomas | Systems Integration Testing (SIT) | SITAG | Complete | COMPLETE |  |  |  |
| 1185 | 1.4.1.4.5.5 | **SIT Operations Manual** |  | 590d? | 2022-10-31 | 2025-01-31 A |  | 100% | 2024-08-01 | 2022-10-31 | 2025-01-31 | 0d |  |  |  |  | Helix |  | SIT | 6.13 | Helix |  |  |  |  | -755.67 |  |  |
| 1186 | 1.4.1.4.5.5.1 | **Version 1 SIT Operations Manual** |  | 35d | 2024-10-07 A | 2024-11-22 A |  | 100% |  | 2024-10-07 | 2024-11-22 | 0d |  |  |  |  | Helix |  | SIT | 6.13 | Helix |  |  |  |  | -755.67 |  |  |
| 1187 | 1.4.1.4.5.5.1.1 | Creation of SIT Operations Manual Template |  | 8d | 2024-10-07 A | 2024-10-16 A |  | 100% |  | 2024-10-07 | 2024-10-16 | 0d |  |  | start no earlier than 2024-10-07 |  | Helix |  | SIT | 6.13 | Helix |  |  | Complete | COMPLETE |  |  |  |
| 1188 | 1.4.1.4.5.5.1.2 | November TORWG Paper Day | milestone | 0d | 2024-11-07 A | 2024-11-07 A | 1187FS+16d | 100% |  | 2024-11-07 | 2024-11-07 | 0d |  |  |  |  | Helix |  | SIT | 6.13 | Helix |  |  | Complete | COMPLETE |  |  |  |
| 1189 | 1.4.1.4.5.5.1.3 | November TORWG (Timeline and Next Steps for SIT Operations Manual) | milestone | 0d | 2024-11-14 A | 2024-11-14 A | 1188FS+5d | 100% |  | 2024-11-14 | 2024-11-14 | 0d |  |  |  |  | Helix |  | SIT | 6.13 | Helix |  |  | Complete | COMPLETE |  |  |  |
| 1190 | 1.4.1.4.5.5.1.4 | SIT Operations Manual Version 1 Shared with MHHSP | milestone | 0d | 2024-11-11 A | 2024-11-11 A | 1187FS+18d | 100% |  | 2024-11-11 | 2024-11-11 | 0d |  |  |  |  | Helix |  | SIT | 6.13 | Helix |  |  | Complete | COMPLETE |  |  |  |
| 1191 | 1.4.1.4.5.5.1.5 | MHHSP provide feedback on SIT Operations Manual Version 1 |  | 9d | 2024-11-12 A | 2024-11-22 A | 1190 | 100% |  | 2024-11-12 | 2024-11-22 | 0d |  |  |  |  | Helix |  | SIT | 6.13 | Helix |  |  | Complete | COMPLETE |  |  |  |
| 1192 | 1.4.1.4.5.5.1.6 | SIT Operations Manual Version 1 Shared with Programme Participants | milestone | 0d | 2024-11-13 A | 2024-11-13 A | 1187FS+20d | 100% |  | 2024-11-13 | 2024-11-13 | 0d |  |  |  |  | Helix |  | SIT | 6.13 | Helix |  |  | Complete | COMPLETE |  |  |  |
| 1193 | 1.4.1.4.5.5.1.7 | PPs provide feedback on SIT Operations Manual Version 1 |  | 7d | 2024-11-14 A | 2024-11-22 A | 1192 | 100% |  | 2024-11-14 | 2024-11-22 | 0d |  |  |  |  | Helix |  | SIT | 6.13 | Helix |  |  | Complete | COMPLETE |  |  |  |
| 1194 | 1.4.1.4.5.5.1.8 | Programme Participants and MHHSP Feedback and Actions Received (SIT Ops Manual Version 1) | milestone | 0d | 2024-11-22 A | 2024-11-22 A | 1193, 1191 | 100% |  | 2024-11-22 | 2024-11-22 | 0d |  |  |  |  | Helix |  | SIT | 6.13 | Helix |  |  | Complete | COMPLETE |  |  |  |
| 1195 | 1.4.1.4.5.5.2 | **Version 2 SIT Operations Manual** |  | 27d | 2024-11-12 A | 2024-12-18 A |  | 100% |  | 2024-11-12 | 2024-12-18 | 0d |  |  |  |  | Helix |  | SIT | 6.13 | Helix |  |  |  |  | -755.67 |  |  |
| 1196 | 1.4.1.4.5.5.2.1 | Version 2 SIT Operations Manual (Composition) |  | 12d | 2024-11-12 A | 2024-11-27 A | 1188FS+2d | 100% |  | 2024-11-12 | 2024-11-27 | 0d |  |  |  |  | Helix |  | SIT | 6.13 | Helix |  |  | Complete | COMPLETE |  |  |  |
| 1197 | 1.4.1.4.5.5.2.2 | Version 2 SIT Operations Manual Completed | milestone | 0d | 2024-11-27 A | 2024-11-27 A | 1196 | 100% |  | 2024-11-27 | 2024-11-27 | 0d |  |  |  |  | Helix |  | SIT | 6.13 | Helix |  | MCAG | Complete | COMPLETE |  | T3-TE-0132 | T3 |
| 1198 | 1.4.1.4.5.5.2.3 | Version 2 SIT Operations Manual Shared with MHHSP & PPs for TORWG (Consultation Starts) | milestone | 0d | 2024-11-27 A | 2024-11-27 A | 1197 | 100% |  | 2024-11-27 | 2024-11-27 | 0d |  |  |  |  | Helix |  | SIT | 6.13 | Helix |  |  | Complete | COMPLETE |  |  |  |
| 1199 | 1.4.1.4.5.5.2.4 | Version 2 SIT Ops Manual - PP Consultation (Iterative Feedback Process) |  | 10d | 2024-11-28 A | 2024-12-11 A | 1198 | 100% |  | 2024-11-28 | 2024-12-11 | 0d |  |  |  |  | Helix |  | SIT | 6.13 | Helix |  |  | Complete | COMPLETE |  |  |  |
| 1200 | 1.4.1.4.5.5.2.5 | Version 2 SIT Ops Manual - PP Consultation Completed | milestone | 0d | 2024-12-11 A | 2024-12-11 A | 1199 | 100% |  | 2024-12-11 | 2024-12-11 | 0d |  |  |  |  | Helix |  | SIT | 6.13 | Helix |  |  | Complete | COMPLETE |  |  |  |
| 1201 | 1.4.1.4.5.5.2.6 | December TORWG Paper Day | milestone | 0d | 2024-12-04 A | 2024-12-04 A | 1196FS+5d | 100% |  | 2024-12-04 | 2024-12-04 | 0d |  |  |  |  | Helix |  | SIT | 6.13 | Helix |  |  | Complete | COMPLETE |  |  |  |
| 1202 | 1.4.1.4.5.5.2.7 | December TORWG (Initial Feedback, Common Themes and Comments) | milestone | 0d | 2024-12-11 A | 2024-12-11 A | 1201FS+5d | 100% |  | 2024-12-11 | 2024-12-11 | 0d |  |  |  |  | Helix |  | SIT | 6.13 | Helix |  |  | Complete | COMPLETE |  |  |  |
| 1203 | 1.4.1.4.5.5.2.8 | December Extraordinary TORWG Paper Day | milestone | 0d | 2024-12-11 A | 2024-12-11 A | 1200 | 100% |  | 2024-12-11 | 2024-12-11 | 0d |  |  |  |  | Helix |  | SIT | 6.13 | Helix |  |  | Complete | COMPLETE |  |  |  |
| 1204 | 1.4.1.4.5.5.2.9 | Publication of key themes from consultation to eTORWG |  | 2d | 2024-12-12 A | 2024-12-13 A | 1203 | 100% |  | 2024-12-12 | 2024-12-13 | 0d |  |  |  |  | Helix |  | SIT | 6.14 |  |  |  | Complete | COMPLETE |  |  |  |
| 1205 | 1.4.1.4.5.5.2.10 | December Extraordinary TORWG (Summary of Version 2 Feedback and Response Approach Shared with PPs) | milestone | 0d | 2024-12-18 A | 2024-12-18 A | 1204FS+3d | 100% |  | 2024-12-18 | 2024-12-18 | 0d |  |  |  |  | Helix |  | SIT | 6.13 | Helix |  |  | Complete | COMPLETE |  |  |  |

| ID | WBS | Task | Type | Duration | Start | Finish | Predecessors | Complete | Actual start | Actual finish | Baseline start | Baseline finish | Baseline duration | Constraint | Responsible | Text9 | Task Status | Update Version | MHHS Resource Name | Sched Status | RAG | Milestone ID | Text29 | Tier |
| --- | --- | --- | --- | --- | --- | --- | --- | --- | --- | --- | --- | --- | --- | --- | --- | --- | --- | --- | --- | --- | --- | --- | --- | --- |
| 1206 | 1.4.1.4.5.5.3 | **Version 3 (Final) SIT Operations Manual** |  | 44d | 2024-11-28 A | 2025-01-28 A |  | 100% |  |  | 2024-11-28 | 2025-01-28 | 0d |  | Helix | SIT | -755.67 | 6.13 | Helix |  |  |  |  |  |
| 1207 | 1.4.1.4.5.5.3.1 | Update SIT Operations Manual (Final) Version 3 (with Comments Received From Version 2) [Pre-Christmas Furlough] |  | 17d | 2024-11-28 A | 2024-12-20 A | 1197, 193FF | 100% |  |  | 2024-11-28 | 2024-12-20 | 0d |  | Helix | SIT |  | 6.13 | Helix | Complete | COMPLETE |  |  |  |
| 1208 | 1.4.1.4.5.5.3.2 | Update SIT Operations Manual (Final) Version 3 (with Comments Received From Version 2) [Post-Christmas Furlough] |  | 5d | 2025-01-02 A | 2025-01-08 A | 1207FS+8d | 100% |  |  | 2025-01-02 | 2025-01-08 | 0d |  | Helix | SIT |  | 6.13 | Helix | Complete | COMPLETE |  |  |  |
| 1209 | 1.4.1.4.5.5.3.3 | SIT Operations Manual (Final) Version 3 Completed | milestone | 0d | 2025-01-08 A | 2025-01-08 A | 1208 | 100% |  |  | 2025-01-08 | 2025-01-08 | 0d |  | Helix | SIT |  | 6.13 | Helix | Complete | COMPLETE | T3-TE-0133 | MCAG | T3 |
| 1210 | 1.4.1.4.5.5.3.4 | January TORWG Paper Day | milestone | 0d | 2025-01-08 A | 2025-01-08 A | 1209 | 100% |  |  | 2025-01-08 | 2025-01-08 | 0d |  | Helix | SIT |  | 6.13 | Helix | Complete | COMPLETE |  |  |  |
| 1211 | 1.4.1.4.5.5.3.5 | January TORWG (SIT Operations Manual Agreement) [Assurance Meeting] | milestone | 0d | 2025-01-15 A | 2025-01-15 A | 1210FS+5d | 100% |  |  | 2025-01-15 | 2025-01-15 | 0d |  | Helix | SIT |  | 6.13 | Helix | Complete | COMPLETE |  |  |  |
| 1212 | 1.4.1.4.5.5.3.6 | January MCAG Paper Day (Final SIT Operations Manual Submitted) | milestone | 0d | 2025-01-21 A | 2025-01-21 A | 1211FS+4d | 100% |  |  | 2025-01-21 | 2025-01-21 | 0d |  | Helix | SIT |  | 6.13 | Helix | Complete | COMPLETE |  |  |  |
| 1213 | 1.4.1.4.5.5.3.7 | January MCAG (Final SIT Operations Manual Endorsement) [Advisory Group Sign-off] | milestone | 0d | 2025-01-28 A | 2025-01-28 A | 1212FS+5d | 100% |  |  | 2025-01-28 | 2025-01-28 | 0d |  | Helix | SIT |  | 6.13 | Helix | Complete | COMPLETE | T3-TE-0135 | MCAG | T3 |
| 1214 | 1.4.1.4.5.5.4 | **Elexon / Helix Service Now Test Prep** |  | 119d? | 2024-08-01 A | 2025-01-14 A |  | 100% |  |  | 2024-07-15 | 2025-01-31 | 0d |  | Helix | SIT | -688.67 | 6.13 | Helix |  |  |  |  |  |
| 1215 | 1.4.1.4.5.5.4.1 | **Incident Management Build** |  | 75d? | 2024-08-05 A | 2024-11-15 A |  | 100% |  |  | 2024-08-05 | 2024-11-15 | 0d |  | Helix | SIT | -728.67 | 6.13 | Helix |  |  |  |  |  |
| 1216 | 1.4.1.4.5.5.4.1.1 | Build |  | 40d | 2024-08-05 A | 2024-09-27 A |  | 100% |  |  | 2024-09-27 | 2024-09-27 | 0d | finish no earlier than 2024-09-27 | Helix | SIT |  | 6.13 | Helix | Complete | COMPLETE |  |  |  |
| 1217 | 1.4.1.4.5.5.4.1.2 | Test |  | 15d | 2024-09-30 A | 2024-10-18 A | 1216 | 100% |  |  | 2024-10-18 | 2024-10-18 | 0d | finish no earlier than 2024-10-18 | Helix | SIT |  | 6.13 | Helix | Complete | COMPLETE |  |  |  |
| 1218 | 1.4.1.4.5.5.4.1.3 | Deploy |  | 20d | 2024-10-21 A | 2024-11-15 A | 1217 | 100% |  |  | 2024-11-15 | 2024-11-15 | 0d | finish no earlier than 2024-11-15 | Helix | SIT |  | 6.13 | Helix | Complete | COMPLETE |  |  |  |
| 1219 | 1.4.1.4.5.5.4.1.4 | Incident Management Build & Configuration Complete | milestone | 0d | 2024-11-15 A | 2024-11-15 A | 1218 | 100% |  |  | 2024-11-15 | 2024-11-15 | 0d |  | Helix | SIT |  | 6.13 | Helix | Complete | COMPLETE |  |  |  |
| 1220 | 1.4.1.4.5.5.4.2 | **Major Incident Management Build & Configuration** |  | 0d? | 2024-11-15 | 2024-11-15 |  | 100% | 2024-10-02 | 2025-01-14 | 2024-10-02 | 2025-01-14 | 0d |  | Helix | SIT | -728.67 | 6.13 | Helix |  |  |  |  |  |
| 1221 | 1.4.1.4.5.5.4.2.1 | Build |  | 40d | 2024-10-02 A | 2024-11-26 A |  | 100% |  |  | 2024-11-26 | 2024-11-26 | 0d | finish no earlier than 2024-11-26 | Helix | SIT |  | 6.13 | Helix | Complete | COMPLETE |  |  |  |
| 1222 | 1.4.1.4.5.5.4.2.2 | Test |  | 15d | 2024-11-27 A | 2024-12-17 A | 1221 | 100% |  |  | 2024-12-17 | 2024-12-17 | 0d | finish no earlier than 2024-12-17 | Helix | SIT |  | 6.13 | Helix | Complete | COMPLETE |  |  |  |
| 1223 | 1.4.1.4.5.5.4.2.3 | Deploy |  | 20d | 2024-12-18 A | 2025-01-14 A | 1222 | 100% |  |  | 2025-01-14 | 2025-01-14 | 0d | finish no earlier than 2025-01-14 | Helix | SIT |  | 6.13 | Helix | Complete | COMPLETE |  |  |  |
| 1224 | 1.4.1.4.5.5.4.2.4 | Major Incident Management Build & Configuration Complete | milestone | 0d | 2025-01-14 A | 2025-01-14 A | 1223 | 100% |  |  | 2025-01-14 | 2025-01-14 | 0d |  | Helix | SIT |  | 6.13 | Helix | Complete | COMPLETE |  |  |  |
| 1225 | 1.4.1.4.5.5.4.3 | **Knowledge Management Build & Configuration** |  | 75d? | 2024-10-02 A | 2025-01-14 A |  | 100% |  |  | 2024-10-02 | 2025-01-14 | 0d |  | Helix | SIT | -728.67 | 6.13 | Helix |  |  |  |  |  |
| 1226 | 1.4.1.4.5.5.4.3.1 | Build |  | 40d | 2024-10-02 A | 2024-11-26 A |  | 100% |  |  | 2024-11-26 | 2024-11-26 | 0d | finish no earlier than 2024-11-26 | Helix | SIT |  | 6.13 | Helix | Complete | COMPLETE |  |  |  |
| 1227 | 1.4.1.4.5.5.4.3.2 | Test |  | 15d | 2024-11-27 A | 2024-12-17 A | 1226 | 100% |  |  | 2024-12-17 | 2024-12-17 | 0d | finish no earlier than 2024-12-17 | Helix | SIT |  | 6.13 | Helix | Complete | COMPLETE |  |  |  |
| 1228 | 1.4.1.4.5.5.4.3.3 | Deploy |  | 20d | 2024-12-18 A | 2025-01-14 A | 1227 | 100% |  |  | 2025-01-14 | 2025-01-14 | 0d | finish no earlier than 2025-01-14 | Helix | SIT |  | 6.13 | Helix | Complete | COMPLETE |  |  |  |
| 1229 | 1.4.1.4.5.5.4.3.4 | Knowledge Management Build & Configuration Complete | milestone | 0d | 2025-01-14 A | 2025-01-14 A | 1228 | 100% |  |  | 2025-01-14 | 2025-01-14 | 0d |  | Helix | SIT |  | 6.13 | Helix | Complete | COMPLETE |  |  |  |

| ID | WBS | Task | Type | Duration | Start | Finish | Predecessors | Complete | Actual start | Actual finish | Baseline start | Baseline finish | Baseline duration | Constraint | Responsible | Text9 | Task Status | Update Version | MHHS Resource Name | Sched Status | RAG | Milestone ID | Text29 | Tier |
| --- | --- | --- | --- | --- | --- | --- | --- | --- | --- | --- | --- | --- | --- | --- | --- | --- | --- | --- | --- | --- | --- | --- | --- | --- |
| 1230 | 1.4.1.4.5.5.4.4 | **Problem Management Build & Configuration** |  | 1d? | 2024-08-01 | 2024-08-01 |  | 100% | 2024-10-02 | 2025-01-14 | 2024-10-02 | 2025-01-14 | 0d |  | Helix | SIT | -728.67 | 6.13 | Helix |  |  |  |  |  |
| 1231 | 1.4.1.4.5.5.4.4.1 | Build |  | 40d | 2024-10-02 A | 2024-11-26 A |  | 100% |  |  | 2024-11-26 | 2024-11-26 | 0d | finish no earlier than 2024-11-26 | Helix | SIT |  | 6.13 | Helix | Complete | COMPLETE |  |  |  |
| 1232 | 1.4.1.4.5.5.4.4.2 | Test |  | 15d | 2024-11-27 A | 2024-12-17 A | 1231 | 100% |  |  | 2024-12-17 | 2024-12-17 | 0d | finish no earlier than 2024-12-17 | Helix | SIT |  | 6.13 | Helix | Complete | COMPLETE |  |  |  |
| 1233 | 1.4.1.4.5.5.4.4.3 | Deploy |  | 20d | 2024-12-18 A | 2025-01-14 A | 1232 | 100% |  |  | 2025-01-14 | 2025-01-14 | 0d | finish no earlier than 2025-01-14 | Helix | SIT |  | 6.13 | Helix | Complete | COMPLETE |  |  |  |
| 1234 | 1.4.1.4.5.5.4.4.4 | Problem Management Build & Configuration Complete | milestone | 0d | 2025-01-14 A | 2025-01-14 A | 1233 | 100% |  |  | 2025-01-14 | 2025-01-14 | 0d | start no earlier than 2025-01-14 | Helix | SIT |  | 6.13 | Helix | Complete | COMPLETE |  |  |  |
| 1235 | 1.4.1.4.5.5.4.5 | **Change Management Build & Configuration** |  | 75d? | 2024-10-02 A | 2025-01-14 A |  | 100% |  |  | 2024-10-02 | 2025-01-14 | 0d |  | Helix | SIT | -728.67 | 6.13 | Helix |  |  |  |  |  |
| 1236 | 1.4.1.4.5.5.4.5.1 | Build |  | 40d | 2024-10-02 A | 2024-11-26 A |  | 100% |  |  | 2024-11-26 | 2024-11-26 | 0d | finish no earlier than 2024-11-26 | Helix | SIT |  | 6.13 | Helix | Complete | COMPLETE |  |  |  |
| 1237 | 1.4.1.4.5.5.4.5.2 | Test |  | 15d | 2024-11-27 A | 2024-12-17 A | 1236 | 100% |  |  | 2024-12-17 | 2024-12-17 | 0d | finish no earlier than 2024-12-17 | Helix | SIT |  | 6.13 | Helix | Complete | COMPLETE |  |  |  |
| 1238 | 1.4.1.4.5.5.4.5.3 | Deploy |  | 20d | 2024-12-18 A | 2025-01-14 A | 1237 | 100% |  |  | 2025-01-14 | 2025-01-14 | 0d | finish no earlier than 2025-01-14 | Helix | SIT |  | 6.13 | Helix | Complete | COMPLETE |  |  |  |
| 1239 | 1.4.1.4.5.5.4.5.4 | Change Management Build & Configuration Complete | milestone | 0d | 2025-01-14 A | 2025-01-14 A | 1238 | 100% |  |  | 2025-01-14 | 2025-01-14 | 0d | start no earlier than 2025-01-14 | Helix | SIT |  | 6.13 | Helix | Complete | COMPLETE |  |  |  |
| 1240 | 1.4.1.4.5.5.4.6 | **Service Catalogue Management Build & Configuration** |  | 75d? | 2024-10-02 A | 2025-01-14 A |  | 100% |  |  | 2024-10-02 | 2025-01-14 | 0d |  | Helix | SIT | -728.67 | 6.13 | Helix |  |  |  |  |  |
| 1241 | 1.4.1.4.5.5.4.6.1 | Build |  | 40d | 2024-10-02 A | 2024-11-26 A |  | 100% |  |  | 2024-11-26 | 2024-11-26 | 0d | finish no earlier than 2024-11-26 | Helix | SIT |  | 6.13 | Helix | Complete | COMPLETE |  |  |  |
| 1242 | 1.4.1.4.5.5.4.6.2 | Test |  | 15d | 2024-11-27 A | 2024-12-17 A | 1241 | 100% |  |  | 2024-12-17 | 2024-12-17 | 0d | finish no earlier than 2024-12-17 | Helix | SIT |  | 6.13 | Helix | Complete | COMPLETE |  |  |  |
| 1243 | 1.4.1.4.5.5.4.6.3 | Deploy |  | 20d | 2024-12-18 A | 2025-01-14 A | 1242 | 100% |  |  | 2025-01-14 | 2025-01-14 | 0d | finish no earlier than 2025-01-14 | Helix | SIT |  | 6.13 | Helix | Complete | COMPLETE |  |  |  |
| 1244 | 1.4.1.4.5.5.4.6.4 | Service Catalogue Management Build & Configuration Complete | milestone | 0d | 2025-01-14 A | 2025-01-14 A | 1243 | 100% |  |  | 2025-01-14 | 2025-01-14 | 0d | start no earlier than 2025-01-14 | Helix | SIT |  | 6.13 | Helix | Complete | COMPLETE |  |  |  |
| 1245 | 1.4.1.4.5.5.4.7 | ServiceNow SIT Ops Available | milestone | 0d? | 2025-01-14 A | 2025-01-14 A | 1219, 1224, 1229, 1234, 1239, 1244 | 100% |  |  | 2025-01-14 | 2025-01-14 | 0d | start no earlier than 2024-09-09 | Helix | SIT |  | 6.13 | Helix | Complete | COMPLETE | T3-TE-0136 | SITAG | T3 |
| 1246 | 1.4.1.4.5.5.4.8 | **Helix Service Management Documentation (Service Design Pack)** |  | 115d | 2024-08-01 A | 2025-01-08 A |  | 100% |  |  | 2024-09-09 | 2025-01-31 | 0d |  | Helix | SIT | -49.67 | 6.0 | Helix |  |  |  |  |  |
| 1247 | 1.4.1.4.5.5.4.8.1 | Document Drafting |  | 95d | 2024-08-01 A | 2024-12-11 A |  | 100% |  |  | 2024-08-01 | 2024-12-11 | 0d | finish no earlier than 2024-12-11 | Helix | SIT |  | 6.11 | Helix | Complete | COMPLETE |  |  |  |
| 1248 | 1.4.1.4.5.5.4.8.2 | Internal Elexon Review |  | 3d | 2025-01-06 A | 2025-01-08 A | 1247 | 100% |  |  | 2024-12-12 | 2024-12-16 | 0d | finish no earlier than 2024-12-16 | Helix | SIT |  | 6.11 | Helix | Complete | COMPLETE |  |  |  |
| 1249 | 1.4.1.4.5.5.4.8.3 | Elexon Service Panel Sign off | milestone | 0d | 2025-01-08 A | 2025-01-08 A | 1248 | 100% |  |  | 2024-12-20 | 2024-12-20 | 0d | start no earlier than 2024-12-20 | Helix | SIT |  | 6.11 | Helix | Complete | COMPLETE |  |  |  |
| 1250 | 1.4.1.4.5.5.5 | **Incident Management Support** |  | 1d? | 2022-10-31 | 2022-10-31 |  | 100% | 2024-12-02 | 2025-01-17 | 2022-10-31 | 2022-10-31 | 0d |  | Helix | SIT | -755.67 | 6.13 | Helix |  | 25d |  |  |  |
| 1251 | 1.4.1.4.5.5.5.1 | Identify Relevant Stakeholders to Support Incident Management Process |  | 10d | 2024-12-02 A | 2024-12-13 A |  | 100% |  |  | 2024-11-18 | 2024-11-29 | 0d | start no earlier than 2024-12-02 | Helix | SIT |  | 6.13 | Helix | Complete | COMPLETE |  |  |  |
| 1252 | 1.4.1.4.5.5.5.2 | Schedule Time to Upskill Stakeholders |  | 5d | 2024-12-16 A | 2024-12-20 A | 1251 | 100% |  |  | 2024-12-02 | 2024-12-06 | 0d |  | Helix | SIT |  | 6.13 | Helix | Complete | COMPLETE |  |  |  |
| 1253 | 1.4.1.4.5.5.5.3 | Helix Stakeholders Attendance at MHHS Defect Triage Meetings [Meeting Dates to be Confirmed] |  | 10d | 2025-01-06 A | 2025-01-17 A | 1252FS+10d | 100% |  |  | 2024-12-09 | 2024-12-20 | 0d |  | Helix | SIT |  | 6.13 | Helix | Complete | COMPLETE |  |  |  |
| 1254 | 1.4.1.4.5.5.6 | SIT Service Readiness (Elexon & Helix) Completed | milestone | 0d | 2025-01-17 A | 2025-01-17 A | 1253 | 100% |  |  | 2024-12-20 | 2024-12-20 | 0d |  | Helix | SIT |  | 6.13 | Helix | Complete | COMPLETE |  |  |  |

| ID | WBS | Task | Type | Duration | Start | Finish | Predecessors | Complete | Actual start | Actual finish | Baseline start | Baseline finish | Baseline duration | Constraint | Responsible | Text9 | Update Version | MHHS Resource Name | Sched Status | RAG | Task Status | Milestone ID | Text29 | Tier |
| --- | --- | --- | --- | --- | --- | --- | --- | --- | --- | --- | --- | --- | --- | --- | --- | --- | --- | --- | --- | --- | --- | --- | --- | --- |
| 1255 | 1.4.1.4.5.5.7 | **SIT Service Readiness (External Parties)** |  | 85d | 2024-10-07 A | 2025-01-31 A |  | 100% |  |  | 2024-09-30 | 2025-01-06 | 0d |  | Helix | SIT | 6.13 | Helix |  |  |  |  |  |  |
| 1256 | 1.4.1.4.5.5.7.1 | **Helix Engagement & Comms** |  | 71d | 2024-10-07 A | 2025-01-13 A |  | 100% |  |  | 2024-09-30 | 2025-01-06 | 0d |  | Helix | SIT | 6.13 | Helix |  |  |  |  |  |  |
| 1257 | 1.4.1.4.5.5.7.1.1 | Engagement Execution |  | 71d | 2024-10-07 A | 2025-01-13 A |  | 100% |  |  | 2024-10-07 | 2025-01-06 | 0d | finish no earlier than 2025-01-13 | Helix | SIT | 6.13 | Helix | Complete | COMPLETE |  |  |  |  |
| 1258 | 1.4.1.4.5.5.7.1.2 | Information Gathering |  | 32d | 2024-11-29 A | 2025-01-13 A |  | 100% |  |  | 2024-10-31 | 2024-11-27 | 0d | finish no earlier than 2025-01-13 | Helix | SIT | 6.13 | Helix | Complete | COMPLETE |  |  |  |  |
| 1259 | 1.4.1.4.5.5.7.1.3 | SIT Participants Preparation |  | 9d | 2024-11-28 A | 2024-12-10 A |  | 100% |  |  | 2024-11-22 | 2025-01-06 | 0d | start no earlier than 2024-11-28 | Helix | SIT | 6.13 | Helix | Complete | COMPLETE |  |  |  |  |
| 1260 | 1.4.1.4.5.5.7.2 | SIT Service Readiness (External Parties) Completed | milestone | 0d | 2025-01-31 A | 2025-01-31 A | 1257FS+9d, 1258, 1259, 1277 | 100% |  |  | 2025-01-06 | 2025-01-06 | 0d |  | Helix | SIT | 6.13 | Helix | Complete | COMPLETE |  |  |  |  |
| 1261 | 1.4.1.4.5.5.8 | **ServiceNow Support Portal Onboarding (Helix Suppliers & SIT Participants)** |  | 78d? | 2024-10-02 A | 2025-01-17 |  | 100% |  | 2025-01-31 | 2024-10-02 | 2025-01-17 | 0d |  | Helix | SIT | 6.13 | Helix |  |  | -755.67 |  |  |  |
| 1262 | 1.4.1.4.5.5.8.1 | **ServiceNow Portal Preparation and Planning** |  | 40d? | 2024-10-02 A | 2024-11-26 A |  | 100% |  |  | 2024-10-02 | 2024-11-26 | 0d |  | Helix | SIT | 6.13 | Helix |  |  | -755.67 |  |  |  |
| 1263 | 1.4.1.4.5.5.8.1.1 | Define Supplier Requirements |  | 30d? | 2024-10-02 A | 2024-11-12 A |  | 100% |  |  | 2024-10-02 | 2024-11-12 | 0d | start no earlier than 2024-10-02 | Helix | SIT | 6.13 | Helix | Complete | COMPLETE |  |  |  |  |
| 1264 | 1.4.1.4.5.5.8.1.2 | Determine Supplier ServiceNow modules |  | 10d? | 2024-11-13 A | 2024-11-26 A | 1263 | 100% |  |  | 2024-11-13 | 2024-11-26 | 0d | finish no earlier than 2024-11-26 | Helix | SIT | 6.13 | Helix | Complete | COMPLETE |  |  |  |  |
| 1265 | 1.4.1.4.5.5.8.1.3 | Review compliance requirements, including data privacy and access limitations. |  | 10d? | 2024-11-13 A | 2024-11-26 A | 1263 | 100% |  |  | 2024-11-13 | 2024-11-26 | 0d | finish no earlier than 2024-11-26 | Helix | SIT | 6.13 | Helix | Complete | COMPLETE |  |  |  |  |
| 1266 | 1.4.1.4.5.5.8.1.4 | Conduct a security assessment to ensure the supplier complies with organisational policies. |  | 10d? | 2024-11-13 A | 2024-11-26 A | 1263 | 100% |  |  | 2024-11-13 | 2024-11-26 | 0d | finish no earlier than 2024-11-26 | Helix | SIT | 6.13 | Helix | Complete | COMPLETE |  |  |  |  |
| 1267 | 1.4.1.4.5.5.8.2 | **ServiceNow Portal System Configuration** |  | 48d? | 2024-11-27 A | 2025-01-31 A |  | 100% |  |  | 2024-11-27 | 2025-01-07 | 0d |  | Helix | SIT | 6.13 | Helix |  |  | -755.67 |  |  |  |
| 1268 | 1.4.1.4.5.5.8.2.1 | Create Supplier User Accounts |  | 48d | 2024-11-27 A | 2025-01-31 A | 1266 | 100% |  |  | 2024-11-27 | 2024-12-10 | 0d | finish no earlier than 2025-01-31 | Helix | SIT | 6.13 | Helix | Complete | COMPLETE |  |  |  |  |
| 1269 | 1.4.1.4.5.5.8.2.2 | Assign appropriate access based on the supplier’s needs and security requirements (e.g., read-only access, submit requests, etc.). |  | 25d? | 2024-12-30 A | 2025-01-31 A | 1268FF | 100% |  |  | 2024-12-11 | 2024-12-24 | 0d | finish no earlier than 2024-12-24 | Helix | SIT | 6.13 | Helix | Complete | COMPLETE |  |  |  |  |
| 1270 | 1.4.1.4.5.5.8.2.3 | Configure Access Controls |  | 25d? | 2024-12-30 A | 2025-01-31 A | 1269FF | 100% |  |  | 2024-12-25 | 2025-01-07 | 0d | finish no earlier than 2025-01-07 | Helix | SIT | 6.13 | Helix | Complete | COMPLETE |  |  |  |  |
| 1271 | 1.4.1.4.5.5.8.3 | **ServiceNow Portal Training and Documentation** |  | 20d? | 2025-01-06 A | 2025-01-31 A |  | 100% |  |  | 2025-01-06 | 2025-01-10 | 0d |  | Helix | SIT | 6.13 | Helix |  |  | -755.67 |  |  |  |
| 1272 | 1.4.1.4.5.5.8.3.1 | Provide Training to the Supplier |  | 1d | 2025-01-31 A | 2025-01-31 A |  | 100% |  |  | 2025-01-06 | 2025-01-10 | 0d | finish no earlier than 2025-01-31 | Helix | SIT | 6.13 | Helix | Complete | COMPLETE |  |  |  |  |
| 1273 | 1.4.1.4.5.5.8.3.2 | Create Supplier Training Documentation |  | 20d | 2025-01-06 A | 2025-01-31 A |  | 100% |  |  | 2025-01-06 | 2025-01-10 | 0d | finish no earlier than 2025-01-31 | Helix | SIT | 6.13 | Helix | Complete | COMPLETE |  |  |  |  |
| 1274 | 1.4.1.4.5.5.8.4 | **ServiceNow Portal Testing and Validation** |  | 18d | 2025-01-08 | 2025-01-31 A |  | 100% | 2025-01-28 |  | 2025-01-08 | 2025-01-17 | 0d |  | Helix | SIT | 6.13 | Helix |  |  | -755.67 |  |  |  |
| 1275 | 1.4.1.4.5.5.8.4.1 | Conduct User Acceptance Testing (UAT) |  | 1d | 2025-01-31 A | 2025-01-31 A | 1272SS | 100% |  |  | 2025-01-13 | 2025-01-17 | 0d | finish no earlier than 2025-01-17 | Helix | SIT | 6.13 | Helix | Complete | COMPLETE |  |  |  |  |
| 1276 | 1.4.1.4.5.5.8.4.2 | Validate Access and Security Controls |  | 4d | 2025-01-28 A | 2025-01-31 A |  | 100% |  |  | 2025-01-13 | 2025-01-17 | 0d | finish no earlier than 2025-01-31 | Helix | SIT | 6.13 | Helix | Complete | COMPLETE |  |  |  |  |
| 1277 | 1.4.1.4.5.5.8.5 | ServiceNow Support Portal Onboarding (Helix Suppliers& SIT Participants) Completed | milestone | 0d | 2025-01-31 A | 2025-01-31 A | 1266, 1270, 1273, 1276, 1272 | 100% |  |  | 2025-01-17 | 2025-01-17 | 0d | start no earlier than 2025-01-17 | Helix | SIT | 6.13 | Helix | Complete | COMPLETE |  |  |  |  |
| 1278 | 1.4.1.4.5.5.9 | Stage 1 - Helix SIT Operational Readiness Completed | milestone | 0d | 2025-01-31 A | 2025-01-31 A | 1260, 1245, 1213 | 100% |  |  | 2025-01-31 | 2025-01-31 | 0d | start no earlier than 2025-01-31 | Helix | SIT | 6.13 | Helix | Complete | COMPLETE |  | T3-TE-0137 | SITAG | T3 |

| ID | WBS | Task | Type | Duration | Start | Finish | Predecessors | Complete | Baseline start | Baseline finish | Baseline duration | Constraint | Baseline cost | Text9 | Task Status | Update Version | Responsible | Involved | MHHS Resource Name | MHHS Programme Phase | Text29 | Sched Status | RAG | Milestone ID | Tier | Guidance |
| --- | --- | --- | --- | --- | --- | --- | --- | --- | --- | --- | --- | --- | --- | --- | --- | --- | --- | --- | --- | --- | --- | --- | --- | --- | --- | --- |
| 1279 | 1.4.1.4.5.6 | **Theme 3 Test Cases Approved** |  | 246d? | 2024-04-10 A | 2025-03-19 A |  | 100% |  |  |  |  |  | SIT | -827.67 | 6.18 |  |  |  |  |  |  |  |  |  |  |
| 1280 | 1.4.1.4.5.6.1 | **Theme 3 (Batch 2)** |  | 64d | 2024-09-19 A | 2024-12-18 A |  | 100% | 2024-09-19 | 2024-12-11 | 116d |  | -0 | SIT | -448.67 | 6.0 | N/A | N/A | Steve Evans | Systems Integration Testing (SIT) | SITAG |  |  |  |  |  |
| 1281 | 1.4.1.4.5.6.1.1 | Conclude BCDR Scope with SRO, Code Bodies and DIP Manager |  | 22d | 2024-09-19 A | 2024-10-18 A |  | 100% | 2024-09-19 | 2024-10-18 | 0d | start no earlier than 2024-09-19 |  | SIT |  | 6.0 | SI Test |  | Steve Evans |  | SITAG | Complete | COMPLETE |  |  |  |
| 1282 | 1.4.1.4.5.6.1.2 | Develop BDCR Test Scenarios & Test Cases (Batch 2) |  | 10d | 2024-10-14 A | 2024-10-25 A | 1281 | 100% | 2024-10-14 | 2024-10-25 | 0d |  |  | SIT |  | 6.0 | SI Test |  | Steve Evans |  | SITAG | Complete | COMPLETE |  |  |  |
| 1283 | 1.4.1.4.5.6.1.3 | Develop DIP Test Scenarios and Test Cases (Batch 2) |  | 27d | 2024-09-19 A | 2024-10-25 A |  | 100% | 2024-09-19 | 2024-10-25 | 0d | start no earlier than 2024-09-19 |  | SIT |  | 6.0 | SI Test |  | Steve Evans |  | SITAG | Complete | COMPLETE |  |  |  |
| 1284 | 1.4.1.4.5.6.1.4 | SRO Review |  | 5d | 2024-10-28 A | 2024-11-01 A | 1283 | 100% | 2024-10-28 | 2024-11-01 | 0d | start no earlier than 2024-10-28 |  | SIT |  | 6.0 | SI Test |  | Steve Evans |  | SITAG | Complete | COMPLETE |  |  |  |
| 1285 | 1.4.1.4.5.6.1.5 | Industry Consultation (Batch 2) |  | 10d | 2024-11-11 A | 2024-11-22 A | 1284 | 100% | 2024-11-11 | 2024-11-22 | 1d |  |  | SIT |  | 6.0 | SI Test, PP | SI Test, PP | Steve Evans |  | SITAG | Complete | COMPLETE |  |  |  |
| 1286 | 1.4.1.4.5.6.1.6 | Review Feedback and Update |  | 4d | 2024-11-25 A | 2024-11-28 A | 1285 | 100% | 2024-11-25 | 2024-11-29 | 0d |  |  | SIT |  | 6.13 | SI Test |  | Steve Evans |  | SITAG | Complete | COMPLETE |  |  |  |
| 1287 | 1.4.1.4.5.6.1.7 | SITWG paper day | milestone | 0d | 2024-11-28 A | 2024-11-28 A | 1286 | 100% | 2024-11-28 | 2024-11-28 | 0d |  |  | SIT |  | 6.13 | SI Test |  | Steve Evans |  | SITAG | Complete | COMPLETE |  |  |  |
| 1288 | 1.4.1.4.5.6.1.8 | Review with SIT WG (Batch 2) |  | 5d | 2024-11-29 A | 2024-12-05 A | 1287 | 100% | 2024-11-29 | 2024-12-05 | 0d |  |  | SIT |  | 6.13 | SI Test |  | Steve Evans |  | SITAG | Complete | COMPLETE |  |  |  |
| 1289 | 1.4.1.4.5.6.1.9 | SITWG endorse Theme 3 (Batch 2) | milestone | 0d | 2024-12-05 A | 2024-12-05 A | 1288 | 100% | 2024-12-05 | 2024-12-05 | 0d |  |  | SIT |  | 6.13 | SI Test |  | Steve Evans |  | SITAG | Complete | COMPLETE |  |  |  |
| 1290 | 1.4.1.4.5.6.1.10 | SITAG paper day | milestone | 0d | 2024-12-11 A | 2024-12-11 A | 1289FS+4d | 100% | 2024-12-11 | 2024-12-11 | 0d |  |  | SIT |  | 6.13 | SI Test |  | Steve Evans |  | SITAG | Complete | COMPLETE |  |  |  |
| 1291 | 1.4.1.4.5.6.1.11 | SITAG approve Theme 3 (Batch 2) | milestone | 0d | 2024-12-18 A | 2024-12-18 A | 1290FS+5d | 100% | 2024-12-18 | 2024-12-18 | 0d |  |  | SIT |  | 6.13 | SI Test |  | Steve Evans |  | SITAG | Complete | COMPLETE | T3-TE-0138 | T3 |  |
| 1292 | 1.4.1.4.5.6.2 | **Theme 3 (Batch 1)** |  | 181d? | 2024-04-10 A | 2024-12-18 A |  | 100% | 2024-04-10 | 2024-12-11 | 0d |  |  | SIT | -688.67 | 6.0 | SI Test |  | Steve Evans |  | SITAG |  |  |  |  |  |
| 1293 | 1.4.1.4.5.6.2.1 | Develop Test Scenarios & Test Cases (Batch 1) |  | 78d | 2024-04-10 A | 2024-07-26 A | 1160 | 100% | 2024-04-10 | 2024-07-26 | 46d |  |  | SIT |  | 6.0 | SI Test | SI Test, PP | Steve Evans |  | SITAG | Complete | COMPLETE |  |  |  |
| 1294 | 1.4.1.4.5.6.2.2 | Conclude Industry Consultation (Batch 1) |  | 11d | 2024-09-05 A | 2024-09-19 A |  | 100% | 2024-09-05 | 2024-09-19 | 0d | start no earlier than 2024-09-05 |  | SIT |  | 6.0 | SI Test |  | Steve Evans |  | SITAG | Complete | COMPLETE |  |  |  |
| 1295 | 1.4.1.4.5.6.2.3 | Review Feedback and Update |  | 5d | 2024-09-20 A | 2024-09-26 A | 1294 | 100% | 2024-09-20 | 2024-09-26 | 0d |  |  | SIT |  | 6.0 | SI Test |  | Steve Evans |  | SITAG | Complete | COMPLETE |  |  |  |
| 1296 | 1.4.1.4.5.6.2.4 | Draft Test Cases from Feedback and LLSD |  | 15d? | 2024-09-30 A | 2024-10-18 A | 1295FS+1d, 1318 | 100% | 2024-09-30 | 2024-10-18 | 0d |  |  | SIT |  | 6.0 | SI Test |  | Steve Evans |  | SITAG | Complete | COMPLETE |  |  |  |
| 1297 | 1.4.1.4.5.6.2.5 | SRO Review |  | 5d? | 2024-10-21 A | 2024-10-25 A | 1296 | 100% | 2024-10-21 | 2024-10-25 | 0d |  |  | SIT |  | 6.0 | SI Test |  | Steve Evans |  | SITAG | Complete | COMPLETE |  |  |  |
| 1298 | 1.4.1.4.5.6.2.6 | Industry Consultation |  | 10d? | 2024-10-28 A | 2024-11-08 A | 1297 | 100% | 2024-10-28 | 2024-11-08 | 0d |  |  | SIT |  | 6.0 | SI Test |  | Steve Evans |  | SITAG | Complete | COMPLETE |  |  |  |
| 1299 | 1.4.1.4.5.6.2.7 | Review Feedback and Update |  | 10d | 2024-11-11 A | 2024-11-22 A | 1298 | 100% | 2024-11-11 | 2024-11-15 | 0d |  |  | SIT |  | 6.0 | SI Test |  | Steve Evans |  | SITAG | Complete | COMPLETE |  |  |  |
| 1300 | 1.4.1.4.5.6.2.8 | SITWG paper day | milestone | 0d | 2024-11-28 A | 2024-11-28 A | 1299FS+4d | 100% | 2024-11-28 | 2024-11-28 | 0d |  |  | SIT |  | 6.13 | SI Test |  | Steve Evans |  | SITAG | Complete | COMPLETE |  |  |  |
| 1301 | 1.4.1.4.5.6.2.9 | Review with SITWG (Batch 1) |  | 5d | 2024-11-29 A | 2024-12-05 A | 1300 | 100% | 2024-11-29 | 2024-12-05 | 0d |  |  | SIT |  | 6.13 | SI Test |  | Steve Evans |  | SITAG | Complete | COMPLETE |  |  |  |
| 1302 | 1.4.1.4.5.6.2.10 | SITWG endorse Theme 3 (Batch 1) | milestone | 0d | 2024-12-05 A | 2024-12-05 A | 1301 | 100% | 2024-12-05 | 2024-12-05 | 0d |  |  | SIT |  | 6.13 | SI Test |  | Steve Evans |  | SITAG | Complete | COMPLETE |  |  |  |
| 1303 | 1.4.1.4.5.6.2.11 | SITAG paper day | milestone | 0d | 2024-12-11 A | 2024-12-11 A | 1302FS+4d | 100% | 2024-12-11 | 2024-12-11 | 0d |  |  | SIT |  | 6.13 | SI Test |  | Steve Evans |  | SITAG | Complete | COMPLETE |  |  |  |
| 1304 | 1.4.1.4.5.6.2.12 | SITAG approve Theme 3 (Batch 1) | milestone | 0d | 2024-12-18 A | 2024-12-18 A | 1303FS+5d | 100% | 2024-12-18 | 2024-12-18 | 0d |  |  | SIT |  | 6.13 | SI Test |  | Steve Evans |  | SITAG | Complete | COMPLETE | T3-TE-0139 | T3 |  |
| 1305 | 1.4.1.4.5.6.2.13 | SIT Operational Scenarios & Test Cases Approved - Theme 3 (Batch 1 + 2) | milestone | 0d | 2024-12-18 A | 2024-12-18 A | 1318, 1291, 1304 | 100% | 2024-12-18 | 2024-12-18 | 0d |  |  | SIT |  | 6.13 | SI Test | SI Test, PP | Steve Evans | Systems Integration Testing (SIT) | SITAG | Complete | COMPLETE | T3-TE-0119 | T3 | 31/7/24: baseline date change approved at esitag on 26/7/24 |

| ID | WBS | Task | Type | Duration | Start | Finish | Predecessors | Complete | Baseline start | Baseline finish | Baseline duration | Constraint | Responsible | Text9 | Task Status | Update Version | MHHS Resource Name | Text29 | Sched Status | RAG |
| --- | --- | --- | --- | --- | --- | --- | --- | --- | --- | --- | --- | --- | --- | --- | --- | --- | --- | --- | --- | --- |
| 1306 | 1.4.1.4.5.6.3 | **Theme 3 (Batch 2) Supplementary** |  | 33d | 2025-02-03 A | 2025-03-19 A |  | 100% | 2025-02-03 | 2025-03-19 | 0d |  | SI Test | SIT | -827.67 | 6.18 | Steve Evans | SITAG |  |  |
| 1307 | 1.4.1.4.5.6.3.1 | Conclude DIP Onboarding / Offboarding Scope with DIP Manager |  | 5d | 2025-02-03 A | 2025-02-07 A |  | 100% | 2025-02-03 | 2025-02-07 | 0d | start no earlier than 2025-02-03 | SI Test | SIT |  | 6.18 | Steve Evans | SITAG | Complete | COMPLETE |
| 1308 | 1.4.1.4.5.6.3.2 | Develop DIP Onboarding / Offboarding Test Scenarios & Test Cases (Batch 2) Supplementary |  | 2d | 2025-02-10 A | 2025-02-11 A | 1307 | 100% | 2025-02-10 | 2025-02-11 | 0d |  | SI Test | SIT |  | 6.18 | Steve Evans | SITAG | Complete | COMPLETE |
| 1309 | 1.4.1.4.5.6.3.3 | SRO Review |  | 5d | 2025-02-12 A | 2025-02-18 A | 1308 | 100% | 2025-02-12 | 2025-02-18 | 0d |  | SI Test | SIT |  | 6.18 | Steve Evans | SITAG | Complete | COMPLETE |
| 1310 | 1.4.1.4.5.6.3.4 | Industry Consultation (Batch 2) Supplementary |  | 10d | 2025-02-19 A | 2025-03-04 A | 1309 | 100% | 2025-02-19 | 2025-03-04 | 0d |  | SI Test | SIT |  | 6.18 | Steve Evans | SITAG | Complete | COMPLETE |
| 1311 | 1.4.1.4.5.6.3.5 | SITWG Paper Day | milestone | 0d | 2025-02-27 A | 2025-02-27 A | 1310SS+7d, 1309FS+7d | 100% | 2025-02-27 | 2025-02-27 | 0d |  | SI Test | SIT |  | 6.18 | Steve Evans | SITAG | Complete | COMPLETE |
| 1312 | 1.4.1.4.5.6.3.6 | Review Feedback and Update |  | 1d | 2025-03-05 A | 2025-03-05 A | 1310 | 100% | 2025-03-05 | 2025-03-05 | 0d |  | SI Test | SIT |  | 6.18 | Steve Evans | SITAG | Complete | COMPLETE |
| 1313 | 1.4.1.4.5.6.3.7 | SITWG endorse Theme 3 (Batch 2) Supplementary | milestone | 0d | 2025-03-06 A | 2025-03-06 A | 1310, 1311, 1312FS+1d | 100% | 2025-03-06 | 2025-03-06 | 0d |  | SI Test | SIT |  | 6.18 | Steve Evans | SITAG | Complete | COMPLETE |
| 1314 | 1.4.1.4.5.6.3.8 | SITAG paper day | milestone | 0d | 2025-03-12 A | 2025-03-12 A | 1313FS+4d | 100% | 2025-03-12 | 2025-03-12 | 0d |  | SI Test | SIT |  | 6.18 | Steve Evans | SITAG | Complete | COMPLETE |
| 1315 | 1.4.1.4.5.6.3.9 | SITAG approve Theme 3 (Batch 2) Supplementary | milestone | 0d | 2025-03-19 A | 2025-03-19 A | 1314FS+5d | 100% | 2025-03-19 | 2025-03-19 | 0d |  | SI Test | SIT |  | 6.18 | Steve Evans | SITAG | Complete | COMPLETE |
| 1316 | 1.4.1.4.5.7 | **Helix SDD and LLSD Development and Approval** |  | 1d | 2024-09-27 A | 2024-09-30 A |  | 100% | 2024-09-27 | 2024-09-30 | 0d |  | SI Test | SIT | -688.67 | 6.0 | Steve Evans | SITAG |  |  |
| 1317 | 1.4.1.4.5.7.1 | Development | milestone | 0d | 2024-09-27 A | 2024-09-27 A |  | 100% | 2024-09-27 | 2024-09-27 | 0d | start no earlier than 2024-09-27 | SI Test | SIT |  | 6.0 | Steve Evans | SITAG | Complete | COMPLETE |
| 1318 | 1.4.1.4.5.7.2 | Approval | milestone | 0d | 2024-09-30 A | 2024-09-30 A |  | 100% | 2024-09-30 | 2024-09-30 | 0d | start no earlier than 2024-09-30 | SI Test | SIT |  | 6.0 | Steve Evans | SITAG | Complete | COMPLETE |
| 1319 | 1.4.1.4.5.8 | **SIT Operational Programme RTTM (Theme 3 (Batch 1))** |  | 35d | 2024-12-09 A | 2025-01-24 A |  | 100% | 2024-12-12 | 2025-01-17 | 0d |  | SI Test | SIT | -686.67 | 6.12 | Steve Evans | SITAG |  |  |
| 1320 | 1.4.1.4.5.8.1 | Develop SIT Operational Theme 3 (Batch 1) RTTM |  | 25d | 2024-12-09 A | 2025-01-10 A | 1305FF | 100% | 2024-12-12 | 2025-01-10 | 0d |  | SI Test | SIT |  | 6.16 | Steve Evans | SITAG | Complete | COMPLETE |
| 1321 | 1.4.1.4.5.8.2 | SRO review of SIT Operational Theme 3 (Batch 1) RTTM |  | 5d | 2025-01-13 A | 2025-01-17 A | 1320 | 100% | 2025-01-13 | 2025-01-17 | 0d |  | SI Test | SIT |  | 6.16 | Steve Evans | SITAG | Complete | COMPLETE |
| 1322 | 1.4.1.4.5.8.3 | DIP Manager / Code Bodies / Full SRO to review |  | 5d | 2025-01-20 A | 2025-01-24 A | 1321 | 100% | 2025-01-20 | 2025-01-24 | 0d |  | SI Test | SIT |  | 6.16 | Steve Evans | SITAG | Complete | COMPLETE |
| 1323 | 1.4.1.4.5.8.4 | DIP Manager / Code Bodies / Full SRO acceptance of Theme 3 (Batch 1) Operational RTTM | milestone | 0d | 2025-01-24 A | 2025-01-24 A | 1322 | 100% | 2025-01-24 | 2025-01-24 | 0d |  | SI Test | SIT |  | 6.16 | Steve Evans | SITAG | Complete | COMPLETE |
| 1324 | 1.4.1.4.5.8.5 | SIT Operational Theme 3 (Batch 1) RTTM Complete | milestone | 0d | 2025-01-24 A | 2025-01-24 A | 1320, 1323 | 100% | 2025-01-10 | 2025-01-10 | 0d |  | SI Test | SIT |  | 6.12 | Steve Evans | SITAG | Complete | COMPLETE |
| 1325 | 1.4.1.4.5.9 | **SIT Operational Programme RTTM (Theme 1, 2 & 3 (Batch 2))** |  | 100d | 2025-01-06 A | 2025-05-23 A |  | 100% | 2025-01-06 | 2025-03-07 | 0d |  | SI Test | SIT | -827.67 | 6.18 | Steve Evans | SITAG |  |  |
| 1326 | 1.4.1.4.5.9.1 | Develop SIT Operational (Theme 1, 2 & 3 (Batch 2)) RTTM |  | 36d | 2025-01-06 A | 2025-02-24 A |  | 100% | 2025-01-06 | 2025-02-07 | 0d | start no earlier than 2025-01-06 | SI Test | SIT |  | 6.18 | Steve Evans | SITAG | Complete | COMPLETE |
| 1327 | 1.4.1.4.5.9.2 | SRO review of SIT Operational (Theme 1, 2 & 3 (Batch 2)) RTTM |  | 9d | 2025-02-25 A | 2025-03-07 A | 1326 | 100% | 2025-02-25 | 2025-03-07 | 0d |  | SI Test | SIT |  | 6.18 | Steve Evans | SITAG | Complete | COMPLETE |
| 1328 | 1.4.1.4.5.9.3 | DIP Manager / Code Bodies / Full SRO to review |  | 34d | 2025-03-10 A | 2025-04-24 A | 1327 | 100% | 2025-03-10 | 2025-03-21 | 0d |  | SI Test | SIT |  | 6.18 | Steve Evans | SITAG | Complete | COMPLETE |
| 1329 | 1.4.1.4.5.9.4 | Incorporate feedback |  | 34d | 2025-03-10 A | 2025-04-24 A | 1328FF | 100% | 2025-03-10 | 2025-03-21 | 0d |  | SI Test | SIT |  | 6.18 | Steve Evans | SITAG | Complete | COMPLETE |
| 1330 | 1.4.1.4.5.9.5 | DIP Manager / Code Bodies / SRO acceptance of (Theme 1, 2 & 3 (Batch 2)) Operational RTTM | milestone | 0d | 2025-04-25 A | 2025-04-25 A | 1328FS+1d | 100% | 2025-03-24 | 2025-03-24 | 0d |  | SI Test | SIT |  | 6.18 | Steve Evans | SITAG | Complete | COMPLETE |
| 1331 | 1.4.1.4.5.9.6 | SIT Operational (Theme 1, 2 & 3 (Batch 2)) RTTM Complete | milestone | 0d | 2025-05-23 A | 2025-05-23 A | 1330 | 100% | 2025-03-24 | 2025-03-24 | 0d | finish no earlier than 2025-05-23 | SI Test | SIT |  | 6.18 | Steve Evans | SITAG | Complete | COMPLETE |

| ID | WBS | Task | Type | Duration | Start | Finish | Predecessors | Complete | Actual start | Actual finish | Baseline start | Baseline finish | Baseline duration | Constraint | Responsible | Text9 | Task Status | Update Version | Sched Status | MHHS Resource Name | Text29 | RAG |
| --- | --- | --- | --- | --- | --- | --- | --- | --- | --- | --- | --- | --- | --- | --- | --- | --- | --- | --- | --- | --- | --- | --- |
| 1332 | 1.4.1.4.5.10 | **SIT Operational Theme 3 (Batch 1) DITL** |  | 17d | 2025-01-06 A | 2025-01-28 A |  | 100% |  |  | 2024-10-08 | 2024-10-17 | 0d |  | SI Test | SIT | 6.33 | 6.15 | No BL | Steve Evans | SITAG |  |
| 1333 | 1.4.1.4.5.10.1 | DITL + Familiarisation session development |  | 8d | 2025-01-06 A | 2025-01-15 A |  | 100% |  |  | 2025-01-06 | 2025-01-17 | 0d | start no earlier than 2025-01-06 | SI Test | SIT |  | 6.15 | Complete | Steve Evans | SITAG | COMPLETE |
| 1334 | 1.4.1.4.5.10.2 | SRO Review |  | 5d | 2025-01-16 A | 2025-01-22 A | 1333 | 100% |  |  | 2025-01-20 | 2025-01-24 | 0d |  | SI Test | SIT |  | 6.15 | Complete | Steve Evans | SITAG | COMPLETE |
| 1335 | 1.4.1.4.5.10.3 | Post-SRO Review Changes |  | 2d | 2025-01-23 A | 2025-01-24 A | 1334 | 100% |  |  | 2025-01-23 | 2025-01-24 | 0d |  | SI Test | SIT |  | 6.16 | Complete | Steve Evans | SITAG | COMPLETE |
| 1336 | 1.4.1.4.5.10.4 | Familiarisation session Service Management test case schedule + mapping | milestone | 0d | 2025-01-24 A | 2025-01-24 A | 1335 | 100% |  |  | 2025-01-24 | 2025-01-24 | 0d |  | SI Test | SIT |  | 6.16 | Complete | Steve Evans | SITAG | COMPLETE |
| 1337 | 1.4.1.4.5.10.5 | Publish Cycle 3 DITL / Cycle 3 DITL Online Sessions for SIT PPs | milestone | 0d | 2025-01-28 A | 2025-01-28 A | 1336FS+2d | 100% |  |  | 2025-01-28 | 2025-01-28 | 0d |  | SI Test | SIT |  | 6.16 | Complete | Steve Evans | SITAG | COMPLETE |
| 1338 | 1.4.1.4.5.11 | **SIT Operational Theme 1, 2 & 3 (Batch 2) DITL** |  | 23d | 2025-02-24 A | 2025-03-26 A |  | 100% |  |  | 2025-02-24 | 2025-03-26 | 0d |  | SI Test | SIT | -828.67 | 6.18 |  | Steve Evans | SITAG |  |
| 1339 | 1.4.1.4.5.11.1 | DITL + Familiarisation session development |  | 15d | 2025-02-24 A | 2025-03-14 A |  | 100% |  |  | 2025-02-24 | 2025-03-14 | 0d | start no earlier than 2025-02-24 | SI Test | SIT |  | 6.18 | Complete | Steve Evans | SITAG | COMPLETE |
| 1340 | 1.4.1.4.5.11.2 | SRO Review |  | 5d | 2025-03-17 A | 2025-03-21 A | 1339 | 100% |  |  | 2025-03-17 | 2025-03-21 | 0d |  | SI Test | SIT |  | 6.18 | Complete | Steve Evans | SITAG | COMPLETE |
| 1341 | 1.4.1.4.5.11.3 | Post-SRO Review Changes |  | 3d | 2025-03-24 A | 2025-03-26 A | 1340 | 100% |  |  | 2025-03-24 | 2025-03-26 | 0d |  | SI Test | SIT |  | 6.18 | Complete | Steve Evans | SITAG | COMPLETE |
| 1342 | 1.4.1.4.5.11.4 | Familiarisation session Service Management test case schedule + mapping | milestone | 0d | 2025-03-26 A | 2025-03-26 A | 1341 | 100% |  |  | 2025-03-26 | 2025-03-26 | 0d |  | SI Test | SIT |  | 6.18 | Complete | Steve Evans | SITAG | COMPLETE |
| 1343 | 1.4.1.4.5.11.5 | Publish Cycle 3 DITL / Cycle 3 DITL Online Sessions for SIT PPs | milestone | 0d | 2025-03-26 A | 2025-03-26 A | 1342 | 100% |  |  | 2025-03-26 | 2025-03-26 | 0d |  | SI Test | SIT |  | 6.18 | Complete | Steve Evans | SITAG | COMPLETE |
| 1344 | 1.4.1.4.5.12 | **SIT Operational Defect Management** |  | 15d? | 2025-01-06 A | 2025-01-24 A |  | 100% |  |  | 2025-01-06 | 2025-01-24 | 0d |  | SI Test | SIT | -807.67 | 6.17 |  | Steve Evans | SITAG |  |
| 1345 | 1.4.1.4.5.12.1 | Develop defect management approach |  | 10d? | 2025-01-06 A | 2025-01-17 A |  | 100% |  |  | 2025-01-06 | 2025-01-17 | 0d | start no earlier than 2025-01-06 | SI Test | SIT |  | 6.17 | Complete | Steve Evans | SITAG | COMPLETE |
| 1346 | 1.4.1.4.5.12.2 | Defect management approach agreed |  | 5d? | 2025-01-20 A | 2025-01-24 A | 1345 | 100% |  |  | 2025-01-20 | 2025-01-24 | 0d |  | SI Test | SIT |  | 6.17 | Complete | Steve Evans | SITAG | COMPLETE |
| 1347 | 1.4.1.4.5.13 | **SIT Operational Execution Model** |  | 43d? | 2024-08-05 | 2024-10-02 |  | 100% | 2024-12-16 | 2025-03-17 | 2024-08-05 | 2024-10-02 | 0d |  | SI Test | SIT | -134.67 | 6.15 |  | Steve Evans | SITAG |  |
| 1348 | 1.4.1.4.5.13.1 | **Theme 3 (Batch 1)** |  | 27d | 2024-08-05 | 2024-09-10 |  | 100% | 2024-12-16 | 2025-01-21 | 2024-08-05 | 2024-09-10 | 0d |  | SI Test | SIT | -134.67 | 6.15 |  | Steve Evans | SITAG |  |
| 1349 | 1.4.1.4.5.13.1.1 | Develop execution model Theme 3 (Batch 1) |  | 3d | 2024-12-16 A | 2024-12-18 A | 1305FF | 100% |  |  | 2024-12-16 | 2024-12-18 | 0d |  | SI Test | SIT |  | 6.15 | Complete | Steve Evans | SITAG | COMPLETE |
| 1350 | 1.4.1.4.5.13.1.2 | SRO provide feedback |  | 14d | 2024-12-19 A | 2025-01-07 A | 1349 | 100% |  |  | 2024-12-19 | 2025-01-07 | 0d |  | SI Test | SIT |  | 6.15 | Complete | Steve Evans | SITAG | COMPLETE |
| 1351 | 1.4.1.4.5.13.1.3 | Address SRO feedback on execution model |  | 2d | 2025-01-08 A | 2025-01-09 A | 1350 | 100% |  |  | 2025-01-08 | 2025-01-09 | 0d |  | SI Test | SIT |  | 6.15 | Complete | Steve Evans | SITAG | COMPLETE |
| 1352 | 1.4.1.4.5.13.1.4 | Finalise execution model |  | 3d | 2025-01-10 A | 2025-01-14 A | 1351 | 100% |  |  | 2025-01-10 | 2025-01-14 | 0d |  | SI Test | SIT |  | 6.15 | Complete | Steve Evans | SITAG | COMPLETE |
| 1353 | 1.4.1.4.5.13.1.5 | SITWG paper day | milestone | 0d | 2025-01-14 A | 2025-01-14 A | 1352 | 100% |  |  | 2025-01-14 | 2025-01-14 | 0d |  | SI Test | SIT |  | 6.15 | Complete | Steve Evans | SITAG | COMPLETE |
| 1354 | 1.4.1.4.5.13.1.6 | SITWG update on execution model | milestone | 0d | 2025-01-21 A | 2025-01-21 A | 1353FS+5d | 100% |  |  | 2025-01-21 | 2025-01-21 | 0d |  | SI Test | SIT |  | 6.15 | Complete | Steve Evans | SITAG | COMPLETE |
| 1355 | 1.4.1.4.5.13.2 | **Theme 1, 2 and 3 (Batch 2)** |  | 23d? | 2024-08-05 | 2024-09-04 |  | 100% | 2025-02-03 | 2025-03-17 | 2024-08-05 | 2024-09-04 | 0d |  | SI Test | SIT | -134.67 | 6.15 |  | Steve Evans | SITAG |  |
| 1356 | 1.4.1.4.5.13.2.1 | Develop execution model Theme 1, 2 and 3 (Batch 2) |  | 10d | 2025-02-03 A | 2025-02-14 A | 1305 | 100% |  |  | 2025-02-03 | 2025-02-14 | 0d | start no earlier than 2025-02-03 | SI Test | SIT |  | 6.15 | Complete | Steve Evans | SITAG | COMPLETE |
| 1357 | 1.4.1.4.5.13.2.2 | SRO provide feedback |  | 5d | 2025-02-25 A | 2025-03-03 A | 1356 | 100% |  |  | 2025-02-17 | 2025-02-21 | 0d | finish no earlier than 2025-01-21 | SI Test | SIT |  | 6.15 | Complete | Steve Evans | SITAG | COMPLETE |
| 1358 | 1.4.1.4.5.13.2.3 | Address SRO feedback on execution model |  | 5d | 2025-03-04 A | 2025-03-10 A | 1357 | 100% |  |  | 2025-02-17 | 2025-02-21 | 0d |  | SI Test | SIT |  | 6.15 | Complete | Steve Evans | SITAG | COMPLETE |
| 1359 | 1.4.1.4.5.13.2.4 | Finalise execution model |  | 5d | 2025-03-11 A | 2025-03-17 A | 1358 | 100% |  |  | 2025-02-24 | 2025-02-27 | 0d |  | SI Test | SIT |  | 6.15 | Complete | Steve Evans | SITAG | COMPLETE |
| 1360 | 1.4.1.4.5.13.2.5 | Execution Model shared with industry | milestone | 0d | 2025-03-17 A | 2025-03-17 A | 1359 | 100% |  |  | 2025-02-27 | 2025-02-27 | 0d |  | SI Test | SIT |  | 6.20 | Complete | Steve Evans | SITAG | COMPLETE |

| ID | WBS | Task | Type | Duration | Start | Finish | Predecessors | Complete | Actual start | Actual finish | Baseline start | Baseline finish | Baseline duration | Baseline 1 start | Baseline 1 finish | Constraint | Baseline cost | Responsible | Text9 | Task Status | Update Version | MHHS Resource Name | Text29 | Sched Status | RAG | Involved | MHHS Programme Phase | Milestone ID | Tier |
| --- | --- | --- | --- | --- | --- | --- | --- | --- | --- | --- | --- | --- | --- | --- | --- | --- | --- | --- | --- | --- | --- | --- | --- | --- | --- | --- | --- | --- | --- |
| 1361 | 1.4.1.4.5.13.3 | **SIT Operational Theme 3 (Batch 1) progress reporting** |  | 29d? | 2024-12-19 A | 2025-01-28 |  | 100% |  | 2025-01-24 | 2024-12-19 | 2025-01-31 | 0d |  |  |  |  | SI Test | SIT | -94.67 | 6.14 | Steve Evans | SITAG |  |  |  |  |  |  |
| 1362 | 1.4.1.4.5.13.3.1 | Determine reporting methodology |  | 2d? | 2024-12-19 A | 2024-12-20 A |  | 100% |  |  | 2024-12-19 | 2025-01-17 | 0d |  |  |  |  | SI Test | SIT |  | 6.14 | Steve Evans | SITAG | Complete | COMPLETE |  |  |  |  |
| 1363 | 1.4.1.4.5.13.3.2 | Implement reporting |  | 25d | 2024-12-23 A | 2025-01-24 A | 1362 | 100% |  |  | 2025-01-20 | 2025-01-31 | 0d |  |  |  |  | SI Test | SIT |  | 6.14 | Steve Evans | SITAG | Complete | COMPLETE |  |  |  |  |
| 1364 | 1.4.1.4.5.14 | **SIT Operational Overarching Test Readiness Reports** |  | 33d? | 2024-08-05 | 2024-09-18 |  | 100% | 2024-12-18 | 2025-03-28 | 2024-08-05 | 2024-09-18 | 151d | 2025-01-07 | 2025-03-03 |  | -0 | N/A | SIT |  | 6.0 | Steve Evans | SITAG |  |  | N/A | Systems Integration Testing (SIT) |  |  |
| 1365 | 1.4.1.4.5.14.1 | **SI SIT Operational Theme 3 (Batch 1) Overarching Test Readiness Report** |  | 31d? | 2024-12-18 A | 2025-01-29 A |  | 100% |  |  | 2024-12-23 | 2025-01-29 | 0d |  |  |  |  | SI Test | SIT | -135.67 | 6.17 | Steve Evans | SITAG |  |  |  |  |  |  |
| 1366 | 1.4.1.4.5.14.1.1 | Develop Overarching SIT Operational Theme 3 (Batch 1) Overarching Test Readiness Report |  | 20d | 2024-12-18 A | 2025-01-14 A | 393FF | 100% |  |  | 2024-12-18 | 2025-01-14 | 0d |  |  | finish no earlier than 2025-01-14 |  | SI Test | SIT |  | 6.17 | Steve Evans | SITAG | Complete | COMPLETE |  |  |  |  |
| 1367 | 1.4.1.4.5.14.1.2 | SRO review |  | 5d | 2025-01-08 A | 2025-01-14 A | 1366FF | 100% |  |  | 2025-01-08 | 2025-01-14 | 0d |  |  | finish no earlier than 2025-01-13 |  | SI Test | SIT |  | 6.17 | Steve Evans | SITAG | Complete | COMPLETE |  |  |  |  |
| 1368 | 1.4.1.4.5.14.1.3 | SITWG Paper day | milestone | 0d | 2025-01-14 A | 2025-01-14 A | 1367 | 100% |  |  | 2025-01-14 | 2025-01-14 | 0d |  |  | finish no earlier than 2025-01-14 |  | SI Test | SIT |  | 6.17 | Steve Evans | SITAG | Complete | COMPLETE |  |  |  |  |
| 1369 | 1.4.1.4.5.14.1.4 | SITWG review the Operational Theme 3 (Batch 1) Overarching Test Readiness Report | milestone | 0d | 2025-01-21 A | 2025-01-21 A | 1368FS+5d | 100% |  |  | 2025-01-21 | 2025-01-21 | 0d |  |  | finish no earlier than 2025-01-21 |  | SI Test | SIT |  | 6.17 | Steve Evans | SITAG | Complete | COMPLETE |  |  |  |  |
| 1370 | 1.4.1.4.5.14.1.5 | Update Operational Theme 3 (Batch 1) Overarching Test Readiness Report following SRO / SITWG feedback |  | 1d | 2025-01-22 A | 2025-01-22 A | 1369 | 100% |  |  | 2025-01-22 | 2025-01-22 | 0d |  |  | start no earlier than 2025-01-22 |  | SI Test | SIT |  | 6.17 | Steve Evans | SITAG | Complete | COMPLETE |  |  |  |  |
| 1371 | 1.4.1.4.5.14.1.6 | SITAG paper day | milestone | 0d | 2025-01-22 A | 2025-01-22 A | 1370 | 100% |  |  | 2025-01-22 | 2025-01-22 | 0d |  |  | finish no earlier than 2025-01-22 |  | SI Test | SIT |  | 6.17 | Steve Evans | SITAG | Complete | COMPLETE |  |  |  |  |
| 1372 | 1.4.1.4.5.14.1.7 | FTIG recommendation | milestone | 0d | 2025-01-24 A | 2025-01-24 A | 1370FS+2d | 100% |  |  | 2025-01-24 | 2025-01-24 | 0d |  |  |  |  | SI Test | SIT |  | 6.17 | Steve Evans | SITAG | Complete | COMPLETE |  |  |  |  |
| 1373 | 1.4.1.4.5.14.1.8 | Republish Operational Theme 3 (Batch 1) Overarching Test Readiness Report with latest data and evidence |  | 1d? | 2025-01-27 A | 2025-01-27 A | 1371FS+2d | 100% |  |  | 2025-01-27 | 2025-01-27 | 0d |  |  |  |  | SI Test | SIT |  | 6.17 | Steve Evans | SITAG | Complete | COMPLETE |  |  |  |  |
| 1374 | 1.4.1.4.5.14.1.9 | SITAG approve Theme 3 (Batch 1) Test Readiness Report | milestone | 0d | 2025-01-29 A | 2025-01-29 A | 1371FS+5d, 1213, 1373 | 100% |  |  | 2025-01-29 | 2025-01-29 | 0d |  |  | finish no earlier than 2025-01-29 |  | SI Test | SIT |  | 6.17 | Steve Evans | SITAG | Complete | COMPLETE |  |  | T3-TE-0192 | T3 |
| 1375 | 1.4.1.4.5.14.2 | **SI SIT Operational Theme 1, 2 and 3 (Batch 2) Overarching Test Readiness Report** |  | 45d | 2025-01-27 A | 2025-03-28 A |  | 100% |  |  | 2025-01-27 | 2025-03-28 | 0d |  |  |  |  | SI Test | SIT | -135.67 | 6.17 | Steve Evans | SITAG |  |  |  |  |  |  |
| 1376 | 1.4.1.4.5.14.2.1 | Develop Overarching SIT Operational Theme 1, 2 and 3 (Batch 2) Overarching Test Readiness Report |  | 20d | 2025-01-27 A | 2025-02-21 A | 376FS+25d | 100% |  |  | 2025-01-27 | 2025-02-21 | 0d |  |  | start no earlier than 2025-01-20 |  | SI Test | SIT |  | 6.17 | Steve Evans | SITAG | Complete | COMPLETE |  |  |  |  |
| 1377 | 1.4.1.4.5.14.2.2 | SRO review |  | 5d | 2025-02-24 A | 2025-02-28 A | 1376 | 100% |  |  | 2025-02-24 | 2025-02-28 | 0d |  |  |  |  | SI Test | SIT |  | 6.17 | Steve Evans | SITAG | Complete | COMPLETE |  |  |  |  |
| 1378 | 1.4.1.4.5.14.2.3 | SITWG Paper day | milestone | 0d | 2025-02-27 A | 2025-02-27 A |  | 100% |  |  | 2025-02-27 | 2025-02-27 | 0d |  |  | finish no earlier than 2025-02-27 |  | SI Test | SIT |  | 6.17 | Steve Evans | SITAG | Complete | COMPLETE |  |  |  |  |
| 1379 | 1.4.1.4.5.14.2.4 | SITWG review the Operational Theme 1, 2 and 3 (Batch 2) Overarching Test Readiness Report | milestone | 0d | 2025-03-06 A | 2025-03-06 A | 1378SS+5d | 100% |  |  | 2025-03-06 | 2025-03-06 | 0d |  |  |  |  | SI Test | SIT |  | 6.17 | Steve Evans | SITAG | Complete | COMPLETE |  |  |  |  |
| 1380 | 1.4.1.4.5.14.2.5 | Update Operational Theme 1, 2 and 3 (Batch 2) Overarching Test Readiness Report following SRO feedback |  | 13d | 2025-03-07 A | 2025-03-25 A | 1379 | 100% |  |  | 2025-03-07 | 2025-03-25 | 0d |  |  | start no earlier than 2025-03-07 |  | SI Test | SIT |  | 6.17 | Steve Evans | SITAG | Complete | COMPLETE |  |  |  |  |
| 1381 | 1.4.1.4.5.14.2.6 | GLIG recommendation | milestone | 0d | 2025-03-21 A | 2025-03-21 A | 1379FS+11d | 100% |  |  | 2025-03-21 | 2025-03-21 | 0d |  |  |  |  | SI Test | SIT |  | 6.17 | Steve Evans | SITAG | Complete | COMPLETE |  |  |  |  |
| 1382 | 1.4.1.4.5.14.2.7 | eSITAG paper day | milestone | 0d | 2025-03-26 A | 2025-03-26 A | 1380 | 100% |  |  | 2025-03-26 | 2025-03-26 | 0d |  |  | finish no earlier than 2025-03-26 |  | SI Test | SIT |  | 6.17 | Steve Evans | SITAG | Complete | COMPLETE |  |  |  |  |
| 1383 | 1.4.1.4.5.14.2.8 | eSITAG approve Operational Theme 1, 2 and 3 (Batch 2) Overarching Test Readiness Report | milestone | 0d | 2025-03-28 A | 2025-03-28 A | 1381, 1391, 1392 | 100% |  |  | 2025-03-28 | 2025-03-28 | 0d |  |  |  |  | SI Test | SIT |  | 6.17 | Steve Evans | SITAG | Complete | COMPLETE |  |  | T3-TE-0193 | T3 |
| 1384 | 1.4.1.4.5.15 | SIT Operational Theme 3 (Batch 1) Testing Preparation Complete | milestone | 0d | 2025-01-31 A | 2025-01-31 A | 1374, 1277 | 100% |  |  | 2025-01-31 | 2025-01-31 | 0d |  |  |  |  | SI Test | SIT |  | 6.15 | Steve Evans | SITAG | Complete | COMPLETE |  |  | T2-TE-0750 | T2 |
| 1385 | 1.4.1.4.5.16 | SIT Operational Theme 1, 2, 3 (Batch 2) Testing Preparation Complete | milestone | 0d | 2025-03-28 A | 2025-03-28 A | 394, 1173, 1179, 1305, 1383, 1363, 1343, 1315 | 100% |  |  | 2025-03-31 | 2025-04-25 | 0d | 2025-03-10 | 2025-03-10 | finish no earlier than 2024-10-04 |  | SI Test | SIT |  | 6.15 | Steve Evans | SITAG | Complete | COMPLETE | PP,IPA | Systems Integration Testing (SIT) | T2-TE-1300 | T2 |

| ID | WBS | Task | Type | Duration | Start | Finish | Predecessors | Complete | Actual finish | Baseline start | Baseline finish | Baseline duration | Constraint | Responsible | Text9 | Task Status | Update Version | MHHS Resource Name | Text29 | Sched Status | RAG | Milestone ID | Tier | Programme Governance Forum responsible for decisio |
| --- | --- | --- | --- | --- | --- | --- | --- | --- | --- | --- | --- | --- | --- | --- | --- | --- | --- | --- | --- | --- | --- | --- | --- | --- |
| 1386 | 1.4.1.4.5.17 | **Test Data - Non-Functional and Operational (SIT B)** |  | 25d? | 2025-02-24 A | 2025-03-28 A |  | 100% |  | 2025-01-06 | 2025-03-14 | 0d |  | SI Test | SIT | -686.67 | 6.0 | Heath Thomas | SITAG |  |  |  |  |  |
| 1387 | 1.4.1.4.5.17.1 | **Data Load** |  | 25d? | 2025-02-24 A | 2025-03-28 A |  | 100% |  | 2025-01-06 | 2025-03-14 | 0d |  | SI Test | SIT | -689.67 | 6.0 | Michael Inije | SITAG |  |  |  |  |  |
| 1388 | 1.4.1.4.5.17.1.1 | Non-Functional Theme 1 (Avenade) Data Load |  | 5d? | 2025-02-24 A | 2025-02-28 A | 1557 | 100% |  | 2025-02-24 | 2025-02-28 | 0d |  | SI Test | SIT |  | 6.15 | Michael Inije | SITAG | Complete | COMPLETE | T3-TE-0126 | T3 |  |
| 1389 | 1.4.1.4.5.17.1.2 | Non-Functional Theme 2 & 3 (Helix, Avenade & PPs) Data Load |  | 5d | 2025-03-24 A | 2025-03-28 A | 1625 | 100% |  | 2025-03-24 | 2025-03-28 | 0d |  | SI Test | SIT |  | 6.15 | Michael Inije | SITAG | Complete | COMPLETE | T3-TE-0127 | T3 |  |
| 1390 | 1.4.1.4.5.17.1.3 | Non-Functional Themes 2 & 3 (LDSO's) Data Load |  | 15d | 2025-03-03 A | 2025-03-21 A | 1116 | 100% |  | 2025-03-03 | 2025-03-21 | 0d |  | SI Test | SIT |  | 6.15 | Michael Inije | SITAG | Complete | COMPLETE | T3-TE-0128 | T3 |  |
| 1391 | 1.4.1.4.5.17.1.4 | Operational Themes 1, 2 & 3 (Batch 2) (LDSO's) Data Load |  | 20d? | 2025-03-03 A | 2025-03-28 A | 1116 | 100% |  | 2025-03-03 | 2025-03-28 | 0d | start no earlier than 2025-01-06 | SI Test | SIT |  | 6.15 | Michael Inije | SITAG | Complete | COMPLETE | T3-TE-0129 | T3 |  |
| 1392 | 1.4.1.4.5.17.1.5 | Operational Themes 1, 2 & 3 (Batch 2) (Helix, Avenade & PPs) Data Load |  | 5d | 2025-03-24 A | 2025-03-28 A | 1625 | 100% |  | 2025-03-24 | 2025-03-28 | 0d |  | SI Test | SIT |  | 6.15 | Michael Inije | SITAG | Complete | COMPLETE | T3-TE-0130 | T3 |  |
| 1393 | 1.4.1.4.5.17.1.6 | Non-Functional and Operational Test Data Preparation Complete | milestone | 0d | 2025-03-28 A | 2025-03-28 A | 1392 | 100% |  | 2025-03-28 | 2025-03-28 | 0d |  | SI Test | SIT |  | 6.15 | Michael Inije | SITAG | Complete | COMPLETE | T3-TE-0131 | T3 |  |
| 1394 | 1.4.1.4.6 | **Regression Test Preparation** |  | 2d? | 2024-11-18 A | 2024-11-19 |  | 100% | 2025-05-16 | 2024-11-18 | 2024-11-19 | 0d |  | SI Test | SIT | -686.67 | 6.17 | Roger Robar | SITAG |  |  |  |  |  |
| 1395 | 1.4.1.4.6.1 | **Regression Test Approach** |  | 10d | 2024-11-18 A | 2024-11-29 |  | 100% | 2025-02-28 | 2024-11-18 | 2024-11-29 | 0d |  | SI Test | SIT | -686.67 | 6.17 | Roger Robar | SITAG |  |  |  |  |  |
| 1396 | 1.4.1.4.6.1.1 | Develop approach doc |  | 45d | 2024-11-18 A | 2025-01-17 A |  | 100% |  | 2024-11-18 | 2025-01-17 | 0d | start no earlier than 2024-09-16 | SI Test | SIT |  | 6.17 | Roger Robar | SITAG | Complete | COMPLETE |  |  |  |
| 1397 | 1.4.1.4.6.1.2 | SRO / LDP review of approach doc |  | 5d | 2025-01-20 A | 2025-01-24 A | 1396 | 100% |  | 2025-01-20 | 2025-01-24 | 0d |  | SI Test | SIT |  | 6.17 | Roger Robar | SITAG | Complete | COMPLETE |  |  |  |
| 1398 | 1.4.1.4.6.1.3 | Incorporate SRO feedback into approach doc |  | 5d | 2025-01-20 A | 2025-01-24 A | 1397FF | 100% |  | 2025-01-20 | 2025-01-24 | 0d |  | SI Test | SIT |  | 6.17 | Roger Robar | SITAG | Complete | COMPLETE |  |  |  |
| 1399 | 1.4.1.4.6.1.4 | Industry review of approach |  | 10d | 2025-01-27 A | 2025-02-07 A | 1398 | 100% |  | 2025-01-27 | 2025-02-07 | 0d |  | SI Test | SIT |  | 6.17 | Roger Robar | SITAG | Complete | COMPLETE |  |  |  |
| 1400 | 1.4.1.4.6.1.5 | Updates to approach doc on back of industry feedback |  | 2d | 2025-02-10 A | 2025-02-11 A | 1399 | 100% |  | 2025-02-10 | 2025-02-11 | 0d |  | SI Test | SIT |  | 6.17 | Roger Robar | SITAG | Complete | COMPLETE |  |  |  |
| 1401 | 1.4.1.4.6.1.6 | eSITWG paper day | milestone | 0d | 2025-02-11 A | 2025-02-11 A | 1400 | 100% |  | 2025-02-11 | 2025-02-11 | 0d |  | SI Test | SIT |  | 6.17 | Roger Robar | SITAG | Complete | COMPLETE |  |  |  |
| 1402 | 1.4.1.4.6.1.7 | eSITWG Recommendation | milestone | 0d | 2025-02-18 A | 2025-02-18 A | 1401FS+5d | 100% |  | 2025-02-18 | 2025-02-18 | 0d | start no earlier than 2025-01-20 | SI Test | SIT |  | 6.17 | Roger Robar | SITAG | Complete | COMPLETE |  |  |  |
| 1403 | 1.4.1.4.6.1.8 | Incorporate eSITWG feedback into approach doc |  | 2d | 2025-02-19 A | 2025-02-20 A | 1402 | 100% |  | 2025-02-19 | 2025-02-20 | 0d |  | SI Test | SIT |  | 6.17 | Roger Robar | SITAG | Complete | COMPLETE |  |  |  |
| 1404 | 1.4.1.4.6.1.9 | eSITAG paper day | milestone | 0d | 2025-02-20 A | 2025-02-20 A | 1403 | 100% |  | 2025-02-20 | 2025-02-20 | 0d |  | SI Test | SIT |  | 6.17 | Roger Robar | SITAG | Complete | COMPLETE |  |  |  |
| 1405 | 1.4.1.4.6.1.10 | eSITAG (inc SRO) Approval | milestone | 0d | 2025-02-28 A | 2025-02-28 A | 1404FS+5d | 100% |  | 2025-02-28 | 2025-02-28 | 0d | finish no earlier than 2025-02-28 | SI Test | SIT |  | 6.17 | Roger Robar | SITAG | Complete | COMPLETE |  |  |  |
| 1406 | 1.4.1.4.6.1.11 | SIT Regression Testing Approach and Plan Approval | milestone | 0d | 2025-02-28 A | 2025-02-28 A | 1405 | 100% |  | 2025-02-28 | 2025-02-28 | 0d |  | SI Test | SIT |  | 6.17 | Roger Robar | SITAG | Complete | COMPLETE | T3-TE-0123 | T3 |  |
| 1407 | 1.4.1.4.6.2 | **Regression Core Test Pack** |  | 52d? | 2025-02-12 A | 2025-04-24 A |  | 100% |  | 2025-02-12 | 2025-04-16 | 0d |  | SI Test | SIT | -686.67 | 6.17 | Roger Robar | SITAG |  |  |  |  |  |
| 1408 | 1.4.1.4.6.2.1 | Build Regression Core Pack |  | 17d | 2025-02-12 A | 2025-03-06 A | 1401, 1411FF | 100% |  |  |  |  | start no earlier than 2025-02-12 | SI Test | SIT |  | 6.19 | Roger Robar | SITAG | Complete | COMPLETE |  |  |  |
| 1409 | 1.4.1.4.6.2.2 | Build Regression Framework |  | 12d | 2025-02-12 A | 2025-02-27 A | 1401 | 100% |  | 2025-02-12 | 2025-02-28 | 0d |  | SI Test | SIT |  | 6.17 | Roger Robar | SITAG | Complete | COMPLETE |  |  |  |
| 1410 | 1.4.1.4.6.2.3 | SITWG paper day | milestone | 0d | 2025-02-27 A | 2025-02-27 A | 1409 | 100% |  | 2025-02-27 | 2025-02-27 | 0d | start no earlier than 2025-02-27 | SI Test | SIT |  | 6.17 | Roger Robar | SITAG | Complete | COMPLETE |  |  |  |
| 1411 | 1.4.1.4.6.2.4 | SITWG provides feedback on Regression Framework approach | milestone | 0d | 2025-03-06 A | 2025-03-06 A | 1410FS+5d | 100% |  | 2025-03-06 | 2025-03-06 | 0d |  | SI Test | SIT |  | 6.17 | Roger Robar | SITAG | Complete | COMPLETE |  |  |  |
| 1412 | 1.4.1.4.6.2.5 | LDP walkthrough of Regression Core Pack |  | 3d | 2025-02-27 A | 2025-03-03 A | 1408SS | 100% |  | 2025-02-28 | 2025-02-28 | 0d | start no earlier than 2025-02-27 | SI Test | SIT |  | 6.17 | Roger Robar | SITAG | Complete | COMPLETE |  |  |  |
| 1413 | 1.4.1.4.6.2.6 | SRO Review of Regression Core Pack |  | 6d | 2025-03-07 A | 2025-03-14 A | 1408SS | 100% |  | 2025-03-03 | 2025-03-07 | 0d | start no earlier than 2025-03-07 | SI Test | SIT |  | 6.20 | Roger Robar | SITAG | Complete | COMPLETE |  |  |  |
| 1414 | 1.4.1.4.6.2.7 | Incorporate SRO feedback into Regression Core Pack |  | 6d | 2025-03-07 A | 2025-03-14 A | 1413SS | 100% |  | 2025-03-03 | 2025-03-07 | 0d |  | SI Test | SIT |  | 6.20 | Roger Robar | SITAG | Complete | COMPLETE |  |  |  |
| 1415 | 1.4.1.4.6.2.8 | Industry review of Regression Core Pack |  | 10d | 2025-03-17 A | 2025-03-28 A | 1414, 1408 | 100% |  | 2025-03-17 | 2025-03-28 | 0d | start no earlier than 2025-03-13 | SI Test | SIT |  | 6.21 | Roger Robar | SITAG | Complete | COMPLETE |  |  |  |
| 1416 | 1.4.1.4.6.2.9 | Regression Test Framework Core Pack - PP Walkthrough |  | 1d? | 2025-03-20 A | 2025-03-20 A | 1415SS | 100% |  | 2025-03-20 | 2025-03-20 | 0d | start no earlier than 2025-03-20 | SI Test | SIT |  | 6.20 | Roger Robar | SITAG | Complete | COMPLETE |  |  |  |
| 1417 | 1.4.1.4.6.2.10 | Regression Test Framework Core Pack - Q&A Drop in session |  | 1d? | 2025-03-27 A | 2025-03-27 A | 1415SS | 100% |  | 2025-03-27 | 2025-03-27 | 0d | start no earlier than 2025-03-27 | SI Test | SIT |  | 6.21 | Roger Robar | SITAG | Complete | COMPLETE |  |  |  |
| 1418 | 1.4.1.4.6.2.11 | Incorporate Industry feedback into Regression Core Pack |  | 3d | 2025-03-31 A | 2025-04-02 A | 1415, 1416, 1417 | 100% |  | 2025-03-31 | 2025-04-02 | 0d |  | SI Test | SIT |  | 6.21 | Roger Robar | SITAG | Complete | COMPLETE |  |  |  |
| 1419 | 1.4.1.4.6.2.12 | Second industry review of Regression Core Pack |  | 5d | 2025-04-03 A | 2025-04-09 A | 1418 | 100% |  | 2025-04-03 | 2025-04-09 | 0d |  | SI Test | SIT |  | 6.21 | Roger Robar | SITAG | Complete | COMPLETE |  |  |  |
| 1420 | 1.4.1.4.6.2.13 | Incorporate industry feedback into regression Core Pack |  | 1d | 2025-04-10 A | 2025-04-10 A | 1419 | 100% |  | 2025-04-10 | 2025-04-10 | 0d |  | SI Test | SIT |  | 6.21 | Roger Robar | SITAG | Complete | COMPLETE |  |  |  |
| 1421 | 1.4.1.4.6.2.14 | SITWG paper day | milestone | 0d | 2025-04-08 A | 2025-04-08 A |  | 100% |  | 2025-04-10 | 2025-04-10 | 0d | finish no earlier than 2025-04-08 | SI Test | SIT |  | 6.21 | Roger Robar | SITAG | Complete | COMPLETE |  |  |  |
| 1422 | 1.4.1.4.6.2.15 | SITWG endorses regression Core Pack | milestone | 0d | 2025-04-15 A | 2025-04-15 A | 1421FS+3d | 100% |  | 2025-04-15 | 2025-04-15 | 0d | finish no earlier than 2025-04-15 | SI Test | SIT |  | 6.21 | Roger Robar | SITAG | Complete | COMPLETE |  |  |  |
| 1423 | 1.4.1.4.6.2.16 | Incorporate SITWG feedback into regression Core Pack |  | 2d | 2025-04-16 A | 2025-04-17 A | 1422 | 100% |  | 2025-04-16 | 2025-04-17 | 0d | start no earlier than 2025-04-16 | SI Test | SIT |  | 6.21 | Roger Robar | SITAG | Complete | COMPLETE |  |  |  |
| 1424 | 1.4.1.4.6.2.17 | Regression Test Approach and Plan Uplift | milestone | 0d | 2025-04-16 A | 2025-04-16 A | 1422 | 100% |  | 2025-04-16 | 2025-04-16 | 0d | start no earlier than 2025-04-16 | SI Test | SIT |  | 6.21 | Roger Robar | SITAG | Complete | COMPLETE |  |  |  |
| 1425 | 1.4.1.4.6.2.18 | Industry Review on the Uplifted Test Approach and Plan |  | 5d | 2025-04-17 A | 2025-04-23 A | 1424 | 100% |  | 2025-04-17 | 2025-04-23 | 0d | finish no earlier than 2025-04-23 | SI Test | SIT |  | 6.21 | Roger Robar | SITAG | Complete | COMPLETE |  |  |  |
| 1426 | 1.4.1.4.6.2.19 | SITAG paper day | milestone | 0d | 2025-04-17 A | 2025-04-17 A |  | 100% |  | 2025-04-17 | 2025-04-17 | 0d | finish no earlier than 2025-04-17 | SI Test | SIT |  | 6.20 | Roger Robar | SITAG | Complete | COMPLETE |  |  |  |
| 1427 | 1.4.1.4.6.2.20 | SITAG (inc SRO) Approval of regression Core Pack | milestone | 0d | 2025-04-24 A | 2025-04-24 A | 1426FS+5d, 1425 | 100% |  | 2025-04-24 | 2025-04-24 | 0d | start no earlier than 2025-04-24 | SI Test | SIT |  | 6.21 | Roger Robar | SITAG | Complete | COMPLETE |  |  |  |
| 1428 | 1.4.1.4.6.2.21 | SIT Regression Approval | milestone | 0d | 2025-04-24 A | 2025-04-24 A | 1427 | 100% |  | 2025-04-24 | 2025-04-24 | 0d |  | SI Test | SIT |  | 6.20 | Roger Robar | SITAG | Complete | COMPLETE | T3-TE-0122 | T3 | SITAG |

| ID | WBS | Task | Type | Duration | Start | Finish | Predecessors | Complete | Actual start | Actual finish | Baseline start | Baseline finish | Baseline duration | Constraint | Responsible | Text9 | Task Status | Update Version | MHHS Resource Name | Text29 | Sched Status | RAG | Milestone ID | Tier |
| --- | --- | --- | --- | --- | --- | --- | --- | --- | --- | --- | --- | --- | --- | --- | --- | --- | --- | --- | --- | --- | --- | --- | --- | --- |
| 1429 | 1.4.1.4.6.3 | **Regression Test Data Load Window (SIT Functional and Migration) - SIT A** |  | 1d? | 2025-04-28 | 2025-04-29 |  | 100% | 2025-03-31 | 2025-05-16 | 2025-03-14 | 2025-03-17 | 0d |  | SI Test | SIT | -686.67 | 6.15 | Michael Inije | SITAG |  |  |  |  |
| 1430 | 1.4.1.4.6.3.1 | Data Load preparation activities |  | 20d | 2025-03-31 A | 2025-04-25 A | 1389 | 100% |  |  | 2025-03-31 | 2025-04-25 | 0d | start no earlier than 2025-03-17 | SI Test | SIT |  | 6.15 | Michael Inije | SITAG | Complete | COMPLETE |  |  |
| 1431 | 1.4.1.4.6.3.2 | Regression Test Data Load Start | milestone | 0d | 2025-04-28 A | 2025-04-28 A | 1617, 1525FS+1d, 1621FS+1d, 1430, 1428 | 100% |  |  | 2025-04-28 | 2025-04-28 | 0d |  | SI Test | SIT |  | 6.15 | Michael Inije | SITAG | Complete | COMPLETE | T2-TE-1000 | T2 |
| 1432 | 1.4.1.4.6.3.3 | Regression Test Data Load Window |  | 14d | 2025-04-29 A | 2025-05-16 A | 1431 | 100% |  |  | 2025-04-28 | 2025-05-16 | 0d | start no earlier than 2025-04-28 | SI Test | SIT |  | 6.15 | Michael Inije | SITAG | Complete | COMPLETE |  |  |
| 1433 | 1.4.1.4.7 | **Single Instance ADO** |  | 32d? | 2024-08-21 A | 2024-10-03 A |  | 100% |  |  | 2024-08-21 | 2024-10-03 | 0d |  | SI Test | SIT | -701.67 | 6.1 | Heath Thomas | SITAG |  |  |  |  |
| 1434 | 1.4.1.4.7.1 | **Single ADO Project for all Cohorts - Implementation and Test Phase** |  | 30d? | 2024-08-21 A | 2024-10-01 A |  | 100% |  |  | 2024-08-21 | 2024-10-01 | 0d |  | SI Test | SIT | -701.67 | 6.1 | Heath Thomas | SITAG |  |  |  |  |
| 1435 | 1.4.1.4.7.1.1 | Create test plans and suites in master project |  | 2d | 2024-08-21 A | 2024-08-22 A |  | 100% |  |  | 2024-08-21 | 2024-08-22 | 0d | finish no earlier than 2024-08-22 | SI Test | SIT |  | 6.1 | Heath Thomas | SITAG | Complete | COMPLETE |  |  |
| 1436 | 1.4.1.4.7.1.2 | Create area paths / iterations |  | 2d | 2024-08-21 A | 2024-08-22 A |  | 100% |  |  | 2024-08-21 | 2024-08-22 | 0d | finish no earlier than 2024-08-22 | SI Test | SIT |  | 6.1 | Heath Thomas | SITAG | Complete | COMPLETE |  |  |
| 1437 | 1.4.1.4.7.1.3 | Create IAM roles |  | 2d | 2024-08-21 A | 2024-08-22 A |  | 100% |  |  | 2024-08-21 | 2024-08-22 | 0d | finish no earlier than 2024-08-22 | SI Test | SIT |  | 6.1 | Heath Thomas | SITAG | Complete | COMPLETE |  |  |
| 1438 | 1.4.1.4.7.1.4 | Add users to roles |  | 1d | 2024-08-23 A | 2024-08-23 A |  | 100% |  |  | 2024-08-23 | 2024-08-23 | 0d | start no earlier than 2024-08-23 | SI Test | SIT |  | 6.1 | Heath Thomas | SITAG | Complete | COMPLETE |  |  |
| 1439 | 1.4.1.4.7.1.5 | **Testing permissions** |  | 2d | 2024-08-27 A | 2024-08-28 A |  | 100% |  |  | 2024-08-27 | 2024-08-28 | 0d |  | SI Test | SIT |  | 6.1 | Heath Thomas | SITAG | Complete | COMPLETE |  |  |
| 1440 | 1.4.1.4.7.1.5.1 | Adding tests |  | 2d | 2024-08-27 A | 2024-08-28 A |  | 100% |  |  | 2024-08-27 | 2024-08-28 | 0d | finish no earlier than 2024-08-28 | SI Test | SIT |  | 6.1 | Heath Thomas | SITAG | Complete | COMPLETE |  |  |
| 1441 | 1.4.1.4.7.1.5.2 | Deleting tests |  | 2d | 2024-08-27 A | 2024-08-28 A |  | 100% |  |  | 2024-08-27 | 2024-08-28 | 0d | finish no earlier than 2024-08-28 | SI Test | SIT |  | 6.1 | Heath Thomas | SITAG | Complete | COMPLETE |  |  |
| 1442 | 1.4.1.4.7.1.5.3 | Adding tests to incorrect Cohort |  | 2d | 2024-08-27 A | 2024-08-28 A |  | 100% |  |  | 2024-08-27 | 2024-08-28 | 0d | finish no earlier than 2024-08-28 | SI Test | SIT |  | 6.1 | Heath Thomas | SITAG | Complete | COMPLETE |  |  |
| 1443 | 1.4.1.4.7.1.5.4 | Add / delete defects |  | 2d | 2024-08-27 A | 2024-08-28 A |  | 100% |  |  | 2024-08-27 | 2024-08-28 | 0d | finish no earlier than 2024-08-28 | SI Test | SIT |  | 6.1 | Heath Thomas | SITAG | Complete | COMPLETE |  |  |
| 1444 | 1.4.1.4.7.1.6 | Migrate defects from cohort project to master - Option 2 |  | 3d | 2024-09-23 A | 2024-09-25 A |  | 100% |  |  | 2024-09-23 | 2024-09-25 | 0d | start no earlier than 2024-09-23 | SI Test | SIT |  | 6.1 | Heath Thomas | SITAG | Complete | COMPLETE |  |  |
| 1445 | 1.4.1.4.7.1.7 | Testing Permissions - Evidence attachment security |  | 10d | 2024-09-18 A | 2024-10-01 A |  | 100% |  |  | 2024-09-18 | 2024-10-01 | 0d | finish no earlier than 2024-10-01 | SI Test | SIT |  | 6.1 | Heath Thomas | SITAG | Complete | COMPLETE |  |  |
| 1446 | 1.4.1.4.7.2 | **ADO Dashboard Updates** |  | 20d? | 2024-09-03 A | 2024-09-30 A |  | 100% |  |  | 2024-09-03 | 2024-09-30 | 0d |  | SI Test | SIT | -701.67 | 6.1 | Heath Thomas | SITAG |  |  |  |  |
| 1447 | 1.4.1.4.7.2.1 | Update reporting dashboards in ADO |  | 3d | 2024-09-03 A | 2024-09-05 A |  | 100% |  |  | 2024-09-03 | 2024-09-05 | 0d | start no earlier than 2024-09-03 | SI Test | SIT |  | 6.1 | Heath Thomas | SITAG | Complete | COMPLETE |  |  |
| 1448 | 1.4.1.4.7.2.2 | Review dashboards with SI LDP leads |  | 16d | 2024-09-06 A | 2024-09-27 A |  | 100% |  |  | 2024-09-06 | 2024-09-27 | 0d | start no earlier than 2024-09-06 | SI Test | SIT |  | 6.1 | Heath Thomas | SITAG | Complete | COMPLETE |  |  |
| 1449 | 1.4.1.4.7.2.3 | Review dashboards with SRO |  | 16d | 2024-09-09 A | 2024-09-30 A |  | 100% |  |  | 2024-09-09 | 2024-09-30 | 0d | start no earlier than 2024-09-09 | SI Test | SIT |  | 6.1 | Heath Thomas | SITAG | Complete | COMPLETE |  |  |
| 1450 | 1.4.1.4.7.2.4 | Update dashboards following review |  | 2d | 2024-09-12 A | 2024-09-13 A |  | 100% |  |  | 2024-09-12 | 2024-09-13 | 0d | start no earlier than 2024-09-12 | SI Test | SIT |  | 6.1 | Heath Thomas | SITAG | Complete | COMPLETE |  |  |
| 1451 | 1.4.1.4.7.2.5 | Document changes to dashboard creation process |  | 4d | 2024-09-16 A | 2024-09-19 A |  | 100% |  |  | 2024-09-16 | 2024-09-19 | 0d | start no earlier than 2024-09-16 | SI Test | SIT |  | 6.1 | Heath Thomas | SITAG | Complete | COMPLETE |  |  |
| 1452 | 1.4.1.4.7.2.6 | Update SIT Dashboards for Sprints 4.1 & 4.2 across all Cohorts |  | 1d | 2024-09-03 A | 2024-09-03 A |  | 100% |  |  | 2024-09-03 | 2024-09-03 | 0d | start no earlier than 2024-09-03 | SI Test | SIT |  | 6.1 | Heath Thomas | SITAG | Complete | COMPLETE |  |  |

| ID | WBS | Task | Duration | Start | Finish | Complete | Baseline start | Baseline finish | Baseline duration | Constraint | Responsible | Text9 | Task Status | Update Version | MHHS Resource Name | Text29 | Sched Status | RAG |
| --- | --- | --- | --- | --- | --- | --- | --- | --- | --- | --- | --- | --- | --- | --- | --- | --- | --- | --- |
| 1453 | 1.4.1.4.7.3 | **Reporting Changes - PowerBI & QIP** | 23d? | 2024-08-23 A | 2024-09-24 A | 100% | 2024-08-23 | 2024-09-24 | 0d |  | SI Test | SIT | -701.67 | 6.1 | Heath Thomas | SITAG |  |  |
| 1454 | 1.4.1.4.7.3.1 | Design, Create and ETL ADO Entities into PowerBI Data Model | 1d? | 2024-08-23 A | 2024-08-23 A | 100% | 2024-08-23 | 2024-08-23 | 0d | start no earlier than 2024-08-23 | SI Test | SIT |  | 6.1 | Heath Thomas | SITAG | Complete | COMPLETE |
| 1455 | 1.4.1.4.7.3.2 | Determine Relationships between ADO Entities & Attributes | 1d? | 2024-08-27 A | 2024-08-27 A | 100% | 2024-08-27 | 2024-08-27 | 0d | start no earlier than 2024-08-27 | SI Test | SIT |  | 6.1 | Heath Thomas | SITAG | Complete | COMPLETE |
| 1456 | 1.4.1.4.7.3.3 | Create Relevant Dax Measures | 1d? | 2024-08-28 A | 2024-08-28 A | 100% | 2024-08-28 | 2024-08-28 | 0d | start no earlier than 2024-08-28 | SI Test | SIT |  | 6.1 | Heath Thomas | SITAG | Complete | COMPLETE |
| 1457 | 1.4.1.4.7.3.4 | Design & Build Visualisations (Graphs) | 1d? | 2024-08-29 A | 2024-08-29 A | 100% | 2024-08-29 | 2024-08-29 | 0d | start no earlier than 2024-08-29 | SI Test | SIT |  | 6.1 | Heath Thomas | SITAG | Complete | COMPLETE |
| 1458 | 1.4.1.4.7.3.5 | Implement Filters | 1d? | 2024-09-23 A | 2024-09-23 A | 100% | 2024-09-23 | 2024-09-23 | 0d | start no earlier than 2024-09-23 | SI Test | SIT |  | 6.1 | Heath Thomas | SITAG | Complete | COMPLETE |
| 1459 | 1.4.1.4.7.3.6 | Check Data Quality & Integrity | 1d? | 2024-09-24 A | 2024-09-24 A | 100% | 2024-09-24 | 2024-09-24 | 0d | start no earlier than 2024-09-24 | SI Test | SIT |  | 6.1 | Heath Thomas | SITAG | Complete | COMPLETE |
| 1460 | 1.4.1.4.7.3.7 | Performance Optimisation | 1d? | 2024-09-24 A | 2024-09-24 A | 100% | 2024-09-24 | 2024-09-24 | 0d | start no earlier than 2024-09-24 | SI Test | SIT |  | 6.1 | Heath Thomas | SITAG | Complete | COMPLETE |
| 1461 | 1.4.1.4.7.4 | **Reporting Changes - Daily Excel Extract & PDF** | 2d | 2024-09-05 A | 2024-09-06 A | 100% | 2024-09-05 | 2024-09-06 | 0d |  | SI Test | SIT | -701.67 | 6.1 | Heath Thomas | SITAG |  |  |
| 1462 | 1.4.1.4.7.4.1 | Excel Daily Report changes (Refer to above) | 2d | 2024-09-05 A | 2024-09-06 A | 100% | 2024-09-05 | 2024-09-06 | 0d | start no earlier than 2024-09-05 | SI Test | SIT |  | 6.1 | Heath Thomas | SITAG | Complete | COMPLETE |
| 1463 | 1.4.1.4.7.4.2 | PDF Daily Report changes (Refer to Above) | 2d | 2024-09-05 A | 2024-09-06 A | 100% | 2024-09-05 | 2024-09-06 | 0d | start no earlier than 2024-09-05 | SI Test | SIT |  | 6.1 | Heath Thomas | SITAG | Complete | COMPLETE |
| 1464 | 1.4.1.4.7.5 | **Documentation Updates** | 23d? | 2024-09-02 A | 2024-10-02 A | 100% | 2024-09-02 | 2024-10-02 | 0d |  | SI Test | SIT | -701.67 | 6.1 | Heath Thomas | SITAG |  |  |
| 1465 | 1.4.1.4.7.5.1 | Changes to onboarding process (security) | 10d | 2024-09-02 A | 2024-09-13 A | 100% | 2024-09-02 | 2024-09-13 | 0d | start no earlier than 2024-09-02 | SI Test | SIT |  | 6.1 | Heath Thomas | SITAG | Complete | COMPLETE |
| 1466 | 1.4.1.4.7.5.2 | Update the documents on loading tests into ADO? | 10d | 2024-09-02 A | 2024-09-13 A | 100% | 2024-09-02 | 2024-09-13 | 0d | start no earlier than 2024-09-02 | SI Test | SIT |  | 6.1 | Heath Thomas | SITAG | Complete | COMPLETE |
| 1467 | 1.4.1.4.7.5.3 | Update ADO Training material | 10d | 2024-09-02 A | 2024-09-13 A | 100% | 2024-09-02 | 2024-09-13 | 0d | start no earlier than 2024-09-02 | SI Test | SIT |  | 6.1 | Heath Thomas | SITAG | Complete | COMPLETE |
| 1468 | 1.4.1.4.7.5.4 | Update ADO User Guide | 10d | 2024-09-02 A | 2024-09-13 A | 100% | 2024-09-02 | 2024-09-13 | 0d | start no earlier than 2024-09-02 | SI Test | SIT |  | 6.1 | Heath Thomas | SITAG | Complete | COMPLETE |
| 1469 | 1.4.1.4.7.5.5 | Update ADO Configuration document | 10d | 2024-09-02 A | 2024-09-13 A | 100% | 2024-09-02 | 2024-09-13 | 0d | start no earlier than 2024-09-02 | SI Test | SIT |  | 6.1 | Heath Thomas | SITAG | Complete | COMPLETE |
| 1470 | 1.4.1.4.7.5.6 | Update ADO Training Material and User Guide following SRO review | 1d? | 2024-10-02 A | 2024-10-02 A | 100% | 2024-10-02 | 2024-10-02 | 0d | start no earlier than 2024-10-02 | SI Test | SIT |  | 6.1 | Heath Thomas | SITAG | Complete | COMPLETE |
| 1471 | 1.4.1.4.7.6 | **ADO Changes - Review Stage** | 19d | 2024-09-09 A | 2024-10-03 A | 100% | 2024-09-09 | 2024-10-03 | 0d |  | SI Test | SIT | -701.67 | 6.1 | Heath Thomas | SITAG |  |  |
| 1472 | 1.4.1.4.7.6.1 | Review implementation with SI LDP leads | 1d | 2024-09-27 A | 2024-09-27 A | 100% | 2024-09-27 | 2024-09-27 | 0d | start no earlier than 2024-09-27 | SI Test | SIT |  | 6.1 | Heath Thomas | SITAG | Complete | COMPLETE |
| 1473 | 1.4.1.4.7.6.2 | Review implementation with SRO | 1d | 2024-09-30 A | 2024-09-30 A | 100% | 2024-09-30 | 2024-09-30 | 0d | start no earlier than 2024-09-30 | SI Test | SIT |  | 6.1 | Heath Thomas | SITAG | Complete | COMPLETE |
| 1474 | 1.4.1.4.7.6.3 | LDP Review - ADO User Guide, Training Materials | 5d | 2024-09-09 A | 2024-09-13 A | 100% | 2024-09-09 | 2024-09-13 | 0d | start no earlier than 2024-09-09 | SI Test | SIT |  | 6.1 | Heath Thomas | SITAG | Complete | COMPLETE |
| 1475 | 1.4.1.4.7.6.4 | SRO Review - ADO User Guide, Training Materials | 1d | 2024-09-30 A | 2024-09-30 A | 100% | 2024-09-30 | 2024-09-30 | 0d | start no earlier than 2024-09-30 | SI Test | SIT |  | 6.1 | Heath Thomas | SITAG | Complete | COMPLETE |
| 1476 | 1.4.1.4.7.6.5 | LDP Review - Config doc | 1d | 2024-09-30 A | 2024-09-30 A | 100% | 2024-09-30 | 2024-09-30 | 0d | start no earlier than 2024-09-30 | SI Test | SIT |  | 6.1 | Heath Thomas | SITAG | Complete | COMPLETE |
| 1477 | 1.4.1.4.7.6.6 | SRO Review - Config doc | 1d | 2024-09-30 A | 2024-09-30 A | 100% | 2024-09-30 | 2024-09-30 | 0d | start no earlier than 2024-09-30 | SI Test | SIT |  | 6.1 | Heath Thomas | SITAG | Complete | COMPLETE |
| 1478 | 1.4.1.4.7.6.7 | SRO Sign-off of all changes | 1d | 2024-10-03 A | 2024-10-03 A | 100% | 2024-10-03 | 2024-10-03 | 0d | start no earlier than 2024-10-03 | SI Test | SIT |  | 6.1 | Heath Thomas | SITAG | Complete | COMPLETE |

| ID | WBS | Task | Type | Duration | Start | Finish | Predecessors | Complete | Baseline start | Baseline finish | Baseline duration | Baseline 1 start | Baseline 1 finish | Constraint | Baseline cost | Responsible | Text9 | Task Status | Update Version | MHHS Resource Name | Text29 | Sched Status | RAG | Involved | MHHS Programme Phase | Artefact ID | Milestone ID | Tier | Future RAG |
| --- | --- | --- | --- | --- | --- | --- | --- | --- | --- | --- | --- | --- | --- | --- | --- | --- | --- | --- | --- | --- | --- | --- | --- | --- | --- | --- | --- | --- | --- |
| 1479 | 1.4.1.4.7.7 | **Azure DevOps Changes - Final Implementation** |  | 1d? | 2024-10-03 A | 2024-10-03 A |  | 100% | 2024-10-03 | 2024-10-03 | 0d |  |  |  |  | SI Test | SIT | -701.67 | 6.1 | Heath Thomas | SITAG |  |  |  |  |  |  |  |  |
| 1480 | 1.4.1.4.7.7.1 | Final task rollout |  | 1d | 2024-10-03 A | 2024-10-03 A |  | 100% | 2024-10-03 | 2024-10-03 | 0d |  |  | start no earlier than 2024-10-03 |  | SI Test | SIT |  | 6.1 | Heath Thomas | SITAG | Complete | COMPLETE |  |  |  |  |  |  |
| 1481 | 1.4.1.4.7.7.2 | ADO Training Drop-in Session ahead of Cycle 3 |  | 1d | 2024-10-03 A | 2024-10-03 A |  | 100% | 2024-10-03 | 2024-10-03 | 0d |  |  | start no earlier than 2024-10-03 |  | SI Test | SIT |  | 6.1 | Heath Thomas | SITAG | Complete | COMPLETE |  |  |  |  |  |  |
| 1482 | 1.4.2 | **SIT Execution** |  | 495d? | 2023-10-30 A | 2025-09-19 A |  | 100% | 2022-10-31 | 2025-11-27 | 390d | 2023-10-30 | 2025-04-25 |  | -0 | N/A | SIT |  | 5.0 | N/A | SITAG |  |  | N/A | Systems Integration Testing (SIT) |  |  |  |  |
| 1483 | 1.4.2.1 | System Integration Testing Start (M9) | milestone | 0d | 2023-10-30 A | 2023-10-30 A | 674FS+5d, 588 | 100% | 2023-10-30 | 2023-10-30 | 0d | 2023-10-30 | 2023-10-30 | must start on 2023-10-30 |  | CPT | SIT |  | 5.11 |  | SITAG | Complete | COMPLETE | PMO | Systems Integration Testing (SIT) | MHHS-ART071 | T1-TE-1000 | T1 |  |
| 1484 | 1.4.2.2 | **SIT Component Integration Testing** |  | 96d | 2023-10-30 A | 2024-03-11 A |  | 100% | 2023-10-30 | 2024-03-11 | 95d | 2023-10-30 | 2024-03-08 |  |  | N/A | SIT |  | 5.0 | N/A | SITAG |  |  | N/A | Systems Integration Testing (SIT) |  |  |  | D24A - Industry Integration Test Completion Report |
| 1485 | 1.4.2.2.1 | SIT Component Integration Testing Start | milestone | 0d | 2023-10-30 A | 2023-10-30 A | 1483 | 100% | 2023-10-30 | 2023-10-30 | 0d | 2023-10-30 | 2023-10-30 |  |  | SI Test | SIT |  | 5.11 |  | SITAG | Complete | COMPLETE | PP | Systems Integration Testing (SIT) |  |  |  |  |
| 1486 | 1.4.2.2.2 | Component Integration Testing Interval 1 Start | milestone | 0d | 2023-10-30 A | 2023-10-30 A | 674SS+1d, 595, 599, 603, 114 | 100% | 2023-10-30 | 2023-10-30 | 0d | 2023-10-30 | 2023-10-30 |  |  | SI Test | SIT |  | 5.11 |  | SITAG | Complete | COMPLETE | PP | Systems Integration Testing (SIT) | MHHS-ART071 | T3-TE-0060 | T3 |  |
| 1487 | 1.4.2.2.3 | Component Integration Testing Interval 2 Start | milestone | 0d | 2023-11-13 A | 2023-11-13 A | 701SS+5d, 595, 603, 599, 114 | 100% | 2023-11-13 | 2023-11-13 | 0d | 2023-11-13 | 2023-11-13 |  |  | SI Test | SIT |  | 5.12 |  | SITAG | Complete | COMPLETE | PP | Systems Integration Testing (SIT) |  | T3-TE-0061 | T3 |  |
| 1488 | 1.4.2.2.4 | Component Integration Testing Interval 3 Start | milestone | 0d | 2023-11-27 A | 2023-11-27 A | 733SS+5d, 595, 599, 603, 114 | 100% | 2023-11-27 | 2023-11-27 | 0d | 2023-11-27 | 2023-11-27 |  |  | SI Test | SIT |  | 5.0 |  | SITAG | Complete | COMPLETE | PP | Systems Integration Testing (SIT) |  | T3-TE-0062 | T3 |  |
| 1489 | 1.4.2.2.5 | Component Integration Testing Interval 4 Start | milestone | 0d | 2023-12-11 A | 2023-12-11 A | 765SS+5d, 595, 599, 603, 114 | 100% | 2023-12-11 | 2023-12-11 | 0d | 2023-12-11 | 2023-12-11 |  |  | SI Test | SIT |  | 5.0 |  | SITAG | Complete | COMPLETE | PP | Systems Integration Testing (SIT) |  | T3-TE-0063 | T3 |  |
| 1490 | 1.4.2.2.6 | Component Integration Testing Interval 5 Start | milestone | 0d | 2024-01-15 A | 2024-01-15 A | 797SS+5d, 595, 599, 603, 114 | 100% | 2024-01-15 | 2024-01-15 | 0d | 2024-01-15 | 2024-01-15 |  |  | SI Test | SIT |  | 5.0 |  | SITAG | Complete | COMPLETE | PP | Systems Integration Testing (SIT) |  | T3-TE-0064 | T3 |  |
| 1491 | 1.4.2.2.7 | Component Integration Testing Interval 6 Start | milestone | 0d | 2024-01-29 A | 2024-01-29 A | 595, 599, 603, 829, 114, 641 | 100% | 2024-01-29 | 2024-01-29 | 0d | 2024-01-29 | 2024-01-29 | must start on 2024-01-29 |  | SI Test | SIT |  | 5.0 |  | SITAG | Complete | COMPLETE | PP | Systems Integration Testing (SIT) |  | T3-TE-0065 | T3 |  |
| 1492 | 1.4.2.2.8 | SIT Component Integration Testing Execution |  | 85d | 2023-10-30 A | 2024-02-23 A | 1486SS | 100% | 2023-10-30 | 2024-02-23 | 85d | 2023-10-30 | 2024-02-23 | must start on 2023-10-30 |  | SI Test | SIT |  | 5.0 |  | SITAG | Complete | COMPLETE | PP | Systems Integration Testing (SIT) |  |  |  | D24A - Industry Integration Test Completion Report |
| 1493 | 1.4.2.2.9 | SIT Component Integration Testing End (incl. confirmation that PPs have submitted their Test Completion Reports to Programme for assurance) | milestone | 0d | 2024-02-23 A | 2024-02-23 A | 1492FF | 100% | 2024-02-23 | 2024-02-23 | 0d | 2024-02-23 | 2024-02-23 | finish no earlier than 2024-02-23 |  | SI Test | SIT |  | 5.19 |  | SITAG | Complete | COMPLETE | PP | Systems Integration Testing (SIT) | MHHS-ART074 | T3-TE-0032 | T3 |  |
| 1494 | 1.4.2.2.10 | Assurance of PPs Test Completion Reports |  | 30d | 2024-01-22 A | 2024-03-01 A | 1493FF+5d | 100% | 2024-01-22 | 2024-03-01 | 30d | 2024-01-22 | 2024-03-01 |  |  | SI Test | SIT |  | 5.19 |  | SITAG | Complete | COMPLETE | PP | Systems Integration Testing (SIT) |  |  |  |  |
| 1495 | 1.4.2.2.11 | **SIT CI Test Completion Report** |  | 18d | 2024-02-07 A | 2024-03-01 A |  | 100% | 2024-02-07 | 2024-03-01 | 18d | 2024-02-07 | 2024-03-01 |  |  | N/A | SIT |  | 5.0 | N/A | SITAG |  |  | N/A | Systems Integration Testing (SIT) |  |  |  |  |
| 1496 | 1.4.2.2.11.1 | Develop document |  | 13d | 2024-02-07 A | 2024-02-23 A | 1493FF | 100% | 2024-02-07 | 2024-02-23 | 13d | 2024-02-07 | 2024-02-23 |  |  | SI Test | SIT |  | 5.19 |  | SITAG | Complete | COMPLETE |  | Systems Integration Testing (SIT) |  |  |  |  |
| 1497 | 1.4.2.2.11.2 | Review & agree document |  | 5d | 2024-02-26 A | 2024-03-01 A | 1496, 1494FF | 100% | 2024-02-26 | 2024-03-01 | 5d | 2024-02-26 | 2024-03-01 |  |  | SI Test | SIT |  | 5.19 |  | SITAG | Complete | COMPLETE | PP,IPA | Systems Integration Testing (SIT) |  |  |  |  |
| 1498 | 1.4.2.2.12 | SIT Component Integration Testing Test Completion Report Approved | milestone | 0d | 2024-03-11 A | 2024-03-11 A | 1497FS+6d | 100% | 2024-03-11 | 2024-03-11 | 0d | 2024-03-08 | 2024-03-08 |  |  | SI Test | SIT |  | 5.18 |  | SITAG | Complete | COMPLETE | PP | Systems Integration Testing (SIT) | MHHS-ART074 | T2-TE-0600 | T2 |  |
| 1499 | 1.4.2.3 | **SIT** |  | 400d? | 2024-03-11 A | 2025-09-19 A |  | 100% | 2022-10-31 | 2025-08-22 | 240d | 2024-03-11 | 2025-02-07 |  | -0 | N/A | SIT |  | 6.24 | N/A | SITAG |  |  | N/A | Systems Integration Testing (SIT) |  |  |  |  |
| 1500 | 1.4.2.3.1 | **SIT Functional Testing (MVC)** |  | 400d? | 2024-03-11 A | 2025-09-19 A |  | 100% | 2022-10-31 | 2025-08-15 | 225d | 2024-03-11 | 2025-01-17 |  |  | N/A | SIT |  | 5.0 | N/A | SITAG |  |  | N/A | Systems Integration Testing (SIT) |  |  |  |  |
| 1501 | 1.4.2.3.1.1 | SIT Functional Testing Start | milestone | 0d | 2024-03-11 A | 2024-03-11 A | 1498, 957FS+5d, 836, 844, 845, 846, 853 | 100% | 2024-03-11 | 2024-03-11 | 0d | 2024-03-11 | 2024-03-11 |  |  | SI Test | SIT |  | 6.1 |  | SITAG | Complete | COMPLETE | PP | Systems Integration Testing (SIT) | MHHS-ART073 | T3-TE-0034 | T3 |  |
| 1502 | 1.4.2.3.1.2 | **SIT Functional Testing Execution (Minimum Viable Cohort)** |  | 295d? | 2024-03-11 A | 2025-04-28 A |  | 100% | 2022-10-31 | 2025-08-15 | 225d | 2024-03-11 | 2025-01-17 |  |  | N/A | SIT | M10 | 5.0 | N/A | SITAG |  |  | N/A | Systems Integration Testing (SIT) |  |  |  | D24C - E2E Test Completion Report |
| 1503 | 1.4.2.3.1.2.1 | **Cycle 1 (Full Cycle)** |  | 70d | 2024-03-11 A | 2024-06-14 A |  | 100% | 2024-03-11 | 2024-06-14 | 90d | 2024-03-11 | 2024-07-12 |  |  | N/A | SIT |  | 5.0 | N/A | SITAG |  |  | N/A | Systems Integration Testing (SIT) |  |  |  |  |
| 1504 | 1.4.2.3.1.2.1.1 | Test Execution |  | 55d | 2024-03-11 A | 2024-05-24 A | 1501SS-1d, 921 | 100% | 2024-03-11 | 2024-05-24 | 80d | 2024-03-11 | 2024-06-28 |  |  | PP | SIT |  | 5.0 |  | SITAG | Complete | COMPLETE | SI Test | Systems Integration Testing (SIT) |  |  |  |  |
| 1505 | 1.4.2.3.1.2.1.2 | Defect resolution, assurance, review, data & environments maintenance |  | 15d | 2024-05-27 A | 2024-06-14 A | 1504 | 100% | 2024-05-27 | 2024-06-14 | 10d | 2024-07-01 | 2024-07-12 |  |  | SI Test | SIT |  | 5.0 |  | SITAG | Complete | COMPLETE | PP | Systems Integration Testing (SIT) |  |  |  |  |

| ID | WBS | Task | Type | Duration | Start | Finish | Predecessors | Complete | Actual finish | Baseline start | Baseline finish | Baseline duration | Baseline 1 start | Baseline 1 finish | Constraint | Responsible | Involved | Text9 | Update Version | MHHS Resource Name | MHHS Programme Phase | Text29 | Sched Status | RAG | Milestone ID | Tier | Task Status |
| --- | --- | --- | --- | --- | --- | --- | --- | --- | --- | --- | --- | --- | --- | --- | --- | --- | --- | --- | --- | --- | --- | --- | --- | --- | --- | --- | --- |
| 1506 | 1.4.2.3.1.2.2 | **Cycle 2 (Defect retests and targeted regression testing)** |  | 80d | 2024-06-17 A | 2024-10-04 A |  | 100% |  | 2024-06-17 | 2024-10-04 | 50d | 2024-07-15 | 2024-09-20 |  | N/A | N/A | SIT | 5.0 | N/A | Systems Integration Testing (SIT) | SITAG |  |  |  |  |  |
| 1507 | 1.4.2.3.1.2.2.1 | Test Execution |  | 70d | 2024-06-17 A | 2024-09-20 A | 1505, 926 | 100% |  | 2024-06-17 | 2024-09-20 | 40d | 2024-07-15 | 2024-09-06 |  | PP | SI Test | SIT | 5.0 | Roger Robar | Systems Integration Testing (SIT) | SITAG | Complete | COMPLETE |  |  |  |
| 1508 | 1.4.2.3.1.2.2.2 | Defect resolution, assurance, review, data & environments maintenance |  | 10d | 2024-09-23 A | 2024-10-04 A | 1507 | 100% |  | 2024-09-23 | 2024-10-04 | 10d | 2024-09-09 | 2024-09-20 |  | SI Test | PP | SIT | 5.0 | Roger Robar | Systems Integration Testing (SIT) | SITAG | Complete | COMPLETE |  |  |  |
| 1509 | 1.4.2.3.1.2.3 | **SIT Functional Testing back-up progress risk-assessment** |  | 7d? | 2024-10-07 A | 2024-10-15 A |  | 100% |  | 2022-10-31 | 2022-10-31 | 20d | 2024-09-23 | 2024-10-18 |  | N/A | N/A | SIT | 5.31 | N/A | Systems Integration Testing (SIT) | SITAG |  |  |  |  |  |
| 1510 | 1.4.2.3.1.2.3.1 | Back-up risk-assessment of SIT Functional progress to assess whether Qualification Execution can start early |  | 1d? | 2024-10-07 A | 2024-10-07 A | 1508 | 100% |  | 2024-10-07 | 2024-10-07 | 0d |  |  |  | SI Test |  | SIT | 5.31 | Nicola Farley |  | SITAG | Complete | COMPLETE |  |  |  |
| 1511 | 1.4.2.3.1.2.3.2 | Back-up SITAG decision on early Qualification Testing Execution start |  | 1d? | 2024-10-15 A | 2024-10-15 A | 1510FS+5d | 100% |  | 2024-10-15 | 2024-10-15 | 0d |  |  |  | SI Test |  | SIT | 5.31 | Nicola Farley |  | SITAG | Complete | COMPLETE |  |  |  |
| 1512 | 1.4.2.3.1.2.4 | **Cycle 3 (Defect retests and targeted regression testing)** |  | 105d? | 2024-10-21 A | 2025-03-14 |  | 100% | 2025-04-28 | 2024-10-21 | 2025-03-14 | 30d | 2024-09-23 | 2024-11-01 |  | SI Test | N/A | SIT | 5.0 | Dom Mooney | Systems Integration Testing (SIT) | SITAG |  |  |  |  |  |
| 1513 | 1.4.2.3.1.2.4.1 | Sprint 5 |  | 10d? | 2024-10-21 A | 2024-11-01 A | 140SS-1d | 100% |  | 2024-10-21 | 2024-11-01 | 0d |  |  |  | SI Test |  | SIT | 6.0 | Dom Mooney |  | SITAG | Complete | COMPLETE |  |  |  |
| 1514 | 1.4.2.3.1.2.4.2 | Sprint 6 |  | 10d? | 2024-11-04 A | 2024-11-15 A | 1513 | 100% |  | 2024-11-04 | 2024-11-15 | 0d |  |  |  | SI Test |  | SIT | 6.0 | Dom Mooney |  | SITAG | Complete | COMPLETE |  |  |  |
| 1515 | 1.4.2.3.1.2.4.3 | Sprint 7 |  | 10d? | 2024-11-18 A | 2024-11-29 A | 1514 | 100% |  | 2024-11-18 | 2024-11-29 | 0d |  |  |  | SI Test |  | SIT | 6.0 | Dom Mooney |  | SITAG | Complete | COMPLETE |  |  |  |
| 1516 | 1.4.2.3.1.2.4.4 | Sprint 8 |  | 15d? | 2024-12-02 A | 2024-12-20 A | 1515 | 100% |  | 2024-12-02 | 2024-12-20 | 0d |  |  |  | SI Test |  | SIT | 6.0 | Dom Mooney |  | SITAG | Complete | COMPLETE |  |  |  |
| 1517 | 1.4.2.3.1.2.4.5 | Christmas downtime |  | 10d? | 2024-12-23 A | 2025-01-03 A | 1516 | 100% |  | 2024-12-23 | 2025-01-03 | 0d |  |  |  | SI Test |  | SIT | 6.0 | Dom Mooney |  | SITAG | Complete | COMPLETE |  |  |  |
| 1518 | 1.4.2.3.1.2.4.6 | Sprint 9 |  | 10d? | 2025-01-06 A | 2025-01-17 A | 1517 | 100% |  | 2025-01-06 | 2025-01-17 | 0d |  |  |  | SI Test |  | SIT | 6.0 | Dom Mooney |  | SITAG | Complete | COMPLETE |  |  |  |
| 1519 | 1.4.2.3.1.2.4.7 | Sprint 10 |  | 10d? | 2025-01-20 A | 2025-01-31 A | 1518 | 100% |  | 2025-01-20 | 2025-01-31 | 0d |  |  |  | SI Test |  | SIT | 6.0 | Dom Mooney |  | SITAG | Complete | COMPLETE |  |  |  |
| 1520 | 1.4.2.3.1.2.4.8 | Sprint 11 |  | 10d? | 2025-02-03 A | 2025-02-14 A | 1519 | 100% |  | 2025-02-03 | 2025-02-14 | 0d |  |  |  | SI Test |  | SIT | 6.0 | Dom Mooney |  | SITAG | Complete | COMPLETE |  |  |  |
| 1521 | 1.4.2.3.1.2.4.9 | Sprint 12 |  | 10d? | 2025-02-17 A | 2025-02-28 A | 1520 | 100% |  | 2025-02-17 | 2025-02-28 | 0d |  |  |  | SI Test |  | SIT | 6.0 | Dom Mooney |  | SITAG | Complete | COMPLETE |  |  |  |
| 1522 | 1.4.2.3.1.2.4.10 | Sprint 13 (RTTM Gap Analysis + CR056) |  | 10d? | 2025-03-03 A | 2025-03-14 A | 1521 | 100% |  | 2025-03-03 | 2025-03-14 | 0d |  |  |  | SI Test |  | SIT | 6.0 | Dom Mooney |  | SITAG | Complete | COMPLETE |  |  |  |
| 1523 | 1.4.2.3.1.2.4.11 | Sprint 14 (RTTM Gap Analysis + CR056) |  | 10d? | 2025-03-17 A | 2025-03-28 A | 1522 | 100% |  | 2025-03-17 | 2025-03-28 | 0d |  |  |  | SI Test |  | SIT | 6.1 | Dom Mooney |  | SITAG | Complete | COMPLETE |  |  |  |
| 1524 | 1.4.2.3.1.2.4.12 | Sprint 15 (Contingency 1) |  | 10d? | 2025-03-31 A | 2025-04-11 A | 1523 | 100% |  | 2025-03-31 | 2025-04-11 | 0d |  |  |  | SI Test |  | SIT | 6.1 | Dom Mooney |  | SITAG | Complete | COMPLETE |  |  |  |
| 1525 | 1.4.2.3.1.2.4.13 | Sprint 16 (Contingency 2) |  | 10d? | 2025-04-14 A | 2025-04-25 A | 1524 | 100% |  | 2025-04-14 | 2025-04-25 | 0d |  |  |  | SI Test |  | SIT | 6.1 | Dom Mooney |  | SITAG | Complete | COMPLETE |  |  |  |
| 1526 | 1.4.2.3.1.2.4.14 | SIT Functional Cycle 3 Complete | milestone | 0d | 2025-04-28 A | 2025-04-28 A | 1525 | 100% |  | 2025-04-28 | 2025-04-28 | 0d |  |  |  | SI Test |  | SIT | 6.13 | Dom Mooney |  | SITAG | Complete | COMPLETE | T2-TE-1150 | T2 |  |
| 1527 | 1.4.2.3.1.3 | **SIT Scope Traceability** |  | 64d | 2025-01-27 A | 2025-04-24 A |  | 100% |  | 2025-01-27 | 2025-03-19 | 0d |  |  |  | SI Test |  | SIT | 6.17 | Salman Bukhari |  | SITAG |  |  |  |  | -94.67 |
| 1528 | 1.4.2.3.1.3.1 | Draft Scope Tracability document |  | 10d | 2025-01-27 A | 2025-02-07 A |  | 100% |  | 2025-01-27 | 2025-02-07 | 0d |  |  | start no earlier than 2025-01-27 | SI Test |  | SIT | 6.17 | Salman Bukhari |  | SITAG | Complete | COMPLETE |  |  |  |
| 1529 | 1.4.2.3.1.3.2 | LDP review |  | 2d | 2025-02-10 A | 2025-02-11 A | 1528 | 100% |  | 2025-02-10 | 2025-02-11 | 0d |  |  |  | SI Test |  | SIT | 6.17 | Salman Bukhari |  | SITAG | Complete | COMPLETE |  |  |  |
| 1530 | 1.4.2.3.1.3.3 | SRO review |  | 5d | 2025-02-12 A | 2025-02-18 A | 1529 | 100% |  | 2025-02-12 | 2025-02-18 | 0d |  |  |  | SI Test |  | SIT | 6.17 | Salman Bukhari |  | SITAG | Complete | COMPLETE |  |  |  |
| 1531 | 1.4.2.3.1.3.4 | Updates to reflect SRO feedback |  | 5d | 2025-02-12 A | 2025-02-18 A | 1530FF | 100% |  | 2025-02-12 | 2025-02-18 | 0d |  |  |  | SI Test |  | SIT | 6.17 | Salman Bukhari |  | SITAG | Complete | COMPLETE |  |  |  |
| 1532 | 1.4.2.3.1.3.5 | Industry Review |  | 10d | 2025-02-19 A | 2025-03-04 A | 1531 | 100% |  | 2025-02-19 | 2025-03-04 | 0d |  |  |  | SI Test |  | SIT | 6.17 | Salman Bukhari |  | SITAG | Complete | COMPLETE |  |  |  |
| 1533 | 1.4.2.3.1.3.6 | SITWG paper day | milestone | 0d | 2025-04-08 A | 2025-04-08 A | 1531FS+35d | 100% |  | 2025-04-08 | 2025-04-08 | 0d |  |  | start no earlier than 2025-04-08 | SI Test |  | SIT | 6.20 | Salman Bukhari |  | SITAG | Complete | COMPLETE |  |  |  |
| 1534 | 1.4.2.3.1.3.7 | SITWG recommends Scope Tracability document | milestone | 0d | 2025-04-15 A | 2025-04-15 A | 1533FS+5d | 100% |  | 2025-04-15 | 2025-04-15 | 0d |  |  |  | SI Test |  | SIT | 6.20 | Salman Bukhari |  | SITAG | Complete | COMPLETE |  |  |  |
| 1535 | 1.4.2.3.1.3.8 | Update document to reflect industry consultation views |  | 8d | 2025-03-05 A | 2025-03-14 A | 1532 | 100% |  | 2025-03-05 | 2025-03-14 | 0d |  |  |  | SI Test |  | SIT | 6.20 | Salman Bukhari |  | SITAG | Complete | COMPLETE |  |  |  |
| 1536 | 1.4.2.3.1.3.9 | SITAG paper day | milestone | 0d | 2025-04-17 A | 2025-04-17 A | 1534FS+2d, 1535 | 100% |  | 2025-04-17 | 2025-04-17 | 0d |  |  |  | SI Test |  | SIT | 6.20 | Salman Bukhari |  | SITAG | Complete | COMPLETE |  |  |  |
| 1537 | 1.4.2.3.1.3.10 | SITAG approve SIT Scope Traceability document | milestone | 0d | 2025-04-24 A | 2025-04-24 A | 1536FS+5d | 100% |  | 2025-04-24 | 2025-04-24 | 0d |  |  |  | SI Test |  | SIT | 6.20 | Salman Bukhari |  | SITAG | Complete | COMPLETE |  |  |  |
| 1538 | 1.4.2.3.1.3.11 | SIT Scope Traceability Approved | milestone | 0d | 2025-04-24 A | 2025-04-24 A | 1537 | 100% |  | 2025-04-24 | 2025-04-24 | 0d |  |  |  | SI Test |  | SIT | 6.20 | Salman Bukhari |  | SITAG | Complete | COMPLETE |  |  |  |

| ID | WBS | Task | Type | Duration | Start | Finish | Predecessors | Complete | Actual start | Actual finish | Baseline start | Baseline finish | Baseline duration | Constraint | Responsible | Text9 | Task Status | Update Version | MHHS Resource Name | Text29 | Sched Status | RAG | Milestone ID | Tier |
| --- | --- | --- | --- | --- | --- | --- | --- | --- | --- | --- | --- | --- | --- | --- | --- | --- | --- | --- | --- | --- | --- | --- | --- | --- |
| 1539 | 1.4.2.3.1.4 | **SIT Functional Settlement Testing** |  | 230d? | 2024-06-17 | 2025-05-02 |  | 100% | 2024-10-07 | 2025-09-19 | 2024-06-17 | 2025-05-02 | 0d |  | SI Test | SIT | -685.67 | 6.12 | Stuart Scott | SITAG |  |  |  |  |
| 1540 | 1.4.2.3.1.4.1 | SIT-B Settlement Testing Cycle 2 |  | 70d | 2025-03-10 A | 2025-06-13 A | 1557FS+10d | 100% |  |  | 2025-03-10 | 2025-06-13 | 0d | start no earlier than 2024-06-17 | SI Test | SIT |  | 6.12 | Stuart Scott | SITAG | Complete | COMPLETE |  |  |
| 1541 | 1.4.2.3.1.4.2 | **SIT-B Settlement Testing Cycle 3** |  | 100d? | 2024-10-07 A | 2025-02-21 A |  | 100% |  |  | 2024-10-07 | 2024-12-20 | 0d |  | SI Test | SIT | -24.67 | 6.12 | Stuart Scott | SITAG |  |  |  |  |
| 1542 | 1.4.2.3.1.4.2.1 | Sprint 5 |  | 20d? | 2024-10-07 A | 2024-11-01 A | 1184 | 100% |  |  | 2024-10-07 | 2024-11-01 | 0d |  | SI Test | SIT |  | 6.12 | Stuart Scott | SITAG | Complete | COMPLETE |  |  |
| 1543 | 1.4.2.3.1.4.2.2 | Sprint 5 Review (Flexibility Window Checkpoint) | milestone | 0d | 2024-11-04 A | 2024-11-04 A | 1542SS+21d | 100% |  |  | 2024-11-04 | 2024-11-04 | 0d |  | SI Test | SIT |  | 6.12 | Stuart Scott | SITAG | Complete | COMPLETE |  |  |
| 1544 | 1.4.2.3.1.4.2.3 | Sprint 6 |  | 10d? | 2024-11-04 A | 2024-11-15 A | 1542 | 100% |  |  | 2024-11-04 | 2024-11-15 | 0d |  | SI Test | SIT |  | 6.12 | Stuart Scott | SITAG | Complete | COMPLETE |  |  |
| 1545 | 1.4.2.3.1.4.2.4 | Sprint 6 Review (Pre Christmas Contingency Decision Point) | milestone | 0d | 2024-11-18 A | 2024-11-18 A | 1544SS+11d | 100% |  |  | 2024-11-18 | 2024-11-18 | 0d |  | SI Test | SIT |  | 6.12 | Stuart Scott | SITAG | Complete | COMPLETE |  |  |
| 1546 | 1.4.2.3.1.4.2.5 | Sprint 7 |  | 10d? | 2024-11-18 A | 2024-11-29 A | 1544 | 100% |  |  | 2024-11-18 | 2024-11-29 | 0d |  | SI Test | SIT |  | 6.12 | Stuart Scott | SITAG | Complete | COMPLETE |  |  |
| 1547 | 1.4.2.3.1.4.2.6 | Sprint 7 Review (Post Christmas Contingency Decision Point) | milestone | 0d | 2024-12-02 A | 2024-12-02 A | 1546SS+11d | 100% |  |  | 2024-12-02 | 2024-12-02 | 0d |  | SI Test | SIT |  | 6.12 | Stuart Scott | SITAG | Complete | COMPLETE |  |  |
| 1548 | 1.4.2.3.1.4.2.7 | Sprint 8 |  | 15d | 2024-12-02 A | 2024-12-20 A | 1546 | 100% |  |  | 2024-12-02 | 2024-12-20 | 0d |  | SI Test | SIT |  | 6.15 | Stuart Scott | SITAG | Complete | COMPLETE |  |  |
| 1549 | 1.4.2.3.1.4.2.8 | Post-Christmas Stabilisation |  | 5d | 2025-01-06 A | 2025-01-10 A | 1548FS+10d | 100% |  |  | 2025-01-06 | 2025-01-10 | 0d |  | SI Test | SIT |  | 6.15 | Stuart Scott | SITAG | Complete | COMPLETE |  |  |
| 1550 | 1.4.2.3.1.4.2.9 | Sprint 9 |  | 10d | 2025-01-06 A | 2025-01-17 A | 1548FS+10d | 100% |  |  | 2025-01-13 | 2025-01-17 | 0d |  | SI Test | SIT |  | 6.15 | Stuart Scott | SITAG | Complete | COMPLETE |  |  |
| 1551 | 1.4.2.3.1.4.2.10 | Sprint 9 Review | milestone | 0d | 2025-01-20 A | 2025-01-20 A | 1550FS+1d | 100% |  |  | 2025-01-20 | 2025-01-20 | 0d |  | SI Test | SIT |  | 6.15 | Stuart Scott | SITAG | Complete | COMPLETE |  |  |
| 1552 | 1.4.2.3.1.4.2.11 | Sprint 10 |  | 10d | 2025-01-20 A | 2025-01-31 A | 1550 | 100% |  |  | 2025-01-20 | 2025-01-31 | 0d |  | SI Test | SIT |  | 6.15 | Stuart Scott | SITAG | Complete | COMPLETE |  |  |
| 1553 | 1.4.2.3.1.4.2.12 | Sprint 10 Review | milestone | 0d | 2025-02-03 A | 2025-02-03 A | 1552FS+1d | 100% |  |  | 2025-02-03 | 2025-02-03 | 0d |  | SI Test | SIT |  | 6.15 | Stuart Scott | SITAG | Complete | COMPLETE |  |  |
| 1554 | 1.4.2.3.1.4.2.13 | Sprint 11 |  | 10d | 2025-02-03 A | 2025-02-14 A | 1552 | 100% |  |  | 2025-02-03 | 2025-02-14 | 0d |  | SI Test | SIT |  | 6.15 | Stuart Scott | SITAG | Complete | COMPLETE |  |  |
| 1555 | 1.4.2.3.1.4.2.14 | Sprint 11 Review | milestone | 0d | 2025-02-14 A | 2025-02-14 A | 1554 | 100% |  |  | 2025-02-14 | 2025-02-14 | 0d |  | SI Test | SIT |  | 6.15 | Stuart Scott | SITAG | Complete | COMPLETE |  |  |
| 1556 | 1.4.2.3.1.4.2.15 | Sprint 12 |  | 5d | 2025-02-17 A | 2025-02-21 A | 1555 | 100% |  |  | 2025-02-17 | 2025-02-21 | 0d |  | SI Test | SIT |  | 6.15 | Stuart Scott | SITAG | Complete | COMPLETE |  |  |
| 1557 | 1.4.2.3.1.4.2.16 | End of Settlement Testing Cycle 3 | milestone | 0d | 2025-02-21 A | 2025-02-21 A | 1556 | 100% |  |  | 2025-02-21 | 2025-02-21 | 0d |  | SI Test | SIT |  | 6.15 | Stuart Scott | SITAG | Complete | COMPLETE | T3-TE-0140 | T3 |
| 1558 | 1.4.2.3.1.4.3 | **SIT-A Settlement Testing** |  | 30d | 2025-05-19 A | 2025-06-27 A |  | 100% |  |  | 2025-05-19 | 2025-06-13 | 0d |  | SI Test | SIT | -258.67 | 6.19 | Stuart Scott | SITAG |  |  |  |  |
| 1559 | 1.4.2.3.1.4.3.1 | SIT-A Settlement Testing Start | milestone | 0d | 2025-05-19 A | 2025-05-19 A | 1432FS+1d | 100% |  |  | 2025-05-19 | 2025-05-19 | 0d |  | SI Test | SIT |  | 6.20 | Stuart Scott | SITAG | Complete | COMPLETE |  |  |
| 1560 | 1.4.2.3.1.4.3.2 | SIT-A Settlement Testing |  | 30d | 2025-05-19 A | 2025-06-27 A | 1559 | 100% |  |  | 2025-05-19 | 2025-06-27 | 0d |  | SI Test | SIT |  | 6.28 | Stuart Scott | SITAG | Complete | COMPLETE |  |  |
| 1561 | 1.4.2.3.1.4.3.3 | eSITAG decision point on end of SIT A testing | milestone | 0d | 2025-06-26 A | 2025-06-26 A |  | 100% |  |  | 2025-06-11 | 2025-06-11 | 0d | finish no earlier than 2025-06-26 | SI Test | SIT |  | 6.28 | Stuart Scott | SITAG | Complete | COMPLETE |  |  |
| 1562 | 1.4.2.3.1.4.3.4 | SIT-A Settlement Decision Point Exit Criteria | milestone | 0d | 2025-06-27 A | 2025-06-27 A | 1560FS-1d | 100% |  |  | 2025-06-27 | 2025-06-27 | 0d |  | SI Test | SIT |  | 6.28 | Stuart Scott | SITAG | Complete | COMPLETE |  |  |
| 1563 | 1.4.2.3.1.4.3.5 | SIT-A Settlement Testing Completed | milestone | 0d | 2025-06-27 A | 2025-06-27 A | 1562 | 100% |  |  | 2025-06-27 | 2025-06-27 | 0d |  | SI Test | SIT |  | 6.28 | Stuart Scott | SITAG | Complete | COMPLETE |  |  |

| ID | WBS | Task | Type | Duration | Start | Finish | Predecessors | Complete | Baseline start | Baseline finish | Baseline duration | Baseline 1 start | Baseline 1 finish | Constraint | Responsible | Involved | Text9 | Task Status | Update Version | MHHS Resource Name | MHHS Programme Phase | Text29 | Sched Status | RAG | Milestone ID | Tier | Artefact ID |
| --- | --- | --- | --- | --- | --- | --- | --- | --- | --- | --- | --- | --- | --- | --- | --- | --- | --- | --- | --- | --- | --- | --- | --- | --- | --- | --- | --- |
| 1564 | 1.4.2.3.1.4.4 | **SIT Functional & Migration Regression Testing (code freeze)** |  | 55d? | 2025-06-30 A | 2025-09-12 A |  | 100% | 2025-06-16 | 2025-08-08 | 45d | 2024-11-04 | 2025-01-03 |  | PP | SI Test | SIT | 84.33 | 6.28 | Roger Robar | Systems Integration Testing (SIT) | SITAG |  |  |  |  |  |
| 1565 | 1.4.2.3.1.4.4.1 | Regression Test Execution Start | milestone | 0d | 2025-06-30 A | 2025-06-30 A | 1432FS+2d, 1563FS+2d | 100% | 2025-06-30 | 2025-06-30 | 0d |  |  |  | SI Test |  | SIT |  | 6.28 | Roger Robar |  | SITAG | Complete | COMPLETE | T2-TE-1250 | T2 |  |
| 1566 | 1.4.2.3.1.4.4.2 | Regression Execution |  | 5d | 2025-06-30 A | 2025-07-04 A | 1565FS-1d | 100% | 2025-06-30 | 2025-07-04 | 0d |  |  |  | SI Test |  | SIT |  | 6.28 | Roger Robar |  | SITAG | Complete | COMPLETE |  |  |  |
| 1567 | 1.4.2.3.1.4.4.3 | Regression Sprint 1 |  | 10d? | 2025-07-07 A | 2025-07-18 A | 1566 | 100% | 2025-07-07 | 2025-07-18 | 0d |  |  |  | SI Test |  | SIT |  | 6.28 | Roger Robar |  | SITAG | Complete | COMPLETE |  |  |  |
| 1568 | 1.4.2.3.1.4.4.4 | Regression Sprint 2 |  | 15d | 2025-07-21 A | 2025-08-08 A | 1567 | 100% | 2025-07-21 | 2025-08-08 | 0d |  |  |  | SI Test |  | SIT |  | 6.28 | Roger Robar |  | SITAG | Complete | COMPLETE |  |  |  |
| 1569 | 1.4.2.3.1.4.4.5 | Cycle 1 SAT Regression |  | 10d | 2025-07-21 A | 2025-08-01 A | 1568SS, 2279 | 100% | 2025-07-21 | 2025-08-01 | 0d |  |  |  | SI Test |  |  |  | 6.29 | Stuart Scott |  | SITAG | Complete | COMPLETE |  |  |  |
| 1570 | 1.4.2.3.1.4.4.6 | Supplementary Regression Testing |  | 20d | 2025-07-21 A | 2025-08-15 A | 1569SS | 100% | 2025-07-21 | 2025-08-15 | 0d |  |  |  | SI Test |  |  |  | 6.30 | Roger Robar |  | SITAG | Complete | COMPLETE |  |  |  |
| 1571 | 1.4.2.3.1.4.4.7 | Cycle 2 SAT Regression |  | 5d | 2025-08-04 A | 2025-08-08 A | 1568SS, 2289 | 100% | 2025-08-04 | 2025-08-08 | 0d |  |  | start no earlier than 2025-08-04 | SI Test |  |  |  | 6.29 | Stuart Scott |  | SITAG | Complete | COMPLETE |  |  |  |
| 1572 | 1.4.2.3.1.4.4.8 | Regression Sprint 3 |  | 10d | 2025-08-11 A | 2025-08-22 A | 1568 | 100% | 2025-08-11 | 2025-08-22 | 0d |  |  |  | SI Test |  | SIT |  | 6.28 | Roger Robar |  | SITAG | Complete | COMPLETE |  |  |  |
| 1573 | 1.4.2.3.1.4.4.9 | Regression Sprint 4 |  | 15d | 2025-08-25 A | 2025-09-12 A | 1572 | 100% | 2025-08-25 | 2025-09-12 | 0d |  |  |  | SI Test |  | SIT |  | 6.28 | Roger Robar |  | SITAG | Complete | COMPLETE |  |  |  |
| 1574 | 1.4.2.3.1.4.5 | **SIT Functional & Migration Overarching Exit Report** |  | 59d | 2025-04-28 A | 2025-07-17 A |  | 100% | 2025-07-21 | 2025-08-15 | 20d | 2024-12-16 | 2025-01-10 |  | SI Test | N/A | SIT |  | 6.1 | Dom Mooney | Systems Integration Testing (SIT) | SITAG |  |  |  |  |  |
| 1575 | 1.4.2.3.1.4.5.1 | Programme drafts Functional & Migration PP Exit Report |  | 32d | 2025-04-28 A | 2025-06-10 A | 1526 | 100% | 2025-04-28 | 2025-06-10 | 0d |  |  |  | SI Test |  | SIT |  | 6.28 | Dom Mooney |  | SITAG | Complete | COMPLETE |  |  |  |
| 1576 | 1.4.2.3.1.4.5.2 | SRO Review PP Exit Reports |  | 10d | 2025-05-22 A | 2025-06-04 A | 1575SS | 100% | 2025-05-22 | 2025-06-04 | 0d |  |  | start no earlier than 2025-05-22 | SI Test |  | SIT |  | 6.28 | Dom Mooney |  | SITAG | Complete | COMPLETE |  |  |  |
| 1577 | 1.4.2.3.1.4.5.3 | Functional & Migration PP Exit Reports shared with PPs | milestone | 0d | 2025-06-10 A | 2025-06-10 A | 1575 | 100% | 2025-06-10 | 2025-06-10 | 0d |  |  | finish no earlier than 2025-05-23 | SI Test |  | SIT |  | 6.28 | Dom Mooney |  | SITAG | Complete | COMPLETE |  |  |  |
| 1578 | 1.4.2.3.1.4.5.4 | PPs review Exit Report and sign Functional & Migration Exit Declaration |  | 10d | 2025-06-11 A | 2025-06-24 A | 1577 | 100% | 2025-06-11 | 2025-06-24 | 0d |  |  | start no earlier than 2025-05-26 | PP |  | SIT |  | 6.28 | Dom Mooney |  | SITAG | Complete | COMPLETE |  |  |  |
| 1579 | 1.4.2.3.1.4.5.5 | Programme drafts SI SIT Functional & Migration Overarching Exit Report |  | 13d | 2025-06-11 A | 2025-06-27 A | 1577 | 100% | 2025-06-11 | 2025-06-27 | 0d |  |  | start no earlier than 2025-05-26 | SI Test |  | SIT |  | 6.28 | Dom Mooney |  | SITAG | Complete | COMPLETE |  |  |  |
| 1580 | 1.4.2.3.1.4.5.6 | SRO/Code Bodies Review SI SIT Funcational & Migration Overarching Exit Report |  | 5d | 2025-06-26 A | 2025-07-02 A | 1579SS | 100% | 2025-06-30 | 2025-07-03 | 0d |  |  | finish no earlier than 2025-07-02 | SRO, Code Bodies |  |  |  |  | Dom Mooney |  | SITAG | Complete | COMPLETE |  |  |  |
| 1581 | 1.4.2.3.1.4.5.7 | SITWG Review status of SI SIT Functional & Migration Overarching Exit Report | milestone | 0d | 2025-07-03 A | 2025-07-03 A | 1579FS+4d, 1580 | 100% | 2025-07-03 | 2025-07-03 | 0d |  |  | start no earlier than 2025-06-05 | SI Test |  | SIT |  | 6.28 | Dom Mooney |  | SITAG | Complete | COMPLETE |  |  |  |
| 1582 | 1.4.2.3.1.4.5.8 | SI SIT Functional & Migration Overarching Exit Report Industry Review |  | 10d | 2025-07-04 A | 2025-07-17 A | 1581 | 100% | 2025-07-04 | 2025-07-17 | 0d |  |  |  | PP |  | SIT |  | 6.28 | Dom Mooney |  | SITAG | Complete | COMPLETE |  |  |  |
| 1583 | 1.4.2.3.1.4.6 | **SIT Settlement and Regression Test Exit Report** |  | 55d | 2025-07-07 A | 2025-09-19 A |  | 100% | 2025-06-30 | 2025-08-15 | 0d |  |  |  | SI Test |  | SIT | -317.67 | 6.28 | Dom Mooney |  | SITAG |  |  |  |  |  |
| 1584 | 1.4.2.3.1.4.6.1 | Programme drafts Settlement and Regression Pathway 2 PP Exit Reports |  | 13d | 2025-07-07 A | 2025-07-23 A | 1567SS | 100% | 2025-06-30 | 2025-08-08 | 0d |  |  | start no earlier than 2025-07-07 | SI Test |  | SIT |  | 6.28 | Dom Mooney |  | SITAG | Complete | COMPLETE |  |  |  |
| 1585 | 1.4.2.3.1.4.6.2 | SRO Review Settlement and Regression Pathway 2 PP Exit Reports |  | 5d | 2025-07-17 A | 2025-07-23 A | 1584SS | 100% | 2025-07-17 | 2025-07-23 | 0d |  |  | finish no earlier than 2025-07-23 | SRO |  | SIT |  | 6.28 | Dom Mooney |  | SITAG | Complete | COMPLETE |  |  |  |
| 1586 | 1.4.2.3.1.4.6.3 | Pathway 2 PPs review and sign off Regression Exit Declaration |  | 6d | 2025-07-21 A | 2025-07-28 A | 1584SS | 100% | 2025-07-07 | 2025-08-08 | 0d |  |  | start no earlier than 2025-07-21 | PP |  | SIT |  | 6.28 | Dom Mooney |  | SITAG | Complete | COMPLETE |  |  |  |
| 1587 | 1.4.2.3.1.4.6.4 | Programme drafts Settlement and Regression Pathway 3 PP Exit Reports |  | 13d | 2025-07-28 A | 2025-08-13 A | 1568SS | 100% | 2025-07-28 | 2025-08-13 | 0d |  |  | start no earlier than 2025-07-28 | SI Test |  | SIT |  | 6.28 | Dom Mooney |  | SITAG | Complete | COMPLETE |  |  |  |
| 1588 | 1.4.2.3.1.4.6.5 | SRO Review Settlement and Regression Pathway 3 PP Exit Reports |  | 5d | 2025-08-07 A | 2025-08-13 A | 1587SS | 100% | 2025-08-07 | 2025-08-13 | 0d |  |  | finish no earlier than 2025-08-13 | SRO |  | SIT |  | 6.28 | Dom Mooney |  | SITAG | Complete | COMPLETE |  |  |  |
| 1589 | 1.4.2.3.1.4.6.6 | Pathway 3 PPs review and sign off Exit Reports |  | 5d | 2025-08-11 A | 2025-08-15 A | 1587SS | 100% | 2025-08-11 | 2025-08-15 | 0d |  |  | start no earlier than 2025-08-11 | PP |  | SIT |  | 6.28 | Dom Mooney |  | SITAG | Complete | COMPLETE |  |  |  |
| 1590 | 1.4.2.3.1.4.6.7 | Programme drafts Settlement and Regression Pathway 4, 5 & 6 PP Exit Reports |  | 25d | 2025-08-18 A | 2025-09-19 A | 1572SS | 100% | 2025-08-18 | 2025-09-19 | 0d |  |  | start no earlier than 2025-08-18 | SI Test |  | SIT |  | 6.28 | Dom Mooney |  | SITAG | Complete | COMPLETE |  |  |  |
| 1591 | 1.4.2.3.1.4.6.8 | Programme drafts SI SIT Settlement and Regression Addendum |  | 15d | 2025-07-21 A | 2025-08-08 A |  | 100% | 2025-07-07 | 2025-08-08 | 0d |  |  | start no earlier than 2025-07-21 | SI Test |  | SIT |  | 6.28 | Dom Mooney |  | SITAG | Complete | COMPLETE |  |  |  |
| 1592 | 1.4.2.3.1.4.6.9 | SRO/Code Bodies Review SI SIT Settlement and Regression Addendum |  | 5d | 2025-08-04 A | 2025-08-08 A | 1591SS | 100% | 2025-08-04 | 2025-08-08 | 0d |  |  | start no earlier than 2025-08-04 | SRO, Code Bodies |  | SIT |  | 6.28 | Dom Mooney |  | SITAG | Complete | COMPLETE |  |  |  |
| 1593 | 1.4.2.3.1.4.6.10 | SI SIT Migration Testing Test Exit Report Approved | milestone | 0d | 2025-08-15 A | 2025-08-15 A |  | 100% | 2025-08-20 | 2025-08-20 | 45d |  |  | start no earlier than 2025-08-15 | SI Test |  | SIT |  | 6.28 | Dom Mooney |  | SITAG | Complete | COMPLETE | T2-TE-0800 | T2 |  |
| 1594 | 1.4.2.3.1.4.6.11 | SI SIT Functional Testing Test Exit Report Approved | milestone | 0d | 2025-08-15 A | 2025-08-15 A | 1591, 1568 | 100% | 2025-08-20 | 2025-08-20 | 0d | 2025-01-17 | 2025-01-17 | finish no earlier than 2025-08-15 | SI Test | PP | SIT |  | 6.28 | Dom Mooney | Systems Integration Testing (SIT) | SITAG | Complete | COMPLETE | T2-TE-0850 | T2 | MHHS-ART072 |
| 1595 | 1.4.2.3.1.4.6.12 | eSITAG Approves SI SIT Functional & Migration (Post-Regression) Overarching Test Exit Report | milestone | 0d | 2025-08-15 A | 2025-08-15 A | 1591, 1568, 1582 | 100% | 2025-08-20 | 2025-08-20 | 0d |  |  | start no earlier than 2025-08-15 | SI Test |  | SIT |  | 6.28 | Dom Mooney |  | SITAG | Complete | COMPLETE |  |  |  |

| ID | WBS | Task | Type | Duration | Start | Finish | Predecessors | Complete | Actual start | Actual finish | Baseline start | Baseline finish | Baseline duration | Baseline 1 start | Baseline 1 finish | Constraint | Baseline cost | Responsible | Involved | Text9 | Update Version | MHHS Resource Name | MHHS Programme Phase | Text29 | Sched Status | RAG | Task Status | Milestone ID | Tier |
| --- | --- | --- | --- | --- | --- | --- | --- | --- | --- | --- | --- | --- | --- | --- | --- | --- | --- | --- | --- | --- | --- | --- | --- | --- | --- | --- | --- | --- | --- |
| 1596 | 1.4.2.3.2 | **SIT Migration Testing** |  | 295d? | 2024-03-11 A | 2025-04-25 A |  | 100% |  |  | 2024-03-11 | 2025-08-22 | 155d | 2024-06-10 | 2024-10-18 |  | -0 | SI Test | N/A | SIT | 6.0 | Ankur Pande | Systems Integration Testing (SIT) | SITAG |  |  |  |  |  |
| 1597 | 1.4.2.3.2.1 | SIT Migration Testing Start | milestone | 0d? | 2024-03-11 A | 2024-03-11 A |  | 100% |  |  | 2024-03-11 | 2024-03-11 | 0d |  |  | start no earlier than 2024-03-11 |  | SI Test |  | SIT | 6.0 | Ankur Pande |  |  | Complete | COMPLETE |  |  |  |
| 1598 | 1.4.2.3.2.2 | **SIT Migration Testing Execution** |  | 295d? | 2024-03-11 A | 2025-04-25 A |  | 100% |  |  | 2024-03-11 | 2025-08-22 | 0d |  |  |  |  | SI Test |  | SIT | 6.0 | Ankur Pande |  | SITAG |  |  | -685.67 |  |  |
| 1599 | 1.4.2.3.2.2.1 | **Cycle 1 (Full Cycle)** |  | 70d? | 2024-03-11 A | 2024-06-14 A |  | 100% |  |  | 2024-03-11 | 2024-06-14 | 0d |  |  |  |  | SI Test |  | SIT | 6.0 | Ankur Pande |  |  |  |  | -685.67 |  |  |
| 1600 | 1.4.2.3.2.2.1.1 | Test Execution |  | 55d? | 2024-03-11 A | 2024-05-24 A |  | 100% |  |  | 2024-03-11 | 2024-05-24 | 0d |  |  | start no earlier than 2024-03-11 |  | SI Test |  | SIT | 6.0 | Ankur Pande |  |  | Complete | COMPLETE |  |  |  |
| 1601 | 1.4.2.3.2.2.1.2 | Defect resolution, assurance, review, data& environments maintenance |  | 15d? | 2024-05-27 A | 2024-06-14 A |  | 100% |  |  | 2024-05-27 | 2024-06-14 | 0d |  |  | finish no earlier than 2024-06-14 |  | SI Test |  | SIT | 6.0 | Ankur Pande |  |  | Complete | COMPLETE |  |  |  |
| 1602 | 1.4.2.3.2.2.2 | **Cycle 2 (Defect retests and targeted regression testing)** |  | 80d? | 2024-03-11 | 2024-06-28 |  | 100% | 2024-06-17 | 2024-10-04 | 2024-03-11 | 2024-06-28 | 0d |  |  |  |  | SI Test |  | SIT | 6.0 | Ankur Pande |  |  |  |  | -685.67 |  |  |
| 1603 | 1.4.2.3.2.2.2.1 | Test Execution |  | 70d? | 2024-06-17 A | 2024-09-20 A | 1601 | 100% |  |  | 2024-06-17 | 2024-09-20 | 0d |  |  | start no earlier than 2024-06-17 |  | SI Test |  | SIT | 6.0 | Ankur Pande |  |  | Complete | COMPLETE |  |  |  |
| 1604 | 1.4.2.3.2.2.2.2 | Defect resolution, assurance, review, data & environments maintenance |  | 10d? | 2024-09-23 A | 2024-10-04 A | 1603 | 100% |  |  | 2024-09-23 | 2024-10-04 | 0d |  |  | finish no earlier than 2024-10-04 |  | SI Test |  | SIT | 6.0 | Ankur Pande |  |  | Complete | COMPLETE |  |  |  |
| 1605 | 1.4.2.3.2.2.3 | **SIT Migration Testing back-up progress risk-assessment** |  | 70d? | 2024-06-17 | 2024-09-20 |  | 100% | 2024-10-07 | 2024-11-01 | 2024-06-17 | 2024-09-20 | 0d |  |  |  |  | SI Test |  | SIT | 6.0 | Ankur Pande |  |  |  |  | -685.67 |  |  |
| 1606 | 1.4.2.3.2.2.3.1 | Back-up risk-assessment of SIT Migration progress to assess whether Qualification Execution can start early |  | 15d? | 2024-10-07 A | 2024-10-25 A | 1604 | 100% |  |  | 2024-10-07 | 2024-10-25 | 0d |  |  | finish no earlier than 2024-10-04 |  | SI Test |  | SIT | 6.0 | Ankur Pande |  |  | Complete | COMPLETE |  |  |  |
| 1607 | 1.4.2.3.2.2.3.2 | Back-up SITAG decision on early Qualification Testing Execution start | milestone | 0d? | 2024-11-01 A | 2024-11-01 A | 1606FS+5d | 100% |  |  | 2024-11-01 | 2024-11-01 | 0d |  |  |  |  | SI Test |  | SIT | 6.0 | Ankur Pande |  |  | Complete | COMPLETE |  |  |  |
| 1608 | 1.4.2.3.2.2.4 | **Cycle 3 (Defect retests and targeted regression testing)** |  | 135d? | 2024-10-21 A | 2025-04-25 A |  | 100% |  |  | 2024-10-21 | 2025-04-25 | 0d |  |  |  |  | SI Test |  | SIT | 6.0 | Dom Mooney |  | SITAG |  |  | -685.67 |  |  |
| 1609 | 1.4.2.3.2.2.4.1 | Sprint 5 |  | 10d | 2024-10-21 A | 2024-11-01 A | 140FS-1d | 100% |  |  | 2024-10-21 | 2024-11-01 | 0d |  |  | start no earlier than 2024-10-21 |  | SI Test |  | SIT | 6.0 | Dom Mooney |  |  | Complete | COMPLETE |  |  |  |
| 1610 | 1.4.2.3.2.2.4.2 | Sprint 6 |  | 10d | 2024-11-04 A | 2024-11-15 A | 1609 | 100% |  |  | 2024-11-04 | 2024-11-15 | 0d |  |  | start no earlier than 2024-11-04 |  | SI Test |  | SIT | 6.0 | Dom Mooney |  |  | Complete | COMPLETE |  |  |  |
| 1611 | 1.4.2.3.2.2.4.3 | Sprint 7 |  | 10d | 2024-11-18 A | 2024-11-29 A | 1610 | 100% |  |  | 2024-11-18 | 2024-11-29 | 0d |  |  |  |  | SI Test |  | SIT | 6.0 | Dom Mooney |  |  | Complete | COMPLETE |  |  |  |
| 1612 | 1.4.2.3.2.2.4.4 | Sprint 8 |  | 15d | 2024-12-02 A | 2024-12-20 A | 1611 | 100% |  |  | 2024-12-02 | 2024-12-20 | 0d |  |  | finish no earlier than 2024-11-15 |  | SI Test |  | SIT | 6.0 | Dom Mooney |  |  | Complete | COMPLETE |  |  |  |
| 1613 | 1.4.2.3.2.2.4.5 | Christmas downtime |  | 10d | 2024-12-23 A | 2025-01-03 A | 1612 | 100% |  |  | 2024-12-23 | 2025-01-03 | 0d |  |  | finish no earlier than 2024-11-29 |  | SI Test |  | SIT | 6.0 | Dom Mooney |  |  | Complete | COMPLETE |  |  |  |
| 1614 | 1.4.2.3.2.2.4.6 | Sprint 9 |  | 10d | 2025-01-06 A | 2025-01-17 A | 1613 | 100% |  |  | 2025-01-06 | 2025-01-17 | 0d |  |  | finish no earlier than 2024-12-20 |  | SI Test |  | SIT | 6.0 | Dom Mooney |  |  | Complete | COMPLETE |  |  |  |
| 1615 | 1.4.2.3.2.2.4.7 | Sprint 10 |  | 10d | 2025-01-20 A | 2025-01-31 A | 1614 | 100% |  |  | 2025-01-20 | 2025-01-31 | 0d |  |  | finish no earlier than 2025-01-03 |  | SI Test |  | SIT | 6.0 | Dom Mooney |  |  | Complete | COMPLETE |  |  |  |
| 1616 | 1.4.2.3.2.2.4.8 | Sprint 11 |  | 10d | 2025-02-03 A | 2025-02-14 A | 1615 | 100% |  |  | 2025-02-03 | 2025-02-14 | 0d |  |  | finish no earlier than 2025-01-17 |  | SI Test |  | SIT | 6.0 | Dom Mooney |  |  | Complete | COMPLETE |  |  |  |
| 1617 | 1.4.2.3.2.2.4.9 | Sprint 12 |  | 10d | 2025-02-17 A | 2025-02-28 A | 1616 | 100% |  |  | 2025-02-17 | 2025-02-28 | 0d |  |  | finish no earlier than 2025-01-31 |  | SI Test |  | SIT | 6.0 | Dom Mooney |  |  | Complete | COMPLETE |  |  |  |
| 1618 | 1.4.2.3.2.2.4.10 | Sprint 13 |  | 10d | 2025-03-03 A | 2025-03-14 A | 1617 | 100% |  |  | 2025-03-03 | 2025-03-14 | 0d |  |  |  |  | SI Test |  | SIT | 6.1 | Dom Mooney |  |  | Complete | COMPLETE |  |  |  |
| 1619 | 1.4.2.3.2.2.4.11 | Sprint 14 (RTTM Gap Analysis + CR056) |  | 10d? | 2025-03-17 A | 2025-03-28 A | 1618 | 100% |  |  | 2025-03-17 | 2025-03-28 | 0d |  |  |  |  | SI Test |  | SIT | 6.1 | Dom Mooney |  |  | Complete | COMPLETE |  |  |  |
| 1620 | 1.4.2.3.2.2.4.12 | Sprint 15 (Contingency 1) |  | 10d? | 2025-03-31 A | 2025-04-11 A | 1619 | 100% |  |  | 2025-03-31 | 2025-04-11 | 0d |  |  |  |  | SI Test |  | SIT | 6.1 | Dom Mooney |  | SITAG | Complete | COMPLETE |  |  |  |
| 1621 | 1.4.2.3.2.2.4.13 | Sprint 16 (Contingency 2) |  | 10d? | 2025-04-14 A | 2025-04-25 A | 1620 | 100% |  |  | 2025-04-14 | 2025-04-25 | 0d |  |  |  |  | SI Test |  | SIT | 6.1 | Dom Mooney |  | SITAG | Complete | COMPLETE |  |  |  |
| 1622 | 1.4.2.3.2.2.4.14 | SIT Migration Cycle 3 Complete | milestone | 0d | 2025-04-25 A | 2025-04-25 A | 1621 | 100% |  |  | 2025-04-25 | 2025-04-25 | 0d |  |  |  |  | SI Test |  | SIT | 6.1 | Dom Mooney |  | SITAG | Complete | COMPLETE |  | T2-TE-1200 | T2 |

| ID | WBS | Task | Type | Duration | Start | Finish | Predecessors | Complete | Baseline start | Baseline finish | Baseline duration | Baseline 1 start | Baseline 1 finish | Constraint | Responsible | Involved | Text9 | Update Version | MHHS Resource Name | MHHS Programme Phase | Text29 | Sched Status | RAG | Milestone ID | Tier | Artefact ID | Guidance | Future RAG | Task Status |
| --- | --- | --- | --- | --- | --- | --- | --- | --- | --- | --- | --- | --- | --- | --- | --- | --- | --- | --- | --- | --- | --- | --- | --- | --- | --- | --- | --- | --- | --- |
| 1623 | 1.4.2.3.3 | **SIT Non-Functional Testing (all SIT PPs)** |  | 112d? | 2025-03-03 A | 2025-08-06 A |  | 100% | 2025-02-28 | 2025-07-10 | 100d | 2024-09-02 | 2025-01-17 |  | N/A | N/A | SIT | 6.1 | N/A | Systems Integration Testing (SIT) | SITAG |  |  |  |  |  |  |  |  |
| 1624 | 1.4.2.3.3.1 | Theme 1 (Helix and DIP Volume Testing) Start | milestone | 0d? | 2025-03-03 A | 2025-03-03 A | 1144FS+1d, 1388 | 100% | 2025-03-03 | 2025-03-03 | 0d |  |  | finish no earlier than 2025-01-13 | SIT Participant |  | SIT | 6.15 | Roger Robar |  | SITAG | Complete | COMPLETE | T3-TE-0124 | T3 |  |  |  |  |
| 1625 | 1.4.2.3.3.2 | Theme 1 (Helix and DIP Volume Testing) Execution |  | 15d? | 2025-03-03 A | 2025-03-21 A | 1624FS-1d | 100% | 2025-03-03 | 2025-03-21 | 0d |  |  | start no earlier than 2025-01-13 | SI Test |  | SIT | 6.15 | Roger Robar |  |  | Complete | COMPLETE |  |  |  |  |  |  |
| 1626 | 1.4.2.3.3.3 | Theme 2 & 3 SIT Non-Functional Testing Start | milestone | 0d | 2025-03-31 A | 2025-03-31 A | 1507, 1068, 1072, 1079, 1085, 1091, 1557, 1153FS+2d, 1390, 1134 | 100% | 2025-03-31 | 2025-03-31 | 0d | 2024-09-02 | 2024-09-02 |  | SI Test | PP | SIT | 6.21 | Roger Robar | Systems Integration Testing (SIT) | SITAG | Complete | COMPLETE | T3-TE-0040 | T3 | MHHS-ART079 | 12/8/24: needs to be 7/10/24 |  |  |
| 1627 | 1.4.2.3.3.4 | Theme 2 & 3 SIT Non-Functional Testing Execution |  | 40d | 2025-03-31 A | 2025-05-23 A | 1626SS-1d | 100% | 2025-03-31 | 2025-05-23 | 90d | 2024-09-02 | 2025-01-03 |  | SI Test | PP | SIT | 6.21 | Roger Robar | Systems Integration Testing (SIT) |  | Complete | COMPLETE |  |  |  |  | D24D - NF Test Completion Report |  |
| 1628 | 1.4.2.3.3.5 | SIT Non-Functional Testing Execution End (all SIT PPs) | milestone | 0d | 2025-05-23 A | 2025-05-23 A | 1627FF | 100% | 2025-05-23 | 2025-05-23 | 0d | 2025-01-03 | 2025-01-03 | start no earlier than 2025-05-23 | SI Test | PP | SIT | 6.26 | Roger Robar | Systems Integration Testing (SIT) | SITAG | Complete | COMPLETE | T3-TE-0047 | T3 | MHHS-ART079 |  |  |  |
| 1629 | 1.4.2.3.3.6 | **SIT Non-Functional Testing Test Exit Report (all SIT PPs)** |  | 52d | 2025-05-26 A | 2025-08-06 A |  | 100% | 2025-05-02 | 2025-05-29 | 20d | 2024-12-16 | 2025-01-10 |  | N/A | N/A | SIT | 6.15 | N/A | Systems Integration Testing (SIT) |  |  |  |  |  |  |  |  |  |
| 1630 | 1.4.2.3.3.6.1 | Programme drafts Non-Functional PP Exit Report |  | 25d | 2025-05-26 A | 2025-06-27 A | 1628 | 100% | 2025-05-26 | 2025-06-27 | 0d |  |  |  | SI Test |  | SIT | 6.25 | Roger Robar |  | SITAG | Complete | COMPLETE |  |  |  |  |  |  |
| 1631 | 1.4.2.3.3.6.2 | Non-Functional PP Exit Reports shared with PPs | milestone | 0d | 2025-06-27 A | 2025-06-27 A | 1630 | 100% | 2025-06-27 | 2025-06-27 | 0d |  |  | start no earlier than 2025-06-09 | SI Test |  | SIT | 6.25 | Roger Robar |  | SITAG | Complete | COMPLETE |  |  |  |  |  |  |
| 1632 | 1.4.2.3.3.6.3 | PPs review Exit Report and Sign PP Exit Declaration |  | 11d | 2025-06-27 A | 2025-07-11 A | 1630SS | 100% | 2025-06-27 | 2025-07-11 | 0d |  |  | start no earlier than 2025-06-27 | PP |  | SIT | 6.28 | Roger Robar |  | SITAG | Complete | COMPLETE |  |  |  |  |  |  |
| 1633 | 1.4.2.3.3.6.4 | Programme drafts SI SIT Non-Functional Overarching Exit Report |  | 16d | 2025-06-27 A | 2025-07-18 A | 1624, 1625, 1626, 1627, 1628 | 100% | 2025-06-27 | 2025-07-18 | 0d |  |  | start no earlier than 2025-06-16 | SI Test |  | SIT | 6.25 | Roger Robar |  | SITAG | Complete | COMPLETE |  |  |  |  |  |  |
| 1634 | 1.4.2.3.3.6.5 | Draft of SI SIT Non-Functional Overarching Exit Report available for SRO review |  | 5d | 2025-07-07 A | 2025-07-11 A | 1633SS | 100% | 2025-07-07 | 2025-07-11 | 0d |  |  | start no earlier than 2025-07-07 | SI Test |  | SIT | 6.25 | Roger Robar |  | SITAG | Complete | COMPLETE |  |  |  |  |  |  |
| 1635 | 1.4.2.3.3.6.6 | SRO / Code Bodies / DIP Manager formal review SI SIT Non-Functional Overarching Exit Report |  | 5d | 2025-07-14 A | 2025-07-18 A | 1634 | 100% | 2025-07-14 | 2025-07-18 | 0d |  |  |  | SRO, Code Bodies, DIP Manager |  | SIT | 6.28 | Roger Robar |  | SITAG | Complete | COMPLETE |  |  |  |  |  |  |
| 1636 | 1.4.2.3.3.6.7 | eSITWG Review status of SI SIT Non-Functional Overarching Exit Report | milestone | 0d | 2025-07-18 A | 2025-07-18 A | 1633 | 100% | 2025-07-18 | 2025-07-18 | 0d |  |  | start no earlier than 2025-07-03 | SI Test |  | SIT | 6.25 | Roger Robar |  | SITAG | Complete | COMPLETE |  |  |  |  |  |  |
| 1637 | 1.4.2.3.3.6.8 | SI SIT Non-Functional Overarching Exit Report published to PPs for industry review | milestone | 0d | 2025-07-18 A | 2025-07-18 A | 1636 | 100% | 2025-07-18 | 2025-07-18 | 0d |  |  |  | SI Test |  | SIT | 6.28 | Roger Robar |  | SITAG | Complete | COMPLETE |  |  |  |  |  |  |
| 1638 | 1.4.2.3.3.6.9 | SI SIT Non-Functional Overarching Exit Report industry review |  | 10d | 2025-07-21 A | 2025-08-01 A | 1637 | 100% | 2025-07-21 | 2025-08-01 | 0d |  |  |  | SI Test |  | SIT | 6.28 | Roger Robar |  | SITAG | Complete | COMPLETE |  |  |  |  |  |  |
| 1639 | 1.4.2.3.3.6.10 | SIT Non-Functional Testing Test Exit Report (all SIT PPs) Approved | milestone | 0d | 2025-08-06 A | 2025-08-06 A | 1633FS+3d, 1638 | 100% | 2025-08-06 | 2025-08-06 | 0d | 2025-01-17 | 2025-01-17 | start no earlier than 2025-08-06 | SI Test | PP | SIT | 6.25 | Roger Robar | Systems Integration Testing (SIT) | SITAG | Complete | COMPLETE | T2-TE-0900 | T2 | MHHS-ART079 |  |  |  |
| 1640 | 1.4.2.3.3.6.11 | eSITAG Approves SI SIT Non-Functional Overarching Test Exit Report | milestone | 0d | 2025-08-06 A | 2025-08-06 A | 1633FS+3d, 1639 | 100% | 2025-08-06 | 2025-08-06 | 0d |  |  | start no earlier than 2025-07-16 | SI Test |  | SIT | 6.25 | Roger Robar |  | SITAG | Complete | COMPLETE |  |  |  |  |  |  |
| 1641 | 1.4.2.3.4 | **SIT Operational Testing (all SIT PPs)** |  | 150d? | 2025-02-03 A | 2025-08-29 A |  | 100% | 2025-02-03 | 2025-06-06 | 90d | 2024-10-07 | 2025-02-07 |  | N/A | N/A | SIT | 5.0 | N/A | Systems Integration Testing (SIT) | SITAG |  |  |  |  |  |  |  |  |
| 1642 | 1.4.2.3.4.1 | **Non-SIT B Testing** |  | 25d? | 2025-02-03 A | 2025-03-07 A |  | 100% | 2025-02-03 | 2025-03-07 | 0d |  |  |  |  |  | SIT |  |  |  | SITAG |  |  |  |  |  |  |  | -686.67 |
| 1643 | 1.4.2.3.4.1.1 | SIT Operational Testing Start (Theme 3 - Batch 1 (Service Management)) | milestone | 0d? | 2025-02-03 A | 2025-02-03 A | 1305, 1245, 1246 | 100% | 2025-02-03 | 2025-02-03 | 0d |  |  | start no earlier than 2025-02-03 | SI Test |  | SIT | 6.0 | Roger Robar |  | SITAG | Complete | COMPLETE | T3-TE-0121 | T3 |  |  |  |  |
| 1644 | 1.4.2.3.4.1.2 | SIT Operational Testing Execution Window (Theme 3 - Batch 1 (Service Management)) |  | 25d? | 2025-02-03 A | 2025-03-07 A | 1643 | 100% | 2025-02-03 | 2025-03-07 | 0d |  |  | start no earlier than 2025-01-06 | SI Test |  | SIT | 6.0 | Roger Robar |  | SITAG | Complete | COMPLETE |  |  |  |  |  |  |
| 1645 | 1.4.2.3.4.2 | **SIT B Testing** |  | 70d | 2025-03-31 A | 2025-07-04 A |  | 100% | 2025-02-07 | 2025-05-16 | 0d |  |  |  | SI Test |  | SIT | 6.15 | Roger Robar |  | SITAG |  |  |  |  |  |  |  | -686.67 |
| 1646 | 1.4.2.3.4.2.1 | SIT Operational Testing Start (SIT B) | milestone | 0d | 2025-03-31 A | 2025-03-31 A | 1385, 1162, 1166, 1173, 1179, 1305, 1383FS+1d, 1391, 1392 | 100% | 2025-03-31 | 2025-03-31 | 0d | 2024-10-07 | 2024-10-07 |  | SI Test | PP | SIT | 6.15 | Roger Robar | Systems Integration Testing (SIT) | SITAG | Complete | COMPLETE | T3-TE-0042 | T3 | MHHS-ART073 MHHS-ART143 |  |  |  |
| 1647 | 1.4.2.3.4.2.2 | SIT Operational Testing Execution Theme 1 |  | 70d | 2025-03-31 A | 2025-07-04 A | 1646FS-1d | 100% | 2025-03-31 | 2025-07-04 | 0d |  |  | finish no earlier than 2025-07-04 | SI Test |  | SIT | 6.22 | Roger Robar |  | SITAG | Complete | COMPLETE |  |  |  |  |  |  |
| 1648 | 1.4.2.3.4.2.3 | SIT Operational Testing Execution Theme 2 |  | 45d | 2025-05-05 A | 2025-07-04 A | 1646 | 100% | 2025-05-05 | 2025-07-04 | 0d |  |  | finish no earlier than 2025-07-04 | SI Test |  | SIT | 6.22 | Roger Robar |  | SITAG | Complete | COMPLETE |  |  |  |  |  |  |
| 1649 | 1.4.2.3.4.2.4 | SIT Operational Testing Execution Theme 3 Batch 2 |  | 20d | 2025-06-09 A | 2025-07-04 A | 1646 | 100% | 2025-06-09 | 2025-07-04 | 0d |  |  | start no earlier than 2025-06-09 | SI Test |  | SIT | 6.22 | Roger Robar |  | SITAG | Complete | COMPLETE |  |  |  |  |  |  |

| ID | WBS | Task | Type | Duration | Start | Finish | Predecessors | Complete | Baseline start | Baseline finish | Baseline duration | Baseline 1 start | Baseline 1 finish | Constraint | Baseline cost | Responsible | Text9 | Task Status | Update Version | MHHS Resource Name | Text29 | Sched Status | RAG | Involved | Artefact ID | MHHS Programme Phase | Milestone ID | Tier |
| --- | --- | --- | --- | --- | --- | --- | --- | --- | --- | --- | --- | --- | --- | --- | --- | --- | --- | --- | --- | --- | --- | --- | --- | --- | --- | --- | --- | --- |
| 1650 | 1.4.2.3.4.2.5 | **SIT Operational Testing Re-test Theme 3 (Batch 1)** |  | 30d | 2025-05-05 A | 2025-06-13 A |  | 100% | 2025-06-09 | 2025-06-13 | 0d |  |  |  |  | SI Test | SIT | 28.33 | 6.25 | Roger Robar | SITAG |  |  |  |  |  |  |  |
| 1651 | 1.4.2.3.4.2.5.1 | SRO Review of re-testing approach |  | 10d | 2025-05-05 A | 2025-05-16 A |  | 100% | 2025-05-05 | 2025-05-16 | 0d |  |  | start no earlier than 2025-05-05 |  | SI Test | SIT |  | 6.25 | Roger Robar | SITAG | Complete | COMPLETE |  |  |  |  |  |
| 1652 | 1.4.2.3.4.2.5.2 | Scripts uploaded to ADO / Project Created |  | 5d | 2025-05-19 A | 2025-05-23 A | 1651 | 100% | 2025-05-19 | 2025-05-23 | 0d |  |  |  |  | SI Test | SIT |  | 6.25 | Roger Robar | SITAG | Complete | COMPLETE |  |  |  |  |  |
| 1653 | 1.4.2.3.4.2.5.3 | SIT Operational Testing Re-test Execution Theme 3 (Batch 1) |  | 5d | 2025-06-09 A | 2025-06-13 A | 1652 | 100% | 2025-06-09 | 2025-06-13 | 0d |  |  | start no earlier than 2025-06-09 |  | SI Test | SIT |  | 6.25 | Roger Robar | SITAG | Complete | COMPLETE |  |  |  |  |  |
| 1654 | 1.4.2.3.4.3 | SIT Operational Testing End (all SIT PPs) (incl. confirmation that PPs have submitted their Test Completion Reports to Programme for assurance) | milestone | 0d | 2025-07-04 A | 2025-07-04 A | 1644, 1647, 1648, 1649, 1653 | 100% | 2025-07-11 | 2025-07-11 | 0d | 2025-01-24 | 2025-01-24 |  |  | SI Test | SIT |  | 6.25 | Roger Robar | SITAG | Complete | COMPLETE | PP | MHHS-ART081 | Systems Integration Testing (SIT) | T3-TE-0050 | T3 |
| 1655 | 1.4.2.3.4.4 | **SIT Operational Testing Test Exit Report (all SIT PPs)** |  | 50d | 2025-06-23 A | 2025-08-29 A |  | 100% | 2025-06-23 | 2025-07-18 | 20d | 2025-01-06 | 2025-01-31 |  |  | N/A | SIT |  | 6.15 | N/A | SITAG |  |  | N/A |  | Systems Integration Testing (SIT) |  |  |
| 1656 | 1.4.2.3.4.4.1 | Programme drafts Pathway 2 PP Exit Report (when Participant completes Operational testing) |  | 15d | 2025-06-30 A | 2025-07-18 A | 1647SS, 1648SS | 100% | 2025-06-30 | 2025-07-18 | 0d |  |  | start no earlier than 2025-06-30 |  | SI Test | SIT |  | 6.28 | Roger Robar | SITAG | Complete | COMPLETE |  |  |  |  |  |
| 1657 | 1.4.2.3.4.4.2 | All Pathway 2 Operational Exit Reports and Exit Declarations shared with PPs | milestone | 0d | 2025-07-21 A | 2025-07-21 A | 1656FS+1d | 100% | 2025-07-21 | 2025-07-21 | 0d |  |  |  |  | SI Test | SIT |  | 6.28 | Roger Robar | SITAG | Complete | COMPLETE |  |  |  |  |  |
| 1658 | 1.4.2.3.4.4.3 | Pathway 2 PPs have reviewed Exit Report and signed Exit Declaration |  | 5d | 2025-07-21 A | 2025-07-25 A | 1656 | 100% | 2025-07-21 | 2025-07-25 | 0d |  |  | start no earlier than 2025-06-13 |  | PP | SIT |  | 6.25 | Roger Robar | SITAG | Complete | COMPLETE |  |  |  |  |  |
| 1659 | 1.4.2.3.4.4.4 | Programme drafts Pathway 3 PP Exit Report (when Participant completes Operational testing) |  | 15d | 2025-07-21 A | 2025-08-08 A | 1656 | 100% | 2025-07-21 | 2025-08-08 | 0d |  |  | start no earlier than 2025-07-21 |  | SI Test | SIT |  | 6.28 | Roger Robar | SITAG | Complete | COMPLETE |  |  |  |  |  |
| 1660 | 1.4.2.3.4.4.5 | All Pathway 3 Operational Exit Reports and Exit Declarations shared with PPs | milestone | 0d | 2025-08-08 A | 2025-08-08 A | 1656, 1659 | 100% | 2025-08-08 | 2025-08-08 | 0d |  |  |  |  | SI Test | SIT |  | 6.28 | Roger Robar | SITAG | Complete | COMPLETE |  |  |  |  |  |
| 1661 | 1.4.2.3.4.4.6 | Pathway 3 PPs have reviewed Exit Report and signed Exit Declaration |  | 5d | 2025-08-11 A | 2025-08-15 A | 1660 | 100% | 2025-08-11 | 2025-08-15 | 0d |  |  |  |  | PP | SIT |  | 6.28 | Roger Robar | SITAG | Complete | COMPLETE |  |  |  |  |  |
| 1662 | 1.4.2.3.4.4.7 | Programme drafts Pathway 4 PP Exit Report (when Participant completes Operational testing) |  | 10d | 2025-08-04 A | 2025-08-15 A | 1667 | 100% |  |  |  |  |  |  |  | SI Test | SIT |  | 6.29 | Roger Robar | SITAG | Complete | COMPLETE |  |  |  |  |  |
| 1663 | 1.4.2.3.4.4.8 | All Pathway 4 Operational Exit Reports and Exit Declarations shared with PPs | milestone | 0d | 2025-08-15 A | 2025-08-15 A | 1662 | 100% |  |  |  |  |  |  |  | SI Test | SIT |  | 6.29 | Roger Robar | SITAG | Complete | COMPLETE |  |  |  |  |  |
| 1664 | 1.4.2.3.4.4.9 | Pathway 4 PPs have reviewed Exit Report and signed Exit Declaration |  | 5d | 2025-08-18 A | 2025-08-22 A | 1663 | 100% |  |  |  |  |  |  |  | PP | SIT |  | 6.29 | Roger Robar | SITAG | Complete | COMPLETE |  |  |  |  |  |
| 1665 | 1.4.2.3.4.4.10 | Programme drafts Pathway 5 & 6 PP Exit Report (when Participant completes Operational testing) |  | 15d | 2025-08-11 A | 2025-08-29 A | 1659 | 100% | 2025-08-11 | 2025-08-29 | 0d |  |  |  |  | SI Test | SIT |  | 6.28 | Roger Robar | SITAG | Complete | COMPLETE |  |  |  |  |  |
| 1666 | 1.4.2.3.4.4.11 | Programme drafts SI SIT Operational Overarching Exit Report |  | 30d | 2025-06-23 A | 2025-08-01 A |  | 100% | 2025-06-23 | 2025-08-01 | 0d |  |  | start no earlier than 2025-06-23 |  | SI Test | SIT |  | 6.28 | Roger Robar | SITAG | Complete | COMPLETE |  |  |  |  |  |
| 1667 | 1.4.2.3.4.4.12 | SRO/Code Bodies/DIP Manager Review SI SIT Operational Overarching Exit Report |  | 5d | 2025-07-28 A | 2025-08-01 A | 1666SS | 100% | 2025-07-28 | 2025-08-01 | 0d |  |  | finish no earlier than 2025-08-01 |  | SRO, Code Bodies, DIP Manager | SIT |  | 6.28 | Roger Robar | SITAG | Complete | COMPLETE |  |  |  |  |  |
| 1668 | 1.4.2.3.4.4.13 | eSITWG Review SI SIT Operational Overarching Exit Report | milestone | 0d | 2025-08-01 A | 2025-08-01 A |  | 100% | 2025-08-01 | 2025-08-01 | 0d |  |  | finish no earlier than 2025-08-01 |  | SI Test | SIT |  | 6.28 | Roger Robar | SITAG | Complete | COMPLETE |  |  |  |  |  |
| 1669 | 1.4.2.3.4.4.14 | SI SIT Operational Overarching Exit Report industry review |  | 6d | 2025-08-05 A | 2025-08-12 A | 1668 | 100% | 2025-08-04 | 2025-08-15 | 0d |  |  |  |  | PP |  |  | 6.28 | Roger Robar | SITAG | Complete | COMPLETE |  |  |  |  |  |
| 1670 | 1.4.2.3.4.4.15 | SIT Operational Testing Test Exit Report (all SIT PPs) Approved | milestone | 0d | 2025-08-15 A | 2025-08-15 A | 1666FS+3d | 100% | 2025-08-15 | 2025-08-15 | 0d | 2025-02-07 | 2025-02-07 | finish no earlier than 2025-08-15 |  | SI Test | SIT |  | 6.28 | Roger Robar | SITAG | Complete | COMPLETE | PP | MHHS-ART081 | Systems Integration Testing (SIT) | T2-TE-0950 | T2 |
| 1671 | 1.4.2.3.4.4.16 | eSITAG Approves SI SIT Operational Testing Test Exit Report | milestone | 0d | 2025-08-15 A | 2025-08-15 A | 1666FS+3d | 100% | 2025-08-15 | 2025-08-15 | 0d |  |  | finish no earlier than 2025-08-15 |  | SI Test | SIT |  | 6.28 | Roger Robar | SITAG | Complete | COMPLETE |  |  |  |  |  |
| 1672 | 1.4.2.3.5 | SIT Complete (SIT Test Exit Report Approved) | milestone | 0d | 2025-08-22 A | 2025-08-22 A | 1498, 1639, 1640, 1593, 1594 | 100% | 2025-08-22 | 2025-08-22 | 0d | 2025-02-07 | 2025-02-07 | finish no earlier than 2025-08-22 |  | CPT | SIT |  | 6.25 | Roger Robar | PSG | Complete | COMPLETE | PP,IPA | MHHS-ART081 | Systems Integration Testing (SIT) | T1-TE-2000 | T1 |
| 1673 | 1.4.3 | **UIT Environment Preparation** |  | 988d | 2022-11-16 A | 2026-08-28 A |  | 100% | 2022-10-31 | 2025-07-04 | 680d | 2022-10-31 | 2025-06-06 |  | -0 | N/A | SIT |  | 6.0 | N/A | SITAG |  |  | N/A |  | Systems Integration Testing (SIT) |  |  |
| 1674 | 1.4.3.1 | **Test Artefact Development** |  | 602d | 2023-03-01 A | 2025-06-19 A |  | 100% | 2023-03-01 | 2024-07-18 | 361d | 2023-03-01 | 2023-08-04 |  | -0 | N/A | SIT |  | 6.0 | N/A | QAG |  |  | N/A |  | Systems Integration Testing (SIT) |  |  |
| 1675 | 1.4.3.1.1 | **E2E Sandbox Guidance** |  | 602d | 2023-03-01 A | 2025-06-19 A |  | 100% | 2023-03-01 | 2024-07-18 | 361d | 2023-03-01 | 2023-08-04 |  | -0 | N/A | SIT |  | 6.0 | N/A | QAG |  |  | N/A |  | Systems Integration Testing (SIT) |  |  |
| 1676 | 1.4.3.1.1.1 | Develop document |  | 83d | 2023-03-01 A | 2023-06-23 A |  | 100% | 2023-03-01 | 2023-06-23 | 83d | 2023-03-01 | 2023-06-23 | start no earlier than 2023-03-01 |  | SI Test | SIT |  | 6.0 | Stuart Scott | QAG | Complete | COMPLETE |  |  | Systems Integration Testing (SIT) |  |  |
| 1677 | 1.4.3.1.1.2 | Artefact review (via SITAG) and updates |  | 25d | 2023-06-26 A | 2023-07-28 A | 1676 | 100% | 2023-06-26 | 2023-07-28 | 25d | 2023-06-26 | 2023-07-28 |  |  | SI Test | SIT |  | 6.0 | Stuart Scott | QAG | Complete | COMPLETE | PP,IPA |  | Systems Integration Testing (SIT) |  |  |
| 1678 | 1.4.3.1.1.3 | E2E Sandbox Guidance approved | milestone | 0d | 2024-07-18 A | 2024-07-18 A | 1677FF+5d | 100% | 2024-07-18 | 2024-07-18 | 0d | 2023-08-04 | 2023-08-04 | start no earlier than 2024-07-18 |  | SI Test | SIT |  | 6.0 | Stuart Scott | QAG | Complete | COMPLETE | PP | MHHS-ART154 | Systems Integration Testing (SIT) | T3-TE-0067 | T3 |
| 1679 | 1.4.3.1.1.4 | Update E2E Sandbox guidance to reflect CR055 |  | 45d | 2025-03-17 A | 2025-05-16 A |  | 100% | 2025-03-17 | 2025-05-16 | 0d |  |  | finish no earlier than 2025-05-16 |  | SI Test | SIT |  | 6.25 | Stuart Scott | QAG | Complete | COMPLETE |  |  |  |  |  |
| 1680 | 1.4.3.1.1.5 | Internal SI review |  | 5d | 2025-05-19 A | 2025-05-23 A | 1679 | 100% | 2025-05-19 | 2025-05-23 | 0d |  |  | start no earlier than 2025-03-17 |  | SI Test | SIT |  | 6.25 | Stuart Scott | QAG | Complete | COMPLETE |  |  |  |  |  |
| 1681 | 1.4.3.1.1.6 | SRO / Code Bodies review |  | 5d | 2025-05-19 A | 2025-05-23 A |  | 100% | 2025-05-19 | 2025-05-23 | 0d |  |  | finish no earlier than 2025-05-23 |  | SI Test | SIT |  | 6.25 | Stuart Scott | QAG | Complete | COMPLETE |  |  |  |  |  |
| 1682 | 1.4.3.1.1.7 | Submit version to QWG | milestone | 0d | 2025-06-03 A | 2025-06-03 A |  | 100% | 2025-06-03 | 2025-06-03 | 0d |  |  | finish no earlier than 2025-06-03 |  | SI Test | SIT |  | 6.25 | Stuart Scott | QAG | Complete | COMPLETE |  |  |  |  |  |
| 1683 | 1.4.3.1.1.8 | Artefact Recommendation for Approval (via QWG) | milestone | 0d | 2025-06-10 A | 2025-06-10 A | 1682 | 100% | 2025-06-10 | 2025-06-10 | 0d |  |  | finish no earlier than 2025-06-10 |  | SI Test | SIT |  | 6.25 | Stuart Scott | QAG | Complete | COMPLETE |  |  |  |  |  |
| 1684 | 1.4.3.1.1.9 | Final Document updates post QWG review | milestone | 0d | 2025-06-11 A | 2025-06-11 A | 1683 | 100% | 2025-06-11 | 2025-06-11 | 0d |  |  | finish no earlier than 2025-06-11 |  | SI Test | SIT |  | 6.25 | Stuart Scott | QAG | Complete | COMPLETE |  |  |  |  |  |
| 1685 | 1.4.3.1.1.10 | Submit final version to QAG | milestone | 0d | 2025-06-12 A | 2025-06-12 A |  | 100% | 2025-06-12 | 2025-06-12 | 0d |  |  | finish no earlier than 2025-06-12 |  | SI Test | SIT |  | 6.25 | Stuart Scott | QAG | Complete | COMPLETE |  |  |  |  |  |
| 1686 | 1.4.3.1.1.11 | E2E Sandbox guidance update approved at QAG | milestone | 0d | 2025-06-19 A | 2025-06-19 A | 1685FS+3d | 100% | 2025-06-19 | 2025-06-19 | 0d |  |  | finish no earlier than 2025-06-19 |  | SI Test | SIT |  | 6.25 | Stuart Scott | QAG | Complete | COMPLETE |  |  |  |  |  |

| ID | WBS | Task | Type | Duration | Start | Finish | Predecessors | Complete | Baseline start | Baseline finish | Baseline duration | Baseline 1 start | Baseline 1 finish | Constraint | Baseline cost | Responsible | Involved | Text9 | Update Version | MHHS Resource Name | MHHS Programme Phase | Text29 | Sched Status | RAG | Milestone ID | Tier | Artefact ID |
| --- | --- | --- | --- | --- | --- | --- | --- | --- | --- | --- | --- | --- | --- | --- | --- | --- | --- | --- | --- | --- | --- | --- | --- | --- | --- | --- | --- |
| 1687 | 1.4.3.1.2 | **E2E Sandbox Test Data Approach & Plan** |  | 73d | 2025-03-10 A | 2025-06-19 A |  | 100% | 2023-12-05 | 2024-05-09 | 93d | 2023-03-29 | 2023-08-04 |  |  | SI Test | N/A | SIT | 6.1 | Stuart Scott | Systems Integration Testing (SIT) | QAG |  |  |  |  |  |
| 1688 | 1.4.3.1.2.1 | Discussion at QWG to reconfirm value provided from E2E Sandbox (UIT) | milestone | 0d | 2025-03-11 A | 2025-03-11 A |  | 100% | 2025-03-11 | 2025-03-11 | 0d |  |  | finish no earlier than 2025-03-11 |  | SI Test |  | SIT | 6.20 | Stuart Scott |  | QAG | Complete | COMPLETE |  |  |  |
| 1689 | 1.4.3.1.2.2 | Create PPIR to request PP responses on subject to gather views |  | 5d | 2025-03-10 A | 2025-03-14 A |  | 100% | 2025-03-10 | 2025-03-14 | 0d |  |  | finish no earlier than 2025-03-14 |  | SI Test |  | SIT | 6.20 | Stuart Scott |  | QAG | Complete | COMPLETE |  |  |  |
| 1690 | 1.4.3.1.2.3 | PPIR shared to industry |  | 9d | 2025-03-24 A | 2025-04-03 A | 1689 | 100% | 2025-03-24 | 2025-04-03 | 0d |  |  | start no earlier than 2025-03-24 |  | SI Test |  | SIT | 6.22 | Stuart Scott |  | QAG | Complete | COMPLETE |  |  |  |
| 1691 | 1.4.3.1.2.4 | Evaluate PPIR responses |  | 2d | 2025-04-04 A | 2025-04-07 A |  | 100% | 2025-04-04 | 2025-04-07 | 0d |  |  | start no earlier than 2025-04-04 |  | SI Test |  | SIT | 6.22 | Stuart Scott |  | QAG | Complete | COMPLETE |  |  |  |
| 1692 | 1.4.3.1.2.5 | Discuss PPIR results at QWG |  | 1d | 2025-04-08 A | 2025-04-08 A | 1691SF-5d | 100% | 2025-04-08 | 2025-04-08 | 0d |  |  | finish no earlier than 2025-04-08 |  | SI Test |  | SIT | 6.20 | Stuart Scott |  | QAG | Complete | COMPLETE |  |  |  |
| 1693 | 1.4.3.1.2.6 | Develop document |  | 27d | 2025-04-10 A | 2025-05-16 A | 1676SS+199d | 100% | 2025-04-10 | 2025-05-16 | 68d | 2023-03-29 | 2023-06-30 | finish no earlier than 2025-05-16 |  | SI Test |  | SIT | 5.0 | Stuart Scott | Systems Integration Testing (SIT) | QAG | Complete | COMPLETE |  |  |  |
| 1694 | 1.4.3.1.2.7 | Internal SI review and updates |  | 5d | 2025-05-19 A | 2025-05-23 A | 1693 | 100% | 2025-05-19 | 2025-05-23 | 0d |  |  |  |  | SI Test |  | SIT | 6.25 | Stuart Scott |  | QAG | Complete | COMPLETE |  |  |  |
| 1695 | 1.4.3.1.2.8 | SRO / Code Bodies review |  | 5d | 2025-05-19 A | 2025-05-23 A | 1694SS | 100% | 2025-05-19 | 2025-05-23 | 0d |  |  |  |  | SI Test |  | SIT | 6.25 | Stuart Scott |  | QAG | Complete | COMPLETE |  |  |  |
| 1696 | 1.4.3.1.2.9 | Final updates prior to consultation |  | 1d | 2025-05-26 A | 2025-05-26 A | 1695 | 100% | 2025-05-26 | 2025-05-26 | 0d |  |  |  |  | SI Test |  | SIT | 6.25 | Stuart Scott |  | QAG | Complete | COMPLETE |  |  |  |
| 1697 | 1.4.3.1.2.10 | Industry Consultation for E2E Sandbox Test Data Approach and Plan document |  | 9d | 2025-05-27 A | 2025-06-06 A | 1696SS | 100% | 2025-05-26 | 2025-06-06 | 0d |  |  |  |  | SI Test |  | SIT | 6.25 | Stuart Scott |  | QAG | Complete | COMPLETE |  |  |  |
| 1698 | 1.4.3.1.2.11 | Document updates post Industry Consultation |  | 2d | 2025-06-06 A | 2025-06-09 A | 1697SS | 100% | 2025-06-07 | 2025-06-09 | 0d |  |  | finish no earlier than 2025-06-09 |  | SI Test |  | SIT | 6.25 | Stuart Scott |  | QAG | Complete | COMPLETE |  |  |  |
| 1699 | 1.4.3.1.2.12 | Submit Proposed Version to QWG | milestone | 0d | 2025-06-10 A | 2025-06-10 A |  | 100% | 2025-06-10 | 2025-06-10 | 0d |  |  | finish no earlier than 2025-06-10 |  | SI Test |  | SIT | 6.25 | Stuart Scott |  | QAG | Complete | COMPLETE |  |  |  |
| 1700 | 1.4.3.1.2.13 | Artefact Approval (via QWG) | milestone | 0d | 2025-06-10 A | 2025-06-10 A | 1699 | 100% | 2025-06-10 | 2025-06-10 | 0d |  |  | finish no earlier than 2025-06-10 |  | SI Test |  | SIT | 6.25 | Stuart Scott |  | QAG | Complete | COMPLETE |  |  |  |
| 1701 | 1.4.3.1.2.14 | Final Document updates post QWG review | milestone | 0d | 2025-06-11 A | 2025-06-11 A | 1700FS+1d | 100% | 2025-06-11 | 2025-06-11 | 0d |  |  | start no earlier than 2024-05-01 |  | SI Test |  | SIT | 6.25 | Stuart Scott |  | QAG | Complete | COMPLETE |  |  |  |
| 1702 | 1.4.3.1.2.15 | Submit final version to QAG | milestone | 0d | 2025-06-12 A | 2025-06-12 A | 1701FS+1d, 1698 | 100% | 2025-06-12 | 2025-06-12 | 0d |  |  | start no earlier than 2024-05-02 |  | SI Test |  | SIT | 6.25 | Stuart Scott |  | QAG | Complete | COMPLETE |  |  |  |
| 1703 | 1.4.3.1.2.16 | E2E Sandbox Test Data Approach and Plan Approved at QAG | milestone | 0d | 2025-06-19 A | 2025-06-19 A | 1702 | 100% | 2025-04-16 | 2025-04-16 | 0d |  |  | start no earlier than 2025-06-19 |  | SI Test |  | SIT | 6.25 | Stuart Scott |  | QAG | Complete | COMPLETE | T3-QU-0124 | T3 |  |
| 1704 | 1.4.3.2 | **UIT Stub Specification and Delivery** |  | 260d | 2023-12-04 A | 2024-11-29 A |  | 100% | 2023-12-04 | 2024-10-18 | 190d | 2023-10-27 | 2024-08-23 |  | -0 | N/A | N/A | SIT | 5.0 | N/A | Systems Integration Testing (SIT) | QAG |  |  |  |  |  |
| 1705 | 1.4.3.2.1 | **Qualification Test Stubs** |  | 260d | 2023-12-04 A | 2024-11-29 A |  | 100% | 2023-12-04 | 2024-10-18 | 190d | 2023-10-27 | 2024-08-23 |  | -0 | N/A | N/A | SIT | 5.16 | N/A | Systems Integration Testing (SIT) | QAG |  |  |  |  |  |
| 1706 | 1.4.3.2.1.1 | Specify |  | 44d | 2023-12-04 A | 2024-02-01 A | 515FS+13d | 100% | 2023-12-04 | 2024-02-01 | 44d | 2023-10-27 | 2023-12-29 |  |  | SI DevOps | Qualification,SRO | SIT | 5.0 | Lewis Hall | Systems Integration Testing (SIT) | QAG | Complete | COMPLETE |  |  |  |
| 1707 | 1.4.3.2.1.2 | Build & Test |  | 141d | 2024-02-02 A | 2024-08-16 A | 1706 | 100% | 2024-02-02 | 2024-08-16 | 141d | 2023-12-29 | 2024-05-24 |  |  | SI DevOps | Qualification,SRO | SIT | 5.23 | Lewis Hall | Systems Integration Testing (SIT) | QAG | Complete | COMPLETE |  |  |  |
| 1708 | 1.4.3.2.1.3 | Prepare for release |  | 75d | 2024-08-19 A | 2024-11-29 A | 1707 | 100% | 2024-08-19 | 2024-11-29 | 5d | 2024-07-29 | 2024-08-23 |  |  | SI DevOps | Qualification,SRO | SIT | 5.0 | Lewis Hall | Systems Integration Testing (SIT) | QAG | Complete | COMPLETE |  |  |  |
| 1709 | 1.4.3.2.1.4 | Non-SIT LDSO Test Harness Released | milestone | 0d | 2024-11-29 A | 2024-11-29 A | 1708 | 100% | 2024-11-29 | 2024-11-29 | 0d | 2024-08-23 | 2024-08-23 |  |  | SI DevOps | Qualification,SRO | SIT | 5.27 | Lewis Hall | Systems Integration Testing (SIT) | QAG | Complete | COMPLETE | T3-TE-0035 | T3 | MHHS-ART080 |
| 1710 | 1.4.3.3 | **Environments (UIT)** |  | 489d | 2022-11-16 A | 2024-09-30 A |  | 100% | 2022-10-31 | 2025-07-04 | 680d | 2022-10-31 | 2025-06-06 |  | -0 | N/A | N/A | SIT | 5.0 | N/A | Systems Integration Testing (SIT) | QAG |  |  |  |  |  |
| 1711 | 1.4.3.3.1 | **Central Party (Avanade) Environments (UIT)** |  | 488d | 2022-11-16 A | 2024-09-27 A |  | 100% | 2022-11-16 | 2024-09-27 | 493d | 2022-11-16 | 2024-10-04 |  | -0 | N/A | N/A | SIT | 5.28 | N/A | Systems Integration Testing (SIT) | QAG |  |  |  |  |  |
| 1712 | 1.4.3.3.1.1 | Central Party (Avandae) environment preparation (incl. security certificates and security compliance) |  | 447d | 2022-11-16 A | 2024-08-01 A | 511 | 100% | 2022-11-16 | 2024-08-01 | 463d | 2022-11-16 | 2024-08-23 |  |  | PP | SI Test | SIT | 5.28 | Heath Thomas | Systems Integration Testing (SIT) | QAG | Complete | COMPLETE |  |  |  |
| 1713 | 1.4.3.3.1.2 | Submit self-declaration of environment preparation complete (incl. security certificates and security compliance) to Programme for assurance |  | 447d | 2022-11-16 A | 2024-08-01 A | 1712SS | 100% | 2022-11-16 | 2024-08-01 | 463d | 2022-11-16 | 2024-08-23 |  |  | PP | SI Test | SIT | 5.28 | Heath Thomas | Systems Integration Testing (SIT) | QAG | Complete | COMPLETE |  |  |  |
| 1714 | 1.4.3.3.1.3 | Central Party (Avanade) UIT environment connectivity proving |  | 25d | 2024-08-26 A | 2024-09-27 A | 1720 | 100% | 2024-08-26 | 2024-09-27 | 25d | 2024-08-27 | 2024-09-20 |  |  | PP | SI Test | SIT | 5.28 | Heath Thomas | Systems Integration Testing (SIT) | QAG | Complete | COMPLETE |  |  |  |
| 1715 | 1.4.3.3.1.4 | Deployment of MHHS solution code to UIT environments |  | 2d | 2024-07-29 A | 2024-07-30 A |  | 100% | 2024-07-29 | 2024-07-30 | 10d | 2024-09-09 | 2024-09-20 | start no earlier than 2024-07-29 |  | PP | SI Test | SIT | 5.28 | Heath Thomas | Systems Integration Testing (SIT) | QAG | Complete | COMPLETE |  |  |  |
| 1716 | 1.4.3.3.1.5 | Central Party (Avanade) UIT environment Regression Testing |  | 1d | 2024-07-31 A | 2024-07-31 A | 1715 | 100% | 2024-07-31 | 2024-07-31 | 10d | 2024-09-23 | 2024-10-04 |  |  | PP | SI Test | SIT | 5.28 | Heath Thomas | Systems Integration Testing (SIT) | QAG | Complete | COMPLETE |  |  |  |

| ID | WBS | Task | Type | Duration | Start | Finish | Predecessors | Complete | Baseline start | Baseline finish | Baseline duration | Baseline 1 start | Baseline 1 finish | Constraint | Baseline cost | Responsible | Involved | Text9 | Update Version | MHHS Resource Name | MHHS Programme Phase | Text29 | Sched Status | RAG | Milestone ID | Tier | Task Status | Artefact ID |
| --- | --- | --- | --- | --- | --- | --- | --- | --- | --- | --- | --- | --- | --- | --- | --- | --- | --- | --- | --- | --- | --- | --- | --- | --- | --- | --- | --- | --- |
| 1717 | 1.4.3.3.2 | **SI Environments (UIT)** |  | 489d | 2022-11-16 A | 2024-09-30 A |  | 100% | 2022-11-16 | 2025-07-04 | 680d | 2022-10-31 | 2025-06-06 |  |  | N/A | N/A | SIT | 5.0 | Heath Thomas | Systems Integration Testing (SIT) | QAG |  |  |  |  |  |  |
| 1718 | 1.4.3.3.2.1 | Coordinate Central Parties' UIT environment preparation |  | 447d | 2022-11-16 A | 2024-08-01 A | 1712SS | 100% | 2022-11-16 | 2024-08-01 | 463d | 2022-11-16 | 2024-08-23 |  |  | SI Test | PP | SIT | 5.0 | Heath Thomas | Systems Integration Testing (SIT) | QAG | Complete | COMPLETE |  |  |  |  |
| 1719 | 1.4.3.3.2.2 | Assure Central Parties' self-declaration of environment preparation complete (incl. security certificates and security compliance) |  | 463d | 2022-11-16 A | 2024-08-23 A | 1713SS | 100% | 2022-11-16 | 2024-08-23 | 463d | 2022-11-16 | 2024-08-23 |  |  | SI Test | PP | SIT | 5.0 | Heath Thomas | Systems Integration Testing (SIT) | QAG | Complete | COMPLETE |  |  |  |  |
| 1720 | 1.4.3.3.2.3 | Central Parties' UIT environments ready to start connectivity proving (incl. certificates and security compliance) | milestone | 0d | 2024-08-23 A | 2024-08-23 A | 1709 | 100% | 2024-08-23 | 2024-08-23 | 0d | 2024-08-23 | 2024-08-23 |  |  | SI Test | PP | SIT | 5.0 | Heath Thomas | Systems Integration Testing (SIT) | QAG | Complete | COMPLETE | T3-TE-0044 | T3 |  |  |
| 1721 | 1.4.3.3.2.4 | Coordinate Central Parties' UIT environment connectivity proving |  | 26d | 2024-08-26 A | 2024-09-30 A | 1714SS | 100% | 2024-08-26 | 2024-09-30 | 19d | 2025-05-12 | 2025-06-05 |  |  | SI Test | PP | SIT | 5.0 | Heath Thomas | Systems Integration Testing (SIT) | QAG | Complete | COMPLETE |  |  |  |  |
| 1722 | 1.4.3.3.2.5 | Coordinate deployment of MHHS solution code to Central Parties' UIT environments |  | 2d | 2024-07-29 A | 2024-07-30 A | 1715SS | 100% | 2024-07-29 | 2024-07-30 | 10d | 2025-05-26 | 2025-06-06 |  |  | SI Test | PP | SIT | 5.0 | Heath Thomas | Systems Integration Testing (SIT) | QAG | Complete | COMPLETE |  |  |  |  |
| 1723 | 1.4.3.3.2.6 | Coordinate Central Parties' UIT environment Regression Testing |  | 1d | 2024-07-31 A | 2024-07-31 A | 1722 | 100% | 2024-07-31 | 2024-07-31 | 10d | 2024-09-23 | 2024-10-04 |  |  | SI Test | PP | SIT | 5.0 | Heath Thomas | Systems Integration Testing (SIT) | QAG | Complete | COMPLETE |  |  |  |  |
| 1724 | 1.4.3.4 | **Onboarding and Test Data (Sandbox UIT)** |  | 325d | 2025-06-02 A | 2026-08-28 A |  | 100% | 2024-08-26 | 2024-10-04 | 30d | 2024-08-26 | 2024-10-04 |  | -0 | N/A | N/A | SIT | 5.0 | N/A | Systems Integration Testing (SIT) | QAG |  |  |  |  |  |  |
| 1725 | 1.4.3.4.1 | LDSO Onboarding and Test Data Creation and Support |  | 169d | 2025-06-02 A | 2026-01-22 A |  | 100% | 2025-06-02 | 2026-01-22 | 0d |  |  | start no earlier than 2025-06-02 |  | SI Test |  | SIT | 6.28 | Stuart Scott, Joseph Wardle |  | QAG | Complete | COMPLETE |  |  |  |  |
| 1726 | 1.4.3.4.2 | Supplier & Agent Onboarding and Test Data Creation and Support |  | 260d | 2025-09-01 A | 2026-08-28 A |  | 100% | 2025-09-01 | 2026-08-28 | 0d |  |  | start no earlier than 2025-09-01 |  | S&A Qualification |  | SIT | 6.28 | David Moss |  | QAG | Complete | COMPLETE |  |  |  |  |
| 1727 | 1.4.4 | **Sandbox Execution** |  | 330d | 2025-05-26 A | 2026-08-28 A |  | 100% |  |  |  |  |  |  |  | N/A |  | SIT | 6.28 | N/A |  | QAG |  |  |  |  | -962.67 |  |
| 1728 | 1.4.4.1 | **SIT PPs Early Sandbox Testing Execution (SIT-A)** |  | 56d | 2025-08-08 A | 2025-10-24 A |  | 100% | 2025-08-08 | 2025-10-24 | 316d | 2024-11-04 | 2026-01-19 |  | -0 | N/A | N/A | SIT | 6.15 | N/A | Systems Integration Testing (SIT) | QAG |  |  |  |  |  |  |
| 1729 | 1.4.4.1.1 | SIT PPs E2E Sandbox Testing Start | milestone | 0d | 2025-08-08 A | 2025-08-08 A | 1568 | 100% | 2025-08-08 | 2025-08-08 | 0d | 2024-11-04 | 2024-11-04 | start no earlier than 2025-07-21 |  | SI Test | PP | SIT | 6.28 | Stuart Scott | Systems Integration Testing (SIT) | QAG | Complete | COMPLETE | T3-QU-0128 | T3 |  | MHHS-ART018 MHHS-ART154 MHHS-ART147 |
| 1730 | 1.4.4.1.2 | SIT PPs E2E Sandbox Testing Execution |  | 56d | 2025-08-08 A | 2025-10-24 A | 1729SS-1d | 100% | 2025-08-08 | 2025-10-24 | 316d | 2024-11-04 | 2026-01-19 | start no earlier than 2025-07-21 |  | PP | SI Test | SIT | 6.28 | Stuart Scott | Systems Integration Testing (SIT) | QAG | Complete | COMPLETE |  |  |  |  |
| 1731 | 1.4.4.1.3 | SIT PPs E2E Sandbox Testing End | milestone | 0d | 2025-10-24 A | 2025-10-24 A | 1730 | 100% | 2025-10-24 | 2025-10-24 | 0d |  |  |  |  | SI Test |  | SIT | 6.28 | Stuart Scott |  | QAG | Complete | COMPLETE | T3-QU-0129 |  |  |  |
| 1732 | 1.4.4.2 | **Sandbox Testing Execution (UIT) - LDSO Participants** |  | 174d | 2025-05-26 A | 2026-01-22 A |  | 100% | 2025-05-26 | 2026-01-22 | 316d | 2024-11-04 | 2026-01-19 |  | -0 | N/A | N/A | SIT | 6.15 | N/A | Systems Integration Testing (SIT) | QAG |  |  |  |  |  |  |
| 1733 | 1.4.4.2.1 | UIT E2E Sandbox Preparation Complete | milestone | 0d | 2025-05-26 A | 2025-05-26 A |  | 100% | 2025-05-26 | 2025-05-26 | 0d | 2024-10-25 | 2024-10-25 | start no earlier than 2025-05-26 |  | SI Test | PP | SIT | 6.28 | Stuart Scott | Systems Integration Testing (SIT) | QAG | Complete | COMPLETE | T3-QU-0125 | T3 |  | MHHS-ART154 MHHS-ART147 |
| 1734 | 1.4.4.2.2 | Sandbox Testing Start (UIT) - LDSO Participants | milestone | 0d | 2025-06-02 A | 2025-06-02 A | 1733 | 100% | 2025-06-02 | 2025-06-02 | 0d | 2024-11-04 | 2024-11-04 | finish no earlier than 2025-06-02 |  | SI Test | PP | SIT | 6.25 | Stuart Scott | Systems Integration Testing (SIT) | QAG | Complete | COMPLETE | T3-QU-0130 | T3 |  | MHHS-ART018 MHHS-ART154 MHHS-ART147 |
| 1735 | 1.4.4.2.3 | Sandbox Testing Execution (UIT) - LDSO Participants |  | 169d | 2025-06-02 A | 2026-01-22 A | 1734SS-1d | 100% | 2025-06-02 | 2026-01-22 | 316d | 2024-11-04 | 2026-01-19 | start no earlier than 2024-11-04 |  | PP | SI Test | SIT | 6.25 | Stuart Scott | Systems Integration Testing (SIT) | QAG | Complete | COMPLETE |  |  |  |  |
| 1736 | 1.4.4.2.4 | Sandbox Testing End (UIT) - LDSO Participants | milestone | 0d | 2026-01-22 A | 2026-01-22 A | 1735 | 100% | 2026-01-22 | 2026-01-22 | 0d |  |  |  |  | SI Test |  | SIT | 6.25 | Stuart Scott / Heath Thomas |  | QAG | Complete | COMPLETE | T3-QU-0131 |  |  |  |
| 1737 | 1.4.4.3 | **Sandbox Testing Execution (UIT) - Supplier & Agent Participants** |  | 260d | 2025-09-01 A | 2026-08-28 A |  | 100% | 2025-09-01 | 2026-08-28 | 316d | 2024-11-04 | 2026-01-19 |  | -0 | N/A | N/A | SIT | 6.15 | N/A | Systems Integration Testing (SIT) | QAG |  |  |  |  |  |  |
| 1738 | 1.4.4.3.1 | UIT E2E Sandbox Preparation Complete - Supplier and Agent | milestone | 0d | 2025-09-01 A | 2025-09-01 A |  | 100% | 2025-09-01 | 2025-09-01 | 0d |  |  | finish no earlier than 2025-09-01 |  | SI Test |  | SIT | 6.28 | Stuart Scott |  | QAG | Complete | COMPLETE | T3-QU-0132 | T3 |  |  |
| 1739 | 1.4.4.3.2 | Sandbox Testing Start (UIT) - Supplier & Agent Participants | milestone | 0d | 2025-09-01 A | 2025-09-01 A | 1672, 2634FS+5d, 1738 | 100% | 2025-09-01 | 2025-09-01 | 0d | 2024-11-04 | 2024-11-04 | start no earlier than 2025-02-10 |  | SI Test | PP | SIT | 6.25 | Stuart Scott | Systems Integration Testing (SIT) | QAG | Complete | COMPLETE | T3-QU-0126 | T3 |  | MHHS-ART018 MHHS-ART154 MHHS-ART147 |
| 1740 | 1.4.4.3.3 | Sandbox Testing Execution (UIT) - Supplier & Agent Participants |  | 260d | 2025-09-01 A | 2026-08-28 A | 1739SS-1d | 100% | 2025-09-01 | 2026-08-28 | 316d | 2024-11-04 | 2026-01-19 | start no earlier than 2024-11-04 |  | PP | SI Test | SIT | 6.25 | Stuart Scott | Systems Integration Testing (SIT) | QAG | Complete | COMPLETE |  |  |  |  |
| 1741 | 1.4.4.3.4 | Sandbox Testing End (UIT) - Supplier & Agent Participants | milestone | 0d | 2026-08-28 A | 2026-08-28 A | 1740 | 100% | 2026-08-28 | 2026-08-28 | 0d |  |  |  |  | SI Test |  | SIT | 6.25 | Stuart Scott / Heath Thomas |  | QAG | Complete | COMPLETE | T3-QU-0127 |  |  |  |

Notes:
- 1741: 26/08/26: Milestone will be considered complete on 28/08. The environment will be kept open for the next 2 months (Elexon BaU decision).

| ID | WBS | Task | Type | Duration | Start | Finish | Predecessors | Complete | Baseline start | Baseline finish | Baseline duration | Constraint | Text9 | Task Status | Update Version | Text29 | Responsible | MHHS Resource Name | Tier | Sched Status | RAG | Milestone ID |
| --- | --- | --- | --- | --- | --- | --- | --- | --- | --- | --- | --- | --- | --- | --- | --- | --- | --- | --- | --- | --- | --- | --- |
| 1742 | 1.4.5 | **System Integration Testing - Tier 1 Milestones** |  | 411d? | 2024-05-28 A | 2025-12-24 A |  | 100% | 2025-02-28 | 2025-12-24 | 0d |  | SIT | -685.67 | 6.15 | SITAG |  |  |  |  |  |  |
| 1743 | 1.4.5.1 | **M10 Checkpoint 1** |  | 63d? | 2025-01-06 A | 2025-04-02 A |  | 100% | 2025-02-28 | 2025-02-28 | 0d |  | SIT | -827.67 | 6.1 | PSG | CPT | Lewis Hall | T3 |  |  |  |
| 1744 | 1.4.5.1.1 | **M10 Readiness** |  | 50d? | 2025-01-06 A | 2025-03-14 A |  | 100% | 2025-01-06 | 2025-03-14 | 0d |  | SIT | -833.67 | 6.18 | PSG | CPT | Lewis Hall |  |  |  |  |
| 1745 | 1.4.5.1.1.1 | Define guiding principles and approach |  | 15d? | 2025-01-06 A | 2025-01-24 A |  | 100% | 2025-01-06 | 2025-01-24 | 0d | start no earlier than 2025-01-06 | PSG |  | 6.18 | PSG | CPT | Lewis Hall |  | Complete | COMPLETE |  |
| 1746 | 1.4.5.1.1.2 | Engage IPA |  | 10d | 2025-01-13 A | 2025-01-24 A |  | 100% | 2025-01-13 | 2025-01-24 | 0d | start no earlier than 2025-01-13 | PSG |  | 6.18 | PSG | CPT | Lewis Hall |  | Complete | COMPLETE |  |
| 1747 | 1.4.5.1.1.3 | Mobilise Get to Go-Live Group |  | 10d | 2025-01-27 A | 2025-02-07 A | 1745, 1746 | 100% | 2025-01-27 | 2025-02-07 | 0d |  | PSG |  | 6.18 | PSG | CPT | Lewis Hall |  | Complete | COMPLETE |  |
| 1748 | 1.4.5.1.1.4 | Progress against the M10 Readiness Criteria |  | 25d? | 2025-02-10 A | 2025-03-14 A | 1747 | 100% | 2025-02-10 | 2025-03-14 | 0d |  | PSG |  | 6.18 | PSG | CPT | Lewis Hall |  | Complete | COMPLETE |  |
| 1749 | 1.4.5.1.2 | **Downstream milestone feasibility assessment** |  | 50d? | 2025-01-06 A | 2025-03-14 A |  | 100% | 2025-01-06 | 2025-03-14 | 0d |  | PSG | -833.67 | 6.18 | PSG | CPT | Lewis Hall |  |  |  |  |
| 1750 | 1.4.5.1.2.1 | Define guiding principles and approach to addressing points 1 - 3 |  | 20d? | 2025-01-06 A | 2025-01-31 A |  | 100% | 2025-01-06 | 2025-01-31 | 0d | start no earlier than 2025-01-06 | PSG |  | 6.18 | PSG | CPT | Lewis Hall |  | Complete | COMPLETE |  |
| 1751 | 1.4.5.1.2.2 | Assess capacity within migration envelopes (Point 1 - Bringing M15 forwards) |  | 20d | 2025-01-20 A | 2025-02-14 A | 1750FF | 100% | 2025-01-20 | 2025-02-14 | 0d | start no earlier than 2025-01-20 | PSG |  | 6.18 | PSG | CPT | Lewis Hall |  | Complete | COMPLETE |  |
| 1752 | 1.4.5.1.2.3 | Review M16 process (Point 3 - Bringing M16 forwards) |  | 25d? | 2025-01-20 A | 2025-02-21 A | 1750FF | 100% | 2025-01-20 | 2025-02-21 | 0d | start no earlier than 2025-01-20 | PSG |  | 6.18 | PSG | CPT | Lewis Hall |  | Complete | COMPLETE |  |
| 1753 | 1.4.5.1.2.4 | Develop M16 process review findings |  | 10d | 2025-02-24 A | 2025-03-07 A | 1752 | 100% | 2025-02-24 | 2025-03-07 | 0d |  | PSG |  | 6.18 | PSG | CPT | Lewis Hall |  | Complete | COMPLETE |  |
| 1754 | 1.4.5.1.2.5 | Agree M16 process review findings with Code Bodies |  | 5d | 2025-03-10 A | 2025-03-14 A | 1753 | 100% | 2025-03-10 | 2025-03-14 | 0d |  | PSG |  | 6.18 | PSG | CPT | Lewis Hall |  | Complete | COMPLETE |  |
| 1755 | 1.4.5.1.2.6 | Agree M16 process review findings with PAB |  | 5d | 2025-03-10 A | 2025-03-14 A | 1753 | 100% | 2025-03-10 | 2025-03-14 | 0d |  | PSG |  | 6.18 | PSG | CPT | Lewis Hall |  | Complete | COMPLETE |  |
| 1756 | 1.4.5.1.2.7 | Run PPIR with impacted parties (Point 2 - Bringing M14 forwards) |  | 10d | 2025-03-03 A | 2025-03-14 A | 1751FS+10d | 100% | 2025-03-03 | 2025-03-14 | 0d |  | PSG |  | 6.18 | PSG | CPT | Lewis Hall |  | Complete | COMPLETE |  |
| 1757 | 1.4.5.1.3 | **Checkpoint governance** |  | 21d | 2025-03-05 A | 2025-04-02 A |  | 100% | 2022-10-31 | 2025-04-02 | 0d |  | PSG | -833.67 | 6.18 | PSG | CPT | Lewis Hall |  |  |  |  |
| 1758 | 1.4.5.1.3.1 | PSG Updated on progress | milestone | 0d | 2025-03-05 A | 2025-03-05 A | 1748SS | 100% | 2025-03-05 | 2025-03-05 | 0d | start no earlier than 2025-03-05 | PSG |  | 6.18 | PSG | CPT | Lewis Hall |  | Complete | COMPLETE |  |
| 1759 | 1.4.5.1.3.2 | Review final M10 Readiness outputs with IPA |  | 5d | 2025-03-17 A | 2025-03-21 A | 1754, 1755, 1756, 1748 | 100% | 2025-03-17 | 2025-03-21 | 0d |  | PSG |  | 6.18 | PSG | CPT | Lewis Hall |  | Complete | COMPLETE |  |
| 1760 | 1.4.5.1.3.3 | Review final M10 Readiness outputs with Ofgem |  | 8d | 2025-03-17 A | 2025-03-26 A | 1754, 1755, 1756, 1748, 1759SS | 100% | 2025-03-17 | 2025-03-26 | 0d |  | PSG |  | 6.18 | PSG | CPT | Lewis Hall |  | Complete | COMPLETE |  |
| 1761 | 1.4.5.1.3.4 | QAG paper day | milestone | 0d | 2025-03-13 A | 2025-03-13 A | 1748SS | 100% | 2025-03-13 | 2025-03-13 | 0d | start no earlier than 2025-03-13 | PSG |  | 6.18 | PSG | CPT | Lewis Hall |  | Complete | COMPLETE |  |
| 1762 | 1.4.5.1.3.5 | QAG recommend M10 Checkpoint | milestone | 0d | 2025-03-20 A | 2025-03-20 A | 1761FS+6d | 100% | 2025-03-20 | 2025-03-20 | 0d |  | PSG |  | 6.18 | PSG | CPT | Lewis Hall |  | Complete | COMPLETE |  |
| 1763 | 1.4.5.1.3.6 | MCAG paper day | milestone | 0d | 2025-03-24 A | 2025-03-24 A | 1748FS+6d | 100% | 2025-03-24 | 2025-03-24 | 0d |  | PSG |  | 6.18 | PSG | CPT | Lewis Hall |  | Complete | COMPLETE |  |
| 1764 | 1.4.5.1.3.7 | MCAG recommend M10 Checkpoint | milestone | 0d | 2025-04-01 A | 2025-04-01 A | 1763FS+6d | 100% | 2025-04-01 | 2025-04-01 | 0d |  | PSG |  | 6.18 | PSG | CPT | Lewis Hall |  | Complete | COMPLETE |  |
| 1765 | 1.4.5.1.3.8 | PSG paper day | milestone | 0d | 2025-03-26 A | 2025-03-26 A | 1760 | 100% | 2025-03-26 | 2025-03-26 | 0d |  | PSG |  | 6.18 | PSG | CPT | Lewis Hall |  | Complete | COMPLETE |  |
| 1766 | 1.4.5.1.3.9 | PSG M10 Checkpoint Meeting | milestone | 0d | 2025-04-02 A | 2025-04-02 A | 1765FS+5d, 1764, 1762, 1759, 1760 | 100% | 2025-04-02 | 2025-04-02 | 0d |  | PSG |  | 6.18 | PSG | CPT | Lewis Hall |  | Complete | COMPLETE |  |
| 1767 | 1.4.5.1.4 | M10 Checkpoint 1 complete | milestone | 0d | 2025-04-02 A | 2025-04-02 A | 1766 | 100% | 2025-04-02 | 2025-04-02 | 0d |  | PSG |  | 6.18 | PSG | CPT | Lewis Hall | T3 | Complete | COMPLETE | T3-MI-0040 |
| 1768 | 1.4.5.2 | M10 Checkpoint 2 Complete | milestone | 0d | 2025-07-02 A | 2025-07-02 A |  | 100% | 2025-07-02 | 2025-07-02 | 0d | finish no earlier than 2025-07-02 | PSG |  | 6.22 | PSG | CPT | Lewis Hall |  | Complete | COMPLETE | T3-MI-0046 |

| ID | WBS | Task | Type | Duration | Start | Finish | Predecessors | Complete | Baseline start | Baseline finish | Baseline duration | Baseline 1 start | Baseline 1 finish | Constraint | Responsible | Text9 | Task Status | Update Version | MHHS Resource Name | Text29 | Sched Status | RAG | Involved | Future RAG | MHHS Programme Phase | Milestone ID | Tier |
| --- | --- | --- | --- | --- | --- | --- | --- | --- | --- | --- | --- | --- | --- | --- | --- | --- | --- | --- | --- | --- | --- | --- | --- | --- | --- | --- | --- |
| 1769 | 1.4.5.3 | **M10 Acceptance Criteria** |  | 358d | 2024-05-28 A | 2025-10-10 A |  | 100% | 2024-05-28 | 2025-10-10 | 0d |  |  |  | CPT | PSG | -889.67 | 6.22 | Lewis Hall | PSG |  |  |  |  |  |  |  |
| 1770 | 1.4.5.3.1 | End of SIT MVC testing | milestone | 0d | 2025-08-22 A | 2025-08-22 A |  | 100% | 2025-08-22 | 2025-08-22 | 0d |  |  | finish no earlier than 2025-08-22 | CPT | PSG |  | 6.22 | Lewis Hall | PSG | Complete | COMPLETE |  |  |  |  |  |
| 1771 | 1.4.5.3.2 | IPA M10 Assurance Report developed and agreed | milestone | 0d | 2025-09-19 A | 2025-09-19 A |  | 100% | 2025-09-19 | 2025-09-19 | 0d |  |  | finish no earlier than 2025-09-19 | CPT | PSG |  | 6.22 | Lewis Hall | PSG | Complete | COMPLETE |  |  |  |  |  |
| 1772 | 1.4.5.3.3 | Non-SIT LDSO Qualification Testing complete | milestone | 0d | 2025-05-16 A | 2025-05-16 A | 1922 | 100% | 2025-05-16 | 2025-05-16 | 0d |  |  | finish no earlier than 2025-05-16 | CPT | PSG |  | 6.22 | Lewis Hall | PSG | Complete | COMPLETE |  |  |  |  |  |
| 1773 | 1.4.5.3.4 | A minimum of 1 supplier & required contracted agents are qualified and ready to operate under new MHHS arrangements | milestone | 0d | 2025-09-12 A | 2025-09-12 A |  | 100% | 2025-09-12 | 2025-09-12 | 0d |  |  | finish no earlier than 2025-09-12 | CPT | PSG |  | 6.22 | Lewis Hall | PSG | Complete | COMPLETE |  |  |  |  |  |
| 1774 | 1.4.5.3.5 | All LDSOs qualified | milestone | 0d | 2025-09-10 A | 2025-09-10 A |  | 100% | 2025-09-10 | 2025-09-10 | 0d |  |  | finish no earlier than 2025-09-10 | CPT | PSG |  | 6.22 | Lewis Hall | PSG | Complete | COMPLETE |  |  |  |  |  |
| 1775 | 1.4.5.3.6 | All pre-migration data cleanse activities complete | milestone | 0d | 2025-09-22 A | 2025-09-22 A |  | 100% | 2025-09-22 | 2025-09-22 | 0d |  |  | start no earlier than 2025-09-22 | CPT | PSG |  | 6.33 | Lewis Hall | PSG | Complete | COMPLETE |  |  |  |  |  |
| 1776 | 1.4.5.3.7 | All data migration activities set out in the cutover plan complete | milestone | 0d | 2025-09-24 A | 2025-09-24 A |  | 100% | 2025-09-24 | 2025-09-24 | 0d |  |  | finish no earlier than 2025-09-24 | CPT | PSG |  | 6.22 | Lewis Hall | PSG | Complete | COMPLETE |  |  |  |  |  |
| 1777 | 1.4.5.3.8 | ISD fully populated by Elexon | milestone | 0d | 2025-09-22 A | 2025-09-22 A |  | 100% | 2025-09-22 | 2025-09-22 | 0d |  |  | finish no earlier than 2025-09-22 | CPT | PSG |  | 6.22 | Lewis Hall | PSG | Complete | COMPLETE |  |  |  |  |  |
| 1778 | 1.4.5.3.9 | Significant Code Review Powers (SCR) enacted by Ofgem (M7) and updates to regulatory code ready to be implemented at M8 | milestone | 0d | 2024-12-11 A | 2024-12-11 A | 2925 | 100% | 2024-12-11 | 2024-12-11 | 0d |  |  | finish no earlier than 2024-12-11 | CPT | PSG |  | 6.22 | Lewis Hall | PSG | Complete | COMPLETE |  |  |  |  |  |
| 1779 | 1.4.5.3.10 | Migration Schedule approved | milestone | 0d | 2025-08-19 A | 2025-08-19 A | 3007 | 100% | 2025-08-19 | 2025-08-19 | 0d |  |  | finish no earlier than 2025-08-19 | CPT | PSG |  | 6.22 | Lewis Hall | PSG | Complete | COMPLETE |  |  |  |  |  |
| 1780 | 1.4.5.3.11 | Migration Framework approved | milestone | 0d | 2025-04-30 A | 2025-04-30 A |  | 100% | 2025-04-30 | 2025-04-30 | 0d |  |  | finish no earlier than 2025-04-30 | CPT | PSG |  | 6.22 | Lewis Hall | PSG | Complete | COMPLETE |  |  |  |  |  |
| 1781 | 1.4.5.3.12 | Migration Control Centre (MCC) delegation of authority approved | milestone | 0d | 2025-04-30 A | 2025-04-30 A |  | 100% | 2025-04-30 | 2025-04-30 | 0d |  |  | finish no earlier than 2025-04-30 | CPT | PSG |  | 6.22 | Lewis Hall | PSG | Complete | COMPLETE |  |  |  |  |  |
| 1782 | 1.4.5.3.13 | Migration incentives implemented | milestone | 0d | 2025-04-30 A | 2025-04-30 A |  | 100% | 2025-04-30 | 2025-04-30 | 0d |  |  | finish no earlier than 2025-04-30 | CPT | PSG |  | 6.22 | Lewis Hall | PSG | Complete | COMPLETE |  |  |  |  |  |
| 1783 | 1.4.5.3.14 | MCC tested and ready to operate | milestone | 0d | 2025-09-19 A | 2025-09-19 A | 3043 | 100% | 2025-09-19 | 2025-09-19 | 0d |  |  | finish no earlier than 2025-09-19 | CPT | PSG |  | 6.22 | Lewis Hall | PSG | Complete | COMPLETE |  |  |  |  |  |
| 1784 | 1.4.5.3.15 | Service Delivery Operating Model in place | milestone | 0d | 2025-09-19 A | 2025-09-19 A |  | 100% | 2025-09-19 | 2025-09-19 | 0d |  |  | finish no earlier than 2025-09-19 | CPT | PSG |  | 6.22 | Lewis Hall | PSG | Complete | COMPLETE |  |  |  |  |  |
| 1785 | 1.4.5.3.16 | Service Delivery Operating Model in place (Self-Certification) | milestone | 0d | 2025-07-03 A | 2025-07-03 A |  | 100% | 2025-07-03 | 2025-07-03 | 0d |  |  | finish no earlier than 2025-07-03 | CPT | PSG |  | 6.22 | Lewis Hall | PSG | Complete | COMPLETE |  |  |  |  |  |
| 1786 | 1.4.5.3.17 | Early Life Support Model defined | milestone | 0d | 2025-04-29 A | 2025-04-29 A | 3399 | 100% | 2025-04-29 | 2025-04-29 | 0d |  |  | finish no earlier than 2025-03-31 | CPT | PSG |  | 6.22 | Lewis Hall | PSG | Complete | COMPLETE |  |  |  |  |  |
| 1787 | 1.4.5.3.18 | Early Life Support Model arrangements in place and operational | milestone | 0d | 2025-09-12 A | 2025-09-12 A |  | 100% | 2025-09-12 | 2025-09-12 | 0d |  |  | finish no earlier than 2025-09-12 | CPT | PSG |  | 6.22 | Lewis Hall | PSG | Complete | COMPLETE |  |  |  |  |  |
| 1788 | 1.4.5.3.19 | Early Life Support Model arrangements in place and operational (Self-Certification) | milestone | 0d | 2025-09-12 A | 2025-09-12 A |  | 100% | 2025-09-12 | 2025-09-12 | 0d |  |  | finish no earlier than 2025-09-12 | CPT | PSG |  | 6.22 | Lewis Hall | PSG | Complete | COMPLETE |  |  |  |  |  |
| 1789 | 1.4.5.3.20 | M10/M11 Cutover Plan in place | milestone | 0d | 2024-05-28 A | 2024-05-28 A |  | 100% | 2024-05-28 | 2024-05-28 | 0d |  |  | finish no earlier than 2024-05-28 | CPT | PSG |  | 6.22 | Lewis Hall | PSG | Complete | COMPLETE |  |  |  |  |  |
| 1790 | 1.4.5.3.21 | Central Programme Party Cutover Plans in place | milestone | 0d | 2025-07-15 A | 2025-07-15 A |  | 100% | 2025-07-15 | 2025-07-15 | 0d |  |  | finish no earlier than 2025-07-15 | CPT | PSG |  | 6.22 | Lewis Hall | PSG | Complete | COMPLETE |  |  |  |  |  |
| 1791 | 1.4.5.3.22 | Production environment in place for LDSOs and Central Parties | milestone | 0d | 2025-09-22 A | 2025-09-22 A |  | 100% | 2025-09-22 | 2025-09-22 | 0d |  |  | finish no earlier than 2025-09-22 | CPT | PSG |  | 6.22 | Lewis Hall | PSG | Complete | COMPLETE |  |  |  |  |  |
| 1792 | 1.4.5.3.23 | Service activation complete to DIP Production environment for Central Parties and LDSOs | milestone | 0d | 2025-10-10 A | 2025-10-10 A |  | 100% | 2025-10-10 | 2025-10-10 | 0d |  |  | finish no earlier than 2025-10-10 | CPT | PSG |  | 6.22 | Lewis Hall | PSG | Complete | COMPLETE |  |  |  |  |  |
| 1793 | 1.4.5.3.24 | Cutover Plan executed | milestone | 0d | 2025-09-23 A | 2025-09-23 A |  | 100% | 2025-09-23 | 2025-09-23 | 0d |  |  | finish no earlier than 2025-09-23 | CPT | PSG |  | 6.22 | Lewis Hall | PSG | Complete | COMPLETE |  |  |  |  |  |
| 1794 | 1.4.5.3.25 | M10 Risk Assessment undertaken | milestone | 0d | 2025-09-03 A | 2025-09-03 A |  | 100% | 2025-09-03 | 2025-09-03 | 0d |  |  | finish no earlier than 2025-09-03 | CPT | PSG |  | 6.22 | Lewis Hall | PSG | Complete | COMPLETE |  |  |  |  |  |
| 1795 | 1.4.5.3.26 | Roles and responsibilities post-M10 agreed and accepted | milestone | 0d | 2025-09-19 A | 2025-09-19 A |  | 100% | 2025-09-19 | 2025-09-19 | 0d |  |  | finish no earlier than 2025-09-19 | CPT | PSG |  | 6.22 | Lewis Hall | PSG | Complete | COMPLETE |  |  |  |  |  |
| 1796 | 1.4.5.3.27 | M10 Work off plan agreed (if required) | milestone | 0d | 2025-09-19 A | 2025-09-19 A |  | 100% | 2025-09-19 | 2025-09-19 | 0d |  |  | finish no earlier than 2025-09-19 | CPT | PSG |  | 6.22 | Lewis Hall | PSG | Complete | COMPLETE |  |  |  |  |  |
| 1797 | 1.4.5.3.28 | Qualification Operating Model in place and operational for all post-M10 activities | milestone | 0d | 2025-09-19 A | 2025-09-19 A |  | 100% | 2025-09-19 | 2025-09-19 | 0d |  |  | finish no earlier than 2025-09-19 | CPT | PSG |  | 6.22 | Lewis Hall | PSG | Complete | COMPLETE |  |  |  |  |  |
| 1798 | 1.4.5.3.29 | Programme Governance updated to reflect required changes to support Programme delivery post-M10. | milestone | 0d | 2025-09-03 A | 2025-09-03 A |  | 100% | 2025-09-03 | 2025-09-03 | 0d |  |  | start no earlier than 2025-09-03 | CPT | PSG |  | 6.32 | Lewis Hall | PSG | Complete | COMPLETE |  |  |  |  |  |
| 1799 | 1.4.5.3.30 | All Suppliers and Agents have made the necessary changes to support losing an MPAN via the Forward Migration Process and gaining an MPAN via the Reverse Migration Process. | milestone | 0d | 2025-09-19 A | 2025-09-19 A |  | 100% | 2025-09-19 | 2025-09-19 | 0d |  |  | finish no earlier than 2025-09-19 | CPT | PSG |  | 6.22 | Lewis Hall | PSG | Complete | COMPLETE |  |  |  |  |  |
| 1800 | 1.4.5.3.31 | Performance Assurance measures are understood and in place to maintain BAU performance during the Migration period. | milestone | 0d | 2025-09-12 A | 2025-09-12 A |  | 100% | 2025-09-12 | 2025-09-12 | 0d |  |  | finish no earlier than 2025-09-12 | CPT | PSG |  | 6.22 | Lewis Hall | PSG | Complete | COMPLETE |  |  |  |  |  |
| 1801 | 1.4.5.3.32 | Programme monitoring, assurance and escalation process for beyond M10 is in place and operational | milestone | 0d | 2025-09-12 A | 2025-09-12 A |  | 100% | 2025-09-12 | 2025-09-12 | 0d |  |  | finish no earlier than 2025-09-12 | CPT | PSG |  | 6.22 | Lewis Hall | PSG | Complete | COMPLETE |  |  |  |  |  |
| 1802 | 1.4.5.4 | Central systems ready for migrating MPANs (M10) | milestone | 0d | 2025-09-22 A | 2025-09-22 A | 1672, 3185, 3192, 2307, 3229 | 100% | 2025-09-22 | 2025-09-22 | 0d | 2025-03-07 | 2025-03-07 | start no earlier than 2025-09-22 | CPT | PSG |  | 6.26 | CPT | PSG | Complete | COMPLETE | CPT | Central systems ready for migrating MPANs | Migration | T1-MI-1000 | T1 |
| 1803 | 1.4.5.5 | M10 Acceptance Criteria Ratification | milestone | 0d | 2025-09-24 A | 2025-09-24 A | 1802FS+2d | 100% | 2025-09-24 | 2025-09-24 | 0d |  |  |  | CPT | PSG |  | 6.26 | CPT | PSG | Complete | COMPLETE |  |  |  | T3-MI-0047 | T3 |
| 1804 | 1.4.5.6 | Central systems ready for migrating MPANs (M10*) - Late Exit | milestone | 0d | 2025-12-24 A | 2025-12-24 A | 1802FS+67d | 100% | 2025-12-24 | 2025-12-24 | 0d | 2025-06-06 | 2025-06-06 |  | CPT | PSG |  | 6.1 | CPT | PSG | Complete | COMPLETE | CPT | Central systems ready for migrating MPANs | Migration | T2-MI-1500 | T1 |

| ID | WBS | Task | Type | Duration | Start | Finish | Predecessors | Complete | Baseline start | Baseline finish | Baseline duration | Baseline 1 start | Baseline 1 finish | Constraint | Baseline cost | Responsible | Involved | Text9 | Update Version | MHHS Resource Name | MHHS Programme Phase | Sched Status | RAG | Text29 | Task Status | Milestone ID | Tier |
| --- | --- | --- | --- | --- | --- | --- | --- | --- | --- | --- | --- | --- | --- | --- | --- | --- | --- | --- | --- | --- | --- | --- | --- | --- | --- | --- | --- |
| 1805 | 1.4.6 | **External Programme Dependency Management** |  | 174d | 2022-10-31 A | 2023-06-30 A |  | 100% | 2022-10-31 | 2023-06-30 | 174d | 2022-10-31 | 2023-06-30 |  |  | N/A | N/A | SIT | 5.0 | N/A | Systems Integration Testing (SIT) |  |  |  |  |  |  |
| 1806 | 1.4.6.1 | **BSC CP1558** |  | 173d | 2022-10-31 A | 2023-06-29 A |  | 100% | 2022-10-31 | 2023-06-29 | 173d | 2022-10-31 | 2023-06-29 |  |  | N/A | N/A | SIT | 5.0 | N/A | Systems Integration Testing (SIT) |  |  |  |  |  |  |
| 1807 | 1.4.6.1.1 | Monitor progress to implementation date |  | 173d | 2022-10-31 A | 2023-06-28 A |  | 100% | 2022-10-31 | 2023-06-28 | 173d | 2022-10-31 | 2023-06-28 |  |  | CPT | Code Bodies | SIT | 5.0 | Andrew Margan | Systems Integration Testing (SIT) | Complete | COMPLETE |  |  |  |  |
| 1808 | 1.4.6.1.2 | BSC CP1558 Implementation Date | milestone | 0d | 2023-06-29 A | 2023-06-29 A | 1807 | 100% | 2023-06-29 | 2023-06-29 | 0d | 2023-06-29 | 2023-06-29 | must start on 2023-06-29 |  | Code Bodies |  | SIT | 5.0 | Andrew Margan | Systems Integration Testing (SIT) | Complete | COMPLETE |  |  |  |  |
| 1809 | 1.4.6.2 | **REC CP R0032** |  | 174d | 2022-10-31 A | 2023-06-30 A |  | 100% | 2022-10-31 | 2023-06-30 | 174d | 2022-10-31 | 2023-06-30 |  |  | N/A | N/A | SIT | 5.0 | N/A | Systems Integration Testing (SIT) |  |  |  |  |  |  |
| 1810 | 1.4.6.2.1 | Monitor progress to implementation date |  | 174d | 2022-10-31 A | 2023-06-29 A |  | 100% | 2022-10-31 | 2023-06-29 | 174d | 2022-10-31 | 2023-06-29 |  |  | CPT | Code Bodies | SIT | 5.0 | Andrew Margan | Systems Integration Testing (SIT) | Complete | COMPLETE |  |  |  |  |
| 1811 | 1.4.6.2.2 | REC CP R0032 Implementation Date | milestone | 0d | 2023-06-30 A | 2023-06-30 A | 1810 | 100% | 2023-06-30 | 2023-06-30 | 0d | 2023-06-30 | 2023-06-30 | must start on 2023-06-30 |  | Code Bodies |  | SIT | 5.0 | Andrew Margan | Systems Integration Testing (SIT) | Complete | COMPLETE |  |  |  |  |
| 1812 | 1.4.6.3 | **REC CP R0044** |  | 173d | 2022-10-31 A | 2023-06-29 A |  | 100% | 2022-10-31 | 2023-06-29 | 173d | 2022-10-31 | 2023-06-29 |  |  | N/A | N/A | SIT | 5.0 | N/A | Systems Integration Testing (SIT) |  |  |  |  |  |  |
| 1813 | 1.4.6.3.1 | Monitor progress to implementation date |  | 173d | 2022-10-31 A | 2023-06-28 A |  | 100% | 2022-10-31 | 2023-06-28 | 173d | 2022-10-31 | 2023-06-28 |  |  | CPT | Code Bodies | SIT | 5.0 | Andrew Margan | Systems Integration Testing (SIT) | Complete | COMPLETE |  |  |  |  |
| 1814 | 1.4.6.3.2 | REC CP R0044 Implementation Date | milestone | 0d | 2023-06-29 A | 2023-06-29 A | 1813 | 100% | 2023-06-29 | 2023-06-29 | 0d | 2023-06-29 | 2023-06-29 | must start on 2023-06-29 |  | Code Bodies |  | SIT | 5.0 | Andrew Margan | Systems Integration Testing (SIT) | Complete | COMPLETE |  |  |  |  |
| 1815 | 1.5 | **NON SIT LDSO QUALIFICATION** |  | 469d? | 2023-11-07 A | 2025-08-22 A |  | 100% | 2023-11-07 | 2025-08-22 | 343d | 2024-01-29 | 2024-07-05 |  | -0 | N/A | N/A | Non-SIT LDSO Qualification |  | N/A | Systems Integration Testing (SIT) |  |  | QAG |  |  |  |
| 1816 | 1.5.1 | **Approach Planning** |  | 208d | 2023-11-07 A | 2024-08-22 A |  | 100% | 2023-11-07 | 2024-08-22 | 208d |  |  |  | -0 | N/A | N/A | Non-SIT LDSO Qualification | 5.24 | N/A |  |  |  |  | -386.67 |  |  |
| 1817 | 1.5.1.1 | Develop Draft Testing Approach & Plan |  | 61d | 2023-11-07 A | 2024-01-30 A |  | 100% | 2023-11-07 | 2024-01-30 | 61d |  |  | start no earlier than 2023-11-07 |  | Non-SIT LDSO | Non-SIT LDSO | Non-SIT LDSO Qualification | 5.24 | Ben Wickins |  | Complete | COMPLETE |  |  |  |  |
| 1818 | 1.5.1.2 | Draft Testing Approach & Plan Issued to LDSO for Review |  | 1d | 2024-01-31 A | 2024-01-31 A | 1817 | 100% | 2024-01-31 | 2024-01-31 | 1d |  |  |  |  | Non-SIT LDSO | Non-SIT LDSO | Non-SIT LDSO Qualification | 5.24 | Ben Wickins |  | Complete | COMPLETE |  |  |  |  |
| 1819 | 1.5.1.3 | LDSO Review Complete |  | 10d | 2024-02-01 A | 2024-02-14 A | 1818 | 100% | 2024-02-01 | 2024-02-14 | 10d |  |  |  |  | LDSOs | Non-SIT LDSO | Non-SIT LDSO Qualification | 5.24 | Ben Wickins |  | Complete | COMPLETE |  |  |  |  |
| 1820 | 1.5.1.4 | Update Following LDSO Review |  | 14d | 2024-02-15 A | 2024-03-05 A | 1819 | 100% | 2024-02-15 | 2024-03-05 | 14d |  |  |  |  | Non-SIT LDSO | Non-SIT LDSO, Code Bodies | Non-SIT LDSO Qualification | 5.24 | Ben Wickins |  | Complete | COMPLETE |  |  |  |  |
| 1821 | 1.5.1.5 | QWG Review of Approach & Plan |  | 1d | 2024-03-12 A | 2024-03-12 A | 1820FS+4d | 100% | 2024-03-12 | 2024-03-12 | 1d |  |  |  |  | Non-SIT LDSO, PP | Non-SIT LDSO, Code Bodies | Non-SIT LDSO Qualification | 5.24 | Ben Wickins |  | Complete | COMPLETE |  |  |  |  |
| 1822 | 1.5.1.6 | QAG Approval for Approach & Plan | milestone | 0d | 2024-03-21 A | 2024-03-21 A | 1821FS+7d | 100% | 2024-03-21 | 2024-03-21 | 0d |  |  |  |  | Code Bodies | Non-SIT LDSO,Code Bodies | Non-SIT LDSO Qualification | 5.24 | Ben Wickins |  | Complete | COMPLETE |  |  |  |  |
| 1823 | 1.5.1.7 | Confirmation of Participants for Non-SIT LDSO Qualification Testing | milestone | 0d | 2024-03-21 A | 2024-03-21 A | 1822 | 100% | 2024-03-21 | 2024-03-21 | 0d | 2024-01-29 | 2024-01-29 |  |  | Non-SIT LDSO | SI Test, PP, IPA | Non-SIT LDSO Qualification | 5.24 | Ben Wickins | Systems Integration Testing (SIT) | Complete | COMPLETE | QAG (Non-SIT LDSO) |  | T3-QU-0011 | T3 |
| 1824 | 1.5.1.8 | Update to Annex 1 for internal review (NF, Not Operational) |  | 15d | 2024-03-18 A | 2024-04-05 A | 1065 | 100% | 2024-03-18 | 2024-04-05 | 15d |  |  |  |  | Non-SIT LDSO | PP, Code Bodies | Non-SIT LDSO Qualification | 5.24 | Ben Wickins |  | Complete | COMPLETE |  |  |  |  |
| 1825 | 1.5.1.9 | Non-Functional, Operational & Migration Approaches Socialised with Code Bodies & LDSO & Feedback Actioned |  | 86d | 2024-04-08 A | 2024-08-05 A | 1824 | 100% | 2024-04-08 | 2024-08-05 | 86d |  |  |  |  | Non-SIT LDSO | PP, Code Bodies | Non-SIT LDSO Qualification | 5.27 | Ben Wickins |  | Complete | COMPLETE |  |  |  |  |
| 1826 | 1.5.1.10 | QWG Review Operational, Non-Functional & Migration Annexes of Approach & Plan |  | 1d | 2024-08-13 A | 2024-08-13 A | 1825FS+5d | 100% | 2024-08-13 | 2024-08-13 | 1d |  |  |  |  | Non-SIT LDSO, PP | Non-SIT LDSO, PP, Code Bodies | Non-SIT LDSO Qualification | 5.27 | Ben Wickins |  | Complete | COMPLETE |  |  |  |  |
| 1827 | 1.5.1.11 | Update Following QWG Review |  | 6d | 2024-08-14 A | 2024-08-21 A | 1826 | 100% | 2024-08-14 | 2024-08-21 | 6d |  |  |  |  | Non-SIT LDSO, PP | Non-SIT LDSO, Code Bodies | Non-SIT LDSO Qualification | 5.27 | Ben Wickins |  | Complete | COMPLETE |  |  |  |  |
| 1828 | 1.5.1.12 | QAG Approval for Operational, Non-Functional & Migration Annexes of Approach & Plan | milestone | 0d | 2024-08-22 A | 2024-08-22 A | 1827FS+1d, 1823, 1068 | 100% | 2024-08-22 | 2024-08-22 | 0d |  |  |  |  | Code Bodies | Non-SIT LDSO, Code Bodies | Non-SIT LDSO Qualification | 5.29 | Ben Wickins |  | Complete | COMPLETE | QAG (Non-SIT LDSO) |  | T3-QU-0110 | T3 |

Notes:
- 1824: Guidance: 26/3: Linked to the development of SIT non functional plan
- 1828: Guidance: 18/7/24: Date change from 18/7/24 to 22/8/24 approved at QAG on 18/7/24

| ID | WBS | Task | Type | Duration | Start | Finish | Predecessors | Complete | Baseline start | Baseline finish | Baseline duration | Baseline 1 start | Baseline 1 finish | Constraint | Baseline cost | Responsible | Involved | Text9 | Task Status | Update Version | MHHS Resource Name | Sched Status | RAG | Milestone ID | Text29 | Tier | MHHS Programme Phase |
| --- | --- | --- | --- | --- | --- | --- | --- | --- | --- | --- | --- | --- | --- | --- | --- | --- | --- | --- | --- | --- | --- | --- | --- | --- | --- | --- | --- |
| 1829 | 1.5.2 | **Functional Test Cases & Scenarios** |  | 58d | 2024-01-30 A | 2024-04-18 A |  | 100% | 2024-01-30 | 2024-04-18 | 58d |  |  |  | -0 | N/A | N/A | Non-SIT LDSO Qualification | -385.67 | 5.24 | N/A |  |  |  |  |  |  |
| 1830 | 1.5.2.1 | **Functional Test Cases & Scenarios Batch 1** |  | 8d | 2024-01-30 A | 2024-02-08 A |  | 100% | 2024-01-30 | 2024-02-08 | 8d |  |  |  | -0 | N/A | N/A | Non-SIT LDSO Qualification |  | 5.24 | N/A |  |  |  |  |  |  |
| 1831 | 1.5.2.1.1 | Walkthrough Test Cases & Scenarios Batch 1 with Code Bodies |  | 1d | 2024-01-30 A | 2024-01-30 A | 1817SS+60d | 100% | 2024-01-30 | 2024-01-30 | 1d |  |  |  |  | Non-SIT LDSO | Non-SIT LDSO, Code Bodies | Non-SIT LDSO Qualification |  | 5.24 | Ben Wickins | Complete | COMPLETE |  |  |  |  |
| 1832 | 1.5.2.1.2 | Walkthrough Test Cases & Scenarios Batch 1 with LDSO |  | 1d | 2024-02-01 A | 2024-02-01 A | 1831 | 100% | 2024-02-01 | 2024-02-01 | 1d |  |  |  |  | LDSO, Non-SIT LDSO | LDSO, Non-SIT LDSO | Non-SIT LDSO Qualification |  | 5.24 | Ben Wickins | Complete | COMPLETE |  |  |  |  |
| 1833 | 1.5.2.1.3 | Action Feedback on Test Cases & Scenarios Batch 1 |  | 5d | 2024-02-02 A | 2024-02-08 A | 1832 | 100% | 2024-02-02 | 2024-02-08 | 5d |  |  |  |  | Non-SIT LDSO | Non-SIT LDSO, LDSO , Code Bodies | Non-SIT LDSO Qualification |  | 5.24 | Ben Wickins | Complete | COMPLETE |  |  |  |  |
| 1834 | 1.5.2.2 | **Functional Test Cases & Scenarios Batch 2** |  | 14d | 2024-02-20 A | 2024-03-08 A |  | 100% | 2024-02-20 | 2024-03-08 | 14d |  |  |  | -0 | N/A | N/A | Non-SIT LDSO Qualification |  | 5.24 | N/A |  |  |  |  |  |  |
| 1835 | 1.5.2.2.1 | Walkthrough Test Cases & Scenarios Batch 2 with Code Bodies |  | 1d | 2024-02-20 A | 2024-02-20 A | 1817SS+75d | 100% | 2024-02-20 | 2024-02-20 | 1d |  |  |  |  | Non-SIT LDSO | Non-SIT LDSO, Code Bodies | Non-SIT LDSO Qualification |  | 5.24 | Ben Wickins | Complete | COMPLETE |  |  |  |  |
| 1836 | 1.5.2.2.2 | Walkthrough Test Cases & Scenarios Batch 2 with LDSO |  | 1d | 2024-03-01 A | 2024-03-01 A | 1835FS+7d | 100% | 2024-03-01 | 2024-03-01 | 1d |  |  |  |  | LDSO, Non-SIT LDSO | LDSO, Non-SIT LDSO | Non-SIT LDSO Qualification |  | 5.24 | Ben Wickins | Complete | COMPLETE |  |  |  |  |
| 1837 | 1.5.2.2.3 | Action Feedback on Test Cases & Scenarios Batch 2 |  | 5d | 2024-03-04 A | 2024-03-08 A | 1836 | 100% | 2024-03-04 | 2024-03-08 | 5d |  |  |  |  | Non-SIT LDSO | Non-SIT LDSO, LDSO , Code Bodies | Non-SIT LDSO Qualification |  | 5.24 | Ben Wickins | Complete | COMPLETE |  |  |  |  |
| 1838 | 1.5.2.3 | **Functional Test Cases & Scenarios Batch 3** |  | 13d | 2024-03-20 A | 2024-04-05 A |  | 100% | 2024-03-20 | 2024-04-05 | 13d |  |  |  | -0 | N/A | N/A | Non-SIT LDSO Qualification |  | 5.24 | N/A |  |  |  |  |  |  |
| 1839 | 1.5.2.3.1 | Walkthrough Test Cases & Scenarios Batch 3 with Code Bodies |  | 1d | 2024-03-20 A | 2024-03-20 A | 1817SS+96d | 100% | 2024-03-20 | 2024-03-20 | 1d |  |  |  |  | Non-SIT LDSO | Non-SIT LDSO, Code Bodies | Non-SIT LDSO Qualification |  | 5.24 | Ben Wickins | Complete | COMPLETE |  |  |  |  |
| 1840 | 1.5.2.3.2 | Walkthrough Test Cases & Scenarios Batch 3 with LDSO |  | 1d | 2024-03-28 A | 2024-03-28 A | 1839FS+5d | 100% | 2024-03-28 | 2024-03-28 | 1d |  |  |  |  | LDSO, Non-SIT LDSO | LDSO, Non-SIT LDSO | Non-SIT LDSO Qualification |  | 5.24 | Ben Wickins | Complete | COMPLETE |  |  |  |  |
| 1841 | 1.5.2.3.3 | Action Feedback on Test Cases & Scenarios Batch 3 |  | 6d | 2024-03-29 A | 2024-04-05 A | 1840 | 100% | 2024-03-29 | 2024-04-05 | 6d |  |  |  |  | Non-SIT LDSO | Non-SIT LDSO, LDSO , Code Bodies | Non-SIT LDSO Qualification |  | 5.24 | Ben Wickins | Complete | COMPLETE |  |  |  |  |
| 1842 | 1.5.2.4 | Test Cases & Scenarios Batch 1-3 Discussion at QWG |  | 1d | 2024-04-09 A | 2024-04-09 A | 1833, 1837, 1841FS+1d | 100% | 2024-04-09 | 2024-04-09 | 1d |  |  |  |  | Non-SIT LDSO, PP | Non-SIT LDSO, Code Bodies | Non-SIT LDSO Qualification |  | 5.24 | Ben Wickins | Complete | COMPLETE |  |  |  |  |
| 1843 | 1.5.2.5 | Action QWG Feedback on Test Cases & Scenarios Batch 1-3 |  | 2d | 2024-04-10 A | 2024-04-11 A | 1842 | 100% | 2024-04-10 | 2024-04-11 | 2d |  |  |  |  | Non-SIT LDSO | Non-SIT LDSO, Code Bodies | Non-SIT LDSO Qualification |  | 5.24 | Ben Wickins | Complete | COMPLETE |  |  |  |  |
| 1844 | 1.5.2.6 | Batch 1-3 Non-SIT LDSO QT Functional Test Scenarios and Test Cases approved | milestone | 0d | 2024-04-18 A | 2024-04-18 A | 1843FS+5d | 100% | 2024-04-18 | 2024-04-18 | 0d |  |  |  |  | Code Bodies | Non-SIT LDSO, Code Bodies | Non-SIT LDSO Qualification |  | 5.24 | Ben Wickins | Complete | COMPLETE | T3-QU-0069 | QAG (Non-SIT LDSO) | T3 |  |
| 1845 | 1.5.3 | **Test Execution Schedule** |  | 161d | 2024-04-19 A | 2024-11-29 A |  | 100% | 2024-04-19 | 2024-11-29 | 90d | 2024-01-29 | 2024-04-26 |  | -0 | N/A | N/A | Non-SIT LDSO Qualification |  | 5.24 | N/A |  |  |  |  |  | Systems Integration Testing (SIT) |
| 1846 | 1.5.3.1 | Draft Test Delivery Schedule for Functional and Operational Testing |  | 20d | 2024-04-19 A | 2024-05-16 A | 1844 | 100% | 2024-04-19 | 2024-05-16 | 20d | 2024-01-29 | 2024-03-22 |  |  | Non-SIT LDSO | SI Test, PP, Non-SIT LDSO | Non-SIT LDSO Qualification |  | 5.24 | Ben Wickins | Complete | COMPLETE |  |  |  | Systems Integration Testing (SIT) |
| 1847 | 1.5.3.2 | Socialise Test Delivery Schedule with Code Bodies & LDSO for Review & Action Feedback |  | 37d | 2024-05-17 A | 2024-07-08 A | 1846 | 100% | 2024-05-17 | 2024-07-08 | 37d |  |  |  |  | Non-SIT LDSO | LDSO, Code Bodies, Non-SIT LDSO | Non-SIT LDSO Qualification |  | 5.24 | Ben Wickins | Complete | COMPLETE |  |  |  |  |
| 1848 | 1.5.3.3 | Agree Test Execution Timetable Format at QWG, Including Anonymisation Requirements |  | 1d | 2024-07-09 A | 2024-07-09 A | 1847 | 100% | 2024-07-09 | 2024-07-09 | 1d | 2024-03-25 | 2024-04-19 |  |  | Non-SIT LDSO, PP | Non-SIT LDSO, Code Bodies | Non-SIT LDSO Qualification |  | 5.24 | Ben Wickins | Complete | COMPLETE |  |  |  | Systems Integration Testing (SIT) |
| 1849 | 1.5.3.4 | Action QWG Feedback |  | 3d | 2024-07-10 A | 2024-07-12 A | 1848 | 100% | 2024-07-10 | 2024-07-12 | 3d |  |  |  |  | Non-SIT LDSO, PP | Non-SIT LDSO, Code Bodies | Non-SIT LDSO Qualification |  | 5.24 | Ben Wickins | Complete | COMPLETE |  |  |  |  |
| 1850 | 1.5.3.5 | Agree Test Execution Timetable Format at QAG, Including Anonymisation Requirements | milestone | 0d | 2024-07-18 A | 2024-07-18 A | 1849FS+4d | 100% | 2024-07-18 | 2024-07-18 | 0d |  |  |  |  | Code Bodies | Non-SIT LDSO, Code Bodies | Non-SIT LDSO Qualification |  | 5.29 | Ben Wickins | Complete | COMPLETE | T3-QU-0111 | QAG (Non-SIT LDSO) | T3 |  |
| 1851 | 1.5.3.6 | Qualification Testing for Non-SIT LDSOs (Functional, Migration, NFT, Operational) Test Execution Schedule Complete | milestone | 0d | 2024-11-29 A | 2024-11-29 A | 1828 | 100% | 2024-11-29 | 2024-11-29 | 0d | 2024-04-26 | 2024-04-26 | finish no earlier than 2024-11-29 |  | Non-SIT LDSO | Non-SIT LDSO, Code Bodies, PP | Non-SIT LDSO Qualification |  | 5.29 | Ben Wickins | Complete | COMPLETE | T3-QU-0008 | QAG (Non-SIT LDSO) | T3 | Systems Integration Testing (SIT) |
| 1852 | 1.5.4 | **Functional, Non-Functional, Operational & Migration Test Scenarios & Cases** |  | 110d | 2024-03-22 A | 2024-08-22 A |  | 100% | 2024-03-22 | 2024-08-22 | 110d |  |  |  | -0 | N/A | N/A | Non-SIT LDSO Qualification |  | 5.24 | N/A |  |  |  |  |  |  |
| 1853 | 1.5.4.1 | Test Scenarios & Cases - Functional - Drafted, Reviewed |  | 14d | 2024-04-01 A | 2024-04-18 A | 1822 | 100% | 2024-04-01 | 2024-04-18 | 14d |  |  |  |  | Non-SIT LDSO | Non-SIT LDSO, LDSO, Code Bodies | Non-SIT LDSO Qualification |  | 5.24 | Ben Wickins | Complete | COMPLETE |  |  |  |  |
| 1854 | 1.5.4.2 | Test Scenarios & Cases- Functional - Approved at QAG | milestone | 0d | 2024-04-18 A | 2024-04-18 A | 1853 | 100% | 2024-04-18 | 2024-04-18 | 0d |  |  |  |  | Non-SIT LDSO | Non-SIT LDSO, LDSO, Code Bodies | Non-SIT LDSO Qualification |  | 5.24 | Ben Wickins | Complete | COMPLETE | T3-QU-0070 | QAG (Non-SIT LDSO) | T3 |  |
| 1855 | 1.5.4.3 | Test Scenarios & Cases - Non-Functional - Drafted, Reviewed |  | 110d | 2024-03-22 A | 2024-08-22 A | 1822, 1085FF | 100% | 2024-03-22 | 2024-08-22 | 110d |  |  |  |  | Non-SIT LDSO | Non-SIT LDSO, LDSO, Code Bodies | Non-SIT LDSO Qualification |  | 5.24 | Ben Wickins | Complete | COMPLETE |  |  |  |  |
| 1856 | 1.5.4.4 | Test Scenarios & Cases - Non-Functional - Approved at QAG | milestone | 0d | 2024-08-22 A | 2024-08-22 A | 1855 | 100% | 2024-08-22 | 2024-08-22 | 0d |  |  |  |  | Non-SIT LDSO | Non-SIT LDSO, LDSO, Code Bodies | Non-SIT LDSO Qualification |  | 5.29 | Ben Wickins | Complete | COMPLETE | T3-QU-0071 | QAG (Non-SIT LDSO) | T3 |  |
| 1857 | 1.5.4.5 | Test Scenarios & Cases - Migration - Drafted, Reviewed |  | 45d | 2024-03-22 A | 2024-05-23 A | 1822 | 100% | 2024-03-22 | 2024-05-23 | 45d |  |  |  |  | Non-SIT LDSO | Non-SIT LDSO, LDSO, Code Bodies | Non-SIT LDSO Qualification |  | 5.24 | Ben Wickins | Complete | COMPLETE |  |  |  |  |
| 1858 | 1.5.4.6 | Test Scenarios & Cases - Migration - Approved at QAG | milestone | 0d | 2024-05-23 A | 2024-05-23 A | 1857 | 100% | 2024-05-23 | 2024-05-23 | 0d |  |  |  |  | Non-SIT LDSO | Non-SIT LDSO, LDSO, Code Bodies | Non-SIT LDSO Qualification |  | 5.24 | Ben Wickins | Complete | COMPLETE | T3-QU-0072 | QAG (Non-SIT LDSO) | T3 |  |
| 1859 | 1.5.4.7 | Test Scenarios & Cases - Operational - Drafted, Reviewed |  | 59d | 2024-06-03 A | 2024-08-22 A | 1822FS+51d | 100% | 2024-06-03 | 2024-08-22 | 59d |  |  |  |  | Non-SIT LDSO | Non-SIT LDSO, LDSO, Code Bodies | Non-SIT LDSO Qualification |  | 5.24 | Ben Wickins | Complete | COMPLETE |  |  |  |  |
| 1860 | 1.5.4.8 | Test Scenarios & Cases - Operational - Approved at QAG | milestone | 0d | 2024-08-22 A | 2024-08-22 A | 1859, 1085FF | 100% | 2024-08-22 | 2024-08-22 | 0d |  |  |  |  | Non-SIT LDSO | Non-SIT LDSO, LDSO, Code Bodies | Non-SIT LDSO Qualification |  | 5.29 | Ben Wickins | Complete | COMPLETE | T3-QU-0073 | QAG (Non-SIT LDSO) | T3 |  |

Notes:
- 1851: Guidance: 18/7/24: Date change from 15/8/24 to 22/8/24 approved at QAG on 18/7/24
- 1856: Guidance: 18/7/24: Date change from 18/7/24 to 22/8/24 approved at QAG on 18/7/24
- 1860: Guidance: 18/7/24: Date change from 18/7/24 to 22/8/24 approved at QAG on 18/7/24

| ID | WBS | Task | Type | Duration | Start | Finish | Predecessors | Complete | Baseline start | Baseline finish | Baseline duration | Constraint | Deadline | Baseline cost | Responsible | Involved | Text9 | Task Status | Update Version | MHHS Resource Name | Sched Status | RAG | Milestone ID | Text29 | Tier |
| --- | --- | --- | --- | --- | --- | --- | --- | --- | --- | --- | --- | --- | --- | --- | --- | --- | --- | --- | --- | --- | --- | --- | --- | --- | --- |
| 1861 | 1.5.5 | **Test Data** |  | 345d | 2024-01-22 A | 2025-05-16 A |  | 100% | 2024-01-22 | 2025-05-16 | 241d |  |  | -0 | N/A | N/A | Non-SIT LDSO Qualification | -385.67 | 5.24 | N/A |  |  |  |  |  |
| 1862 | 1.5.5.1 | Test Data Plan Drafted & Reviewed |  | 89d | 2024-01-22 A | 2024-05-23 A | 1817 | 100% | 2024-01-22 | 2024-05-23 | 89d |  |  |  | Code Bodies | Non-SIT LDSO, Code Bodies | Non-SIT LDSO Qualification |  | 5.24 | Ben Wickins | Complete | COMPLETE |  |  |  |
| 1863 | 1.5.5.2 | Non-SIT LDSO QT Test Data Plan Approved by QAG | milestone | 0d | 2024-05-23 A | 2024-05-23 A | 1862 | 100% | 2024-05-23 | 2024-05-23 | 0d |  |  |  | Code Bodies | Non-SIT LDSO, Code Bodies | Non-SIT LDSO Qualification |  | 5.24 | Ben Wickins | Complete | COMPLETE | T3-QU-0074 | QAG (Non-SIT LDSO) | T3 |
| 1864 | 1.5.5.3 | Develop Test Data Matrices |  | 10d | 2024-05-24 A | 2024-06-06 A | 1863 | 100% | 2024-05-24 | 2024-06-06 | 10d |  |  |  | Non-SIT LDSO | Non-SIT LDSO | Non-SIT LDSO Qualification |  | 5.24 | Ben Wickins | Complete | COMPLETE |  |  |  |
| 1865 | 1.5.5.4 | Test Data Cut |  | 17d | 2024-05-24 A | 2024-06-17 A | 1863 | 100% | 2024-05-24 | 2024-06-17 | 17d |  |  |  | PP, Non-SIT LDSO | PP, Non-SIT LDSO | Non-SIT LDSO Qualification |  | 5.24 | Ben Wickins | Complete | COMPLETE |  |  |  |
| 1866 | 1.5.5.5 | Test Data Cut Complete | milestone | 0d | 2024-06-17 A | 2024-06-17 A | 1865, 1864 | 100% | 2024-06-17 | 2024-06-17 | 0d |  |  |  | PP, Non-SIT LDSO | PP, Non-SIT LDSO | Non-SIT LDSO Qualification |  | 5.27 | Ben Wickins | Complete | COMPLETE | T3-QU-0112 | QAG (Non-SIT LDSO) | T3 |
| 1867 | 1.5.5.6 | Test Data Reviewed by the Programme |  | 39d | 2024-06-18 A | 2024-08-09 A | 1866 | 100% | 2024-06-18 | 2024-08-09 | 39d |  |  |  | Non-SIT LDSO | PP, Non-SIT LDSO | Non-SIT LDSO Qualification |  | 5.24 | Ben Wickins | Complete | COMPLETE |  |  |  |
| 1868 | 1.5.5.7 | Test Data Loaded |  | 85d | 2024-08-12 A | 2024-12-06 A | 1867 | 100% | 2024-08-12 | 2024-12-06 | 17d |  |  |  | Non-SIT LDSO | PP, Non-SIT LDSO | Non-SIT LDSO Qualification |  | 5.24 | Ben Wickins | Complete | COMPLETE |  |  |  |
| 1869 | 1.5.5.8 | Test Data Signed Off | milestone | 0d | 2024-12-06 A | 2024-12-06 A | 1868 | 100% | 2024-12-06 | 2024-12-06 | 0d |  |  |  | Non-SIT LDSO | PP, Non-SIT LDSO | Non-SIT LDSO Qualification |  | 5.25 | Ben Wickins | Complete | COMPLETE | T3-QU-0113 | QAG (Non-SIT LDSO) | T3 |
| 1870 | 1.5.5.9 | Test Execution Data Support |  | 115d | 2024-12-09 A | 2025-05-16 A | 1869 | 100% | 2024-12-09 | 2025-05-16 | 79d |  |  |  | Non-SIT LDSO | Non-SIT LDSO | Non-SIT LDSO Qualification |  | 5.24 | Ben Wickins | Complete | COMPLETE |  |  |  |
| 1871 | 1.5.6 | **Tooling** |  | 148d | 2024-01-31 A | 2024-08-23 A |  | 100% | 2024-01-31 | 2024-08-23 | 148d |  |  | -0 | N/A | N/A | Non-SIT LDSO Qualification | -385.67 | 5.24 | N/A |  |  |  |  |  |
| 1872 | 1.5.6.1 | Design Approach & Set-Up ADO Tool for Test & Defect Management Tool |  | 53d | 2024-01-31 A | 2024-04-12 A | 1817 | 100% | 2024-01-31 | 2024-04-12 | 53d |  |  |  | Non-SIT LDSO | Non-SIT LDSO, SI Test | Non-SIT LDSO Qualification |  | 5.24 | Ben Wickins | Complete | COMPLETE |  |  |  |
| 1873 | 1.5.6.2 | Develop Training Requirements & Materials Inc. Day in the Life |  | 87d | 2024-04-15 A | 2024-08-13 A | 1872 | 100% | 2024-04-15 | 2024-08-13 | 87d |  |  |  | Non-SIT LDSO | Non-SIT LDSO, SI Test | Non-SIT LDSO Qualification |  | 5.24 | Ben Wickins | Complete | COMPLETE |  |  |  |
| 1874 | 1.5.6.3 | ADO Launch complete |  | 1d | 2024-08-23 A | 2024-08-23 A | 1873, 1854, 1858, 1860 | 100% | 2024-08-23 | 2024-08-23 | 1d |  |  |  | Non-SIT LDSO | Non-SIT LDSO | Non-SIT LDSO Qualification |  | 5.24 | Ben Wickins | Complete | COMPLETE |  |  |  |
| 1875 | 1.5.7 | **Pre-Integration Testing** |  | 263d | 2024-01-31 A | 2025-01-31 A |  | 100% | 2024-01-31 | 2024-11-29 | 174d |  |  | -0 | N/A | N/A | Non-SIT LDSO Qualification | -385.67 | 5.24 | N/A |  |  |  |  |  |
| 1876 | 1.5.7.1 | PIT Guidance & Templates & Approach & Plans Developed |  | 106d | 2024-02-05 A | 2024-07-01 A | 1817FS+3d | 100% | 2024-02-05 | 2024-07-01 | 106d |  |  |  | Non-SIT LDSO | Non-SIT LDSO, LDSO | Non-SIT LDSO Qualification |  | 5.27 | Ben Wickins | Complete | COMPLETE |  |  |  |
| 1877 | 1.5.7.2 | PIT Test Approach & Plan Deadline for Submission for Non-SIT LDSO​ QT | milestone | 0d | 2024-07-01 A | 2024-07-01 A | 1876 | 100% | 2024-07-01 | 2024-07-01 | 0d |  |  |  | Non-SIT LDSO | Non-SIT LDSO, LDSO | Non-SIT LDSO Qualification |  | 5.28 | Ben Wickins | Complete | COMPLETE | T3-QU-0075 | QAG (Non-SIT LDSO) | T3 |
| 1878 | 1.5.7.3 | Develop and agree PIT Test Scenarios |  | 20d | 2024-07-02 A | 2024-07-29 A | 1877 | 100% | 2024-07-02 | 2024-07-29 | 31d |  |  |  | Non-SIT LDSO | Non-SIT LDSO, Code Bodies, LDSO | Non-SIT LDSO Qualification |  | 5.24 | Ben Wickins | Complete | COMPLETE |  |  |  |
| 1879 | 1.5.7.4 | PIT Execution (Functional and Migration) | manual | 45d | 2024-09-30 A | 2024-11-29 A | 1878 | 100% | 2024-09-30 | 2024-11-29 | 45d | start no earlier than 2024-09-30 |  |  | Non-SIT LDSO | Non-SIT LDSO, LDSO | Non-SIT LDSO Qualification |  | 5.24 | Ben Wickins | Complete | COMPLETE |  |  |  |
| 1880 | 1.5.7.5 | PIT Execution (Non-Functional and Operational) |  | 95d | 2024-09-23 A | 2025-01-31 A | 1878 | 100% | 2024-09-23 | 2025-01-31 | 0d | finish no earlier than 2025-01-31 |  |  | Non-SIT LDSO |  | Non-SIT LDSO Qualification |  | 5.24 | Ben Wickins | Complete | COMPLETE |  |  |  |
| 1881 | 1.5.7.6 | Non-SIT LDSO Participants have submitted functional PIT Test Completion Report & evidence for QT Entry​ | milestone | 0d | 2024-11-29 A | 2024-11-29 A | 1879 | 100% | 2024-11-29 | 2024-11-29 | 0d |  |  |  | Non-SIT LDSO | Non-SIT LDSO, LDSO | Non-SIT LDSO Qualification |  | 5.24 | Ben Wickins | Complete | COMPLETE | T3-QU-0076 | QAG (Non-SIT LDSO) | T3 |
| 1882 | 1.5.7.7 | Non-SIT LDSO Participants have submitted non-functional PIT Test Completion Report | milestone | 0d | 2025-01-31 A | 2025-01-31 A | 1880 | 100% | 2025-01-31 | 2025-01-31 | 0d |  |  |  | Non-SIT LDSO |  | Non-SIT LDSO Qualification |  | 5.24 | Ben Wickins | Complete | COMPLETE |  |  |  |
| 1883 | 1.5.7.8 | **Placing Reliance - Code Body & LDSO Functional and Migration** |  | 147d | 2024-01-31 A | 2024-08-22 A |  | 100% | 2024-01-31 | 2024-08-22 | 147d |  |  | -0 | N/A | N/A | Non-SIT LDSO Qualification | -100.67 | 5.24 | N/A |  |  |  |  |  |
| 1884 | 1.5.7.8.1 | Placing Reliance Submitted & Reviewed |  | 21d | 2024-01-31 A | 2024-02-28 A | 1817 | 100% | 2024-01-31 | 2024-02-28 | 21d |  | 2024-01-05 |  | LDSO, Non-SIT LDSO | LDSO, Non-SIT LDSO | Non-SIT LDSO Qualification |  | 5.24 | Ben Wickins | Complete | COMPLETE |  |  |  |
| 1885 | 1.5.7.8.2 | Define & Agree QT Testing for Each LDSO |  | 22d | 2024-02-29 A | 2024-03-29 A | 1884 | 100% | 2024-02-29 | 2024-03-29 | 22d |  |  |  | Non-SIT LDSO | LDSO, Non-SIT LDSO | Non-SIT LDSO Qualification |  | 5.24 | Ben Wickins | Complete | COMPLETE |  |  |  |
| 1886 | 1.5.7.8.3 | Develop Test Scope & Reliance Submissions |  | 20d | 2024-04-01 A | 2024-04-26 A | 1885 | 100% | 2024-04-01 | 2024-04-26 | 20d |  |  |  | Non-SIT LDSO | LDSO, Non-SIT LDSO, Code Bodies | Non-SIT LDSO Qualification |  | 5.24 | Ben Wickins | Complete | COMPLETE |  |  |  |
| 1887 | 1.5.7.8.4 | Review and Consultation |  | 84d | 2024-04-29 A | 2024-08-22 A | 1886, 1828FF | 100% | 2024-04-29 | 2024-08-22 | 84d |  |  |  | Non-SIT LDSO | LDSO, Non-SIT LDSO | Non-SIT LDSO Qualification |  | 5.27 | Ben Wickins | Complete | COMPLETE |  |  |  |

| ID | WBS | Task | Type | Duration | Start | Finish | Predecessors | Complete | Baseline start | Baseline finish | Baseline duration | Baseline 1 start | Baseline 1 finish | Constraint | Deadline | Baseline cost | Responsible | Involved | Text9 | Task Status | Update Version | MHHS Resource Name | Sched Status | RAG | Milestone ID | Text29 | Tier | MHHS Programme Phase | Action |
| --- | --- | --- | --- | --- | --- | --- | --- | --- | --- | --- | --- | --- | --- | --- | --- | --- | --- | --- | --- | --- | --- | --- | --- | --- | --- | --- | --- | --- | --- |
| 1888 | 1.5.7.9 | **Placing Reliance - Code Body & LDSO Non Functional and Operational** |  | 49d | 2024-06-17 A | 2024-08-22 A |  | 100% | 2024-06-17 | 2024-08-22 | 49d |  |  |  |  | -0 | N/A | N/A | Non-SIT LDSO Qualification | -100.67 | 5.25 | N/A |  |  |  |  |  |  |  |
| 1889 | 1.5.7.9.1 | Placing Reliance Submitted & Reviewed |  | 32d | 2024-06-17 A | 2024-07-30 A | 1826FF-10d | 100% | 2024-06-17 | 2024-07-30 | 32d |  |  |  |  |  | LDSO, Non-SIT LDSO | LDSO, Non-SIT LDSO | Non-SIT LDSO Qualification |  | 5.27 | Ben Wickins | Complete | COMPLETE |  |  |  |  |  |
| 1890 | 1.5.7.9.2 | Review and Consultation |  | 17d | 2024-07-31 A | 2024-08-22 A | 1889 | 100% | 2024-07-31 | 2024-08-22 | 17d |  |  |  |  |  | Non-SIT LDSO | LDSO, Non-SIT LDSO | Non-SIT LDSO Qualification |  | 5.27 | Ben Wickins | Complete | COMPLETE |  |  |  |  |  |
| 1891 | 1.5.7.9.3 | PP Test Scope Presented at QAG | milestone | 0d | 2024-08-22 A | 2024-08-22 A | 1890, 1887 | 100% | 2024-08-22 | 2024-08-22 | 0d |  |  |  |  |  | Non-SIT LDSO | LDSO, Non-SIT LDSO | Non-SIT LDSO Qualification |  | 5.29 | Ben Wickins | Complete | COMPLETE | T3-QU-0077 | QAG (Non-SIT LDSO) | T3 |  |  |
| 1892 | 1.5.8 | **LDSO Test Readiness Reporting** |  | 71d | 2024-04-19 A | 2024-07-26 A |  | 100% | 2024-04-19 | 2024-07-26 | 118d |  |  |  |  | -0 | N/A | N/A | Non-SIT LDSO Qualification |  | 5.24 | N/A |  |  |  |  |  |  |  |
| 1893 | 1.5.8.1 | Interim Test Readiness Report & Plan Developed & Reviewed |  | 71d | 2024-04-19 A | 2024-07-26 A | 1844 | 100% | 2024-04-19 | 2024-07-26 | 71d |  |  |  |  |  | Non-SIT LDSO, LDSO | Non-SIT LDSO, LDSO | Non-SIT LDSO Qualification |  | 5.24 | Ben Wickins | Complete | COMPLETE |  |  |  |  |  |
| 1894 | 1.5.8.2 | Test Plan Submission to MHHS Programme For Review | milestone | 0d | 2024-07-26 A | 2024-07-26 A | 1893 | 100% | 2024-07-26 | 2024-07-26 | 0d |  |  |  |  |  | LDSO | Non-SIT LDSO, LDSO | Non-SIT LDSO Qualification |  | 5.30 | Ben Wickins | Complete | COMPLETE | T3-QU-0114 | QAG (Non-SIT LDSO) | T3 |  |  |
| 1895 | 1.5.9 | **Test Environment** |  | 163d | 2024-04-17 A | 2024-11-29 A |  | 100% | 2024-04-17 | 2024-11-29 | 111d | 2024-01-29 | 2024-07-05 |  |  | -0 | N/A | N/A | Non-SIT LDSO Qualification |  | 5.24 | N/A |  |  |  |  |  | Systems Integration Testing (SIT) |  |
| 1896 | 1.5.9.1 | Define Test Harness Requirements and Sign-Off with SRO |  | 13d | 2024-04-17 A | 2024-05-03 A | 516 | 100% | 2024-04-17 | 2024-05-03 | 13d |  |  |  |  |  | Non-SIT LDSO | Non-SIT LDSO,SRO,Sims and Ems | Non-SIT LDSO Qualification |  | 5.24 | Ben Wickins | Complete | COMPLETE |  |  |  |  |  |
| 1897 | 1.5.9.2 | Central System (DIP Env & Helix Test Harness) Test Environment DBT |  | 163d | 2024-04-17 A | 2024-11-29 A | 516 | 100% | 2024-04-17 | 2024-11-29 | 92d |  |  | finish no earlier than 2024-11-29 |  |  | LDSO | Non SIT-LDSO, LDSO | Non-SIT LDSO Qualification |  | 5.24 | Ben Wickins | Complete | COMPLETE |  |  |  |  |  |
| 1898 | 1.5.9.3 | Coordinate LDSO Environment Preparation |  | 101d | 2024-07-12 A | 2024-11-29 A | 1897FF | 100% | 2024-07-12 | 2024-11-29 | 30d |  |  |  |  |  | Non-SIT LDSO | Non-SIT LDSO | Non-SIT LDSO Qualification |  | 5.24 | Ben Wickins | Complete | COMPLETE |  |  |  |  |  |
| 1899 | 1.5.9.4 | DIP available for Onboarding |  | 1d | 2024-08-01 A | 2024-08-01 A |  | 100% | 2024-08-01 | 2024-08-01 | 1d |  |  | start no earlier than 2024-08-01 |  |  | Test Env | Test Env, Non-SIT LDSO | Non-SIT LDSO Qualification |  | 5.24 | Ben Wickins | Complete | COMPLETE |  |  |  |  | 11/3: Ask Simon B for the link |
| 1900 | 1.5.9.5 | Qualification Testing for Non-SIT LDSOs Participants' environments) Ready to start DIP onboarding (incl. certificates and security compliance) | milestone | 0d | 2024-08-05 A | 2024-08-05 A | 1899FS+2d | 100% | 2024-08-05 | 2024-08-05 | 0d | 2024-04-26 | 2024-04-26 |  |  |  | Non-SIT LDSO | Code Bodies, PP, IPA | Non-SIT LDSO Qualification |  | 5.30 | Ben Wickins | Complete | COMPLETE | T3-QU-0009 | QAG (Non-SIT LDSO) | T3 | Systems Integration Testing (SIT) |  |
| 1901 | 1.5.9.6 | LDSO Test Environments Connection Confirmed to UIT Environment | milestone | 0d | 2024-11-29 A | 2024-11-29 A | 1900FS+32d, 1898 | 100% | 2024-11-29 | 2024-11-29 | 0d |  |  |  |  |  | Non-SIT LDSO | Code Bodies, PP, IPA | Non-SIT LDSO Qualification |  | 5.24 | Ben Wickins | Complete | COMPLETE | T3-QU-0078 | QAG (Non-SIT LDSO) | T3 |  |  |
| 1902 | 1.5.10 | **Test Readiness** |  | 124d | 2024-07-02 A | 2024-12-20 A |  | 100% | 2024-07-02 | 2024-12-20 | 76d |  |  |  |  | -0 | N/A | N/A | Non-SIT LDSO Qualification |  | 5.24 | N/A |  |  |  |  |  |  |  |
| 1903 | 1.5.10.1 | Preparation for Interim Test Readiness Report |  | 19d | 2024-07-02 A | 2024-07-26 A | 1877 | 100% | 2024-07-02 | 2024-07-26 | 30d |  |  |  |  |  | LDSO | LDSO, Non-SIT LDSO | Non-SIT LDSO Qualification |  | 5.24 | Ben Wickins | Complete | COMPLETE |  |  |  |  |  |
| 1904 | 1.5.10.2 | Interim Test Readiness Report Submission to MHHS Programme for Review | milestone | 0d | 2024-07-26 A | 2024-07-26 A | 1903 | 100% | 2024-07-26 | 2024-07-26 | 0d |  |  |  |  |  | LDSO | Non-SIT LDSO, LDSO | Non-SIT LDSO Qualification |  | 5.25 | Ben Wickins | Complete | COMPLETE | T3-QU-0116 | QAG (Non-SIT LDSO) | T3 |  |  |
| 1905 | 1.5.10.3 | LDSO Update Readiness Report & Final Assurance by Programme |  | 99d | 2024-07-29 A | 2024-12-12 A | 1904 | 100% | 2024-07-29 | 2024-12-12 | 25d |  |  |  |  |  | Non-SIT LDSO, LDSO | Non-SIT LDSO, LDSO | Non-SIT LDSO Qualification |  | 5.24 | Ben Wickins | Complete | COMPLETE |  |  |  |  |  |
| 1906 | 1.5.10.4 | Final Test Readiness Report Submitted to MHHS Programme |  | 1d | 2024-12-13 A | 2024-12-13 A | 1905 | 100% | 2024-12-13 | 2024-12-13 | 1d |  |  |  |  |  | LDSO | Non-SIT LDSO, Code Bodies | Non-SIT LDSO Qualification |  | 5.24 | Ben Wickins | Complete | COMPLETE |  |  |  |  |  |
| 1907 | 1.5.10.5 | Final Programme Assurance of LDSO Test Readiness |  | 6d | 2024-12-13 A | 2024-12-20 A | 1905 | 100% | 2024-12-13 | 2024-12-20 | 21d |  |  |  |  |  | Non-SIT LDSO | Non-SIT LDSO, LDSO | Non-SIT LDSO Qualification |  | 5.24 | Ben Wickins | Complete | COMPLETE |  |  |  |  |  |
| 1908 | 1.5.10.6 | Qualification Testing for Non-SIT LDSOs (Functional, Migration, NFT, Operational) Programme Test Readiness confirmed | milestone | 0d | 2024-12-20 A | 2024-12-20 A | 1906FS+5d, 1881, 1854, 1856, 1858, 1896 | 100% | 2024-12-20 | 2024-12-20 | 0d | 2024-07-05 | 2024-07-05 |  |  |  | Non-SIT LDSO | SI Test, PP, Non-SIT LDSO | Non-SIT LDSO Qualification |  | 5.24 | Ben Wickins | Complete | COMPLETE | T3-QU-0007 | QAG (Non-SIT LDSO) | T3 | Systems Integration Testing (SIT) |  |
| 1909 | 1.5.10.7 | Qualification Testing for Non-SIT LDSOs (Functional, Migration, NFT, Operational) Test Readiness Confirmed (Final Test Readiness Review for LDSO) | milestone | 0d | 2024-12-20 A | 2024-12-20 A | 1905, 1907 | 100% | 2024-12-20 | 2024-12-20 | 0d | 2024-07-05 | 2024-07-05 |  |  |  | LDSO | SI Test, PP, LDSO | Non-SIT LDSO Qualification |  | 5.24 | Ben Wickins | Complete | COMPLETE | T2-QU-0550 | QAG (Non-SIT LDSO) | T2 | Systems Integration Testing (SIT) |  |
| 1910 | 1.5.11 | **Test Window** |  | 165d? | 2025-01-06 A | 2025-08-22 A |  | 100% | 2025-01-06 | 2025-05-16 | 59d |  |  |  |  | -0 | N/A | N/A | Non-SIT LDSO Qualification | -527.67 | 6.0 | N/A |  |  |  | QAG (Non-SIT LDSO) |  |  |  |
| 1911 | 1.5.11.1 | **All Non-SIT LDSOs Qualification Testing** |  | 94d | 2025-01-06 A | 2025-05-16 A | 1909, 1901 | 100% | 2025-01-06 | 2025-05-16 | 59d |  |  |  |  |  | LDSO | Non-SIT LDSO,Code Bodies, LDSO | Non-SIT LDSO Qualification | 118.33 | 6.0 | Ben Wickins |  |  |  | QAG (Non-SIT LDSO) |  |  |  |
| 1912 | 1.5.11.1.1 | Non-SIT LDSO QT Test Execution Starts | milestone | 0d | 2025-01-06 A | 2025-01-06 A | 1909FS+11d | 100% | 2025-01-06 | 2025-01-06 | 0d |  |  | start no earlier than 2024-11-01 |  |  | Non-SIT LDSO | Non-SIT LDSO, LDSO, Code Bodies | Non-SIT LDSO Qualification |  | 6.0 | Ben Wickins | Complete | COMPLETE | T3-QU-0115 | QAG (Non-SIT LDSO) | T3 |  |  |
| 1913 | 1.5.11.1.2 | LDSO Alpha |  | 86d | 2025-01-06 A | 2025-05-05 A | 1912FS-1d | 100% | 2025-01-06 | 2025-05-05 | 0d |  |  |  |  |  | LDSO |  | Non-SIT LDSO Qualification |  | 6.15 | Ben Wickins | Complete | COMPLETE |  | QAG (Non-SIT LDSO) |  |  |  |
| 1914 | 1.5.11.1.3 | LDSO Bravo |  | 86d | 2025-01-06 A | 2025-05-05 A | 1912FS-1d | 100% | 2025-01-06 | 2025-05-05 | 0d |  |  | finish no earlier than 2025-05-05 |  |  | LDSO |  | Non-SIT LDSO Qualification |  | 6.21 | Ben Wickins | Complete | COMPLETE |  | QAG (Non-SIT LDSO) |  |  |  |
| 1915 | 1.5.11.1.4 | LDSO Charlie |  | 88d | 2025-01-06 A | 2025-05-07 A | 1912FS-1d | 100% | 2025-01-06 | 2025-05-07 | 0d |  |  |  |  |  | LDSO |  | Non-SIT LDSO Qualification |  | 6.15 | Ben Wickins | Complete | COMPLETE |  | QAG (Non-SIT LDSO) |  |  |  |
| 1916 | 1.5.11.1.5 | LDSO Delta |  | 83d | 2025-01-06 A | 2025-04-30 A | 1912FS-1d | 100% | 2025-01-06 | 2025-04-30 | 0d |  |  |  |  |  | LDSO |  | Non-SIT LDSO Qualification |  | 6.15 | Ben Wickins | Complete | COMPLETE |  | QAG (Non-SIT LDSO) |  |  |  |
| 1917 | 1.5.11.1.6 | LDSO Echo |  | 69d | 2025-01-06 A | 2025-04-10 A | 1912FS-1d | 100% | 2025-01-06 | 2025-04-10 | 0d |  |  |  |  |  | LDSO |  | Non-SIT LDSO Qualification |  | 6.15 | Ben Wickins | Complete | COMPLETE |  | QAG (Non-SIT LDSO) |  |  |  |
| 1918 | 1.5.11.1.7 | LDSO Foxtrot |  | 84d | 2025-01-20 A | 2025-05-15 A | 1912FS+9d | 100% | 2025-01-20 | 2025-05-15 | 0d |  |  | finish no earlier than 2025-05-15 |  |  | LDSO |  | Non-SIT LDSO Qualification |  | 6.21 | Ben Wickins | Complete | COMPLETE |  | QAG (Non-SIT LDSO) |  |  |  |
| 1919 | 1.5.11.1.8 | LDSO Golf |  | 80d | 2025-01-06 A | 2025-04-25 A | 1912FS-1d | 100% | 2025-01-06 | 2025-04-25 | 0d |  |  | finish no earlier than 2025-04-25 |  |  | LDSO |  | Non-SIT LDSO Qualification |  | 6.15 | Ben Wickins | Complete | COMPLETE |  | QAG (Non-SIT LDSO) |  |  |  |
| 1920 | 1.5.11.1.9 | LDSO Hotel |  | 86d | 2025-01-06 A | 2025-05-05 A | 1912FS-1d | 100% | 2025-01-06 | 2025-05-05 | 0d |  |  | finish no earlier than 2025-05-05 |  |  | LDSO |  | Non-SIT LDSO Qualification |  | 6.21 | Ben Wickins | Complete | COMPLETE |  | QAG (Non-SIT LDSO) |  |  |  |
| 1921 | 1.5.11.1.10 | LDSO India |  | 86d | 2025-01-06 A | 2025-05-05 A | 1912FS-1d | 100% | 2025-01-06 | 2025-05-05 | 0d |  |  |  |  |  | LDSO |  | Non-SIT LDSO Qualification |  | 6.15 | Ben Wickins | Complete | COMPLETE |  | QAG (Non-SIT LDSO) |  |  |  |
| 1922 | 1.5.11.1.11 | Qualification Testing for Non-SIT LDSOs (Functional, Migration, NFT, Operational) 1 End | milestone | 0d | 2025-05-16 A | 2025-05-16 A | 1913, 1914, 1915, 1916, 1917, 1918, 1919, 1920, 1921 | 100% | 2025-05-16 | 2025-05-16 | 0d |  |  | start no earlier than 2025-05-16 | 2025-05-16 |  | LDSO |  | Non-SIT LDSO Qualification |  | 6.0 | Ben Wickins | Complete | COMPLETE | T3-QU-0010 | QAG (Non-SIT LDSO) | T3 |  |  |
| 1923 | 1.5.11.2 | Potential for non-SIT LDSO QT Regression for Qualification |  | 70d? | 2025-05-19 A | 2025-08-22 A | 1922FS+1d | 100% | 2025-05-19 | 2025-08-22 | 0d |  |  |  |  |  | Non-SIT LDSO |  | Non-SIT LDSO Qualification |  | 6.12 | Ben Wickins | Complete | COMPLETE |  | QAG (Non-SIT LDSO) |  |  |  |

Notes:
- 1891: Guidance: 18/7/24: Date change from 18/7/24 to 22/8/24 approved at QAG on 18/7/24

| ID | WBS | Task | Type | Duration | Start | Finish | Predecessors | Complete | Actual start | Baseline start | Baseline finish | Baseline duration | Constraint | Baseline cost | Responsible | Involved | Text9 | Update Version | MHHS Resource Name | Text29 | Sched Status | RAG | Milestone ID | Tier | Task Status | Previous RAG |
| --- | --- | --- | --- | --- | --- | --- | --- | --- | --- | --- | --- | --- | --- | --- | --- | --- | --- | --- | --- | --- | --- | --- | --- | --- | --- | --- |
| 1924 | 1.5.12 | **Test Result Assurance** |  | 30d | 2025-04-04 A | 2025-05-16 A |  | 100% |  | 2025-04-21 | 2025-05-29 | 60d |  | -0 | N/A | N/A | Non-SIT LDSO Qualification | 6.0 | N/A | QAG (Non-SIT LDSO) |  |  |  |  |  |  |
| 1925 | 1.5.12.1 | Test Reports Reviewed By MHHS & Code Bodies & Finalised |  | 30d | 2025-04-04 A | 2025-05-16 A | 1922FF | 100% |  | 2025-04-04 | 2025-05-16 | 16d |  |  | Non-SIT LDSO | Non-SIT LDSO, Code Bodies | Non-SIT LDSO Qualification | 6.0 | Ben Wickins | QAG (Non-SIT LDSO) | Complete | COMPLETE |  |  |  |  |
| 1926 | 1.5.12.2 | Non-SIT LDSOs submission deadline for their QT Test Completion Report to MHHS Programme | milestone | 0d | 2025-05-16 A | 2025-05-16 A | 1925, 1911, 1922 | 100% |  | 2025-05-16 | 2025-05-16 | 0d |  |  | Non-SIT LDSO | Non-SIT LDSO | Non-SIT LDSO Qualification | 6.23 | Ben Wickins | QAG (Non-SIT LDSO) | Complete | COMPLETE | T3-QU-0079 | T3 |  |  |
| 1927 | 1.5.13 | **Non-SIT LDSO Qualification Closure** |  | 31d | 2025-05-16 A | 2025-06-27 A |  | 100% |  | 2025-05-30 | 2025-08-22 | 49d |  | -0 | N/A | N/A | Non-SIT LDSO Qualification | 6.0 | N/A | QAG (Non-SIT LDSO) |  |  |  |  |  |  |
| 1928 | 1.5.13.1 | Non-SIT LDSO Qualification Learned Captured |  | 10d | 2025-05-16 A | 2025-05-29 A | 1926 | 100% |  | 2025-05-16 | 2025-05-29 | 15d | start no earlier than 2025-04-16 |  | Non-SIT LDSO | Non-SIT LDSO | Non-SIT LDSO Qualification | 6.23 | Ben Wickins | QAG (Non-SIT LDSO) | Complete | COMPLETE |  |  |  |  |
| 1929 | 1.5.13.2 | Non-SIT LDSO Regression Testing |  | 26d | 2025-05-16 A | 2025-06-20 A | 1926 | 100% |  | 2025-05-16 | 2025-06-20 | 0d |  |  | Non-SIT LDSO |  | Non-SIT LDSO Qualification | 6.23 | Ben Wickins | QAG (Non-SIT LDSO) | Complete | COMPLETE |  |  |  |  |
| 1930 | 1.5.13.3 | Non-SIT LDSO Qualification Closure Down |  | 5d | 2025-06-23 A | 2025-06-27 A | 1929 | 100% |  | 2025-06-23 | 2025-06-27 | 5d | finish no earlier than 2025-06-26 |  | Non-SIT LDSO | Non-SIT LDSO | Non-SIT LDSO Qualification | 6.23 | Ben Wickins | QAG (Non-SIT LDSO) | Complete | COMPLETE |  |  |  |  |
| 1931 | 1.6 | **HELIX / ELEXON M10 READINESS** |  | 837d? | 2022-10-31 | 2026-01-13 A |  | 100% | 2024-04-02 | 2025-03-03 | 2025-09-01 | 0d |  |  | Helix |  | Helix / Elexon M10 Readiness | 6.26 | Helix | Helix Programme Board |  |  |  |  | -918.67 |  |
| 1932 | 1.6.1 | **Service Management - M10 Readiness** |  | 147d | 2025-03-03 A | 2025-09-24 A |  | 100% |  | 2025-03-03 | 2025-09-01 | 0d |  |  | Helix |  | Helix / Elexon M10 Readiness | 6.24 | Helix | Helix Programme Board |  |  |  |  |  |  |
| 1933 | 1.6.1.1 | **Service Model Design (Cross Party Service Desk)** |  | 135d | 2025-03-03 A | 2025-09-05 A |  | 100% |  | 2025-03-03 | 2025-07-15 | 0d |  |  | Helix |  | Helix / Elexon M10 Readiness | 6.24 | Helix | Helix Programme Board | No BL |  |  |  | 0.33 | Service Model Design (Cross Party Service Desk) |
| 1934 | 1.6.1.1.1 | **Cross Party Service Desk** |  | 55d | 2025-03-03 A | 2025-05-19 A |  | 100% |  | 2025-03-03 | 2025-07-01 | 0d |  |  | Helix |  | Helix / Elexon M10 Readiness | 6.24 | Helix | Helix Programme Board |  |  |  |  |  | Service Model Design (Cross Party Service Desk) |
| 1935 | 1.6.1.1.1.1 | Cross Party Service Desk Definition and Design |  | 24d | 2025-03-03 A | 2025-04-03 A |  | 100% |  | 2025-03-03 | 2025-04-03 | 0d |  |  | Helix |  | Helix / Elexon M10 Readiness | 6.24 | Helix | Helix Programme Board | Complete | COMPLETE |  |  |  | Service Model Design (Cross Party Service Desk) |
| 1936 | 1.6.1.1.1.2 | Cross Party Service Desk Design Document MHHS Review | milestone | 0d | 2025-04-03 A | 2025-04-03 A | 1935 | 100% |  | 2025-04-03 | 2025-04-03 | 0d | start no earlier than 2025-04-03 |  | Helix |  | Helix / Elexon M10 Readiness | 6.24 | Helix | Helix Programme Board | Complete | COMPLETE |  |  |  | Service Model Design (Cross Party Service Desk) |
| 1937 | 1.6.1.1.1.3 | Cross Party Service Desk Model Issued | milestone | 0d | 2025-04-07 A | 2025-04-07 A | 1936 | 100% |  | 2025-04-07 | 2025-04-07 | 0d | start no earlier than 2025-04-07 |  | Helix |  | Helix / Elexon M10 Readiness | 6.24 | Helix | Helix Programme Board | Complete | COMPLETE |  |  |  | Service Model Design (Cross Party Service Desk) |
| 1938 | 1.6.1.1.1.4 | Cross Party Service Desk Model Reissued | milestone | 0d | 2025-04-15 A | 2025-04-15 A | 1937 | 100% |  | 2025-04-15 | 2025-04-15 | 0d | start no earlier than 2025-04-15 |  | Helix |  | Helix / Elexon M10 Readiness | 6.24 | Helix | Helix Programme Board | Complete | COMPLETE |  |  |  | Service Model Design (Cross Party Service Desk) |
| 1939 | 1.6.1.1.1.5 | **Cross Party Service Desk Consultation** |  | 30d | 2025-04-07 A | 2025-05-19 A |  | 100% |  | 2025-04-07 | 2025-07-01 | 0d |  |  | Helix |  | Helix / Elexon M10 Readiness | 6.24 | Helix | Helix Programme Board |  |  |  |  |  | Service Model Design (Cross Party Service Desk) |
| 1940 | 1.6.1.1.1.5.1 | Cross Party Service Desk Consultation |  | 16d | 2025-04-07 A | 2025-04-28 A | 1936, 1938FF | 100% |  | 2025-04-07 | 2025-04-28 | 0d | finish no earlier than 2025-04-28 |  | Helix |  | Helix / Elexon M10 Readiness | 6.24 | Helix | Helix Programme Board | Complete | COMPLETE |  |  |  | Service Model Design (Cross Party Service Desk) |
| 1941 | 1.6.1.1.1.5.2 | Cross Party Service Desk Consultation Completed | milestone | 0d | 2025-04-28 A | 2025-04-28 A | 1940 | 100% |  | 2025-04-28 | 2025-04-28 | 0d | start no earlier than 2025-03-28 |  | Helix |  | Helix / Elexon M10 Readiness | 6.24 | Helix | Helix Programme Board | Complete | COMPLETE |  |  |  | Service Model Design (Cross Party Service Desk) |
| 1942 | 1.6.1.1.1.5.3 | Cross Party Service Desk Model Updates (Feedback Review) |  | 8d | 2025-04-29 A | 2025-05-08 A | 1941 | 100% |  | 2025-04-29 | 2025-05-08 | 0d | start no earlier than 2025-04-23 |  | Helix |  | Helix / Elexon M10 Readiness | 6.24 | Helix | Helix Programme Board | Complete | COMPLETE |  |  |  | Service Model Design (Cross Party Service Desk) |
| 1943 | 1.6.1.1.1.5.4 | Cross Party Service Desk Model Spotlight at Elexon Service Management Steering Group | milestone | 0d | 2025-05-07 A | 2025-05-07 A | 1942FF-1d | 100% |  | 2025-05-07 | 2025-05-07 | 0d | start no earlier than 2025-05-07 |  | Helix |  | Helix / Elexon M10 Readiness | 6.24 | Helix | Helix Programme Board | Complete | COMPLETE |  |  |  | Service Model Design (Cross Party Service Desk) |
| 1944 | 1.6.1.1.1.5.5 | Updated Consultation Documents Shared with MHHS and Industry | milestone | 0d | 2025-05-08 A | 2025-05-08 A | 1942 | 100% |  | 2025-05-08 | 2025-05-08 | 0d | start no earlier than 2025-04-14 |  | Helix |  | Helix / Elexon M10 Readiness | 6.24 | Helix | Helix Programme Board | Complete | COMPLETE |  |  |  | Service Model Design (Cross Party Service Desk) |
| 1945 | 1.6.1.1.1.5.6 | TORWG Post-Consultation Update (CPSD) | milestone | 0d | 2025-05-14 A | 2025-05-14 A | 1944 | 100% |  | 2025-05-14 | 2025-05-14 | 0d | start no earlier than 2025-05-14 |  | Helix |  | Helix / Elexon M10 Readiness | 6.24 | Helix | Helix Programme Board | Complete | COMPLETE |  |  |  | Service Model Design (Cross Party Service Desk) |
| 1946 | 1.6.1.1.1.5.7 | Updated Consultation Documents Released to Industry for eTORWG | milestone | 0d | 2025-05-16 A | 2025-05-16 A | 1945FS+3d | 100% |  | 2025-05-16 | 2025-05-16 | 0d |  |  | Helix |  | Helix / Elexon M10 Readiness | 6.24 | Helix | Helix Programme Board | Complete | COMPLETE |  |  |  | Service Model Design (Cross Party Service Desk) |
| 1947 | 1.6.1.1.1.5.8 | CPSD, Operating Hours & Triage Updates Endorsement (eTORWG) | milestone | 0d | 2025-05-19 A | 2025-05-19 A | 1946 | 100% |  | 2025-05-20 | 2025-05-20 | 0d | start no earlier than 2025-05-19 |  | Helix |  | Helix / Elexon M10 Readiness | 6.24 | Helix | Helix Programme Board | Complete | COMPLETE |  |  |  | Service Model Design (Cross Party Service Desk) |
| 1948 | 1.6.1.1.1.6 | Cross Party Service Desk Model Completed | milestone | 0d | 2025-05-19 A | 2025-05-19 A | 1947 | 100% |  | 2025-05-20 | 2025-05-20 | 0d | start no earlier than 2025-03-28 |  | Helix |  | Helix / Elexon M10 Readiness | 6.24 | Helix | Helix Programme Board | Complete | COMPLETE |  |  |  | Service Model Design (Cross Party Service Desk) |

| ID | WBS | Task | Type | Duration | Start | Finish | Predecessors | Complete | Baseline start | Baseline finish | Baseline duration | Constraint | Responsible | Text9 | Task Status | Update Version | Sched Status | MHHS Resource Name | Previous RAG | Text29 | RAG |
| --- | --- | --- | --- | --- | --- | --- | --- | --- | --- | --- | --- | --- | --- | --- | --- | --- | --- | --- | --- | --- | --- |
| 1949 | 1.6.1.1.2 | **Service Documentation** |  | 77d | 2025-04-29 A | 2025-08-13 A |  | 100% | 2025-04-29 | 2025-07-15 | 0d |  | Helix | Helix / Elexon M10 Readiness | 0.33 | 6.24 | No BL | Helix | Service Model Design (Cross Party Service Desk) | Helix Programme Board |  |
| 1950 | 1.6.1.1.2.1 | Operations Manual Updates Post-Consultation |  | 13d | 2025-04-29 A | 2025-05-15 A | 1941 | 100% | 2025-04-29 | 2025-05-15 | 0d | start no earlier than 2025-04-23 | Helix | Helix / Elexon M10 Readiness |  | 6.24 | Complete | Helix | Service Model Design (Cross Party Service Desk) | Helix Programme Board | COMPLETE |
| 1951 | 1.6.1.1.2.2 | Operations Manual Version 1.3 (TORWG) | milestone | 0d | 2025-05-15 A | 2025-05-15 A | 1950 | 100% | 2025-05-15 | 2025-05-15 | 0d |  | Helix | Helix / Elexon M10 Readiness |  | 6.28 | Complete | Helix | Service Model Design (Cross Party Service Desk) | Helix Programme Board | COMPLETE |
| 1952 | 1.6.1.1.2.3 | Operations Manual Updates Pre-ORT |  | 14d | 2025-05-16 A | 2025-06-04 A | 1951 | 100% | 2025-06-04 | 2025-06-04 | 0d | start no earlier than 2025-05-16 | Helix | Helix / Elexon M10 Readiness |  | 6.26 | Complete | Helix |  | Helix Programme Board | COMPLETE |
| 1953 | 1.6.1.1.2.4 | Operations Manual version 1.4 (ORT) (TORWG Paper Day) | milestone | 0d | 2025-06-04 A | 2025-06-04 A |  | 100% | 2025-06-11 | 2025-06-11 | 0d | start no earlier than 2025-06-04 | Helix | Helix / Elexon M10 Readiness |  | 6.26 | Complete | Helix |  | Helix Programme Board | COMPLETE |
| 1954 | 1.6.1.1.2.5 | Service User LLSD Updates Post Consultation |  | 13d | 2025-05-19 A | 2025-06-04 A |  | 100% | 2025-05-19 | 2025-06-04 | 0d | start no earlier than 2025-05-19 | Helix | Helix / Elexon M10 Readiness |  | 6.26 | Complete | Helix |  | Helix Programme Board | COMPLETE |
| 1955 | 1.6.1.1.2.6 | Service User LLSD Version 1.2 (ORT) (TORWG Paper Day) | milestone | 0d | 2025-06-04 A | 2025-06-04 A | 1953 | 100% | 2025-06-04 | 2025-06-04 | 0d |  | Helix | Helix / Elexon M10 Readiness |  | 6.26 | Complete | Helix |  | Helix Programme Board | COMPLETE |
| 1956 | 1.6.1.1.2.7 | CPSD Scenarios and Runbook |  | 19d | 2025-04-29 A | 2025-05-23 A |  | 100% | 2025-04-29 | 2025-05-23 | 0d | start no earlier than 2025-04-29 | Helix | Helix / Elexon M10 Readiness |  | 6.26 | Complete | Helix |  | Helix Programme Board | COMPLETE |
| 1957 | 1.6.1.1.2.8 | CPSD Scenarios and Runbook Shared with MHHS Team for Review | milestone | 0d | 2025-05-23 A | 2025-05-23 A | 1956 | 100% | 2025-05-23 | 2025-05-23 | 0d |  | Helix | Helix / Elexon M10 Readiness |  | 6.26 | Complete | Helix |  | Helix Programme Board | COMPLETE |
| 1958 | 1.6.1.1.2.9 | CPSD Scenarios and Runbook Review Window |  | 8d | 2025-05-26 A | 2025-06-04 A | 1957 | 100% | 2025-05-26 | 2025-06-04 | 0d |  | Helix | Helix / Elexon M10 Readiness |  | 6.26 | Complete | Helix |  | Helix Programme Board | COMPLETE |
| 1959 | 1.6.1.1.2.10 | CPSD Scenarios and Runbook Released for TORWG (Paper Day) | milestone | 0d | 2025-06-04 A | 2025-06-04 A | 1958 | 100% | 2025-06-04 | 2025-06-04 | 0d |  | Helix | Helix / Elexon M10 Readiness |  | 6.26 | Complete | Helix |  | Helix Programme Board | COMPLETE |
| 1960 | 1.6.1.1.2.11 | Parent/Child Industry Engagement Session | milestone | 0d | 2025-06-06 A | 2025-06-06 A | 1959 | 100% | 2025-06-06 | 2025-06-06 | 0d | start no earlier than 2025-06-06 | Helix | Helix / Elexon M10 Readiness |  | 6.26 | Complete | Helix |  | Helix Programme Board | COMPLETE |
| 1961 | 1.6.1.1.2.12 | CPSD Runbook Completed | milestone | 0d | 2025-06-11 A | 2025-06-11 A | 1959FS+5d | 100% | 2025-06-11 | 2025-06-11 | 0d |  | Helix | Helix / Elexon M10 Readiness |  | 6.26 | Complete | Helix |  | Helix Programme Board | COMPLETE |
| 1962 | 1.6.1.1.2.13 | **Service Documentation V2** |  | 23d | 2025-07-14 A | 2025-08-13 A |  | 100% | 2025-07-14 | 2025-08-13 | 0d |  | Helix |  | -973.67 | 6.28 |  | Helix |  | Helix Programme Board |  |
| 1963 | 1.6.1.1.2.13.1 | Post-ORT Operations Manual and LLSD Updates |  | 3d | 2025-07-14 A | 2025-07-16 A | 1951, 2019 | 100% | 2025-07-14 | 2025-07-16 | 0d | start no earlier than 2025-07-14 | Helix | Helix / Elexon M10 Readiness |  | 6.28 | Complete | Helix | Service Model Design (Cross Party Service Desk) | Helix Programme Board | COMPLETE |
| 1964 | 1.6.1.1.2.13.2 | M10 Operations Manual Version 2.0 & LLSD Issued for Consultation | milestone | 0d | 2025-07-16 A | 2025-07-16 A | 1963 | 100% | 2025-07-16 | 2025-07-16 | 0d | start no earlier than 2025-04-01 | Helix | Helix / Elexon M10 Readiness |  | 6.28 | Complete | Helix | Service Model Design (Cross Party Service Desk) | Helix Programme Board | COMPLETE |
| 1965 | 1.6.1.1.2.13.3 | Operations Manual and LLSD v2 Consultation |  | 10d | 2025-07-17 A | 2025-07-30 A | 1964 | 100% | 2025-07-17 | 2025-07-30 | 0d |  | PP | Helix / Elexon M10 Readiness |  | 6.28 | Complete | Helix |  | Helix Programme Board | COMPLETE |
| 1966 | 1.6.1.1.2.13.4 | Operations Manual and LLSD v2 Consultation Completed | milestone | 0d | 2025-07-30 A | 2025-07-30 A | 1965 | 100% | 2025-07-30 | 2025-07-30 | 0d |  | Helix | Helix / Elexon M10 Readiness |  | 6.28 | Complete | Helix |  | Helix Programme Board | COMPLETE |
| 1967 | 1.6.1.1.2.13.5 | Consultation Feedback Implemented Operations Manual and LLSD v2 |  | 5d | 2025-07-31 A | 2025-08-06 A | 1966 | 100% | 2025-07-31 | 2025-08-06 | 0d |  | Helix | Helix / Elexon M10 Readiness |  | 6.28 | Complete | Helix |  | Helix Programme Board | COMPLETE |
| 1968 | 1.6.1.1.2.13.6 | Operations Manual and LLSD v2 Feedback Implemented | milestone | 0d | 2025-08-06 A | 2025-08-06 A | 1967 | 100% | 2025-08-06 | 2025-08-06 | 0d |  | Helix | Helix / Elexon M10 Readiness |  | 6.28 | Complete | Helix |  | Helix Programme Board | COMPLETE |
| 1969 | 1.6.1.1.2.13.7 | TORWG Paper Day | milestone | 0d | 2025-08-06 A | 2025-08-06 A | 1968 | 100% | 2025-08-06 | 2025-08-06 | 0d |  | Helix | Helix / Elexon M10 Readiness |  | 6.28 | Complete | Helix |  | Helix Programme Board | COMPLETE |
| 1970 | 1.6.1.1.2.13.8 | TORWG Operations Manual and LLSD v2 Approval | milestone | 0d | 2025-08-13 A | 2025-08-13 A | 1969FS+5d | 100% | 2025-08-13 | 2025-08-13 | 0d |  | Helix | Helix / Elexon M10 Readiness |  | 6.28 | Complete | Helix |  | Helix Programme Board | COMPLETE |
| 1971 | 1.6.1.1.2.13.9 | Operations Manual and LLSD v2 Approved and Completed | milestone | 0d | 2025-08-13 A | 2025-08-13 A | 1970 | 100% | 2025-08-13 | 2025-08-13 | 0d |  | Helix | Helix / Elexon M10 Readiness |  | 6.28 | Complete | Helix |  | Helix Programme Board | COMPLETE |
| 1972 | 1.6.1.1.3 | **LDSO Onboarding - Phase 1** |  | 28d | 2025-06-23 A | 2025-07-30 A |  | 100% | 2025-06-23 | 2025-07-30 | 0d |  | Helix | 08/07/25 - Activity added | -980.67 | 6.29 |  | Helix |  | Helix Programme Board |  |
| 1973 | 1.6.1.1.3.1 | LDSO Communication and Information Gathering - Phase 1 |  | 18d | 2025-06-23 A | 2025-07-16 A |  | 100% | 2025-06-23 | 2025-07-11 | 0d | start no earlier than 2025-06-23 | Helix | 08/07/25 - Activity added |  | 6.29 | Complete | Helix |  | Helix Programme Board | COMPLETE |
| 1974 | 1.6.1.1.3.2 | LDSO Communication and Information Gathering Completed - Phase 1 | milestone | 0d | 2025-07-16 A | 2025-07-16 A |  | 100% | 2025-07-16 | 2025-07-16 | 0d | start no earlier than 2025-07-16 | Helix |  |  | 6.30 | Complete | Helix |  | Helix Programme Board | COMPLETE |
| 1975 | 1.6.1.1.3.3 | LDSO ServiceNow Configuration - Phase 1/2 |  | 10d | 2025-07-10 A | 2025-07-23 A | 1973SS+13d | 100% | 2025-07-10 | 2025-07-23 | 0d |  | Helix | 08/07/25 - Activity added |  | 6.29 | Complete | Helix |  | Helix Programme Board | COMPLETE |
| 1976 | 1.6.1.1.3.4 | LDSO ServiceNow Configuration Completed - Phase 1/2 | milestone | 0d | 2025-07-16 A | 2025-07-16 A |  | 100% | 2025-07-16 | 2025-07-16 | 0d | finish no earlier than 2025-07-16 | Helix |  |  | 6.30 | Complete | Helix |  | Helix Programme Board | COMPLETE |
| 1977 | 1.6.1.1.3.5 | LDSO Testing and Further Communication - Phase 1 |  | 6d | 2025-07-23 A | 2025-07-30 A | 1975SS+9d | 100% | 2025-07-23 | 2025-07-30 | 0d |  | Helix | 08/07/25 - Activity added |  | 6.29 | Complete | Helix |  | Helix Programme Board | COMPLETE |
| 1978 | 1.6.1.1.3.6 | LDSO Testing and Further Communication Completed - Phase 1 | milestone | 0d | 2025-07-30 A | 2025-07-30 A |  | 100% | 2025-07-30 | 2025-07-30 | 0d | start no earlier than 2025-07-30 | Helix |  |  | 6.30 | Complete | Helix |  | Helix Programme Board | COMPLETE |
| 1979 | 1.6.1.1.3.7 | LDSOs Onboarded into Elexon ServiceNow - Phase 1 | milestone | 0d | 2025-07-30 A | 2025-07-30 A | 1977 | 100% | 2025-07-30 | 2025-07-30 | 0d |  | Helix | 08/07/25 - Activity added |  | 6.29 | Complete | Helix |  | Helix Programme Board | COMPLETE |

| ID | WBS | Task | Type | Duration | Start | Finish | Predecessors | Complete | Baseline start | Baseline finish | Baseline duration | Constraint | Responsible | Task Status | Update Version | MHHS Resource Name | Text29 | Sched Status | RAG | Text9 | Previous RAG |
| --- | --- | --- | --- | --- | --- | --- | --- | --- | --- | --- | --- | --- | --- | --- | --- | --- | --- | --- | --- | --- | --- |
| 1980 | 1.6.1.1.4 | **LDSO Onboarding - Phase 2** |  | 27d | 2025-07-31 A | 2025-09-05 A |  | 100% | 2025-07-31 | 2025-09-05 | 0d |  | Helix | -1002.67 | 6.30 | Helix | Helix Programme Board |  |  |  |  |
| 1981 | 1.6.1.1.4.1 | LDSO Resources Enrolled in Authenticator - Phase 2 |  | 20d | 2025-07-31 A | 2025-08-27 A |  | 100% | 2025-07-31 | 2025-08-27 | 0d | start no earlier than 2025-07-31 | Helix |  | 6.30 | Helix | Helix Programme Board | Complete | COMPLETE |  |  |
| 1982 | 1.6.1.1.4.2 | LDSO Resources Enrolled in Authenticator Completed - Phase 2 | milestone | 0d | 2025-08-27 A | 2025-08-27 A |  | 100% | 2025-08-27 | 2025-08-27 | 0d | start no earlier than 2025-08-27 | Helix |  | 6.30 | Helix | Helix Programme Board | Complete | COMPLETE |  |  |
| 1983 | 1.6.1.1.4.3 | Elexon Phase 2 Resources Setup in Portal - Phase 2 |  | 7d | 2025-08-28 A | 2025-09-05 A | 1981 | 100% | 2025-08-28 | 2025-09-05 | 0d |  | Helix |  | 6.30 | Helix | Helix Programme Board | Complete | COMPLETE |  |  |
| 1984 | 1.6.1.1.4.4 | Elexon Phase 2 Resources Setup in Portal Completed - Phase 2 | milestone | 0d | 2025-09-05 A | 2025-09-05 A | 1983 | 100% | 2025-09-05 | 2025-09-05 | 0d |  | Helix |  | 6.30 | Helix | Helix Programme Board | Complete | COMPLETE |  |  |
| 1985 | 1.6.1.2 | **Operational Readiness Testing** |  | 116d | 2025-03-03 A | 2025-08-12 A |  | 100% | 2025-03-03 | 2025-07-21 | 0d |  | Helix | 0.33 | 6.24 | Helix | Helix Programme Board | No BL |  | Helix / Elexon M10 Readiness | Operational Readiness Testing |
| 1986 | 1.6.1.2.1 | **ORT Design** |  | 72d | 2025-03-03 A | 2025-06-10 A |  | 100% | 2025-03-03 | 2025-06-10 | 0d |  | Helix |  | 6.24 | Helix | Helix Programme Board |  |  | Helix / Elexon M10 Readiness | Operational Readiness Testing |
| 1987 | 1.6.1.2.1.1 | ORT Test Scope and Approach |  | 25d | 2025-03-03 A | 2025-04-04 A | 1935FF | 100% | 2025-03-03 | 2025-04-04 | 0d | start no earlier than 2025-03-03 | Helix |  | 6.24 | Helix | Helix Programme Board | Complete | COMPLETE | Helix / Elexon M10 Readiness | Operational Readiness Testing |
| 1988 | 1.6.1.2.1.2 | ORT Test Approach Shared with MHHS (Initial Review) | milestone | 0d | 2025-04-02 A | 2025-04-02 A | 1987FS-3d | 100% | 2025-04-02 | 2025-04-02 | 0d | start no earlier than 2025-04-02 | Helix |  | 6.24 | Helix | Helix Programme Board | Complete | COMPLETE | Helix / Elexon M10 Readiness | Operational Readiness Testing |
| 1989 | 1.6.1.2.1.3 | ORT Test Scenarios Shared with MHHS (Initial Review) | milestone | 0d | 2025-04-02 A | 2025-04-02 A | 1987FS-3d | 100% | 2025-04-02 | 2025-04-02 | 0d | start no earlier than 2025-04-02 | Helix |  | 6.24 | Helix | Helix Programme Board | Complete | COMPLETE | Helix / Elexon M10 Readiness | Operational Readiness Testing |
| 1990 | 1.6.1.2.1.4 | ORT Test Scope and Approach Documents Shared with Industry | milestone | 0d | 2025-04-07 A | 2025-04-07 A | 1989 | 100% | 2025-04-07 | 2025-04-07 | 0d | start no earlier than 2025-04-07 | Helix |  | 6.24 | Helix | Helix Programme Board | Complete | COMPLETE | Helix / Elexon M10 Readiness | Operational Readiness Testing |
| 1991 | 1.6.1.2.1.5 | **ORT Test Scope and Approach Consultation (Test Scope and Approach & Test Scripts)** |  | 29d | 2025-04-08 A | 2025-05-19 A |  | 100% | 2025-04-08 | 2025-05-20 | 0d |  | Helix |  | 6.24 | Helix | Helix Programme Board |  |  | Helix / Elexon M10 Readiness | Operational Readiness Testing |
| 1992 | 1.6.1.2.1.5.1 | ORT Test Scope and Approach Consultation |  | 15d | 2025-04-08 A | 2025-04-28 A | 1990 | 100% | 2025-04-08 | 2025-04-28 | 0d | finish no earlier than 2025-04-28 | PP |  | 6.24 | Helix | Helix Programme Board | Complete | COMPLETE | Helix / Elexon M10 Readiness | Operational Readiness Testing |
| 1993 | 1.6.1.2.1.5.2 | ORT Test Scope and Approach Consultation Completed | milestone | 0d | 2025-04-28 A | 2025-04-28 A | 1992 | 100% | 2025-04-28 | 2025-04-28 | 0d | start no earlier than 2025-03-28 | Helix |  | 6.24 | Helix | Helix Programme Board | Complete | COMPLETE | Helix / Elexon M10 Readiness | Operational Readiness Testing |
| 1994 | 1.6.1.2.1.5.3 | ORT Test Scope and Approach Updates (Feedback Review) |  | 8d | 2025-04-29 A | 2025-05-08 A | 1993 | 100% | 2025-04-29 | 2025-05-08 | 0d | start no earlier than 2025-04-14 | Helix |  | 6.24 | Helix | Helix Programme Board | Complete | COMPLETE | Helix / Elexon M10 Readiness | Operational Readiness Testing |
| 1995 | 1.6.1.2.1.5.4 | Updated ORT Test Scope and Approach Documents Shared with MHHS and Industry | milestone | 0d | 2025-05-08 A | 2025-05-08 A | 1994 | 100% | 2025-05-08 | 2025-05-08 | 0d | start no earlier than 2025-04-14 | Helix |  | 6.24 | Helix | Helix Programme Board | Complete | COMPLETE | Helix / Elexon M10 Readiness | Operational Readiness Testing |
| 1996 | 1.6.1.2.1.5.5 | TORWG Post-Consultation Update (ORT Approach) | milestone | 0d | 2025-05-14 A | 2025-05-14 A | 1995 | 100% | 2025-05-14 | 2025-05-14 | 0d | start no earlier than 2025-05-14 | Helix |  | 6.24 | Helix | Helix Programme Board | Complete | COMPLETE | Helix / Elexon M10 Readiness | Operational Readiness Testing |
| 1997 | 1.6.1.2.1.5.6 | Updated ORT Test Scope and Approach Documents Released to Industry for eSITWG | milestone | 0d | 2025-05-16 A | 2025-05-16 A | 1995, 1996 | 100% | 2025-05-16 | 2025-05-16 | 0d | start no earlier than 2025-05-16 | Helix |  | 6.24 | Helix | Helix Programme Board | Complete | COMPLETE | Helix / Elexon M10 Readiness | Operational Readiness Testing |
| 1998 | 1.6.1.2.1.5.7 | ORT Test Scope and Approach Endorsement (eSITWG) | milestone | 0d | 2025-05-19 A | 2025-05-19 A | 1997 | 100% | 2025-05-20 | 2025-05-20 | 0d | start no earlier than 2025-05-19 | Helix |  | 6.24 | Helix | Helix Programme Board | Complete | COMPLETE | Helix / Elexon M10 Readiness | Operational Readiness Testing |
| 1999 | 1.6.1.2.1.6 | ORT Test Script Production and Updates |  | 23d | 2025-04-08 A | 2025-05-08 A | 1993FF, 1994FF, 1940FF | 100% | 2025-04-08 | 2025-05-08 | 0d | start no earlier than 2025-04-07 | Helix |  | 6.24 | Helix | Helix Programme Board | Complete | COMPLETE | Helix / Elexon M10 Readiness | Operational Readiness Testing |
| 2000 | 1.6.1.2.1.7 | ORT Test Scripts Shared | milestone | 0d | 2025-05-08 A | 2025-05-08 A | 1999 | 100% | 2025-05-08 | 2025-05-08 | 0d | start no earlier than 2025-05-07 | Helix |  | 6.24 | Helix | Helix Programme Board | Complete | COMPLETE | Helix / Elexon M10 Readiness | Operational Readiness Testing |
| 2001 | 1.6.1.2.1.8 | **ORT Test Scripts Consultation** |  | 25d | 2025-05-07 A | 2025-06-10 A |  | 100% | 2025-05-07 | 2025-06-10 | 0d |  | Helix |  | 6.24 | Helix | Helix Programme Board |  |  | Helix / Elexon M10 Readiness | Operational Readiness Testing |
| 2002 | 1.6.1.2.1.8.1 | ORT Spotlight (Test Approach) at Elexon Service Management Helix Steering Group | milestone | 0d | 2025-05-07 A | 2025-05-07 A |  | 100% | 2025-05-07 | 2025-05-07 | 0d | start no earlier than 2025-05-07 | Helix |  | 6.24 | Helix | Helix Programme Board | Complete | COMPLETE | Helix / Elexon M10 Readiness | Operational Readiness Testing |
| 2003 | 1.6.1.2.1.8.2 | ORT Test Scripts Consultation |  | 6d | 2025-05-09 A | 2025-05-16 A | 1999, 2000 | 100% | 2025-05-09 | 2025-05-15 | 0d | start no earlier than 2025-05-01 | PP |  | 6.24 | Helix | Helix Programme Board | Complete | COMPLETE | Helix / Elexon M10 Readiness | Operational Readiness Testing |
| 2004 | 1.6.1.2.1.8.3 | ORT Test Scripts Consultation Completed | milestone | 0d | 2025-05-16 A | 2025-05-16 A | 2003 | 100% | 2025-05-15 | 2025-05-15 | 0d | start no earlier than 2025-03-28 | Helix |  | 6.24 | Helix | Helix Programme Board | Complete | COMPLETE | Helix / Elexon M10 Readiness | Operational Readiness Testing |
| 2005 | 1.6.1.2.1.8.4 | ORT Test Scripts Updates (Feedback Review) |  | 4d | 2025-05-19 A | 2025-05-22 A | 2004 | 100% | 2025-05-16 | 2025-05-22 | 0d | start no earlier than 2025-04-02 | Helix |  | 6.24 | Helix | Helix Programme Board | Complete | COMPLETE | Helix / Elexon M10 Readiness | Operational Readiness Testing |
| 2006 | 1.6.1.2.1.8.5 | ORT Test Scipts Updates Shared with MHHS and Industry | milestone | 0d | 2025-05-22 A | 2025-05-22 A | 2005 | 100% | 2025-05-22 | 2025-05-22 | 0d | start no earlier than 2025-04-14 | Helix |  | 6.24 | Helix | Helix Programme Board | Complete | COMPLETE | Helix / Elexon M10 Readiness | Operational Readiness Testing |
| 2007 | 1.6.1.2.1.8.6 | Industry Assurance Review Session Post-Consultation Update (ORT Test Scripts) | milestone | 0d | 2025-05-30 A | 2025-05-30 A | 2006FS+6d | 100% | 2025-05-30 | 2025-05-30 | 0d | start no earlier than 2025-04-14 | Helix |  | 6.24 | Helix | Helix Programme Board | Complete | COMPLETE | Helix / Elexon M10 Readiness | Operational Readiness Testing |
| 2008 | 1.6.1.2.1.8.7 | Updated ORT Test Script Consultation Documents Released to industry for eSITWG | milestone | 0d | 2025-06-03 A | 2025-06-03 A | 2007FS+2d | 100% | 2025-06-03 | 2025-06-03 | 0d | start no earlier than 2025-04-04 | Helix |  | 6.24 | Helix | Helix Programme Board | Complete | COMPLETE | Helix / Elexon M10 Readiness | Operational Readiness Testing |
| 2009 | 1.6.1.2.1.8.8 | ORT Test Scripts and Readiness Spotlight at Elexon Service Management Steering Group | milestone | 0d | 2025-06-04 A | 2025-06-04 A | 2008FS+1d | 100% | 2025-06-04 | 2025-06-04 | 0d | start no earlier than 2025-04-22 | Helix |  | 6.24 | Helix | Helix Programme Board | Complete | COMPLETE | Helix / Elexon M10 Readiness | Operational Readiness Testing |
| 2010 | 1.6.1.2.1.8.9 | ORT Test Scipt Updates Endorsement (eSITWG) | milestone | 0d | 2025-06-10 A | 2025-06-10 A | 2008FS+5d | 100% | 2025-06-10 | 2025-06-10 | 0d | start no earlier than 2025-04-14 | SITWG |  | 6.24 | Helix | Helix Programme Board | Complete | COMPLETE | Helix / Elexon M10 Readiness | Operational Readiness Testing |

| ID | WBS | Task | Type | Duration | Start | Finish | Predecessors | Complete | Baseline start | Baseline finish | Baseline duration | Constraint | Responsible | Text9 | Update Version | MHHS Resource Name | Previous RAG | Text29 | Sched Status | RAG | Task Status | Issue |
| --- | --- | --- | --- | --- | --- | --- | --- | --- | --- | --- | --- | --- | --- | --- | --- | --- | --- | --- | --- | --- | --- | --- |
| 2011 | 1.6.1.2.2 | **ORT Preparation** |  | 32d | 2025-05-01 A | 2025-06-13 A |  | 100% | 2025-05-01 | 2025-06-03 | 0d |  | Helix | Helix / Elexon M10 Readiness | 6.24 | Helix | Operational Readiness Testing | Helix Programme Board |  |  |  |  |
| 2012 | 1.6.1.2.2.1 | ORT Participant/User Scheduling |  | 24d | 2025-05-01 A | 2025-06-03 A |  | 100% | 2025-05-01 | 2025-05-16 | 0d | start no earlier than 2025-05-01 | Helix | Helix / Elexon M10 Readiness | 6.24 | Helix | Operational Readiness Testing | Helix Programme Board | Complete | COMPLETE |  |  |
| 2013 | 1.6.1.2.2.2 | ORT Participant/User Scheduling Completed | milestone | 0d | 2025-06-03 A | 2025-06-03 A | 2012 | 100% | 2025-05-16 | 2025-05-16 | 0d | start no earlier than 2025-03-28 | Helix | Helix / Elexon M10 Readiness | 6.24 | Helix | Operational Readiness Testing | Helix Programme Board | Complete | COMPLETE |  |  |
| 2014 | 1.6.1.2.2.3 | ORT Training and Preparation |  | 6d | 2025-06-04 A | 2025-06-11 A | 1992, 1999, 2002, 2006 | 100% | 2025-06-04 | 2025-06-11 | 0d | start no earlier than 2025-06-04 | Helix | Helix / Elexon M10 Readiness | 6.24 | Helix | Operational Readiness Testing | Helix Programme Board | Complete | COMPLETE |  |  |
| 2015 | 1.6.1.2.2.4 | ORT DITL Session | milestone | 0d | 2025-06-12 A | 2025-06-12 A | 2004FS+2d, 2007 | 100% | 2025-06-12 | 2025-06-12 | 0d | start no earlier than 2025-06-12 | Helix | Helix / Elexon M10 Readiness | 6.24 | Helix | Operational Readiness Testing | Helix Programme Board | Complete | COMPLETE |  |  |
| 2016 | 1.6.1.2.2.5 | ORT Orientation (JiT) | milestone | 0d | 2025-06-13 A | 2025-06-13 A | 2014FS+2d | 100% | 2025-06-13 | 2025-06-13 | 0d | start no earlier than 2025-05-30 | Helix | Helix / Elexon M10 Readiness | 6.24 | Helix | Operational Readiness Testing | Helix Programme Board | Complete | COMPLETE |  |  |
| 2017 | 1.6.1.2.3 | **ORT Execution** |  | 20d | 2025-06-16 A | 2025-07-11 A |  | 100% | 2025-06-16 | 2025-07-11 | 0d |  | Helix | Helix / Elexon M10 Readiness | 6.24 | Helix | Operational Readiness Testing | Helix Programme Board |  |  |  |  |
| 2018 | 1.6.1.2.3.1 | ORT Execution |  | 20d | 2025-06-16 A | 2025-07-11 A | 2014, 2016, 1998 | 100% | 2025-06-16 | 2025-07-11 | 0d | start no earlier than 2025-06-02 | Helix | Helix / Elexon M10 Readiness | 6.24 | Helix | Operational Readiness Testing | Helix Programme Board | Complete | COMPLETE |  |  |
| 2019 | 1.6.1.2.3.2 | ORT Execution Completed | milestone | 0d | 2025-07-11 A | 2025-07-11 A | 2018 | 100% | 2025-07-11 | 2025-07-11 | 0d | start no earlier than 2025-03-28 | Helix | Helix / Elexon M10 Readiness | 6.24 | Helix | Operational Readiness Testing | Helix Programme Board | Complete | COMPLETE |  |  |
| 2020 | 1.6.1.2.4 | **ORT Exit** |  | 14d | 2025-07-14 A | 2025-07-31 A | 1998, 2005, 2008, 2012 | 100% | 2025-07-14 | 2025-07-31 | 0d |  | Helix | Helix / Elexon M10 Readiness | 6.24 | Helix | Operational Readiness Testing | Helix Programme Board |  |  |  |  |
| 2021 | 1.6.1.2.4.1 | ORT Wrap Up |  | 5d | 2025-07-14 A | 2025-07-18 A | 2019 | 100% | 2025-07-14 | 2025-07-18 | 0d | start no earlier than 2025-04-22 | Helix | Helix / Elexon M10 Readiness | 6.24 | Helix | Operational Readiness Testing | Helix Programme Board | Complete | COMPLETE |  |  |
| 2022 | 1.6.1.2.4.2 | ORT Exit Report |  | 10d | 2025-07-14 A | 2025-07-25 A | 2019 | 100% | 2025-07-14 | 2025-07-25 | 0d | start no earlier than 2025-04-02 | Helix | Helix / Elexon M10 Readiness | 6.24 | Helix | Operational Readiness Testing | Helix Programme Board | Complete | COMPLETE |  |  |
| 2023 | 1.6.1.2.4.3 | ORT Exit Report Shared with Participants | milestone | 0d | 2025-07-25 A | 2025-07-25 A | 2022 | 100% | 2025-07-25 | 2025-07-25 | 0d | start no earlier than 2025-04-22 | Helix | Helix / Elexon M10 Readiness | 6.24 | Helix | Operational Readiness Testing | Helix Programme Board | Complete | COMPLETE |  |  |
| 2024 | 1.6.1.2.4.4 | ORT eSITWG Exit Report Endorsement | milestone | 0d | 2025-07-31 A | 2025-07-31 A | 2023FS+4d | 100% | 2025-07-31 | 2025-07-31 | 0d | start no earlier than 2025-04-02 | SITWG | Helix / Elexon M10 Readiness | 6.24 | Helix | Operational Readiness Testing | Helix Programme Board | Complete | COMPLETE |  |  |
| 2025 | 1.6.1.2.5 | **Codification of Service** |  | 67d | 2025-05-09 A | 2025-08-12 A |  | 100% | 2025-05-09 | 2025-07-31 | 0d? |  | Helix | Helix / Elexon M10 Readiness | 6.26 | Helix | Codification of Service | Helix Programme Board | No BL |  | 0.33 |  |
| 2026 | 1.6.1.2.5.1 | OFGEM Review Meeting | milestone | 0d | 2025-05-09 A | 2025-05-09 A |  | 100% | 2025-05-09 | 2025-05-09 | 0d? | start no earlier than 2025-04-04 | Helix | Helix / Elexon M10 Readiness | 6.26 | Helix | Codification of Service | Helix Programme Board | Complete | COMPLETE |  |  |
| 2027 | 1.6.1.2.5.2 | Codification Update at TORWG | milestone | 0d | 2025-05-14 A | 2025-05-14 A | 2026 | 100% | 2025-05-14 | 2025-05-14 | 0d? | start no earlier than 2025-05-14 | Helix | Helix / Elexon M10 Readiness | 6.26 | Helix | Codification of Service | Helix Programme Board | Complete | COMPLETE |  | ADO item Required - Codification activity timeline at risk |
| 2028 | 1.6.1.2.5.3 | DIP Code Change Presented at DCAB | milestone | 0d | 2025-08-12 A | 2025-08-12 A |  | 100% |  |  |  | start no earlier than 2025-08-12 | Helix |  | 6.32 | Helix |  | Helix Programme Board | Complete | COMPLETE |  |  |
| 2029 | 1.6.1.3 | **Service Go-Live** |  | 32d | 2025-07-31 A | 2025-09-15 A |  | 100% | 2025-07-02 | 2025-09-01 | 0d |  | Helix | Helix / Elexon M10 Readiness | 6.24 | Helix | Governance Approach and Feedback Cycle | Helix Programme Board | No BL |  | 0.33 |  |
| 2030 | 1.6.1.3.1 | Service Management Ready (inc. Partners) | milestone | 0d | 2025-07-31 A | 2025-07-31 A |  | 100% | 2025-09-01 | 2025-09-01 | 0d |  | Helix | Helix / Elexon M10 Readiness | 6.30 | Helix | Governance Approach and Feedback Cycle | Helix Programme Board | Complete | COMPLETE |  |  |
| 2031 | 1.6.1.3.2 | Helix Service Management Live for LDSO DIP Onboarding | milestone | 0d | 2025-08-04 A | 2025-08-04 A | 1979 | 100% | 2025-08-04 | 2025-08-04 | 0d | start no earlier than 2025-08-04 | Helix | Helix / Elexon M10 Readiness | 6.26 | Helix |  | Helix Programme Board | Complete | COMPLETE |  |  |
| 2032 | 1.6.1.3.3 | Helix Service Management Live for MHHS Enduring Arrangements | milestone | 0d | 2025-09-15 A | 2025-09-15 A | 2039 | 100% | 2025-09-15 | 2025-09-15 | 0d | start no earlier than 2025-09-15 | Helix | Helix / Elexon M10 Readiness | 6.33 | Helix |  | Helix Programme Board | Complete | COMPLETE |  |  |
| 2033 | 1.6.1.4 | **Non-LDSO SIT PPs ServiceNow Onboarding** |  | 12d | 2025-09-05 A | 2025-09-24 A |  | 100% | 2025-08-27 | 2025-09-24 | 0d |  | Helix |  | 6.31 | Helix |  | Helix Programme Board |  |  | -1016.67 |  |
| 2034 | 1.6.1.4.1 | Pathway 2 | milestone | 0d | 2025-09-05 A | 2025-09-05 A |  | 100% | 2025-08-27 | 2025-08-27 | 0d | finish no earlier than 2025-09-05 | Helix |  | 6.31 | Helix |  | Helix Programme Board | Complete | COMPLETE |  |  |
| 2035 | 1.6.1.4.2 | Pathway 3 | milestone | 0d | 2025-09-09 A | 2025-09-09 A |  | 100% | 2025-09-09 | 2025-09-09 | 0d | start no earlier than 2025-09-09 | Helix |  | 6.31 | Helix |  | Helix Programme Board | Complete | COMPLETE |  |  |
| 2036 | 1.6.1.4.3 | Pathway 4 | milestone | 0d | 2025-09-24 A | 2025-09-24 A |  | 100% | 2025-09-24 | 2025-09-24 | 0d | start no earlier than 2025-09-24 | Helix |  | 6.31 | Helix |  | Helix Programme Board | Complete | COMPLETE |  |  |

| ID | WBS | Task | Type | Duration | Start | Finish | Predecessors | Complete | Actual start | Actual finish | Baseline start | Baseline finish | Baseline duration | Constraint | Responsible | Text9 | Task Status | Update Version | MHHS Resource Name | Text29 | Sched Status | RAG |
| --- | --- | --- | --- | --- | --- | --- | --- | --- | --- | --- | --- | --- | --- | --- | --- | --- | --- | --- | --- | --- | --- | --- |
| 2037 | 1.6.2 | **Business Readiness (inc DIP)** |  | 140d? | 2025-04-07 A | 2025-10-17 A |  | 100% |  |  | 2024-04-02 | 2025-12-02 | 0d |  | Helix | Helix / Elexon M10 Readiness | -940.67 | 6.26 | Helix | Helix Programme Board |  |  |
| 2038 | 1.6.2.1 | Knowledge Transfer triage |  | 35d? | 2025-04-28 A | 2025-06-13 A |  | 100% |  |  | 2025-04-28 | 2025-06-13 | 0d | start no earlier than 2025-04-28 | Helix | Helix / Elexon M10 Readiness |  | 6.26 | Helix | Helix Programme Board | Complete | COMPLETE |
| 2039 | 1.6.2.2 | Elexon Leading Triage |  | 56d | 2025-06-16 A | 2025-09-01 A | 2038 | 100% |  |  | 2025-06-16 | 2025-09-01 | 0d | start no earlier than 2025-06-16 | Helix | Helix / Elexon M10 Readiness |  | 6.26 | Helix | Helix Programme Board | Complete | COMPLETE |
| 2040 | 1.6.2.3 | MHHS Transition (Knowledge Transfer) |  | 64d | 2025-05-06 A | 2025-08-01 A |  | 100% |  |  | 2025-05-06 | 2025-08-01 | 0d | start no earlier than 2025-05-06 | Helix | Helix / Elexon M10 Readiness |  | 6.26 | Helix | Helix Programme Board | Complete | COMPLETE |
| 2041 | 1.6.2.4 | Artefact Handshake with MHHS | milestone | 0d | 2025-09-01 A | 2025-09-01 A | 2040 | 100% |  |  | 2025-08-01 | 2025-08-01 | 0d | finish no earlier than 2025-09-01 | Helix | Helix / Elexon M10 Readiness |  | 6.26 | Helix | Helix Programme Board | Complete | COMPLETE |
| 2042 | 1.6.2.5 | Operational Control Centre (OCC) Development |  | 85d | 2025-04-07 A | 2025-08-01 A |  | 100% |  |  | 2025-04-07 | 2025-08-01 | 0d | start no earlier than 2025-04-07 | Helix | Helix / Elexon M10 Readiness |  | 6.26 | Helix | Helix Programme Board | Complete | COMPLETE |
| 2043 | 1.6.2.6 | Operational Control Centre (OCC) Live (Service and ULT Triage) | milestone | 0d | 2025-08-04 A | 2025-08-04 A | 2042FS+1d | 100% |  |  | 2025-08-04 | 2025-08-04 | 0d |  | Helix | Helix / Elexon M10 Readiness |  | 6.28 | Helix | Helix Programme Board | Complete | COMPLETE |
| 2044 | 1.6.2.7 | Operational Control Centre (OCC) Live | milestone | 0d | 2025-08-29 A | 2025-08-29 A |  | 100% |  |  | 2025-08-29 | 2025-08-29 | 0d | finish no earlier than 2025-08-29 | Helix | Helix / Elexon M10 Readiness |  | 6.28 | Helix | Helix Programme Board | Complete | COMPLETE |
| 2045 | 1.6.2.8 | **DIP Guidance Notes** |  | 55d | 2025-05-05 A | 2025-07-18 A |  | 100% |  |  | 2025-05-05 | 2025-07-18 | 0d |  | Helix | Helix / Elexon M10 Readiness | -47.67 | 6.28 | Helix | Helix Programme Board |  |  |
| 2046 | 1.6.2.8.1 | GN/LWI creation & publication |  | 55d | 2025-05-05 A | 2025-07-18 A |  | 100% |  |  | 2025-05-05 | 2025-07-18 | 0d | start no earlier than 2025-05-05 | Helix | Helix / Elexon M10 Readiness |  | 6.28 | Helix | Helix Programme Board | Complete | COMPLETE |
| 2047 | 1.6.2.8.2 | Tranche 1 GN/LWI created & published (critical for M10) | milestone | 0d | 2025-06-20 A | 2025-06-20 A |  | 100% |  |  | 2025-06-20 | 2025-06-20 | 0d | start no earlier than 2025-06-20 | Helix | Helix / Elexon M10 Readiness |  | 6.28 | Helix | Helix Programme Board | Complete | COMPLETE |
| 2048 | 1.6.2.8.3 | Tranche 2 GN/LWI created & published | milestone | 0d | 2025-07-04 A | 2025-07-04 A |  | 100% |  |  | 2025-07-04 | 2025-07-04 | 0d | start no earlier than 2025-07-04 | Helix | Helix / Elexon M10 Readiness |  | 6.28 | Helix | Helix Programme Board | Complete | COMPLETE |
| 2049 | 1.6.2.8.4 | Tranche 3 GN/LWI created & published | milestone | 0d | 2025-07-18 A | 2025-07-18 A |  | 100% |  |  | 2025-07-18 | 2025-07-18 | 0d | start no earlier than 2025-07-18 | Helix | Helix / Elexon M10 Readiness |  | 6.28 | Helix | Helix Programme Board | Complete | COMPLETE |
| 2050 | 1.6.2.9 | DIP Reporting (M11) |  | 115d | 2025-05-12 A | 2025-10-17 A |  | 100% |  |  | 2025-05-12 | 2025-10-17 | 0d | start no earlier than 2025-05-12 | Helix | Helix / Elexon M10 Readiness |  | 6.35 | Helix | Helix Programme Board | Complete | COMPLETE |
| 2051 | 1.6.2.10 | Functional Training Execution |  | 95d | 2025-05-05 A | 2025-09-12 A |  | 100% |  |  | 2025-05-05 | 2025-08-29 | 0d | start no earlier than 2025-05-05 | Helix | Helix / Elexon M10 Readiness |  | 6.32 | Helix | Helix Programme Board | Complete | COMPLETE |
| 2052 | 1.6.3 | **DIP UIT Onboarding** |  | 837d? | 2022-10-31 | 2026-01-13 A |  | 100% | 2024-04-02 |  | 2022-10-31 | 2025-12-31 | 0d |  | Helix |  | -1016.67 | 6.31 | Helix | Helix Programme Board |  |  |
| 2053 | 1.6.3.1 | **LDSOs** |  | 0d | 2025-07-25 A | 2025-07-25 A |  | 100% |  |  | 2025-07-25 | 2025-07-25 | 0d |  | Helix |  | -1016.67 | 6.31 | Helix | Helix Programme Board |  |  |
| 2054 | 1.6.3.1.1 | Date to be Onboarded by | milestone | 0d | 2025-07-25 A | 2025-07-25 A |  | 100% |  |  | 2025-07-25 | 2025-07-25 | 0d | start no earlier than 2025-07-25 | Helix |  |  | 6.31 | Helix | Helix Programme Board | Complete | COMPLETE |
| 2055 | 1.6.3.2 | **Pathway 2** |  | 23d | 2025-07-25 A | 2025-08-27 A |  | 100% |  |  | 2025-07-25 | 2025-08-27 | 0d |  | Helix |  | -18.67 | 6.31 | Helix | Helix Programme Board |  |  |
| 2056 | 1.6.3.2.1 | Proforma Issued | milestone | 0d | 2025-07-25 A | 2025-07-25 A |  | 100% |  |  | 2025-07-25 | 2025-07-25 | 0d | start no earlier than 2025-07-25 | Helix |  |  | 6.31 | Helix | Helix Programme Board | Complete | COMPLETE |
| 2057 | 1.6.3.2.2 | Invite to Onbaord Issued | milestone | 0d | 2025-08-08 A | 2025-08-08 A |  | 100% |  |  | 2025-08-08 | 2025-08-08 | 0d | start no earlier than 2025-08-08 | Helix |  |  | 6.31 | Helix | Helix Programme Board | Complete | COMPLETE |
| 2058 | 1.6.3.2.3 | Date to be Onboarded by | milestone | 0d | 2025-08-27 A | 2025-08-27 A |  | 100% |  |  | 2025-08-27 | 2025-08-27 | 0d | start no earlier than 2025-08-27 | Helix |  |  | 6.31 | Helix | Helix Programme Board | Complete | COMPLETE |
| 2059 | 1.6.3.3 | **Pathway 3** |  | 0d | 2022-10-31 | 2022-10-31 |  | 100% | 2025-08-04 | 2025-09-09 | 2022-10-31 | 2022-10-31 | 0d |  | Helix |  | -8.67 | 6.31 | Helix | Helix Programme Board |  |  |
| 2060 | 1.6.3.3.1 | Proforma Issued | milestone | 0d | 2025-08-04 A | 2025-08-04 A |  | 100% |  |  | 2025-08-04 | 2025-08-04 | 0d | start no earlier than 2025-08-04 | Helix |  |  | 6.31 | Helix | Helix Programme Board | Complete | COMPLETE |
| 2061 | 1.6.3.3.2 | Invite to Onbaord Issued | milestone | 0d | 2025-08-18 A | 2025-08-18 A |  | 100% |  |  | 2025-08-18 | 2025-08-18 | 0d | start no earlier than 2025-08-18 | Helix |  |  | 6.31 | Helix | Helix Programme Board | Complete | COMPLETE |
| 2062 | 1.6.3.3.3 | Date to be Onboarded by | milestone | 0d | 2025-09-09 A | 2025-09-09 A |  | 100% |  |  | 2025-09-09 | 2025-09-09 | 0d | start no earlier than 2025-09-09 | Helix |  |  | 6.31 | Helix | Helix Programme Board | Complete | COMPLETE |

| ID | WBS | Task | Type | Duration | Start | Finish | Predecessors | Complete | Actual start | Actual finish | Baseline start | Baseline finish | Baseline duration | Constraint | Responsible | Task Status | Update Version | MHHS Resource Name | Text29 | Sched Status | RAG | Text9 | Previous RAG | Future RAG | Text21 |
| --- | --- | --- | --- | --- | --- | --- | --- | --- | --- | --- | --- | --- | --- | --- | --- | --- | --- | --- | --- | --- | --- | --- | --- | --- | --- |
| 2063 | 1.6.3.4 | **Pathway 4** |  | 0d | 2022-10-31 | 2022-10-31 |  | 100% | 2025-08-22 | 2025-09-24 | 2022-10-31 | 2022-10-31 | 0d |  | Helix | -1016.67 | 6.31 | Helix | Helix Programme Board |  |  |  |  |  |  |
| 2064 | 1.6.3.4.1 | Proforma Issued | milestone | 0d | 2025-08-22 A | 2025-08-22 A |  | 100% |  |  | 2025-08-22 | 2025-08-22 | 0d | start no earlier than 2025-08-22 | Helix |  | 6.31 | Helix | Helix Programme Board | Complete | COMPLETE |  |  |  |  |
| 2065 | 1.6.3.4.2 | Invite to Onbaord Issued | milestone | 0d | 2025-09-05 A | 2025-09-05 A |  | 100% |  |  | 2025-09-05 | 2025-09-05 | 0d | start no earlier than 2025-09-05 | Helix |  | 6.31 | Helix | Helix Programme Board | Complete | COMPLETE |  |  |  |  |
| 2066 | 1.6.3.4.3 | Date to be Onboarded by | milestone | 0d | 2025-09-24 A | 2025-09-24 A |  | 100% |  |  | 2025-09-24 | 2025-09-24 | 0d | start no earlier than 2025-09-24 | Helix |  | 6.31 | Helix | Helix Programme Board | Complete | COMPLETE |  |  |  |  |
| 2067 | 1.6.3.5 | **Operational Readiness E2E Testing** |  | 64d | 2025-05-13 | 2025-08-08 |  | 100% | 2025-05-14 | 2025-09-05 | 2025-05-13 | 2025-08-08 | 0d |  | Helix |  | 6.28 | Helix | Helix Programme Board |  |  | Helix / Elexon M10 Readiness | Service Activation Plan |  |  |
| 2068 | 1.6.3.5.1 | Phase 1 Test Execution (Service Activation and Participant Management) |  | 66d | 2025-05-14 A | 2025-08-13 A |  | 100% |  |  | 2025-05-13 | 2025-07-18 | 0d | finish no earlier than 2025-07-18 | Helix |  | 6.32 | Helix | Helix Programme Board | Complete | COMPLETE | Helix / Elexon M10 Readiness | Service Activation Plan | Business Readiness |  |
| 2069 | 1.6.3.5.2 | Phase 2 Test Execution (S&I) |  | 45d | 2025-06-11 A | 2025-08-20 A |  | 100% |  |  | 2025-06-11 | 2025-07-11 | 0d | finish no earlier than 2025-07-11 | Helix |  | 6.32 | Helix | Helix Programme Board | Complete | COMPLETE | Helix / Elexon M10 Readiness | Service Activation Plan | Business Readiness |  |
| 2070 | 1.6.3.5.3 | Phase 3 Test Execution (Assurance & mop-up) |  | 25d | 2025-07-21 A | 2025-08-22 A |  | 100% |  |  | 2025-07-02 | 2025-07-18 | 0d | start no earlier than 2025-07-21 | Helix |  | 6.32 | Helix | Helix Programme Board | Complete | COMPLETE | Helix / Elexon M10 Readiness | Service Activation Plan |  |  |
| 2071 | 1.6.3.5.4 | E2E Operational Testing Completed | milestone | 0d | 2025-09-05 A | 2025-09-05 A | 2068, 2069, 2070 | 100% |  |  | 2025-07-18 | 2025-07-18 | 0d | finish no earlier than 2025-09-05 | Helix |  | 6.33 | Helix | Helix Programme Board | Complete | COMPLETE | Helix / Elexon M10 Readiness | Service Activation Plan |  |  |
| 2072 | 1.6.3.6 | **Service Activation Readiness** |  | 466d? | 2024-04-02 A | 2026-01-13 A |  | 100% |  |  | 2024-04-02 | 2025-12-02 | 0d |  | Helix |  | 6.26 | Helix | Helix Programme Board |  |  | Helix / Elexon M10 Readiness |  |  |  |
| 2073 | 1.6.3.6.1 | **Phase 1 - Preparation** |  | 374d? | 2024-04-02 A | 2025-09-05 A |  | 100% |  |  | 2024-04-02 | 2025-09-26 | 0d |  | Helix |  | 6.26 | Helix | Helix Programme Board |  |  | Helix / Elexon M10 Readiness | Service Activation Plan |  |  |
| 2074 | 1.6.3.6.1.1 | **Business Service Activation Governance, Planning & Scope** |  | 128d | 2024-04-04 A | 2024-09-30 A |  | 100% |  |  | 2024-04-04 | 2024-09-30 | 0d |  | Helix |  | 6.26 | Helix | Helix Programme Board |  |  | Helix / Elexon M10 Readiness | Service Activation Plan |  |  |
| 2075 | 1.6.3.6.1.1.1 | Create and Confirm SA Scope |  | 9d | 2024-06-03 A | 2024-06-13 A |  | 100% |  |  | 2024-06-03 | 2024-06-13 | 0d | finish no earlier than 2024-06-13 | Helix |  | 6.26 | Helix | Helix Programme Board | Complete | COMPLETE | Helix / Elexon M10 Readiness | Service Activation Plan | Business Readiness |  |
| 2076 | 1.6.3.6.1.1.2 | POAP Service Activation |  | 13d | 2024-06-03 A | 2024-06-19 A |  | 100% |  |  | 2024-06-03 | 2024-06-19 | 0d | finish no earlier than 2024-06-19 | Helix |  | 6.26 | Helix | Helix Programme Board | Complete | COMPLETE | Helix / Elexon M10 Readiness | Service Activation Plan | Business Readiness |  |
| 2077 | 1.6.3.6.1.1.3 | Service Activation Working Group |  | 62d | 2024-04-04 A | 2024-06-28 A |  | 100% |  |  | 2024-04-04 | 2024-06-28 | 0d | finish no earlier than 2024-06-28 | Helix |  | 6.26 | Helix | Helix Programme Board | Complete | COMPLETE | Helix / Elexon M10 Readiness | Service Activation Plan | Business Readiness |  |
| 2078 | 1.6.3.6.1.1.4 | Business Readiness Governance Framework |  | 42d | 2024-08-02 A | 2024-09-30 A |  | 100% |  |  | 2024-08-02 | 2024-09-30 | 0d | finish no earlier than 2024-09-30 | Helix |  | 6.26 | Helix | Helix Programme Board | Complete | COMPLETE | Helix / Elexon M10 Readiness | Service Activation Plan | Business Readiness |  |
| 2079 | 1.6.3.6.1.1.5 | Service Activation Governance Framework Completed | milestone | 0d | 2024-09-30 A | 2024-09-30 A | 2075, 2076, 2077, 2078 | 100% |  |  | 2024-09-30 | 2024-09-30 | 0d | finish no earlier than 2024-06-28 | Helix |  | 6.26 | Helix | Helix Programme Board | Complete | COMPLETE | Helix / Elexon M10 Readiness | Service Activation Plan |  |  |
| 2080 | 1.6.3.6.1.2 | **Service Activation High Level Process Models** |  | 109d | 2024-04-02 A | 2024-08-31 A |  | 100% |  |  | 2024-04-02 | 2024-08-31 | 0d |  | Helix |  | 6.26 | Helix | Helix Programme Board |  |  | Helix / Elexon M10 Readiness | Service Activation Plan |  |  |
| 2081 | 1.6.3.6.1.2.1 | Transition Process Model |  | 70d | 2024-04-02 A | 2024-07-08 A |  | 100% |  |  | 2024-04-02 | 2024-07-08 | 0d | finish no earlier than 2024-07-08 | Helix |  | 6.26 | Helix | Helix Programme Board | Complete | COMPLETE | Helix / Elexon M10 Readiness | Service Activation Plan | Business Readiness |  |
| 2082 | 1.6.3.6.1.2.2 | Migration Process Model |  | 14d | 2024-08-13 A | 2024-08-30 A |  | 100% |  |  | 2024-08-13 | 2024-08-30 | 0d | finish no earlier than 2024-08-31 | Helix |  | 6.26 | Helix | Helix Programme Board | Complete | COMPLETE | Helix / Elexon M10 Readiness | Service Activation Plan | Business Readiness |  |
| 2083 | 1.6.3.6.1.2.3 | Enduring Process Model |  | 44d | 2024-06-03 A | 2024-08-01 A |  | 100% |  |  | 2024-06-03 | 2024-08-01 | 0d | start no earlier than 2024-06-01 | Helix |  | 6.26 | Helix | Helix Programme Board | Complete | COMPLETE | Helix / Elexon M10 Readiness | Service Activation Plan | Business Readiness |  |
| 2084 | 1.6.3.6.1.2.4 | Service Activation High Level Process Models Completed | milestone | 0d | 2024-08-31 A | 2024-08-31 A | 2081, 2082, 2083 | 100% |  |  | 2024-08-31 | 2024-08-31 | 0d | start no earlier than 2024-08-31 | Helix |  | 6.26 | Helix | Helix Programme Board | Complete | COMPLETE | Helix / Elexon M10 Readiness | Service Activation Plan |  |  |
| 2085 | 1.6.3.6.1.3 | **Target Operating Model for Service Activation** |  | 83d | 2024-06-21 A | 2024-10-15 A |  | 100% |  |  | 2024-06-21 | 2024-10-15 | 0d |  | Helix |  | 6.26 | Helix | Helix Programme Board |  |  | Helix / Elexon M10 Readiness | Service Activation Plan |  |  |
| 2086 | 1.6.3.6.1.3.1 | MHHSP Engagement Team understanding |  | 25d | 2024-06-21 A | 2024-07-25 A |  | 100% |  |  | 2024-06-21 | 2024-07-25 | 0d | finish no earlier than 2024-07-25 | Helix |  | 6.26 | Helix | Helix Programme Board | Complete | COMPLETE | Helix / Elexon M10 Readiness | Service Activation Plan | Business Readiness |  |
| 2087 | 1.6.3.6.1.3.2 | Define and produce organisation model for Service Activation in Elexon |  | 83d | 2024-06-21 A | 2024-10-15 A |  | 100% |  |  | 2024-06-21 | 2024-10-15 | 0d | finish no earlier than 2024-10-15 | Helix |  | 6.26 | Helix | Helix Programme Board | Complete | COMPLETE | Helix / Elexon M10 Readiness | Service Activation Plan | Business Readiness |  |
| 2088 | 1.6.3.6.1.3.3 | Implement Target Operating model |  | 1d | 2024-10-15 A | 2024-10-15 A |  | 100% |  |  | 2024-10-15 | 2024-10-15 | 0d | start no earlier than 2024-10-15 | Helix |  | 6.26 | Helix | Helix Programme Board | Complete | COMPLETE | Helix / Elexon M10 Readiness | Service Activation Plan | Business Readiness |  |
| 2089 | 1.6.3.6.1.3.4 | Target Operating Model for Service Activation Completed | milestone | 0d | 2024-10-15 A | 2024-10-15 A | 2086, 2087, 2088 | 100% |  |  | 2024-10-15 | 2024-10-15 | 0d | start no earlier than 2024-10-15 | Helix |  | 6.26 | Helix | Helix Programme Board | Complete | COMPLETE | Helix / Elexon M10 Readiness | Service Activation Plan |  | H9 / M15 - Service Delivery Operating Model in place |

| ID | WBS | Task | Type | Duration | Start | Finish | Predecessors | Complete | Actual finish | Baseline start | Baseline finish | Baseline duration | Constraint | Responsible | Text9 | Update Version | MHHS Resource Name | Previous RAG | Text29 | Future RAG | Sched Status | RAG | Text8 | Text21 |
| --- | --- | --- | --- | --- | --- | --- | --- | --- | --- | --- | --- | --- | --- | --- | --- | --- | --- | --- | --- | --- | --- | --- | --- | --- |
| 2090 | 1.6.3.6.1.4 | **SIT Operational Testing for Service Activation** |  | 5d? | 2024-08-12 A | 2024-08-16 A |  | 100% |  | 2024-08-12 | 2024-08-16 | 0d |  | Helix | Helix / Elexon M10 Readiness | 6.26 | Helix | Service Activation Plan | Helix Programme Board |  |  |  |  |  |
| 2091 | 1.6.3.6.1.4.1 | Review and validate test cases |  | 5d | 2024-08-12 A | 2024-08-16 A |  | 100% |  | 2024-08-12 | 2024-08-16 | 0d | finish no earlier than 2024-08-16 | Helix | Helix / Elexon M10 Readiness | 6.26 | Helix | Service Activation Plan | Helix Programme Board | Business Readiness | Complete | COMPLETE |  |  |
| 2092 | 1.6.3.6.1.4.2 | SIT Operational Testing for Service Activation Completed |  | 1d? | 2024-08-16 A | 2024-08-16 A |  | 100% |  | 2024-08-16 | 2024-08-16 | 0d | start no earlier than 2024-08-16 | Helix | Helix / Elexon M10 Readiness | 6.26 | Helix |  | Helix Programme Board |  | Complete | COMPLETE |  |  |
| 2093 | 1.6.3.6.1.5 | **Operational Training for Service Activation** |  | 73d | 2025-05-15 A | 2025-08-25 A |  | 100% |  | 2024-11-13 | 2025-07-25 | 0d |  | Helix | Helix / Elexon M10 Readiness | 6.26 | Helix | Service Activation Plan | Helix Programme Board |  |  |  |  |  |
| 2094 | 1.6.3.6.1.5.1 | Training Execution [Placeholder] |  | 73d | 2025-05-15 A | 2025-08-25 A |  | 100% |  | 2025-05-15 | 2025-08-29 | 0d | start no earlier than 2024-11-13 | Helix | Helix / Elexon M10 Readiness | 6.26 | Helix | Service Activation Plan | Helix Programme Board |  | Complete | COMPLETE |  |  |
| 2095 | 1.6.3.6.1.5.2 | Service Activation Training Completed | milestone | 0d | 2025-08-25 A | 2025-08-25 A | 2094 | 100% |  | 2025-08-29 | 2025-08-29 | 0d | start no earlier than 2025-07-25 | Helix | Helix / Elexon M10 Readiness | 6.26 | Helix | Service Activation Plan | Helix Programme Board |  | Complete | COMPLETE |  |  |
| 2096 | 1.6.3.6.1.6 | **Service Activation Readiness** |  | 7d | 2025-08-04 A | 2025-08-12 A |  | 100% |  | 2025-08-04 | 2025-08-12 | 0d |  | Helix | Helix / Elexon M10 Readiness | 6.26 | Helix | Service Activation Plan | Helix Programme Board |  |  |  |  |  |
| 2097 | 1.6.3.6.1.6.1 | Dress Rehearsal 1 |  | 2d | 2025-08-04 A | 2025-08-05 A | 2079, 2084, 2089 | 100% |  | 2025-08-04 | 2025-08-05 | 0d | start no earlier than 2025-08-04 | Helix | Helix / Elexon M10 Readiness | 6.26 | Helix | Service Activation Plan | Helix Programme Board | Participant Management | Complete | COMPLETE | DIP Team |  |
| 2098 | 1.6.3.6.1.6.2 | Dress Rehearsal 1 Complete | milestone | 0d | 2025-08-05 A | 2025-08-05 A | 2097 | 100% |  | 2025-08-05 | 2025-08-05 | 0d | start no earlier than 2025-01-22 | Helix | Helix / Elexon M10 Readiness | 6.26 | Helix | Service Activation Plan | Helix Programme Board | Participant Management | Complete | COMPLETE | DIP Team |  |
| 2099 | 1.6.3.6.1.6.3 | Dress Rehearsal 2 |  | 2d | 2025-08-11 A | 2025-08-12 A | 2098FS+3d | 100% |  | 2025-08-11 | 2025-08-12 | 0d | start no earlier than 2025-08-04 | Helix | Helix / Elexon M10 Readiness | 6.26 | Helix | Service Activation Plan | Helix Programme Board | Participant Management | Complete | COMPLETE | DIP Team |  |
| 2100 | 1.6.3.6.1.6.4 | Dress Rehearsal 2 Complete | milestone | 0d | 2025-08-12 A | 2025-08-12 A | 2099 | 100% |  | 2025-08-12 | 2025-08-12 | 0d | start no earlier than 2025-01-22 | Helix | Helix / Elexon M10 Readiness | 6.26 | Helix | Service Activation Plan | Helix Programme Board | Participant Management | Complete | COMPLETE | DIP Team |  |
| 2101 | 1.6.3.6.1.7 | **Service Activation Go / No Go** |  | 1d | 2025-08-22 A | 2025-08-22 A |  | 100% |  | 2025-08-13 | 2025-08-22 | 0d |  | Helix | Helix / Elexon M10 Readiness | 6.26 | Helix | Service Activation Plan | Helix Programme Board |  |  |  |  |  |
| 2102 | 1.6.3.6.1.7.1 | **Final Service Activation Go/No Go Decision** |  | 1d | 2025-08-22 A | 2025-08-22 A |  | 100% |  | 2025-08-13 | 2025-08-22 | 0d |  | Helix | Helix / Elexon M10 Readiness | 6.26 | Helix | Service Activation Plan | Helix Programme Board |  |  |  |  |  |
| 2103 | 1.6.3.6.1.7.1.1 | DIP Team Ready |  | 1d | 2025-08-22 A | 2025-08-22 A | 2100FS+7d, 2098 | 100% |  | 2025-08-22 | 2025-08-22 | 0d |  | Helix | Helix / Elexon M10 Readiness | 6.28 | Helix |  | Helix Programme Board |  | Complete | COMPLETE |  |  |
| 2104 | 1.6.3.6.1.7.1.2 | DIP Technical Onboarding Processes Completed | milestone | 0d | 2025-08-22 A | 2025-08-22 A |  | 100% |  | 2025-08-22 | 2025-08-22 | 0d | start no earlier than 2025-08-22 | Helix | Helix / Elexon M10 Readiness | 6.26 | Helix | Service Activation Plan | Helix Programme Board |  | Complete | COMPLETE |  | H15 / M26 DIP transition completed and operational |
| 2105 | 1.6.3.6.1.7.1.3 | PM Team Ready | milestone | 0d | 2025-08-22 A | 2025-08-22 A | 2098, 2100 | 100% |  | 2025-08-22 | 2025-08-22 | 0d | start no earlier than 2025-08-22 | Helix | Helix / Elexon M10 Readiness | 6.26 | Helix | Service Activation Plan | Helix Programme Board |  | Complete | COMPLETE |  |  |
| 2106 | 1.6.3.6.1.7.1.4 | Operational Support Ready (Ops Control Centre, Account Managers) | milestone | 0d | 2025-08-22 A | 2025-08-22 A |  | 100% |  | 2025-08-22 | 2025-08-22 | 0d | start no earlier than 2025-08-22 | Helix | Helix / Elexon M10 Readiness | 6.26 | Helix | Service Activation Plan | Helix Programme Board |  | Complete | COMPLETE |  |  |
| 2107 | 1.6.3.6.1.7.1.5 | Service Management Activity Completed (Resolver Groups) | milestone | 0d | 2025-08-22 A | 2025-08-22 A |  | 100% |  | 2025-08-22 | 2025-08-22 | 0d | start no earlier than 2025-08-22 | Helix | Helix / Elexon M10 Readiness | 6.26 | Helix | Service Activation Plan | Helix Programme Board |  | Complete | COMPLETE |  |  |
| 2108 | 1.6.3.6.1.7.1.6 | Process 1.1.1 ISD and Related LWIs Completed | milestone | 0d | 2025-08-22 A | 2025-08-22 A | 2107 | 100% |  | 2025-08-22 | 2025-08-22 | 0d |  | Helix | Helix / Elexon M10 Readiness | 6.26 | Helix |  | Helix Programme Board |  | Complete | COMPLETE |  |  |
| 2109 | 1.6.3.6.1.8 | **SOLR Consultation** |  | 107d? | 2025-04-10 A | 2025-09-05 A | 2127 | 100% |  | 2025-04-10 | 2025-09-26 | 0d |  | Helix | Helix / Elexon M10 Readiness | 6.26 | Helix | Service Activation Plan | Helix Programme Board |  |  |  |  |  |
| 2110 | 1.6.3.6.1.8.1 | SOLR workshop 1 |  | 1d | 2025-04-10 A | 2025-04-10 A | 2127SF | 100% |  | 2025-04-10 | 2025-04-10 | 0d | start no earlier than 2025-04-10 | Helix | Helix / Elexon M10 Readiness | 6.26 | Helix | Service Activation Plan | Helix Programme Board |  | Complete | COMPLETE |  |  |
| 2111 | 1.6.3.6.1.8.2 | SOLR workshop 2 |  | 1d | 2025-04-29 A | 2025-04-29 A | 2127SF | 100% |  | 2025-04-29 | 2025-04-29 | 0d | start no earlier than 2025-04-29 | Helix | Helix / Elexon M10 Readiness | 6.26 | Helix | Service Activation Plan | Helix Programme Board |  | Complete | COMPLETE |  |  |
| 2112 | 1.6.3.6.1.8.3 | **SOLR consultation** |  | 81d? | 2025-04-10 A | 2025-07-31 |  | 100% | 2025-09-05 | 2025-04-10 | 2025-07-31 | 0d |  | Helix | Helix / Elexon M10 Readiness | 6.28 | Helix | Service Activation Plan | Helix Programme Board |  |  |  |  |  |
| 2113 | 1.6.3.6.1.8.3.1 | SOLR consultation |  | 81d? | 2025-04-10 A | 2025-07-31 A |  | 100% |  | 2025-04-10 | 2025-07-31 | 0d | start no earlier than 2025-04-10 | PP | Helix / Elexon M10 Readiness | 6.29 | Helix |  | Helix Programme Board |  | Complete | COMPLETE |  |  |
| 2114 | 1.6.3.6.1.8.3.2 | LDSO Workshop | milestone | 0d | 2025-06-30 A | 2025-06-30 A |  | 100% |  | 2025-06-30 | 2025-06-30 | 0d | start no earlier than 2025-06-30 | Helix | Helix / Elexon M10 Readiness | 6.28 | Helix |  | Helix Programme Board |  | Complete | COMPLETE |  |  |
| 2115 | 1.6.3.6.1.8.3.3 | GLIG | milestone | 0d | 2025-07-04 A | 2025-07-04 A |  | 100% |  | 2025-07-04 | 2025-07-04 | 0d | start no earlier than 2025-07-04 | Helix | Helix / Elexon M10 Readiness | 6.28 | Helix |  | Helix Programme Board |  | Complete | COMPLETE |  |  |
| 2116 | 1.6.3.6.1.8.3.4 | QWG | milestone | 0d | 2025-07-08 A | 2025-07-08 A |  | 100% |  | 2025-07-08 | 2025-07-08 | 0d | start no earlier than 2025-07-08 | Helix | Helix / Elexon M10 Readiness | 6.28 | Helix |  | Helix Programme Board |  | Complete | COMPLETE |  |  |
| 2117 | 1.6.3.6.1.8.3.5 | GLIG (Second presentation) | milestone | 0d | 2025-07-18 A | 2025-07-18 A |  | 100% |  | 2025-07-18 | 2025-07-18 | 0d | start no earlier than 2025-07-18 | MHHS | Helix / Elexon M10 Readiness | 6.28 | Helix |  | Helix Programme Board |  | Complete | COMPLETE |  |  |
| 2118 | 1.6.3.6.1.8.3.6 | Process Refinement |  | 33d | 2025-06-17 A | 2025-07-31 A |  | 100% |  | 2025-06-17 | 2025-07-31 | 0d | start no earlier than 2025-06-17 | Helix | Helix / Elexon M10 Readiness | 6.30 | Helix |  | Helix Programme Board |  | Complete | COMPLETE |  |  |
| 2119 | 1.6.3.6.1.8.3.7 | Process Test |  | 26d | 2025-08-01 A | 2025-09-05 A | 2118 | 100% |  | 2025-08-01 | 2025-08-14 | 0d |  | Helix | Helix / Elexon M10 Readiness | 6.30 | Helix |  | Helix Programme Board |  | Complete | COMPLETE |  |  |
| 2120 | 1.6.3.6.1.8.4 | SOLR comms to MHHS for review |  | 1d | 2025-08-27 A | 2025-08-27 A |  | 100% |  | 2025-08-26 | 2025-08-26 | 0d | finish no earlier than 2025-08-26 | Helix | Helix / Elexon M10 Readiness | 6.26 | Helix | Service Activation Plan | Helix Programme Board |  | Complete | COMPLETE |  |  |

| ID | WBS | Task | Type | Duration | Start | Finish | Predecessors | Complete | Baseline start | Baseline finish | Baseline duration | Constraint | Responsible | Text9 | Update Version | MHHS Resource Name | Previous RAG | Text29 | Sched Status | RAG | Future RAG | Text23 |
| --- | --- | --- | --- | --- | --- | --- | --- | --- | --- | --- | --- | --- | --- | --- | --- | --- | --- | --- | --- | --- | --- | --- |
| 2121 | 1.6.3.6.1.9 | **MDR Process** |  | 77d | 2025-04-16 A | 2025-07-31 A |  | 100% | 2025-04-16 | 2025-07-31 | 0d |  | Helix | Helix / Elexon M10 Readiness | 6.26 | Helix | Service Activation Plan | Helix Programme Board |  |  |  |  |
| 2122 | 1.6.3.6.1.9.1 | MDR workshop 1 |  | 1d | 2025-04-16 A | 2025-04-16 A |  | 100% | 2025-04-16 | 2025-04-16 | 0d | start no earlier than 2025-04-16 | Helix | Helix / Elexon M10 Readiness | 6.26 | Helix | Service Activation Plan | Helix Programme Board | Complete | COMPLETE |  |  |
| 2123 | 1.6.3.6.1.9.2 | MDR workshop 2 |  | 1d | 2025-04-30 A | 2025-04-30 A |  | 100% | 2025-04-30 | 2025-04-30 | 0d | start no earlier than 2025-04-30 | Helix | Helix / Elexon M10 Readiness | 6.26 | Helix | Service Activation Plan | Helix Programme Board | Complete | COMPLETE |  |  |
| 2124 | 1.6.3.6.1.9.3 | MDR workshop |  | 1d | 2025-05-27 A | 2025-05-27 A |  | 100% | 2025-05-27 | 2025-05-27 | 0d | start no earlier than 2025-05-27 | Helix | Helix / Elexon M10 Readiness | 6.26 | Helix |  | Helix Programme Board | Complete | COMPLETE |  |  |
| 2125 | 1.6.3.6.1.9.4 | MDR consultation |  | 12d | 2025-05-06 A | 2025-05-21 A |  | 100% | 2025-05-06 | 2025-05-21 | 0d | start no earlier than 2025-05-06 | PP | Helix / Elexon M10 Readiness | 6.26 | Helix | Service Activation Plan | Helix Programme Board | Complete | COMPLETE |  |  |
| 2126 | 1.6.3.6.1.9.5 | MDR consultation ongoing actions |  | 62d | 2025-05-07 A | 2025-07-31 A |  | 100% | 2025-05-07 | 2025-07-31 | 0d | start no earlier than 2025-05-07 | Helix | Helix / Elexon M10 Readiness | 6.26 | Helix |  | Helix Programme Board | Complete | COMPLETE |  |  |
| 2127 | 1.6.3.6.1.10 | Service Activation Go / No Go | milestone | 0d | 2025-08-22 A | 2025-08-22 A | 2104, 2105, 2106FF, 2107FF, 2043FF, 2108 | 100% | 2025-08-22 | 2025-08-22 | 0d |  | Helix | Helix / Elexon M10 Readiness | 6.27 | Helix | Service Activation Plan | Helix Programme Board | Complete | COMPLETE |  |  |
| 2128 | 1.6.3.6.2 | **Phase 2 - Implementation** |  | 418d? | 2024-06-07 A | 2026-01-13 A |  | 100% | 2024-06-07 | 2025-12-02 | 0d |  | Helix | Helix / Elexon M10 Readiness | 6.26 | Helix | Service Activation Plan | Helix Programme Board |  |  |  |  |
| 2129 | 1.6.3.6.2.1 | **Non-SIT LDSO & SIT MVC Data Loading (M10 Ready)** |  | 6d | 2024-06-07 A | 2024-06-14 A |  | 100% | 2024-06-07 | 2024-06-14 | 0d |  | Helix | Helix / Elexon M10 Readiness | 6.26 | Helix | Service Activation Plan | Helix Programme Board |  |  |  |  |
| 2130 | 1.6.3.6.2.1.1 | Define Non-SIT LDSO Upfront Activities |  | 6d | 2024-06-07 A | 2024-06-14 A |  | 100% | 2024-06-07 | 2024-06-14 | 0d | finish no earlier than 2024-06-15 | Helix | Helix / Elexon M10 Readiness | 6.26 | Helix | Service Activation Plan | Helix Programme Board | Complete | COMPLETE | Business Readiness |  |
| 2131 | 1.6.3.6.2.2 | **M10-Ready Activation Preparation Tasks** |  | 15d? | 2025-08-25 A | 2025-09-12 A | 2130 | 100% | 2025-08-25 | 2025-09-08 | 0d |  | Helix | Helix / Elexon M10 Readiness | 6.26 | Helix | Service Activation Plan | Helix Programme Board |  |  | Business Readiness |  |
| 2132 | 1.6.3.6.2.2.1 | Identify Resources |  | 1d | 2025-08-25 A | 2025-08-25 A |  | 100% | 2025-08-25 | 2025-08-25 | 0d | start no earlier than 2025-08-25 | Helix | Helix / Elexon M10 Readiness | 6.26 | Helix | Service Activation Plan | Helix Programme Board | Complete | COMPLETE |  |  |
| 2133 | 1.6.3.6.2.2.2 | Confirmation from Qualification of Wave Participants Complete | milestone | 0d | 2025-08-25 A | 2025-08-25 A |  | 100% | 2025-08-25 | 2025-08-25 | 0d | start no earlier than 2025-08-25 | Helix | Helix / Elexon M10 Readiness | 6.26 | Helix | Service Activation Plan | Helix Programme Board | Complete | COMPLETE | Business Readiness |  |
| 2134 | 1.6.3.6.2.2.3 | Agree & Understand Support Model |  | 1d | 2025-08-26 A | 2025-08-26 A |  | 100% | 2025-08-26 | 2025-08-26 | 0d | start no earlier than 2025-08-26 | Helix | Helix / Elexon M10 Readiness | 6.26 | Helix | Service Activation Plan | Helix Programme Board | Complete | COMPLETE | Business Readiness |  |
| 2135 | 1.6.3.6.2.2.4 | Confirm Training complete | milestone | 0d | 2025-08-27 A | 2025-08-27 A |  | 100% | 2025-08-27 | 2025-08-27 | 0d | start no earlier than 2025-08-27 | Helix | Helix / Elexon M10 Readiness | 6.26 | Helix | Service Activation Plan | Helix Programme Board | Complete | COMPLETE | DIP Team |  |
| 2136 | 1.6.3.6.2.2.5 | Confirm IDNOs global sign completed prior to M10 |  | 7d | 2025-08-28 A | 2025-09-05 A |  | 100% | 2025-08-28 | 2025-08-28 | 0d | finish no earlier than 2025-09-05 | Helix | Helix / Elexon M10 Readiness | 6.33 | Helix | Service Activation Plan | Helix Programme Board | Complete | COMPLETE | Participant Management | Sara Doubleday |
| 2137 | 1.6.3.6.2.2.6 | Engagement / Communications with Participants |  | 9d | 2025-08-29 A | 2025-09-10 A |  | 100% | 2025-08-29 | 2025-08-29 | 0d | finish no earlier than 2025-09-10 | Helix | Helix / Elexon M10 Readiness | 6.33 | Helix | Service Activation Plan | Helix Programme Board | Complete | COMPLETE | Business Readiness/Participant Management |  |
| 2138 | 1.6.3.6.2.2.7 | **Internal Communications** |  | 1d | 2025-09-01 A | 2025-09-01 A |  | 100% | 2025-09-01 | 2025-09-01 | 0d |  | Helix | Helix / Elexon M10 Readiness | 6.26 | Helix | Service Activation Plan | Helix Programme Board |  |  |  |  |
| 2139 | 1.6.3.6.2.2.7.1 | Agree Content for Livewire |  | 1d | 2025-09-01 A | 2025-09-01 A |  | 100% | 2025-09-01 | 2025-09-01 | 0d | start no earlier than 2025-09-01 | Helix | Helix / Elexon M10 Readiness | 6.26 | Helix | Service Activation Plan | Helix Programme Board | Complete | COMPLETE |  |  |
| 2140 | 1.6.3.6.2.2.7.2 | Publish Content for Livewire | milestone | 0d | 2025-09-01 A | 2025-09-01 A |  | 100% | 2025-09-01 | 2025-09-01 | 0d | start no earlier than 2025-09-01 | Helix | Helix / Elexon M10 Readiness | 6.26 | Helix | Service Activation Plan | Helix Programme Board | Complete | COMPLETE | Business Readiness |  |
| 2141 | 1.6.3.6.2.2.8 | Validate User Access |  | 1d | 2025-09-02 A | 2025-09-02 A |  | 100% | 2025-09-02 | 2025-09-02 | 0d | start no earlier than 2025-09-02 | Helix | Helix / Elexon M10 Readiness | 6.26 | Helix | Service Activation Plan | Helix Programme Board | Complete | COMPLETE | Business Readiness |  |
| 2142 | 1.6.3.6.2.2.9 | Target Systems and Environments Ready |  | 1d | 2025-09-03 A | 2025-09-03 A |  | 100% | 2025-09-03 | 2025-09-03 | 0d | start no earlier than 2025-09-03 | Helix | Helix / Elexon M10 Readiness | 6.26 | Helix | Service Activation Plan | Helix Programme Board | Complete | COMPLETE | Participant Management |  |
| 2143 | 1.6.3.6.2.2.10 | Publish the guidence with Parties |  | 1d | 2025-09-12 A | 2025-09-12 A |  | 100% | 2025-09-04 | 2025-09-04 | 0d | start no earlier than 2025-09-12 | Helix | Helix / Elexon M10 Readiness | 6.33 | Helix | Service Activation Plan | Helix Programme Board | Complete | COMPLETE | Business Readiness |  |
| 2144 | 1.6.3.6.2.2.11 | Provide LWIs |  | 1d? | 2025-09-12 A | 2025-09-12 A |  | 100% | 2025-09-05 | 2025-09-05 | 0d | finish no earlier than 2025-09-12 | Helix | Helix / Elexon M10 Readiness | 6.33 | Helix |  | Helix Programme Board | Complete | COMPLETE |  |  |
| 2145 | 1.6.3.6.2.2.12 | Business Readiness Governance Approval |  | 1d | 2025-09-08 A | 2025-09-08 A | 2144 | 100% | 2025-09-08 | 2025-09-08 | 0d | start no earlier than 2025-09-05 | Helix | Helix / Elexon M10 Readiness | 6.26 | Helix | Service Activation Plan | Helix Programme Board | Complete | COMPLETE |  |  |
| 2146 | 1.6.3.6.2.2.13 | M10-Ready Participants Service Activation Preparation Completed | milestone | 0d | 2025-09-08 A | 2025-09-08 A | 2132, 2134, 2135, 2136, 2138, 2141, 2142, 2145 | 100% | 2025-09-08 | 2025-09-08 | 0d | start no earlier than 2025-09-05 | Helix | Helix / Elexon M10 Readiness | 6.26 | Helix | Service Activation Plan | Helix Programme Board | Complete | COMPLETE |  |  |

| ID | WBS | Task | Type | Duration | Start | Finish | Predecessors | Complete | Baseline start | Baseline finish | Baseline duration | Constraint | Responsible | Future RAG | Text9 | Update Version | MHHS Resource Name | Previous RAG | Text29 | Sched Status | RAG | Text23 |
| --- | --- | --- | --- | --- | --- | --- | --- | --- | --- | --- | --- | --- | --- | --- | --- | --- | --- | --- | --- | --- | --- | --- |
| 2147 | 1.6.3.6.2.3 | **M10-Ready (Inlcuding Non-SIT LDSOs) Service Activation Implementation** |  | 6d | 2025-09-10 A | 2025-09-19 A |  | 100% | 2025-08-06 | 2025-09-19 | 0d |  | Helix | MHHS Migration | Helix / Elexon M10 Readiness | 6.26 | Helix | Service Activation Plan | Helix Programme Board |  |  |  |
| 2148 | 1.6.3.6.2.3.1 | MHHSP Enabled Confirmation | milestone | 0d | 2025-09-10 A | 2025-09-10 A | 2389, 2392 | 100% | 2025-09-10 | 2025-09-10 | 0d | start no earlier than 2025-09-08 | PAB | MHHS qualification | Helix / Elexon M10 Readiness | 6.26 | Helix | Service Activation Plan | Helix Programme Board | Complete | COMPLETE |  |
| 2149 | 1.6.3.6.2.3.2 | Add EFD (ISD Calendar Date) to DIP |  | 1d | 2025-09-11 A | 2025-09-11 A | 2141, 2142, 2145, 2148 | 100% | 2025-09-11 | 2025-09-11 | 0d | start no earlier than 2025-09-11 | Helix | DIP Team | Helix / Elexon M10 Readiness | 6.26 | Helix | Service Activation Plan | Helix Programme Board | Complete | COMPLETE |  |
| 2150 | 1.6.3.6.2.3.3 | Non-SIT LDSO PP DIP User Promoted to Production |  | 1d | 2025-09-12 A | 2025-09-12 A | 2149 | 100% | 2025-09-12 | 2025-09-12 | 0d | start no earlier than 2025-09-12 | Helix | Market Entry/MHHS Qualification | Helix / Elexon M10 Readiness | 6.28 | Helix | Service Activation Plan | Helix Programme Board | Complete | COMPLETE | ?? |
| 2151 | 1.6.3.6.2.3.4 | Create M16 in Customer Solution Started | milestone | 0d | 2025-09-11 A | 2025-09-11 A |  | 100% | 2025-09-11 | 2025-09-11 | 0d | start no earlier than 2025-09-11 | Helix |  | Helix / Elexon M10 Readiness | 6.26 | Helix | Service Activation Plan | Helix Programme Board | Complete | COMPLETE |  |
| 2152 | 1.6.3.6.2.3.5 | Create M16 in Customer Solution |  | 1d | 2025-09-11 A | 2025-09-11 A | 2151SS, 2155SS | 100% | 2025-09-11 | 2025-09-11 | 0d | start no earlier than 2025-09-11 | Helix | Market Entry/MHHS Qualification | Helix / Elexon M10 Readiness | 6.26 | Helix | Service Activation Plan | Helix Programme Board | Complete | COMPLETE | ?? |
| 2153 | 1.6.3.6.2.3.6 | DIP Production Success Checks |  | 1d | 2025-09-12 A | 2025-09-12 A | 2149, 2152 | 100% | 2025-09-12 | 2025-09-12 | 0d |  | Helix |  | Helix / Elexon M10 Readiness | 6.26 | Helix |  | Helix Programme Board | Complete | COMPLETE |  |
| 2154 | 1.6.3.6.2.3.7 | 1st ISD Publish Started | milestone | 0d | 2025-09-11 A | 2025-09-11 A |  | 100% | 2025-09-11 | 2025-09-11 | 0d | start no earlier than 2025-09-11 | Helix |  | Helix / Elexon M10 Readiness | 6.26 | Helix | Service Activation Plan | Helix Programme Board | Complete | COMPLETE |  |
| 2155 | 1.6.3.6.2.3.8 | 1st ISD Publish (7 day window for this activity is consistent with Code requirements) |  | 6d | 2025-09-11 A | 2025-09-18 A | 2149SS, 2154SS | 100% | 2025-09-11 | 2025-09-18 | 0d | start no earlier than 2025-09-11 | Helix | Participant Management | Helix / Elexon M10 Readiness | 6.27 | Helix | Service Activation Plan | Helix Programme Board | Complete | COMPLETE | Allan Toule |
| 2156 | 1.6.3.6.2.3.9 | Go Live ISD |  | 1d | 2025-09-18 A | 2025-09-18 A |  | 100% | 2025-09-18 | 2025-09-18 | 0d | start no earlier than 2025-09-18 | Helix |  | Helix / Elexon M10 Readiness | 6.26 | Helix |  | Helix Programme Board | Complete | COMPLETE |  |
| 2157 | 1.6.3.6.2.3.10 | M10-Ready Service Activation Implementation Completed | milestone | 0d | 2025-09-19 A | 2025-09-19 A | 2148, 2149, 2150, 2152, 2155, 2156 | 100% | 2025-09-19 | 2025-09-19 | 0d | start no earlier than 2025-09-19 | Helix |  | Helix / Elexon M10 Readiness | 6.26 | Helix | Service Activation Plan | Helix Programme Board | Complete | COMPLETE |  |
| 2158 | 1.6.3.6.2.4 | **M10-Ready Service Activation Implementation MDD** |  | 6d | 2025-09-10 A | 2025-09-18 A |  | 100% | 2025-09-10 | 2025-09-19 | 0d |  | Helix | Participant Management | Helix / Elexon M10 Readiness | 6.26 | Helix | Service Activation Plan | Helix Programme Board |  |  | Diana Utubor |
| 2159 | 1.6.3.6.2.4.1 | MDD Final Circular Completed | milestone | 0d | 2025-09-10 A | 2025-09-10 A | 2145 | 100% | 2025-09-10 | 2025-09-10 | 0d | finish no earlier than 2025-09-10 | Helix | Participant Management | Helix / Elexon M10 Readiness | 6.26 | Helix | Service Activation Plan | Helix Programme Board | Complete | COMPLETE | Diana Utubor |
| 2160 | 1.6.3.6.2.4.2 | MDD Manual Update |  | 3d | 2025-09-11 A | 2025-09-15 A | 2159FF | 100% | 2025-09-11 | 2025-09-15 | 0d | finish no earlier than 2025-09-15 | Helix | Participant Management | Helix / Elexon M10 Readiness | 6.26 | Helix | Service Activation Plan | Helix Programme Board | Complete | COMPLETE | Diana Utubor |
| 2161 | 1.6.3.6.2.4.3 | MDD Publish |  | 6d | 2025-09-11 A | 2025-09-18 A | 2160SF | 100% | 2025-09-11 | 2025-09-18 | 0d | finish no earlier than 2025-09-18 | Helix | Participant Management | Helix / Elexon M10 Readiness | 6.26 | Helix | Service Activation Plan | Helix Programme Board | Complete | COMPLETE | Diana Utubor |
| 2162 | 1.6.3.6.2.4.4 | MDD Go Live | milestone | 0d | 2025-09-18 A | 2025-09-18 A | 2161 | 100% | 2025-09-18 | 2025-09-18 | 0d | finish no earlier than 2025-09-18 | Helix |  | Helix / Elexon M10 Readiness | 6.26 | Helix | Service Activation Plan | Helix Programme Board | Complete | COMPLETE |  |
| 2163 | 1.6.3.6.2.4.5 | Non-SIT LDSO & SIT MVC Service Activation Implementation MDD Completed | milestone | 0d | 2025-09-18 A | 2025-09-18 A | 2159, 2160, 2161, 2162 | 100% | 2025-09-18 | 2025-09-18 | 0d | finish no earlier than 2025-09-18 | Helix |  | Helix / Elexon M10 Readiness | 6.26 | Helix | Service Activation Plan | Helix Programme Board | Complete | COMPLETE |  |
| 2164 | 1.6.3.6.2.5 | **Non-SIT LDSO & SIT Service Activation Hypercare (M10 Ready)** |  | 54d | 2025-09-18 A | 2025-12-02 A |  | 100% | 2025-09-18 | 2025-12-02 | 0d |  | Helix | Participant Management/Business Readiness | Helix / Elexon M10 Readiness | 6.26 | Helix | Service Activation Plan | Helix Programme Board |  |  |  |
| 2165 | 1.6.3.6.2.5.1 | Monitoring |  | 54d | 2025-09-18 A | 2025-12-02 A |  | 100% | 2025-09-18 | 2025-12-02 | 0d | finish no earlier than 2025-12-02 | Helix | Participant Management/Business Readiness | Helix / Elexon M10 Readiness | 6.26 | Helix | Service Activation Plan | Helix Programme Board | Complete | COMPLETE |  |
| 2166 | 1.6.3.6.2.5.2 | Reporting |  | 54d | 2025-09-18 A | 2025-12-02 A |  | 100% | 2025-09-18 | 2025-12-02 | 0d | start no earlier than 2025-09-18 | Helix | Participant Management/Business Readiness | Helix / Elexon M10 Readiness | 6.26 | Helix | Service Activation Plan | Helix Programme Board | Complete | COMPLETE |  |
| 2167 | 1.6.3.6.2.5.3 | Issue Management |  | 54d | 2025-09-18 A | 2025-12-02 A |  | 100% | 2025-09-18 | 2025-12-02 | 0d | finish no earlier than 2025-12-02 | Helix | Participant Management/Business Readiness | Helix / Elexon M10 Readiness | 6.26 | Helix | Service Activation Plan | Helix Programme Board | Complete | COMPLETE |  |
| 2168 | 1.6.3.6.2.5.4 | Closed Down Activities |  | 1d | 2025-09-19 A | 2025-09-19 A | 2165SS, 2166SS, 2167SS | 100% | 2025-09-19 | 2025-09-19 | 0d | finish no earlier than 2025-09-19 | Helix | Business Readiness | Helix / Elexon M10 Readiness | 6.26 | Helix | Service Activation Plan | Helix Programme Board | Complete | COMPLETE |  |
| 2169 | 1.6.3.6.2.5.5 | Inform MHHSP |  | 1d | 2025-09-19 A | 2025-09-19 A | 2168SS | 100% | 2025-09-19 | 2025-09-19 | 0d | finish no earlier than 2025-09-19 | Helix |  | Helix / Elexon M10 Readiness | 6.26 | Helix | Service Activation Plan | Helix Programme Board | Complete | COMPLETE |  |
| 2170 | 1.6.3.6.2.6 | **M11-Ready Activation Preparation Tasks** |  | 3d | 2025-10-09 A | 2025-10-13 A | 2130 | 100% | 2025-09-18 | 2025-12-02 | 0d |  | Helix | Business Readiness | Helix / Elexon M10 Readiness | 6.27 | Helix | Service Activation Plan | Helix Programme Board |  |  |  |
| 2171 | 1.6.3.6.2.6.1 | Engagement / Communications with Participants |  | 1d | 2025-10-09 A | 2025-10-09 A |  | 100% | 2025-10-09 | 2025-10-09 | 0d | start no earlier than 2025-10-09 | Helix | Business Readiness/Participant Management | Helix / Elexon M10 Readiness | 6.27 | Helix | Service Activation Plan | Helix Programme Board | Complete | COMPLETE |  |
| 2172 | 1.6.3.6.2.6.2 | Validate User Access |  | 1d | 2025-10-13 A | 2025-10-13 A |  | 100% | 2025-10-13 | 2025-10-13 | 0d | start no earlier than 2025-10-13 | Helix | Business Readiness | Helix / Elexon M10 Readiness | 6.27 | Helix | Service Activation Plan | Helix Programme Board | Complete | COMPLETE |  |
| 2173 | 1.6.3.6.2.6.3 | M11-Ready Participants Service Activation Preparation Completed | milestone | 0d | 2025-10-13 A | 2025-10-13 A | 2171, 2172 | 100% | 2025-10-16 | 2025-10-16 | 0d | start no earlier than 2025-09-05 | Helix |  | Helix / Elexon M10 Readiness | 6.27 | Helix | Service Activation Plan | Helix Programme Board | Complete | COMPLETE |  |

| ID | WBS | Task | Type | Duration | Start | Finish | Predecessors | Complete | Baseline start | Baseline finish | Baseline duration | Constraint | Responsible | Future RAG | Text9 | Update Version | MHHS Resource Name | Previous RAG | Text29 | Task Status | Sched Status | RAG | Text23 |
| --- | --- | --- | --- | --- | --- | --- | --- | --- | --- | --- | --- | --- | --- | --- | --- | --- | --- | --- | --- | --- | --- | --- | --- |
| 2174 | 1.6.3.6.2.7 | **M11-Ready Service Activation Implementation** |  | 19d? | 2025-09-25 A | 2025-10-22 A |  | 100% | 2025-10-15 | 2025-10-22 | 0d |  | Helix | MHHS Migration | Helix / Elexon M10 Readiness | 6.27 | Helix | Service Activation Plan | Helix Programme Board |  |  |  |  |
| 2175 | 1.6.3.6.2.7.1 | **Pathway 4 PPs** |  | 6d? | 2025-09-25 A | 2025-10-03 A |  | 100% |  |  |  |  | Helix |  | Helix / Elexon M10 Readiness | 6.28 | Helix |  | Helix Programme Board | -965.67 |  |  |  |
| 2176 | 1.6.3.6.2.7.1.1 | MHHSP Enabled Confirmation | milestone | 0d | 2025-09-25 A | 2025-09-25 A | 2400 | 100% | 2025-10-15 | 2025-10-15 | 0d | start no earlier than 2025-09-25 | PAB | MHHS qualification | Helix / Elexon M10 Readiness | 6.28 | Helix | Service Activation Plan | Helix Programme Board |  | Complete | COMPLETE |  |
| 2177 | 1.6.3.6.2.7.1.2 | Add EFD (ISD Calendar Date) to DIP | milestone | 0d | 2025-09-25 A | 2025-09-25 A | 2176 | 100% | 2025-10-16 | 2025-10-16 | 0d |  | Helix | DIP Team | Helix / Elexon M10 Readiness | 6.28 | Helix | Service Activation Plan | Helix Programme Board |  | Complete | COMPLETE |  |
| 2178 | 1.6.3.6.2.7.1.3 | Create M16 in Customer Solution | milestone | 0d | 2025-09-25 A | 2025-09-25 A | 2176 | 100% | 2025-10-16 | 2025-10-16 | 0d |  | Helix | Market Entry/MHHS Qualification | Helix / Elexon M10 Readiness | 6.28 | Helix | Service Activation Plan | Helix Programme Board |  | Complete | COMPLETE | ?? |
| 2179 | 1.6.3.6.2.7.1.4 | DIP Production Success Checks |  | 1d? | 2025-09-26 A | 2025-09-26 A | 2177, 2178 | 100% | 2025-10-17 | 2025-10-17 | 0d |  | Helix |  | Helix / Elexon M10 Readiness | 6.28 | Helix |  | Helix Programme Board |  | Complete | COMPLETE |  |
| 2180 | 1.6.3.6.2.7.1.5 | Publish ISD |  | 6d | 2025-09-26 A | 2025-10-03 A | 2176 | 100% | 2025-10-15 | 2025-10-22 | 0d | start no earlier than 2025-09-26 | Helix | Participant Management | Helix / Elexon M10 Readiness | 6.28 | Helix | Service Activation Plan | Helix Programme Board |  | Complete | COMPLETE | Allan Toule |
| 2181 | 1.6.3.6.2.7.1.6 | Go Live ISD | milestone | 0d | 2025-10-03 A | 2025-10-03 A | 2180 | 100% | 2025-10-22 | 2025-10-22 | 0d |  | Helix |  | Helix / Elexon M10 Readiness | 6.28 | Helix |  | Helix Programme Board |  | Complete | COMPLETE |  |
| 2182 | 1.6.3.6.2.7.1.7 | Pathway 4 Service Activation Implementation Completed | milestone | 0d | 2025-10-03 A | 2025-10-03 A | 2177, 2178, 2181 | 100% | 2025-10-22 | 2025-10-22 | 0d | start no earlier than 2025-09-19 | Helix |  | Helix / Elexon M10 Readiness | 6.28 | Helix | Service Activation Plan | Helix Programme Board |  | Complete | COMPLETE |  |
| 2183 | 1.6.3.6.2.7.2 | **Pathway 5 PPs** |  | 5d? | 2025-10-15 A | 2025-10-22 A |  | 100% |  |  |  |  | Helix |  | Helix / Elexon M10 Readiness | 6.28 | Helix |  | Helix Programme Board | -965.67 |  |  |  |
| 2184 | 1.6.3.6.2.7.2.1 | MHHSP Enabled Confirmation | milestone | 0d | 2025-10-15 A | 2025-10-15 A | 2403 | 100% | 2025-10-15 | 2025-10-15 | 0d | start no earlier than 2025-09-08 | PAB | MHHS qualification | Helix / Elexon M10 Readiness | 6.28 | Helix | Service Activation Plan | Helix Programme Board |  | Complete | COMPLETE |  |
| 2185 | 1.6.3.6.2.7.2.2 | Add EFD (ISD Calendar Date) to DIP | milestone | 0d | 2025-10-15 A | 2025-10-15 A | 2184 | 100% | 2025-10-16 | 2025-10-16 | 0d | start no earlier than 2025-10-15 | Helix | DIP Team | Helix / Elexon M10 Readiness | 6.28 | Helix | Service Activation Plan | Helix Programme Board |  | Complete | COMPLETE |  |
| 2186 | 1.6.3.6.2.7.2.3 | Create M16 in Customer Solution | milestone | 0d | 2025-10-16 A | 2025-10-16 A | 2184 | 100% | 2025-10-16 | 2025-10-16 | 0d | start no earlier than 2025-10-16 | Helix | Market Entry/MHHS Qualification | Helix / Elexon M10 Readiness | 6.28 | Helix | Service Activation Plan | Helix Programme Board |  | Complete | COMPLETE | ?? |
| 2187 | 1.6.3.6.2.7.2.4 | DIP Production Success Checks |  | 1d? | 2025-10-16 A | 2025-10-16 A | 2185, 2186 | 100% | 2025-10-17 | 2025-10-17 | 0d |  | Helix |  | Helix / Elexon M10 Readiness | 6.28 | Helix |  | Helix Programme Board |  | Complete | COMPLETE |  |
| 2188 | 1.6.3.6.2.7.2.5 | Publish ISD |  | 5d | 2025-10-16 A | 2025-10-22 A | 2184 | 100% | 2025-10-15 | 2025-10-22 | 0d | start no earlier than 2025-10-15 | Helix | Participant Management | Helix / Elexon M10 Readiness | 6.28 | Helix | Service Activation Plan | Helix Programme Board |  | Complete | COMPLETE | Allan Toule |
| 2189 | 1.6.3.6.2.7.2.6 | Go Live ISD | milestone | 0d | 2025-10-22 A | 2025-10-22 A | 2188 | 100% | 2025-10-22 | 2025-10-22 | 0d | start no earlier than 2025-10-17 | Helix |  | Helix / Elexon M10 Readiness | 6.28 | Helix |  | Helix Programme Board |  | Complete | COMPLETE |  |
| 2190 | 1.6.3.6.2.7.2.7 | Publish MDD |  | 5d | 2025-10-16 A | 2025-10-22 A | 2184 | 100% | 2025-10-16 | 2025-10-22 | 0d |  | Helix |  | Helix / Elexon M10 Readiness | 6.28 | Helix |  | Helix Programme Board |  | Complete | COMPLETE |  |
| 2191 | 1.6.3.6.2.7.2.8 | MDD Go Live | milestone | 0d | 2025-10-22 A | 2025-10-22 A | 2190 | 100% | 2025-10-22 | 2025-10-22 | 0d |  | Helix |  | Helix / Elexon M10 Readiness | 6.28 | Helix |  | Helix Programme Board |  | Complete | COMPLETE |  |
| 2192 | 1.6.3.6.2.7.2.9 | Pathway 5 Service Activation Implementation Completed | milestone | 0d | 2025-10-22 A | 2025-10-22 A | 2184, 2185, 2186, 2189 | 100% | 2025-10-22 | 2025-10-22 | 0d | start no earlier than 2025-09-19 | Helix |  | Helix / Elexon M10 Readiness | 6.28 | Helix | Service Activation Plan | Helix Programme Board |  | Complete | COMPLETE |  |
| 2193 | 1.6.3.6.2.8 | **M11-Ready Service Activation Hypercare** |  | 16d | 2025-10-15 A | 2025-11-05 A |  | 100% | 2025-09-18 | 2025-12-02 | 0d |  | Helix | Participant Management/Business Readiness | Helix / Elexon M10 Readiness | 6.27 | Helix | Service Activation Plan | Helix Programme Board |  |  |  |  |
| 2194 | 1.6.3.6.2.8.1 | Monitoring |  | 11d | 2025-10-15 A | 2025-10-29 A |  | 100% | 2025-10-15 | 2025-10-29 | 0d | start no earlier than 2025-10-15 | Helix | Participant Management/Business Readiness | Helix / Elexon M10 Readiness | 6.27 | Helix | Service Activation Plan | Helix Programme Board |  | Complete | COMPLETE |  |
| 2195 | 1.6.3.6.2.8.2 | Reporting |  | 11d | 2025-10-15 A | 2025-10-29 A |  | 100% | 2025-11-18 | 2025-12-02 | 0d | start no earlier than 2025-10-15 | Helix | Participant Management/Business Readiness | Helix / Elexon M10 Readiness | 6.27 | Helix | Service Activation Plan | Helix Programme Board |  | Complete | COMPLETE |  |
| 2196 | 1.6.3.6.2.8.3 | Issue Management |  | 11d | 2025-10-15 A | 2025-10-29 A |  | 100% | 2025-10-15 | 2025-10-29 | 0d | start no earlier than 2025-10-15 | Helix | Participant Management/Business Readiness | Helix / Elexon M10 Readiness | 6.27 | Helix | Service Activation Plan | Helix Programme Board |  | Complete | COMPLETE |  |
| 2197 | 1.6.3.6.2.8.4 | Closed Down Activities |  | 3d | 2025-10-30 A | 2025-11-03 A | 2196 | 100% | 2025-11-18 | 2025-11-20 | 0d | finish no earlier than 2025-09-19 | Helix | Business Readiness | Helix / Elexon M10 Readiness | 6.27 | Helix | Service Activation Plan | Helix Programme Board |  | Complete | COMPLETE |  |
| 2198 | 1.6.3.6.2.8.5 | Inform MHHSP |  | 2d | 2025-11-04 A | 2025-11-05 A | 2197 | 100% | 2025-11-18 | 2025-11-19 | 0d | finish no earlier than 2025-09-19 | Helix |  | Helix / Elexon M10 Readiness | 6.27 | Helix | Service Activation Plan | Helix Programme Board |  | Complete | COMPLETE |  |
| 2199 | 1.6.3.6.2.8.6 | M11-Ready Service Activation Hypercare Completed | milestone | 0d | 2025-11-05 A | 2025-11-05 A | 2198 | 100% | 2025-11-19 | 2025-11-19 | 0d |  | Helix |  | Helix / Elexon M10 Readiness | 6.27 | Helix |  | Helix Programme Board |  | Complete | COMPLETE |  |

| ID | WBS | Task | Type | Duration | Start | Finish | Predecessors | Complete | Baseline start | Baseline finish | Baseline duration | Constraint | Responsible | Future RAG | Text9 | Update Version | MHHS Resource Name | Previous RAG | Text29 | Sched Status | RAG | Task Status | Text23 |
| --- | --- | --- | --- | --- | --- | --- | --- | --- | --- | --- | --- | --- | --- | --- | --- | --- | --- | --- | --- | --- | --- | --- | --- |
| 2200 | 1.6.3.6.2.9 | **Not M11-Ready Service Activation Preparation Tasks** |  | 4d | 2025-10-13 A | 2025-10-16 A | 2130 | 100% | 2025-08-25 | 2025-09-08 | 0d |  | Helix | Business Readiness | Helix / Elexon M10 Readiness | 6.27 | Helix | Service Activation Plan | Helix Programme Board |  |  |  |  |
| 2201 | 1.6.3.6.2.9.1 | Engagement / Communications with Participants |  | 1d | 2025-10-16 A | 2025-10-16 A |  | 100% | 2025-12-04 | 2025-12-04 | 0d | start no earlier than 2025-10-16 | Helix | Business Readiness/Participant Management | Helix / Elexon M10 Readiness | 6.27 | Helix | Service Activation Plan | Helix Programme Board | Complete | COMPLETE |  |  |
| 2202 | 1.6.3.6.2.9.2 | Validate User Access |  | 1d | 2025-10-13 A | 2025-10-13 A |  | 100% | 2025-12-08 | 2025-12-08 | 0d | start no earlier than 2025-10-13 | Helix | Business Readiness | Helix / Elexon M10 Readiness | 6.27 | Helix | Service Activation Plan | Helix Programme Board | Complete | COMPLETE |  |  |
| 2203 | 1.6.3.6.2.10 | **Not M11-Ready Service Activation Implementation** |  | 53d | 2025-10-30 A | 2026-01-13 A |  | 100% | 2025-12-17 | 2025-12-31 | 0d |  | Helix | MHHS Migration | Helix / Elexon M10 Readiness | 6.27 | Helix | Service Activation Plan | Helix Programme Board |  |  |  |  |
| 2204 | 1.6.3.6.2.10.1 | **First Pathway 6 PAB** |  | 16d | 2025-10-30 A | 2025-11-21 A |  | 100% |  |  |  |  | Helix |  |  | 6.28 | Helix |  | Helix Programme Board |  |  | -974.67 |  |
| 2205 | 1.6.3.6.2.10.1.1 | MHHSP Enabled Confirmation | milestone | 0d | 2025-10-30 A | 2025-10-30 A | 2411 | 100% | 2025-12-17 | 2025-12-17 | 0d | start no earlier than 2025-09-08 | PAB | MHHS qualification | Helix / Elexon M10 Readiness | 6.37 | Helix | Service Activation Plan | Helix Programme Board | Complete | COMPLETE |  |  |
| 2206 | 1.6.3.6.2.10.1.2 | Add EFD (ISD Calendar Date) to DIP | milestone | 0d | 2025-10-30 A | 2025-10-30 A | 2205 | 100% | 2025-12-18 | 2025-12-19 | 0d | start no earlier than 2025-09-11 | Helix | DIP Team | Helix / Elexon M10 Readiness | 6.37 | Helix | Service Activation Plan | Helix Programme Board | Complete | COMPLETE |  |  |
| 2207 | 1.6.3.6.2.10.1.3 | Create M16 in Customer Solution | milestone | 0d | 2025-10-31 A | 2025-10-31 A | 2205FS+1d | 100% | 2025-12-22 | 2025-12-22 | 0d | finish no earlier than 2025-10-31 | Helix | Market Entry/MHHS Qualification | Helix / Elexon M10 Readiness | 6.37 | Helix | Service Activation Plan | Helix Programme Board | Complete | COMPLETE |  | ?? |
| 2208 | 1.6.3.6.2.10.1.4 | DIP Production Success Checks | milestone | 0d | 2025-10-31 A | 2025-10-31 A | 2207 | 100% | 2025-12-23 | 2025-12-31 | 0d | finish no earlier than 2025-10-31 | Helix |  | Helix / Elexon M10 Readiness | 6.37 | Helix |  | Helix Programme Board | Complete | COMPLETE |  |  |
| 2209 | 1.6.3.6.2.10.1.5 | Publish ISD |  | 6d | 2025-11-14 A | 2025-11-21 A |  | 100% | 2025-11-14 | 2025-11-21 | 0d | start no earlier than 2025-11-14 | Helix | Participant Management | Helix / Elexon M10 Readiness | 6.37 | Helix | Service Activation Plan | Helix Programme Board | Complete | COMPLETE |  | Allan Toule |
| 2210 | 1.6.3.6.2.10.1.6 | Go Live ISD | milestone | 0d | 2025-11-21 A | 2025-11-21 A | 2209 | 100% | 2025-11-21 | 2025-11-21 | 0d | start no earlier than 2025-09-18 | Helix |  | Helix / Elexon M10 Readiness | 6.37 | Helix |  | Helix Programme Board | Complete | COMPLETE |  |  |
| 2211 | 1.6.3.6.2.10.1.7 | Publish MDD |  | 6d | 2025-11-14 A | 2025-11-21 A |  | 100% | 2025-11-14 | 2025-11-21 | 0d | start no earlier than 2025-11-14 | Helix |  | Helix / Elexon M10 Readiness | 6.37 | Helix |  | Helix Programme Board | Complete | COMPLETE |  |  |
| 2212 | 1.6.3.6.2.10.1.8 | MDD Go Live | milestone | 0d | 2025-11-21 A | 2025-11-21 A | 2211 | 100% | 2025-11-21 | 2025-11-21 | 0d |  | Helix |  | Helix / Elexon M10 Readiness | 6.37 | Helix |  | Helix Programme Board | Complete | COMPLETE |  |  |
| 2213 | 1.6.3.6.2.10.1.9 | Service Activation Implementation Completed | milestone | 0d | 2025-11-21 A | 2025-11-21 A | 2210, 2212 | 100% | 2025-11-21 | 2025-11-21 | 0d |  | Helix |  | Helix / Elexon M10 Readiness | 6.37 | Helix | Service Activation Plan | Helix Programme Board | Complete | COMPLETE |  |  |
| 2214 | 1.6.3.6.2.10.2 | **Final Pathway 6 PAB** |  | 19d | 2025-12-18 A | 2026-01-13 A |  | 100% | 2025-12-17 | 2025-12-30 | 0d |  | Helix |  | Helix / Elexon M10 Readiness | 6.28 | Helix |  | Helix Programme Board |  |  | -974.67 |  |
| 2215 | 1.6.3.6.2.10.2.1 | MHHSP Enabled Confirmation | milestone | 0d | 2025-12-18 A | 2025-12-18 A | 2413 | 100% | 2025-12-18 | 2025-12-18 | 0d | start no earlier than 2025-12-18 | PAB | MHHS qualification | Helix / Elexon M10 Readiness | 6.40 | Helix | Service Activation Plan | Helix Programme Board | Complete | COMPLETE |  |  |
| 2216 | 1.6.3.6.2.10.2.2 | Add EFD (ISD Calendar Date) to DIP | milestone | 0d | 2025-12-18 A | 2025-12-18 A | 2215 | 100% | 2025-12-18 | 2025-12-18 | 0d | start no earlier than 2025-09-11 | Helix | DIP Team | Helix / Elexon M10 Readiness | 6.40 | Helix | Service Activation Plan | Helix Programme Board | Complete | COMPLETE |  |  |
| 2217 | 1.6.3.6.2.10.2.3 | Create M16 in Customer Solution | milestone | 0d | 2025-12-18 A | 2025-12-18 A | 2215FS+1d | 100% | 2025-12-22 | 2025-12-22 | 0d | start no earlier than 2025-12-17 | Helix | Market Entry/MHHS Qualification | Helix / Elexon M10 Readiness | 6.37 | Helix | Service Activation Plan | Helix Programme Board | Complete | COMPLETE |  | ?? |
| 2218 | 1.6.3.6.2.10.2.4 | DIP Production Success Checks | milestone | 0d | 2025-12-18 A | 2025-12-18 A | 2216, 2217 | 100% | 2025-12-23 | 2025-12-23 | 0d |  | Helix |  | Helix / Elexon M10 Readiness | 6.37 | Helix |  | Helix Programme Board | Complete | COMPLETE |  |  |
| 2219 | 1.6.3.6.2.10.2.5 | Publish ISD |  | 7d | 2026-01-05 A | 2026-01-13 A | 2215FS+12d | 100% | 2026-01-05 | 2026-01-13 | 0d |  | Helix | Participant Management | Helix / Elexon M10 Readiness | 6.40 | Helix | Service Activation Plan | Helix Programme Board | Complete | COMPLETE |  | Allan Toule |
| 2220 | 1.6.3.6.2.10.2.6 | Go Live ISD | milestone | 0d | 2026-01-13 A | 2026-01-13 A | 2219 | 100% | 2026-01-13 | 2026-01-13 | 0d | start no earlier than 2025-09-18 | Helix |  | Helix / Elexon M10 Readiness | 6.40 | Helix |  | Helix Programme Board | Complete | COMPLETE |  |  |
| 2221 | 1.6.3.6.2.10.2.7 | Publish MDD |  | 7d | 2025-12-22 A | 2025-12-30 A | 2215FS+2d | 100% | 2025-12-22 | 2025-12-30 | 0d |  | Helix |  | Helix / Elexon M10 Readiness | 6.40 | Helix |  | Helix Programme Board | Complete | COMPLETE |  |  |
| 2222 | 1.6.3.6.2.10.2.8 | MDD Go Live | milestone | 0d | 2025-12-30 A | 2025-12-30 A | 2221 | 100% | 2025-12-30 | 2025-12-30 | 0d |  | Helix |  | Helix / Elexon M10 Readiness | 6.40 | Helix |  | Helix Programme Board | Complete | COMPLETE |  |  |
| 2223 | 1.6.3.6.2.10.2.9 | Service Activation Implementation Completed | milestone | 0d | 2026-01-13 A | 2026-01-13 A | 2220, 2222 | 100% | 2026-01-13 | 2026-01-13 | 0d |  | Helix |  | Helix / Elexon M10 Readiness | 6.40 | Helix | Service Activation Plan | Helix Programme Board | Complete | COMPLETE |  |  |

| ID | WBS | Task | Type | Duration | Start | Finish | Predecessors | Complete | Baseline start | Baseline finish | Baseline duration | Constraint | Responsible | Future RAG | Text9 | Update Version | MHHS Resource Name | Previous RAG | Text29 | Sched Status | RAG | Task Status |
| --- | --- | --- | --- | --- | --- | --- | --- | --- | --- | --- | --- | --- | --- | --- | --- | --- | --- | --- | --- | --- | --- | --- |
| 2224 | 1.6.3.6.2.11 | **Not M11-Ready Service Activation Hypercare** |  | 11d | 2025-12-17 A | 2025-12-31 A |  | 100% | 2025-12-17 | 2025-12-31 | 0d |  | Helix | Participant Management/Business Readiness | Helix / Elexon M10 Readiness | 6.27 | Helix | Service Activation Plan | Helix Programme Board |  |  |  |
| 2225 | 1.6.3.6.2.11.1 | Monitoring |  | 11d | 2025-12-17 A | 2025-12-31 A |  | 100% | 2025-12-17 | 2025-12-31 | 0d | start no earlier than 2025-12-17 | Helix | Participant Management/Business Readiness | Helix / Elexon M10 Readiness | 6.27 | Helix | Service Activation Plan | Helix Programme Board | Complete | COMPLETE |  |
| 2226 | 1.6.3.6.2.11.2 | Reporting |  | 11d | 2025-12-17 A | 2025-12-31 A |  | 100% | 2025-12-17 | 2025-12-31 | 0d | start no earlier than 2025-12-17 | Helix | Participant Management/Business Readiness | Helix / Elexon M10 Readiness | 6.27 | Helix | Service Activation Plan | Helix Programme Board | Complete | COMPLETE |  |
| 2227 | 1.6.3.6.2.11.3 | Issue Management |  | 11d | 2025-12-17 A | 2025-12-31 A |  | 100% | 2025-12-17 | 2025-12-31 | 0d | start no earlier than 2025-12-17 | Helix | Participant Management/Business Readiness | Helix / Elexon M10 Readiness | 6.27 | Helix | Service Activation Plan | Helix Programme Board | Complete | COMPLETE |  |
| 2228 | 1.6.3.6.2.11.4 | Closed Down Activities |  | 3d | 2025-12-29 A | 2025-12-31 A | 2225SS, 2226SS, 2227SS | 100% | 2025-12-29 | 2025-12-31 | 0d | start no earlier than 2025-12-29 | Helix | Business Readiness | Helix / Elexon M10 Readiness | 6.27 | Helix | Service Activation Plan | Helix Programme Board | Complete | COMPLETE |  |
| 2229 | 1.6.3.6.2.11.5 | Inform MHHSP |  | 2d | 2025-12-30 A | 2025-12-31 A | 2228SS | 100% | 2025-12-30 | 2025-12-31 | 0d | start no earlier than 2025-12-30 | Helix |  | Helix / Elexon M10 Readiness | 6.27 | Helix | Service Activation Plan | Helix Programme Board | Complete | COMPLETE |  |
| 2230 | 1.6.3.6.2.11.6 | Not M11-Ready Service Activation Hypercare Completed | milestone | 0d | 2025-12-31 A | 2025-12-31 A | 2229 | 100% | 2025-12-31 | 2025-12-31 | 0d |  | Helix |  |  | 6.27 | Helix |  | Helix Programme Board | Complete | COMPLETE |  |
| 2231 | 1.6.4 | **Helix Solution Build** |  | 284d? | 2024-08-19 A | 2025-09-18 A |  | 100% | 2024-08-19 | 2025-08-07 | 0d |  | Helix |  | Helix / Elexon M10 Readiness | 6.26 | Helix |  | Helix Programme Board |  |  | -940.67 |
| 2232 | 1.6.4.1 | M10 Build Candidate |  | 80d | 2025-04-28 A | 2025-08-15 A |  | 100% | 2025-04-28 | 2025-07-16 | 0d | start no earlier than 2025-04-28 | Helix |  | Helix / Elexon M10 Readiness | 6.32 | Helix |  | Helix Programme Board | Complete | COMPLETE |  |
| 2233 | 1.6.4.2 | Helix Code Uplifts |  | 24d | 2025-08-18 A | 2025-09-18 A | 2232 | 100% | 2025-08-18 | 2025-09-18 | 0d | start no earlier than 2025-07-09 | Helix |  | Helix / Elexon M10 Readiness | 6.32 | Helix |  | Helix Programme Board | Complete | COMPLETE |  |
| 2234 | 1.6.4.3 | **Helix E2E Settlement Assurance Testing (SAT)** |  | 260d? | 2024-08-19 A | 2025-08-15 A |  | 100% | 2025-01-06 | 2025-04-04 | 0d |  | Helix |  | Helix / Elexon M10 Readiness | 6.0 | Helix |  | Helix Programme Board |  |  | -689.67 |
| 2235 | 1.6.4.3.1 | **Test design** |  | 125d | 2024-09-02 A | 2025-02-21 A |  | 100% | 2024-09-02 | 2025-02-21 | 0d |  | Helix |  | Helix / Elexon M10 Readiness | 6.18 | Helix |  | Helix Programme Board |  |  | -827.67 |
| 2236 | 1.6.4.3.1.1 | SAT tests (Review and finalise) |  | 95d | 2024-09-02 A | 2025-01-10 A |  | 100% | 2024-09-02 | 2025-01-10 | 0d | start no earlier than 2024-09-02 | Helix |  | Helix / Elexon M10 Readiness | 6.18 | Helix |  | Helix Programme Board | Complete | COMPLETE |  |
| 2237 | 1.6.4.3.1.2 | Test Automation and Supporting Tools |  | 80d | 2024-11-04 A | 2025-02-21 A |  | 100% | 2024-11-04 | 2025-02-21 | 0d | start no earlier than 2024-11-04 | Helix |  | Helix / Elexon M10 Readiness | 6.18 | Helix |  | Helix Programme Board | Complete | COMPLETE |  |
| 2238 | 1.6.4.3.1.3 | SAT tests batch 3 |  | 50d | 2024-12-16 A | 2025-02-21 A |  | 100% | 2024-12-16 | 2025-02-21 | 0d | start no earlier than 2024-12-16 | Helix |  | Helix / Elexon M10 Readiness | 6.18 | Helix |  | Helix Programme Board | Complete | COMPLETE |  |
| 2239 | 1.6.4.3.2 | **Data and environment** |  | 120d? | 2024-08-19 A | 2025-01-31 A |  | 100% | 2024-08-19 | 2025-01-31 | 0d |  | Helix |  | Helix / Elexon M10 Readiness | 6.18 | Helix |  | Helix Programme Board |  |  | -827.67 |
| 2240 | 1.6.4.3.2.1 | Data and environment requirements |  | 55d | 2024-08-19 A | 2024-11-01 A |  | 100% | 2024-08-19 | 2024-11-01 | 0d | start no earlier than 2024-08-19 | Helix |  | Helix / Elexon M10 Readiness | 6.18 | Helix |  | Helix Programme Board | Complete | COMPLETE |  |
| 2241 | 1.6.4.3.2.2 | Data sourcing |  | 95d | 2024-09-02 A | 2025-01-10 A |  | 100% | 2024-09-02 | 2025-01-10 | 0d | start no earlier than 2024-09-02 | Helix |  | Helix / Elexon M10 Readiness | 6.18 | Helix |  | Helix Programme Board | Complete | COMPLETE |  |
| 2242 | 1.6.4.3.2.3 | Environment data check |  | 15d? | 2025-01-13 A | 2025-01-31 A | 2241 | 100% | 2025-01-13 | 2025-01-31 | 0d |  | Helix |  | Helix / Elexon M10 Readiness | 6.18 | Helix |  | Helix Programme Board | Complete | COMPLETE |  |
| 2243 | 1.6.4.3.3 | **Execution** |  | 200d | 2024-11-11 A | 2025-08-15 A |  | 100% | 2024-11-11 | 2025-07-03 | 0d |  | Helix |  | Helix / Elexon M10 Readiness | 6.18 | Helix |  | Helix Programme Board |  |  | -827.67 |
| 2244 | 1.6.4.3.3.1 | Trial test runs |  | 50d | 2024-11-11 A | 2025-01-17 A |  | 100% | 2024-11-11 | 2025-01-17 | 0d | start no earlier than 2024-11-11 | Helix |  | Helix / Elexon M10 Readiness | 6.18 | Helix |  | Helix Programme Board | Complete | COMPLETE |  |
| 2245 | 1.6.4.3.3.2 | Test planning prioritisation |  | 14d | 2025-01-20 A | 2025-02-06 A | 2244 | 100% | 2025-01-20 | 2025-02-06 | 0d |  | Helix |  | Helix / Elexon M10 Readiness | 6.18 | Helix |  | Helix Programme Board | Complete | COMPLETE |  |
| 2246 | 1.6.4.3.3.3 | Programme agreement to start SAT testing | milestone | 0d | 2025-02-06 A | 2025-02-06 A | 2245 | 100% | 2025-02-06 | 2025-02-06 | 0d |  | Helix |  | Helix / Elexon M10 Readiness | 6.18 | Helix |  | Helix Programme Board | Complete | COMPLETE |  |
| 2247 | 1.6.4.3.3.4 | SAT Testing Start | milestone | 0d | 2025-02-06 A | 2025-02-06 A | 2246 | 100% | 2025-02-06 | 2025-02-06 | 0d |  | Helix |  | Helix / Elexon M10 Readiness | 6.18 | Helix |  | Helix Programme Board | Complete | COMPLETE |  |

| ID | WBS | Task | Type | Duration | Start | Finish | Predecessors | Complete | Baseline start | Baseline finish | Baseline duration | Constraint | Responsible | Text9 | Update Version | MHHS Resource Name | Text29 | Task Status | Sched Status | RAG |
| --- | --- | --- | --- | --- | --- | --- | --- | --- | --- | --- | --- | --- | --- | --- | --- | --- | --- | --- | --- | --- |
| 2248 | 1.6.4.3.3.5 | **SAT Cycle 1** |  | 114d | 2025-02-07 A | 2025-07-16 A | 2247 | 100% | 2025-02-07 | 2025-04-02 | 0d |  | Helix | Helix / Elexon M10 Readiness | 6.26 | Helix | Helix Programme Board |  |  |  |
| 2249 | 1.6.4.3.3.5.1 | **Legacy** |  | 99d | 2025-02-07 A | 2025-06-25 A |  | 100% | 2025-02-07 | 2025-06-25 | 0d |  | Helix | Helix / Elexon M10 Readiness | 6.26 | Helix | Helix Programme Board | -110.67 |  |  |
| 2250 | 1.6.4.3.3.5.1.1 | GMT |  | 89d | 2025-02-07 A | 2025-06-11 A |  | 100% | 2025-02-07 | 2025-06-11 | 0d |  | Helix | Helix / Elexon M10 Readiness | 6.26 | Helix | Helix Programme Board |  | Complete | COMPLETE |
| 2251 | 1.6.4.3.3.5.1.2 | P0210 file shared for NESO Validation | milestone | 0d | 2025-05-23 A | 2025-05-23 A |  | 100% | 2025-05-23 | 2025-05-23 | 0d | start no earlier than 2025-05-23 | Helix | Helix / Elexon M10 Readiness | 6.26 | Helix | Helix Programme Board |  | Complete | COMPLETE |
| 2252 | 1.6.4.3.3.5.1.3 | NESO Validation Period (GMT) |  | 5d | 2025-05-28 A | 2025-06-03 A | 2251 | 100% | 2025-05-28 | 2025-06-03 | 0d | start no earlier than 2025-05-28 | Helix | Helix / Elexon M10 Readiness | 6.26 | Helix | Helix Programme Board |  | Complete | COMPLETE |
| 2253 | 1.6.4.3.3.5.1.4 | Long |  | 13d | 2025-05-28 A | 2025-06-13 A |  | 100% | 2025-05-28 | 2025-06-13 | 0d | start no earlier than 2025-05-28 | Helix | Helix / Elexon M10 Readiness | 6.26 | Helix | Helix Programme Board |  | Complete | COMPLETE |
| 2254 | 1.6.4.3.3.5.1.5 | Helix SAT Confidence Check 1 | milestone | 0d | 2025-06-10 A | 2025-06-10 A |  | 100% | 2025-06-10 | 2025-06-10 | 0d | finish no earlier than 2025-06-10 | Helix | Helix / Elexon M10 Readiness | 6.26 | Helix | Helix Programme Board |  | Complete | COMPLETE |
| 2255 | 1.6.4.3.3.5.1.6 | P0210 file shared for NESO Validation | milestone | 0d | 2025-06-13 A | 2025-06-13 A | 2253 | 100% | 2025-06-13 | 2025-06-13 | 0d | start no earlier than 2025-06-13 | Helix | Helix / Elexon M10 Readiness | 6.26 | Helix | Helix Programme Board |  | Complete | COMPLETE |
| 2256 | 1.6.4.3.3.5.1.7 | Helix SAT Confidence Check 2 | milestone | 0d | 2025-06-13 A | 2025-06-13 A |  | 100% | 2025-06-13 | 2025-06-13 | 0d | finish no earlier than 2025-06-13 | Helix | Helix / Elexon M10 Readiness | 6.26 | Helix | Helix Programme Board |  | Complete | COMPLETE |
| 2257 | 1.6.4.3.3.5.1.8 | NESO Validation Period (Long) |  | 5d | 2025-06-16 A | 2025-06-20 A | 2255 | 100% | 2025-06-16 | 2025-06-20 | 0d | start no earlier than 2025-06-16 | Helix | Helix / Elexon M10 Readiness | 6.26 | Helix | Helix Programme Board |  | Complete | COMPLETE |
| 2258 | 1.6.4.3.3.5.1.9 | BST |  | 13d | 2025-06-02 A | 2025-06-18 A |  | 100% | 2025-06-02 | 2025-06-18 | 0d | start no earlier than 2025-06-02 | Helix | Helix / Elexon M10 Readiness | 6.26 | Helix | Helix Programme Board |  | Complete | COMPLETE |
| 2259 | 1.6.4.3.3.5.1.10 | P0210 file shared for NESO Validation | milestone | 0d | 2025-06-18 A | 2025-06-18 A | 2258 | 100% | 2025-06-18 | 2025-06-18 | 0d |  | Helix | Helix / Elexon M10 Readiness | 6.26 | Helix | Helix Programme Board |  | Complete | COMPLETE |
| 2260 | 1.6.4.3.3.5.1.11 | NESO Validation Period (BST) |  | 5d | 2025-06-19 A | 2025-06-25 A |  | 100% | 2025-06-19 | 2025-06-25 | 0d | start no earlier than 2025-06-19 | Helix | Helix / Elexon M10 Readiness | 6.26 | Helix | Helix Programme Board |  | Complete | COMPLETE |
| 2261 | 1.6.4.3.3.5.1.12 | Trading Dispute |  | 3d | 2025-06-18 A | 2025-06-20 A |  | 100% | 2025-06-18 | 2025-06-20 | 0d | start no earlier than 2025-06-18 | Helix | Helix / Elexon M10 Readiness | 6.26 | Helix | Helix Programme Board |  | Complete | COMPLETE |
| 2262 | 1.6.4.3.3.5.2 | **Transition** |  | 36d | 2025-05-28 A | 2025-07-16 A |  | 100% | 2025-05-28 | 2025-07-16 | 0d |  | Helix | Helix / Elexon M10 Readiness | 6.26 | Helix | Helix Programme Board | -110.67 |  |  |
| 2263 | 1.6.4.3.3.5.2.1 | GMT |  | 19d | 2025-05-28 A | 2025-06-23 A |  | 100% | 2025-05-28 | 2025-06-23 | 0d | start no earlier than 2025-05-28 | Helix | Helix / Elexon M10 Readiness | 6.26 | Helix | Helix Programme Board |  | Complete | COMPLETE |
| 2264 | 1.6.4.3.3.5.2.2 | P0210 file shared for NESO Validation | milestone | 0d | 2025-06-13 A | 2025-06-13 A |  | 100% | 2025-06-13 | 2025-06-13 | 0d | finish no earlier than 2025-06-13 | Helix | Helix / Elexon M10 Readiness | 6.26 | Helix | Helix Programme Board |  | Complete | COMPLETE |
| 2265 | 1.6.4.3.3.5.2.3 | NESO Validation Period (GMT) |  | 5d | 2025-06-17 A | 2025-06-23 A | 2264 | 100% | 2025-06-17 | 2025-06-23 | 0d | finish no earlier than 2025-06-23 | Helix | Helix / Elexon M10 Readiness | 6.26 | Helix | Helix Programme Board |  | Complete | COMPLETE |
| 2266 | 1.6.4.3.3.5.2.4 | Long |  | 4d | 2025-06-24 A | 2025-06-27 A |  | 100% | 2025-06-24 | 2025-06-27 | 0d | start no earlier than 2025-06-24 | Helix | Helix / Elexon M10 Readiness | 6.26 | Helix | Helix Programme Board |  | Complete | COMPLETE |
| 2267 | 1.6.4.3.3.5.2.5 | P0210 file shared for NESO Validation | milestone | 0d | 2025-06-27 A | 2025-06-27 A | 2266 | 100% | 2025-06-27 | 2025-06-27 | 0d |  | Helix | Helix / Elexon M10 Readiness | 6.26 | Helix | Helix Programme Board |  | Complete | COMPLETE |
| 2268 | 1.6.4.3.3.5.2.6 | NESO Validation Period (Long) |  | 5d | 2025-06-30 A | 2025-07-04 A | 2267 | 100% | 2025-06-30 | 2025-07-04 | 0d | start no earlier than 2025-06-30 | Helix | Helix / Elexon M10 Readiness | 6.26 | Helix | Helix Programme Board |  | Complete | COMPLETE |
| 2269 | 1.6.4.3.3.5.2.7 | BST |  | 4d | 2025-06-26 A | 2025-07-01 A |  | 100% | 2025-06-26 | 2025-07-01 | 0d | start no earlier than 2025-06-26 | Helix | Helix / Elexon M10 Readiness | 6.26 | Helix | Helix Programme Board |  | Complete | COMPLETE |
| 2270 | 1.6.4.3.3.5.2.8 | P0210 file shared for NESO Validation | milestone | 0d | 2025-07-01 A | 2025-07-01 A | 2269 | 100% | 2025-07-01 | 2025-07-01 | 0d |  | Helix | Helix / Elexon M10 Readiness | 6.26 | Helix | Helix Programme Board |  | Complete | COMPLETE |
| 2271 | 1.6.4.3.3.5.2.9 | NESO Validation Period (BST) |  | 5d | 2025-07-03 A | 2025-07-09 A | 2270 | 100% | 2025-07-03 | 2025-07-09 | 0d | finish no earlier than 2025-07-09 | Helix | Helix / Elexon M10 Readiness | 6.26 | Helix | Helix Programme Board |  | Complete | COMPLETE |
| 2272 | 1.6.4.3.3.5.2.10 | Short |  | 7d | 2025-07-01 A | 2025-07-09 A |  | 100% | 2025-07-01 | 2025-07-03 | 0d | start no earlier than 2025-07-01 | Helix | Helix / Elexon M10 Readiness | 6.26 | Helix | Helix Programme Board |  | Complete | COMPLETE |
| 2273 | 1.6.4.3.3.5.2.11 | P0210 file shared for NESO Validation | milestone | 0d | 2025-07-03 A | 2025-07-03 A | 2272 | 100% | 2025-07-03 | 2025-07-03 | 0d |  | Helix | Helix / Elexon M10 Readiness | 6.26 | Helix | Helix Programme Board |  | Complete | COMPLETE |
| 2274 | 1.6.4.3.3.5.2.12 | NESO Validation Period (Short) |  | 5d | 2025-07-08 A | 2025-07-14 A | 2273 | 100% | 2025-07-04 | 2025-07-10 | 0d | start no earlier than 2025-07-08 | Helix | Helix / Elexon M10 Readiness | 6.26 | Helix | Helix Programme Board |  | Complete | COMPLETE |
| 2275 | 1.6.4.3.3.5.2.13 | DCP MPAN Mig |  | 3d | 2025-07-01 A | 2025-07-03 A |  | 100% | 2025-07-01 | 2025-07-03 | 0d | start no earlier than 2025-07-01 | Helix | Helix / Elexon M10 Readiness | 6.26 | Helix | Helix Programme Board |  | Complete | COMPLETE |
| 2276 | 1.6.4.3.3.5.2.14 | ISD |  | 3d | 2025-07-01 A | 2025-07-03 A |  | 100% | 2025-07-01 | 2025-07-03 | 0d | start no earlier than 2025-07-01 | Helix | Helix / Elexon M10 Readiness | 6.26 | Helix | Helix Programme Board |  | Complete | COMPLETE |
| 2277 | 1.6.4.3.3.5.2.15 | Data Agg |  | 6d | 2025-07-04 A | 2025-07-11 A |  | 100% | 2025-07-04 | 2025-07-11 | 0d | start no earlier than 2025-07-04 | Helix | Helix / Elexon M10 Readiness | 6.26 | Helix | Helix Programme Board |  | Complete | COMPLETE |
| 2278 | 1.6.4.3.3.5.2.16 | M16 |  | 3d | 2025-07-14 A | 2025-07-16 A |  | 100% | 2025-07-14 | 2025-07-16 | 0d | start no earlier than 2025-07-14 | Helix | Helix / Elexon M10 Readiness | 6.26 | Helix | Helix Programme Board |  | Complete | COMPLETE |
| 2279 | 1.6.4.3.3.5.2.17 | End of Cycle 1 | milestone | 0d | 2025-07-16 A | 2025-07-16 A |  | 100% | 2025-07-16 | 2025-07-16 | 0d | start no earlier than 2025-07-16 | Helix | Helix / Elexon M10 Readiness | 6.26 | Helix | Helix Programme Board |  | Complete | COMPLETE |

| ID | WBS | Task | Type | Duration | Start | Finish | Predecessors | Complete | Baseline start | Baseline finish | Baseline duration | Constraint | Responsible | Text9 | Task Status | Update Version | MHHS Resource Name | Text29 | Sched Status | RAG |
| --- | --- | --- | --- | --- | --- | --- | --- | --- | --- | --- | --- | --- | --- | --- | --- | --- | --- | --- | --- | --- |
| 2280 | 1.6.4.3.3.6 | **SAT Cycle 2** |  | 12d | 2025-07-17 A | 2025-08-01 A |  | 100% | 2025-07-17 | 2025-08-01 | 0d |  | Helix | Helix / Elexon M10 Readiness | -940.67 | 6.26 | Helix | Helix Programme Board |  |  |
| 2281 | 1.6.4.3.3.6.1 | **Legacy** |  | 12d | 2025-07-17 A | 2025-08-01 A |  | 100% | 2025-07-17 | 2025-08-01 | 0d |  | Helix | Helix / Elexon M10 Readiness | -940.67 | 6.26 | Helix | Helix Programme Board |  |  |
| 2282 | 1.6.4.3.3.6.1.1 | Pre-M10 |  | 1d | 2025-07-17 A | 2025-07-17 A |  | 100% | 2025-07-17 | 2025-07-17 | 0d | start no earlier than 2025-07-17 | Helix | Helix / Elexon M10 Readiness |  | 6.26 | Helix | Helix Programme Board | Complete | COMPLETE |
| 2283 | 1.6.4.3.3.6.1.2 | GMT & BST & Long |  | 6d | 2025-07-18 A | 2025-07-25 A |  | 100% | 2025-07-18 | 2025-07-25 | 0d | start no earlier than 2025-07-18 | Helix | Helix / Elexon M10 Readiness |  | 6.26 | Helix | Helix Programme Board | Complete | COMPLETE |
| 2284 | 1.6.4.3.3.6.1.3 | NESO Validation Period (GMT & BST & Long) |  | 5d | 2025-07-28 A | 2025-08-01 A | 2283 | 100% | 2025-07-28 | 2025-08-01 | 0d |  | Helix | Helix / Elexon M10 Readiness |  | 6.26 | Helix | Helix Programme Board | Complete | COMPLETE |
| 2285 | 1.6.4.3.3.6.1.4 | Trading Dispute |  | 2d | 2025-07-28 A | 2025-07-29 A |  | 100% | 2025-07-28 | 2025-07-29 | 0d | start no earlier than 2025-07-28 | Helix | Helix / Elexon M10 Readiness |  | 6.26 | Helix | Helix Programme Board | Complete | COMPLETE |
| 2286 | 1.6.4.3.3.6.2 | **Transition** |  | 4d | 2025-07-24 A | 2025-07-29 A |  | 100% | 2025-07-24 | 2025-07-29 | 0d |  | Helix | Helix / Elexon M10 Readiness | -940.67 | 6.26 | Helix | Helix Programme Board |  |  |
| 2287 | 1.6.4.3.3.6.2.1 | ISD |  | 4d | 2025-07-24 A | 2025-07-29 A |  | 100% | 2025-07-24 | 2025-07-29 | 0d | start no earlier than 2025-07-24 | Helix | Helix / Elexon M10 Readiness |  | 6.26 | Helix | Helix Programme Board | Complete | COMPLETE |
| 2288 | 1.6.4.3.3.6.2.2 | Data Agg |  | 3d | 2025-07-24 A | 2025-07-28 A |  | 100% | 2025-07-24 | 2025-07-28 | 0d | start no earlier than 2025-07-24 | Helix | Helix / Elexon M10 Readiness |  | 6.26 | Helix | Helix Programme Board | Complete | COMPLETE |
| 2289 | 1.6.4.3.3.6.3 | End of Cycle 2 | milestone | 0d | 2025-08-01 A | 2025-08-01 A |  | 100% | 2025-08-01 | 2025-08-01 | 0d | start no earlier than 2025-08-01 | Helix | Helix / Elexon M10 Readiness |  | 6.26 | Helix | Helix Programme Board | Complete | COMPLETE |
| 2290 | 1.6.4.3.3.7 | SAT Exit Report |  | 11d | 2025-08-01 A | 2025-08-15 A | 2289 | 100% | 2025-08-01 | 2025-08-15 | 0d |  | Helix | Helix / Elexon M10 Readiness |  | 6.31 | Helix | Helix Programme Board | Complete | COMPLETE |
| 2291 | 1.6.4.3.4 | SAT Complete | milestone | 0d | 2025-08-01 A | 2025-08-01 A |  | 100% | 2025-08-01 | 2025-08-01 | 0d | start no earlier than 2025-08-01 | Helix | Helix / Elexon M10 Readiness |  | 6.26 | Helix | Helix Programme Board | Complete | COMPLETE |
| 2292 | 1.6.4.4 | DR Testing |  | 90d | 2025-04-28 A | 2025-08-29 A |  | 100% | 2025-04-28 | 2025-06-06 | 0d | start no earlier than 2025-04-28 | Helix | Helix / Elexon M10 Readiness |  | 6.30 | Helix | Helix Programme Board | Complete | COMPLETE |
| 2293 | 1.6.4.5 | Pen Testing |  | 40d? | 2025-04-28 A | 2025-06-20 A |  | 100% | 2025-04-28 | 2025-06-20 | 0d | start no earlier than 2025-04-28 | Helix | Helix / Elexon M10 Readiness |  | 6.26 | Helix | Helix Programme Board | Complete | COMPLETE |
| 2294 | 1.6.4.6 | Production Environment Build |  | 35d | 2025-06-30 A | 2025-08-15 A |  | 100% | 2025-06-30 | 2025-07-31 | 0d | finish no earlier than 2025-07-31 | Helix | Helix / Elexon M10 Readiness |  | 6.28 | Helix | Helix Programme Board | Complete | COMPLETE |
| 2295 | 1.6.4.7 | Production Environment Base Platform Sign-off | milestone | 0d | 2025-08-15 A | 2025-08-15 A | 2294FF | 100% | 2025-08-08 | 2025-08-08 | 0d | finish no earlier than 2025-08-08 | Helix | Helix / Elexon M10 Readiness |  | 6.28 | Helix | Helix Programme Board | Complete | COMPLETE |
| 2296 | 1.6.5 | **Implementation (Helix & DIP)** |  | 116d | 2025-04-28 A | 2025-10-06 A |  | 100% | 2025-04-28 | 2025-10-06 | 0d |  | Helix | Helix / Elexon M10 Readiness | -940.67 | 6.26 | Helix | Helix Programme Board |  |  |
| 2297 | 1.6.5.1 | Go / No-Go (DIP & SM) | milestone | 0d | 2025-07-31 A | 2025-07-31 A | 2030, 2047, 2048, 2049 | 100% | 2025-07-31 | 2025-07-31 | 0d | start no earlier than 2025-07-31 | Helix | Helix / Elexon M10 Readiness |  | 6.26 | Helix | Helix Programme Board | Complete | COMPLETE |
| 2298 | 1.6.5.2 | Implementation Readiness (inc Technical Readiness, Approach and Runbook, Walkthrough / Rehearsals |  | 71d | 2025-04-28 A | 2025-08-04 A |  | 100% | 2025-04-28 | 2025-08-04 | 0d | start no earlier than 2025-04-28 | Helix | Helix / Elexon M10 Readiness |  | 6.28 | Helix | Helix Programme Board | Complete | COMPLETE |
| 2299 | 1.6.5.3 | M10 Implementation Approach & Go-Live Runbook |  | 46d | 2025-04-28 A | 2025-06-30 A |  | 100% | 2025-04-28 | 2025-06-06 | 0d | start no earlier than 2025-04-28 | Helix | Helix / Elexon M10 Readiness |  | 6.28 | Helix | Helix Programme Board | Complete | COMPLETE |
| 2300 | 1.6.5.4 | DIP Production Build |  | 15d | 2025-06-09 A | 2025-06-27 A |  | 100% | 2025-06-09 | 2025-06-27 | 0d | start no earlier than 2025-06-09 | Helix | Helix / Elexon M10 Readiness |  | 6.28 | Helix | Helix Programme Board | Complete | COMPLETE |
| 2301 | 1.6.5.5 | Final Production Deployment |  | 30d | 2025-07-07 A | 2025-08-15 A |  | 100% | 2025-07-07 | 2025-07-31 | 0d | start no earlier than 2025-07-07 | Helix | Helix / Elexon M10 Readiness |  | 6.28 | Helix | Helix Programme Board | Complete | COMPLETE |
| 2302 | 1.6.5.6 | DIP Portal Available | milestone | 0d | 2025-08-04 A | 2025-08-04 A | 2301 | 100% | 2025-08-04 | 2025-08-04 | 0d | finish no earlier than 2025-08-04 | Helix | Helix / Elexon M10 Readiness |  | 6.28 | Helix | Helix Programme Board | Complete | COMPLETE |
| 2303 | 1.6.5.7 | Go / No-Go (Helix Central Systems) | milestone | 0d | 2025-08-12 A | 2025-08-12 A | 2291, 2295, 1568 | 100% | 2025-08-08 | 2025-08-08 | 0d | start no earlier than 2025-08-12 | Helix | Helix / Elexon M10 Readiness |  | 6.28 | Helix | Helix Programme Board | Complete | COMPLETE |
| 2304 | 1.6.5.8 | ISD Data Migration |  | 10d | 2025-08-18 A | 2025-08-29 A | 2303, 2290 | 100% | 2025-08-15 | 2025-08-26 | 0d |  | Helix | Helix / Elexon M10 Readiness |  | 6.32 | Helix | Helix Programme Board | Complete | COMPLETE |
| 2305 | 1.6.5.9 | DAH & ISD Dark Mode | milestone | 0d | 2025-09-01 A | 2025-09-01 A | 2304 | 100% | 2025-08-26 | 2025-08-26 | 0d | start no earlier than 2025-09-01 | Helix | Helix / Elexon M10 Readiness |  | 6.32 | Helix | Helix Programme Board | Complete | COMPLETE |
| 2306 | 1.6.5.10 | VAS Inspection pre-prod |  | 16d | 2025-08-27 A | 2025-09-17 A |  | 100% | 2025-08-27 | 2025-09-17 | 0d | start no earlier than 2025-08-27 | Helix | Helix / Elexon M10 Readiness |  | 6.32 | Helix | Helix Programme Board | Complete | COMPLETE |
| 2307 | 1.6.5.11 | M10 Cutover Weekend (20/09 and 21/09) |  | 2d | 2025-09-19 A | 2025-09-22 A | 2306 | 100% | 2025-09-22 | 2025-09-22 | 0d | start no earlier than 2025-09-19 | Helix | Helix / Elexon M10 Readiness |  | 6.32 | Helix | Helix Programme Board | Complete | COMPLETE |
| 2308 | 1.6.5.12 | Post Implementation Review |  | 1d | 2025-10-06 A | 2025-10-06 A | 2307FS+9d | 100% | 2025-10-06 | 2025-10-06 | 0d | start no earlier than 2025-10-06 | Helix | Helix / Elexon M10 Readiness |  | 6.32 | Helix | Helix Programme Board | Complete | COMPLETE |

| ID | WBS | Task | Type | Duration | Start | Finish | Predecessors | Complete | Remaining | Baseline start | Baseline finish | Baseline duration | Baseline 1 start | Baseline 1 finish | Total slack | Constraint | Baseline cost | Responsible | Task Status | Update Version | MHHS Resource Name | Text29 | Sched Status | RAG | Involved | Text9 | MHHS Programme Phase | Milestone ID | Tier |
| --- | --- | --- | --- | --- | --- | --- | --- | --- | --- | --- | --- | --- | --- | --- | --- | --- | --- | --- | --- | --- | --- | --- | --- | --- | --- | --- | --- | --- | --- |
| 2309 | 1.7 | **ELEXON / HELIX M10 - M16** |  | 65d | 2026-04-01 A | 2026-06-30 A |  | 100% |  | 2025-09-03 | 2026-12-09 | 0d |  |  |  |  |  | Helix | -1053.67 | 6.34 | Helix | Helix Programme Board |  |  |  |  |  |  |  |
| 2310 | 1.7.1 | **SAT M16 Test Case Execution** |  | 65d | 2026-04-01 A | 2026-06-30 A |  | 100% |  | 2026-04-01 | 2026-06-30 | 0d |  |  |  |  |  | Helix | 138.33 | 6.44 | Helix | Helix Programme Board | Complete | COMPLETE |  |  |  |  |  |
| 2311 | 1.7.1.1 | SAT Prep / Analysis |  | 22d | 2026-04-01 A | 2026-04-30 A |  | 100% |  | 2026-04-01 | 2026-04-30 | 0d |  |  |  | start no earlier than 2026-04-01 |  |  |  | 6.44 | Helix | Helix Programme Board | Complete | COMPLETE |  |  |  |  |  |
| 2312 | 1.7.1.2 | SAT Functional Work / Bug Dependency |  | 21d | 2026-05-01 A | 2026-05-29 A | 2311 | 100% |  | 2026-05-01 | 2026-05-29 | 0d |  |  |  | start no earlier than 2026-05-01 |  |  |  | 6.44 | Helix | Helix Programme Board | Complete | COMPLETE |  |  |  |  |  |
| 2313 | 1.7.1.3 | SAT Test & Sign-off of Two Cases (Elexon Internal Sign-off) |  | 22d | 2026-06-01 A | 2026-06-30 A | 2312 | 100% |  | 2026-06-01 | 2026-06-30 | 0d |  |  |  | start no earlier than 2026-06-01 |  |  |  | 6.44 | Helix | Helix Programme Board | Complete | COMPLETE |  |  |  |  |  |
| 2314 | 1.7.1.4 | SAT Programme Assurance Review of Test Results |  | 65d | 2026-04-01 A | 2026-06-30 A |  | 100% |  | 2026-04-01 | 2026-06-30 | 0d |  |  |  | start no earlier than 2026-04-01 |  |  |  | 6.44 | Helix | Helix Programme Board | Complete | COMPLETE |  |  |  |  |  |
| 2315 | 1.7.2 | LSS provides Load Shape data that is publicly accessible - Business Requirement MHHSP-37 | milestone | 0d | 2026-04-08 A | 2026-04-08 A | 3383FS+120d | 100% |  | 2026-04-08 | 2026-04-08 | 0d |  |  |  |  |  | Helix |  | 6.35 | Helix | Helix Programme Board | Complete | COMPLETE |  |  |  |  |  |
| 2316 | 1.8 | **S & A QUALIFICATION** |  | 807d? | 2023-11-07 A | 2026-12-09 |  | 99% | 0d? | 2023-11-07 | 2027-01-28 | 603d | 2024-01-29 | 2024-07-05 | 271d |  | -0 | N/A | -461.67 | 5.24 | N/A |  |  |  | N/A | S&A Qualification | Systems Integration Testing (SIT) |  |  |
| 2317 | 1.8.1 | **MHHS Qualification - Qualification Deliverables** |  | 509d | 2023-11-07 A | 2025-10-17 A |  | 100% |  | 2023-11-07 | 2025-08-14 | 349d |  |  |  |  | -0 | N/A | -131.67 | 5.24 | N/A |  |  |  | N/A | S&A Qualification |  |  |  |
| 2318 | 1.8.1.1 | **BSC & REC Assessment Criteria** |  | 463d | 2023-11-07 A | 2025-08-14 A |  | 100% |  | 2023-11-07 | 2025-08-14 | 212d |  |  |  |  | -0 | N/A | -131.67 | 5.24 | N/A |  |  |  | N/A | S&A Qualification |  |  |  |
| 2319 | 1.8.1.1.1 | Draft BSC Assessment Criteria (Functional) |  | 21d | 2023-11-07 A | 2023-12-05 A |  | 100% |  | 2023-11-07 | 2023-12-05 | 21d |  |  |  | finish no earlier than 2023-12-05 |  | Code Bodies |  | 5.24 | Ben Gilbert |  | Complete | COMPLETE | Code Bodies | S&A Qualification |  |  |  |
| 2320 | 1.8.1.1.2 | BSC PAB Review |  | 1d | 2023-12-14 A | 2023-12-14 A |  | 100% |  | 2023-12-14 | 2023-12-14 | 1d |  |  |  | start no earlier than 2023-12-14 |  | Code Bodies |  | 5.24 | Ben Gilbert |  | Complete | COMPLETE | Code Bodies | S&A Qualification |  |  |  |
| 2321 | 1.8.1.1.3 | Update BSC Assessment Criteria (Functional, Non-Functional, Migration) |  | 30d | 2024-02-07 A | 2024-03-19 A |  | 100% |  | 2024-02-07 | 2024-03-19 | 30d |  |  |  | finish no earlier than 2024-03-19 |  | Code Bodies |  | 5.24 | Ben Gilbert |  | Complete | COMPLETE | Code Bodies | S&A Qualification |  |  |  |
| 2322 | 1.8.1.1.4 | REC & BSC PAB Approval |  | 3d | 2024-03-26 A | 2024-03-28 A |  | 100% |  | 2024-03-26 | 2024-03-28 | 3d |  |  |  | start no earlier than 2024-03-28 |  | Code Bodies |  | 5.24 | Ben Gilbert |  | Complete | COMPLETE | Code Bodies | S&A Qualification |  |  |  |
| 2323 | 1.8.1.1.5 | Update BSC Assessment Criteria (Functional, Non-Functional, Migration, Operational) |  | 20d | 2024-07-24 A | 2024-08-20 A |  | 100% |  | 2024-07-24 | 2024-08-20 | 20d |  |  |  |  |  | Code Bodies |  | 5.24 | Ben Gilbert |  | Complete | COMPLETE | Code Bodies | S&A Qualification |  |  |  |
| 2324 | 1.8.1.1.6 | Assessment Criteria (Functional, Non-Functional, Migration, Operational) Approved by REC PAB and BSC PAB |  | 250d | 2024-08-29 A | 2025-08-14 A | 2323FS+7d | 100% |  | 2024-08-29 | 2025-08-14 | 0d |  |  |  | start no earlier than 2023-09-15 |  | Code Bodies |  | 5.25 | Ben Gilbert | QAG | Complete | COMPLETE | Code Bodies | S&A Qualification |  | T3-QU-0080 | T3 |
| 2325 | 1.8.1.2 | **Qualification Approach and Plan** |  | 194d | 2023-12-04 A | 2024-08-29 A |  | 100% |  | 2023-12-04 | 2024-08-29 | 194d |  |  |  |  | -0 | N/A | -131.67 | 5.24 | Ben Gilbert |  |  |  | N/A | S&A Qualification |  |  |  |
| 2326 | 1.8.1.2.1 | **Qualification Approach and Plan v2** |  | 84d | 2023-12-04 A | 2024-03-28 A |  | 100% |  | 2023-12-04 | 2024-03-28 | 84d |  |  |  |  | -0 | N/A | -131.67 | 5.24 | Ben Gilbert |  |  |  | N/A | S&A Qualification |  |  |  |
| 2327 | 1.8.1.2.1.1 | Draft Qualification Approach and Plan v2 |  | 30d | 2023-12-04 A | 2024-01-12 A |  | 100% |  | 2023-12-04 | 2024-01-12 | 30d |  |  |  | finish no earlier than 2024-01-12 |  | Code Bodies |  | 5.24 | Ben Gilbert |  | Complete | COMPLETE | Code Bodies | S&A Qualification |  |  |  |
| 2328 | 1.8.1.2.1.2 | Internal Review (Code Bodies and MHHSP) for Qualification Approach and Plan V2 |  | 10d | 2024-01-15 A | 2024-01-26 A | 2327 | 100% |  | 2024-01-15 | 2024-01-26 | 10d |  |  |  | finish no earlier than 2024-01-26 |  | Code Bodies, SI Team, SRO |  | 5.24 | Ben Gilbert |  | Complete | COMPLETE | Code Bodies, SI Team, SRO | S&A Qualification |  |  |  |
| 2329 | 1.8.1.2.1.3 | Industry consultation for Qualification Approach and Plan v2 |  | 11d | 2024-01-31 A | 2024-02-14 A | 2328 | 100% |  | 2024-01-31 | 2024-02-14 | 11d |  |  |  | start no earlier than 2024-01-31 |  | Participants |  | 5.24 | Ben Gilbert |  | Complete | COMPLETE | Participants | S&A Qualification |  |  |  |
| 2330 | 1.8.1.2.1.4 | Update Qualification Approach and Plan v2 post industry consultation |  | 10d | 2024-02-15 A | 2024-02-28 A | 2329 | 100% |  | 2024-02-15 | 2024-02-28 | 10d |  |  |  |  |  | Code Bodies |  | 5.24 | Ben Gilbert |  | Complete | COMPLETE | Code Bodies | S&A Qualification |  |  |  |
| 2331 | 1.8.1.2.1.5 | QWG Endorsement of Qualification Approach and Plan v2 |  | 1d | 2024-03-12 A | 2024-03-12 A |  | 100% |  | 2024-03-12 | 2024-03-12 | 1d |  |  |  | start no earlier than 2024-03-12 |  | Code Bodies |  | 5.24 | Ben Gilbert |  | Complete | COMPLETE | Code Bodies | S&A Qualification |  |  |  |
| 2332 | 1.8.1.2.1.6 | QAG Approval of Qualification Approach and Plan v2 |  | 1d | 2024-03-21 A | 2024-03-21 A |  | 100% |  | 2024-03-21 | 2024-03-21 | 1d |  |  |  | start no earlier than 2024-03-21 |  | Code Bodies |  | 5.24 | Ben Gilbert |  | Complete | COMPLETE | Code Bodies | S&A Qualification |  |  |  |
| 2333 | 1.8.1.2.1.7 | BSC and REC PAB Approval of Qualification Approach and Plan v2 |  | 3d | 2024-03-26 A | 2024-03-28 A |  | 100% |  | 2024-03-26 | 2024-03-28 | 3d |  |  |  | finish no earlier than 2024-03-28 |  | Code Bodies |  | 5.24 | Ben Gilbert |  | Complete | COMPLETE | Code Bodies | S&A Qualification |  |  |  |
| 2334 | 1.8.1.2.1.8 | Functional Testing elements of Qualification Approach & Plan v2 approvement by REC PAB and BSC PAB | milestone | 0d | 2024-03-28 A | 2024-03-28 A | 2333 | 100% |  | 2024-03-28 | 2024-03-28 | 0d |  |  |  |  |  | Code Bodies |  | 5.24 | Ben Gilbert | QAG | Complete | COMPLETE | Code Bodies | S&A Qualification |  | T3-QU-0063 | T3 |
| 2335 | 1.8.1.2.1.9 | Migration Testing elements of Qualification Approach & Plan v2 appoved by REC PAB and BSC PAB | milestone | 0d | 2024-03-28 A | 2024-03-28 A | 2333 | 100% |  | 2024-03-28 | 2024-03-28 | 0d |  |  |  |  |  | Code Bodies |  | 5.24 | Ben Gilbert | QAG | Complete | COMPLETE | Code Bodies | S&A Qualification |  | T3-QU-0064 | T3 |

| ID | WBS | Task | Type | Duration | Start | Finish | Predecessors | Complete | Baseline start | Baseline finish | Baseline duration | Constraint | Baseline cost | Responsible | Involved | Text9 | Task Status | Update Version | MHHS Resource Name | Sched Status | RAG | Milestone ID | Text29 | Tier |
| --- | --- | --- | --- | --- | --- | --- | --- | --- | --- | --- | --- | --- | --- | --- | --- | --- | --- | --- | --- | --- | --- | --- | --- | --- |
| 2336 | 1.8.1.2.2 | **Qualification Approach and Plan v3** |  | 84d | 2024-05-06 A | 2024-08-29 A |  | 100% | 2024-05-06 | 2024-08-29 | 84d |  | -0 | N/A | N/A | S&A Qualification | -133.67 | 5.24 | Ben Gilbert |  |  |  |  |  |
| 2337 | 1.8.1.2.2.1 | Draft Qualification Approach and Plan v3 |  | 35d | 2024-05-06 A | 2024-06-21 A | 1068 | 100% | 2024-05-06 | 2024-06-21 | 35d | finish no earlier than 2024-05-17 |  | Code Bodies | Code Bodies | S&A Qualification |  | 5.27 | Ben Gilbert | Complete | COMPLETE |  |  |  |
| 2338 | 1.8.1.2.2.2 | Internal Review (Code Bodies and MHHSP) of Qualification Approach and Plan v3 |  | 10d | 2024-06-24 A | 2024-07-05 A | 2337 | 100% | 2024-06-24 | 2024-07-05 | 10d |  |  | Code Bodies, SI Team, SRO | Code Bodies, SI Team, SRO | S&A Qualification |  | 5.27 | Ben Gilbert | Complete | COMPLETE |  |  |  |
| 2339 | 1.8.1.2.2.3 | Industry consultation for Qualification Approach and Plan v3 |  | 10d | 2024-07-08 A | 2024-07-19 A | 2338 | 100% | 2024-07-08 | 2024-07-19 | 10d |  |  | Participants | Participants | S&A Qualification |  | 5.27 | Ben Gilbert | Complete | COMPLETE |  |  |  |
| 2340 | 1.8.1.2.2.4 | Update Qualification Approach and Plan v3 Post-Consultation |  | 10d | 2024-07-22 A | 2024-08-02 A | 2339 | 100% | 2024-07-22 | 2024-08-02 | 10d |  |  | Code Bodies | Code Bodies | S&A Qualification |  | 5.27 | Ben Gilbert | Complete | COMPLETE |  |  |  |
| 2341 | 1.8.1.2.2.5 | QWG Endorsement of Qualification Approach and Plan v3 |  | 1d | 2024-08-13 A | 2024-08-13 A | 2340FS+6d | 100% | 2024-08-13 | 2024-08-13 | 1d |  |  | Code Bodies | Code Bodies | S&A Qualification |  | 5.27 | Ben Gilbert | Complete | COMPLETE |  |  |  |
| 2342 | 1.8.1.2.2.6 | QAG Approval of Qualification Approach and Plan v3 | milestone | 0d | 2024-08-22 A | 2024-08-22 A | 2341FS+7d | 100% | 2024-08-22 | 2024-08-22 | 0d |  |  | Code Bodies | Code Bodies | S&A Qualification |  | 5.27 | Ben Gilbert | Complete | COMPLETE | T3-QU-0081 | QAG | T3 |
| 2343 | 1.8.1.2.2.7 | BSC and REC PAB Approval of Qualification Approach and Plan v3 |  | 3d | 2024-08-27 A | 2024-08-29 A | 2342FS+2d | 100% | 2024-08-27 | 2024-08-29 | 3d |  |  | Code Bodies | Code Bodies | S&A Qualification |  | 5.27 | Ben Gilbert | Complete | COMPLETE |  |  |  |
| 2344 | 1.8.1.2.2.8 | Non-Functional Testing elements of Qualification Approach and Plan v3 approved by REC PAB and BSC PAB | milestone | 0d | 2024-08-29 A | 2024-08-29 A | 2343 | 100% | 2024-08-29 | 2024-08-29 | 0d |  |  | Code Bodies | Code Bodies | S&A Qualification |  | 5.27 | Ben Gilbert | Complete | COMPLETE | T3-QU-0065 | QAG | T3 |
| 2345 | 1.8.1.3 | **Qualification Assessment Document** |  | 476d | 2023-12-22 A | 2025-10-17 A |  | 100% | 2023-12-22 | 2025-03-07 | 316d |  | -0 | N/A | N/A | S&A Qualification | -131.67 | 5.24 | Ben Gilbert |  |  |  |  |  |
| 2346 | 1.8.1.3.1 | **Qualification Assessment Document v1** |  | 70d | 2023-12-22 A | 2024-03-28 A |  | 100% | 2023-12-22 | 2024-03-28 | 70d |  | -0 | N/A | N/A | S&A Qualification | -131.67 | 5.24 | Ben Gilbert |  |  |  |  |  |
| 2347 | 1.8.1.3.1.1 | Draft Qualification Assessment Document v1 |  | 30d | 2023-12-22 A | 2024-02-01 A |  | 100% | 2023-12-22 | 2024-02-01 | 30d | finish no earlier than 2024-02-01 |  | Code Bodies | Code Bodies | S&A Qualification |  | 5.24 | Ben Gilbert | Complete | COMPLETE |  |  |  |
| 2348 | 1.8.1.3.1.2 | Internal Review (Code Bodies and MHHSP) of Qualification Assessment Document v1 |  | 10d | 2024-02-01 A | 2024-02-14 A |  | 100% | 2024-02-01 | 2024-02-14 | 10d | finish no earlier than 2024-02-14 |  | Code Bodies, SI Team, SRO | Code Bodies, SI Team, SRO | S&A Qualification |  | 5.24 | Ben Gilbert | Complete | COMPLETE |  |  |  |
| 2349 | 1.8.1.3.1.3 | Industry consultation for Qualification Assessment Document v1 |  | 11d | 2024-02-16 A | 2024-03-01 A |  | 100% | 2024-02-16 | 2024-03-01 | 11d | start no earlier than 2024-02-16 |  | Participants | Participants | S&A Qualification |  | 5.24 | Ben Gilbert | Complete | COMPLETE |  |  |  |
| 2350 | 1.8.1.3.1.4 | Update Post-Consultation for Qualification Assessment Document v1 |  | 10d | 2024-03-04 A | 2024-03-15 A | 2349 | 100% | 2024-03-04 | 2024-03-15 | 10d |  |  | Code Bodies | Code Bodies | S&A Qualification |  | 5.24 | Ben Gilbert | Complete | COMPLETE |  |  |  |
| 2351 | 1.8.1.3.1.5 | BSC and REC PAB Approval of Qualification Assessment Document v1 |  | 3d | 2024-03-26 A | 2024-03-28 A |  | 100% | 2024-03-26 | 2024-03-28 | 3d | start no earlier than 2024-03-26 |  | Code Bodies | Code Bodies | S&A Qualification |  | 5.24 | Ben Gilbert | Complete | COMPLETE |  |  |  |
| 2352 | 1.8.1.3.1.6 | Qualification Assessment Document v1 approved by REC PAB and BSC PAB | milestone | 0d | 2024-03-28 A | 2024-03-28 A | 2351 | 100% | 2024-03-28 | 2024-03-28 | 0d |  |  | Code Bodies | Code Bodies | S&A Qualification |  | 5.24 | Ben Gilbert | Complete | COMPLETE | T3-QU-0066 | QAG | T3 |
| 2353 | 1.8.1.3.2 | **Qualification Assessment Document v3** |  | 110d | 2024-03-29 A | 2024-08-29 A |  | 100% | 2024-03-29 | 2024-08-29 | 110d |  | -0 | N/A | N/A | S&A Qualification | -131.67 | 5.24 | Ben Gilbert |  |  |  |  |  |
| 2354 | 1.8.1.3.2.1 | Draft Qualification Assessment Document V1.1 |  | 26d | 2024-03-29 A | 2024-05-03 A | 2352 | 100% | 2024-03-29 | 2024-05-03 | 26d |  |  | Code Bodies |  | S&A Qualification |  | 5.24 | Ben Gilbert | Complete | COMPLETE |  |  |  |
| 2355 | 1.8.1.3.2.2 | Industry Consultation for Qualification Assessment Document V1.1 |  | 12d | 2024-05-06 A | 2024-05-21 A | 2354 | 100% | 2024-05-06 | 2024-05-21 | 12d |  |  | Participants |  | S&A Qualification |  | 5.24 | Ben Gilbert | Complete | COMPLETE |  |  |  |
| 2356 | 1.8.1.3.2.3 | Draft Qualification Assessment Document v3 |  | 6d | 2024-06-14 A | 2024-06-21 A | 1176, 2355 | 100% | 2024-06-14 | 2024-06-21 | 6d |  |  | Code Bodies | Code Bodies | S&A Qualification |  | 5.24 | Ben Gilbert | Complete | COMPLETE |  |  |  |
| 2357 | 1.8.1.3.2.4 | Internal Review (Code Bodies and MHHSP) of Qualification Assessment Document v3 |  | 10d | 2024-06-24 A | 2024-07-05 A | 2356 | 100% | 2024-06-24 | 2024-07-05 | 10d |  |  | Code Bodies, SI Team, SRO | Code Bodies, SI Team, SRO | S&A Qualification |  | 5.24 | Ben Gilbert | Complete | COMPLETE |  |  |  |
| 2358 | 1.8.1.3.2.5 | Industry consultation for Qualification Assessment Document v3 |  | 10d | 2024-07-08 A | 2024-07-19 A | 2357 | 100% | 2024-07-08 | 2024-07-19 | 10d |  |  | Participants | Participants | S&A Qualification |  | 5.24 | Ben Gilbert | Complete | COMPLETE |  |  |  |
| 2359 | 1.8.1.3.2.6 | Update Post-Consultation for Qualification Assessment Document v3 |  | 10d | 2024-07-22 A | 2024-08-02 A | 2358 | 100% | 2024-07-22 | 2024-08-02 | 10d |  |  | Code Bodies | Code Bodies | S&A Qualification |  | 5.24 | Ben Gilbert | Complete | COMPLETE |  |  |  |
| 2360 | 1.8.1.3.2.7 | QWG Endorsement of Qualification Assessment Document v3 |  | 1d | 2024-08-13 A | 2024-08-13 A | 2359FS+6d | 100% | 2024-08-13 | 2024-08-13 | 1d |  |  | Code Bodies | Code Bodies | S&A Qualification |  | 5.24 | Ben Gilbert | Complete | COMPLETE |  |  |  |
| 2361 | 1.8.1.3.2.8 | QAG Endorsement of Qualification Assessment Document v3 |  | 1d | 2024-08-22 A | 2024-08-22 A | 2360FS+6d | 100% | 2024-08-22 | 2024-08-22 | 1d |  |  | Code Bodies | Code Bodies | S&A Qualification |  | 5.25 | Ben Gilbert | Complete | COMPLETE | T3-QU-0083 | QAG | T3 |
| 2362 | 1.8.1.3.2.9 | BSC and REC PAB Approval of Qualification Assessment Document v3 |  | 3d | 2024-08-27 A | 2024-08-29 A | 2361FS+2d | 100% | 2024-08-27 | 2024-08-29 | 3d |  |  | Code Bodies | Code Bodies | S&A Qualification |  | 5.24 | Ben Gilbert | Complete | COMPLETE |  |  |  |
| 2363 | 1.8.1.3.2.10 | Qualification Assessment Document v3 approved by REC PAB and BSC PAB | milestone | 0d | 2024-08-29 A | 2024-08-29 A | 2362 | 100% | 2024-08-29 | 2024-08-29 | 0d |  |  | Code Bodies | Code Bodies | S&A Qualification |  | 5.24 | Ben Gilbert | Complete | COMPLETE | T3-QU-0067 | QAG | T3 |

| ID | WBS | Task | Type | Duration | Start | Finish | Predecessors | Complete | Baseline start | Baseline finish | Baseline duration | Baseline 1 start | Baseline 1 finish | Constraint | Baseline cost | Responsible | Involved | Text9 | Task Status | Update Version | MHHS Resource Name | Sched Status | RAG | Milestone ID | Text29 | Tier | MHHS Programme Phase |
| --- | --- | --- | --- | --- | --- | --- | --- | --- | --- | --- | --- | --- | --- | --- | --- | --- | --- | --- | --- | --- | --- | --- | --- | --- | --- | --- | --- |
| 2364 | 1.8.1.3.3 | **Qualification Assessment Document Portal** |  | 445d | 2024-02-05 A | 2025-10-17 A |  | 100% | 2024-02-05 | 2025-03-07 | 285d |  |  |  | -0 | N/A | N/A | S&A Qualification | -131.67 | 5.24 | Ben Gilbert |  |  |  |  |  |  |
| 2365 | 1.8.1.3.3.1 | Design Completion |  | 30d | 2024-02-05 A | 2024-03-15 A |  | 100% | 2024-02-05 | 2024-03-15 | 30d |  |  | finish no earlier than 2024-03-15 |  | QAD Portal Dev Team | QAD Portal Dev Team | S&A Qualification |  | 5.24 | Ben Gilbert | Complete | COMPLETE |  |  |  |  |
| 2366 | 1.8.1.3.3.2 | Qualification Assessment Document Portal Build |  | 30d | 2024-03-18 A | 2024-04-26 A | 2365 | 100% | 2024-03-18 | 2024-04-26 | 30d |  |  |  |  | QAD Portal Dev Team | QAD Portal Dev Team | S&A Qualification |  | 5.24 | Ben Gilbert | Complete | COMPLETE |  |  |  |  |
| 2367 | 1.8.1.3.3.3 | Qualification Assessment Document Internal Testing |  | 20d | 2024-04-29 A | 2024-05-24 A | 2366 | 100% | 2024-04-29 | 2024-05-24 | 20d |  |  |  |  | QAD Portal Dev Team. Code Bodies | QAD Portal Dev Team. Code Bodies | S&A Qualification |  | 5.24 | Ben Gilbert | Complete | COMPLETE |  |  |  |  |
| 2368 | 1.8.1.3.3.4 | Qualification Assessment Document Portal Training and Onboarding Material Creation |  | 20d | 2024-05-27 A | 2024-06-21 A | 2367 | 100% | 2024-05-27 | 2024-06-21 | 20d |  |  |  |  | QAD Portal Dev Team | QAD Portal Dev Team | S&A Qualification |  | 5.24 | Ben Gilbert | Complete | COMPLETE |  |  |  |  |
| 2369 | 1.8.1.3.3.5 | Qualification Assessment Document Portal Webinar (Date TBC) |  | 1d | 2024-06-18 A | 2024-06-18 A |  | 100% | 2024-06-18 | 2024-06-18 | 1d |  |  | start no earlier than 2024-06-18 |  | QAD Portal Dev Team | QAD Portal Dev Team | S&A Qualification |  | 5.24 | Ben Gilbert | Complete | COMPLETE |  |  |  |  |
| 2370 | 1.8.1.3.3.6 | SIT Participant QAD Application Creation in Portal |  | 10d | 2024-12-09 A | 2024-12-20 A | 2368FS+120d | 100% | 2024-12-09 | 2024-12-20 | 10d |  |  |  |  | Code Bodies | Code Bodies | S&A Qualification |  | 5.24 | Ben Gilbert | Complete | COMPLETE |  |  |  |  |
| 2371 | 1.8.1.3.3.7 | Non-SIT LDSO Participant QAD Application Creation in Portal |  | 10d | 2024-12-09 A | 2024-12-20 A | 2368FS+120d | 100% | 2024-12-09 | 2024-12-20 | 10d |  |  |  |  | Code Bodies | Code Bodies | S&A Qualification |  | 5.24 | Ben Gilbert | Complete | COMPLETE |  |  |  |  |
| 2372 | 1.8.1.3.3.8 | QT Wave 1 Participant QAD Application Creation in Portal |  | 10d | 2025-04-21 A | 2025-05-02 A | 2368FS+215d | 100% | 2025-04-21 | 2025-05-02 | 10d |  |  |  |  | Code Bodies | Code Bodies | S&A Qualification |  | 6.1 | Ben Gilbert | Complete | COMPLETE |  |  |  |  |
| 2373 | 1.8.1.3.3.9 | QT Wave 2 Participant QAD Application Creation in Portal |  | 10d | 2025-05-26 A | 2025-06-06 A | 2368FS+240d | 100% | 2025-05-26 | 2025-06-06 | 10d |  |  |  |  | Code Bodies | Code Bodies | S&A Qualification |  | 6.1 | Ben Gilbert | Complete | COMPLETE |  |  |  |  |
| 2374 | 1.8.1.3.3.10 | QT Wave 3 Participant QAD Application Creation in Portal |  | 10d | 2025-07-28 A | 2025-08-08 A | 2368FS+285d | 100% | 2025-07-28 | 2025-08-08 | 10d |  |  |  |  | Code Bodies | Code Bodies | S&A Qualification |  | 6.1 | Ben Gilbert | Complete | COMPLETE |  |  |  |  |
| 2375 | 1.8.1.3.3.11 | QT Wave 4 Participant QAD Application Creation in Portal |  | 10d | 2025-10-06 A | 2025-10-17 A | 2368FS+335d | 100% | 2025-10-06 | 2025-10-17 | 10d |  |  |  |  | Code Bodies | Code Bodies | S&A Qualification |  | 6.1 | Ben Gilbert | Complete | COMPLETE |  |  |  |  |
| 2376 | 1.8.1.3.3.12 | Update to Qualification Assessment Document Portal post QAD V3 |  | 10d | 2024-08-30 A | 2024-09-12 A | 2363 | 100% | 2024-08-30 | 2024-09-12 | 10d |  |  |  |  | QAD Portal Dev Team | QAD Portal Dev Team | S&A Qualification |  | 6.1 | Ben Gilbert | Complete | COMPLETE |  |  |  |  |
| 2377 | 1.8.1.3.3.13 | Update to Qualification Assessment Document Portal post QAD V3 Complete | milestone | 0d | 2024-09-12 A | 2024-09-12 A | 2376 | 100% | 2024-09-12 | 2024-09-12 | 0d |  |  |  |  | QAD Portal Dev Team | QAD Portal Dev Team | S&A Qualification |  | 6.1 | Ben Gilbert | Complete | COMPLETE | T3-QU-0084 | QAG | T3 |  |
| 2378 | 1.8.2 | **MHHS Qualification - SIT Participants** |  | 408d? | 2025-01-06 A | 2026-07-30 A |  | 100% | 2025-01-06 | 2025-12-22 | 194d | 2024-01-29 | 2024-07-05 |  | -0 | N/A | N/A | S&A Qualification | -133.67 | 6.11 | Ben Gilbert |  |  |  |  |  | Systems Integration Testing (SIT) |
| 2379 | 1.8.2.1 | Initial QAD Submission Window opens | milestone | 0d | 2025-01-06 A | 2025-01-06 A | 2370FS+10d | 100% | 2025-01-06 | 2025-01-06 | 0d |  |  | start no earlier than 2025-01-06 |  | Participants | Participants | S&A Qualification |  | 6.11 | Ben Gilbert | Complete | COMPLETE |  |  |  |  |
| 2380 | 1.8.2.2 | SIT Participants submit Initial QAD |  | 30d | 2025-01-06 A | 2025-02-14 A |  | 100% | 2025-01-06 | 2025-02-14 | 29d |  |  | start no earlier than 2025-01-06 |  | Participants | Participants | S&A Qualification |  | 6.11 | Ben Gilbert | Complete | COMPLETE |  |  |  |  |
| 2381 | 1.8.2.3 | Code Bodies review Initial QAD |  | 36d | 2025-02-14 A | 2025-04-04 A | 2380FS-1d | 100% | 2025-02-14 | 2025-04-04 | 36d |  |  |  |  | Code Bodies | Code Bodies | S&A Qualification |  | 6.11 | Ben Gilbert | Complete | COMPLETE |  |  |  |  |
| 2382 | 1.8.2.4 | Completion of Code Bodies review of Initial QAD | milestone | 0d | 2025-04-04 A | 2025-04-04 A | 2381 | 100% | 2025-04-04 | 2025-04-04 | 0d |  |  |  |  | Code Bodies | Code Bodies | S&A Qualification |  | 6.11 | Ben Gilbert | Complete | COMPLETE |  |  |  |  |
| 2383 | 1.8.2.5 | **MHHS Qualification - M10-Ready** |  | 113d | 2025-04-07 A | 2025-09-10 A |  | 100% | 2025-04-07 | 2025-09-11 | 64d |  |  |  |  | N/A | N/A | S&A Qualification | -154.67 | 6.25 | Ben Gilbert |  |  |  |  |  |  |
| 2384 | 1.8.2.5.1 | Final QAD Submission Window opens | milestone | 0d | 2025-04-07 A | 2025-04-07 A | 2381, 2377, 2382FS+1d | 100% | 2025-04-07 | 2025-04-07 | 0d |  |  |  |  | Participants | Participants | S&A Qualification |  | 6.25 | Ben Gilbert | Complete | COMPLETE |  |  |  |  |
| 2385 | 1.8.2.5.2 | SIT M10-ready Participants submit Final QAD (exc Test Reports) |  | 25d | 2025-04-07 A | 2025-05-09 A | 2384FS-1d | 100% | 2025-04-07 | 2025-05-09 | 26d |  |  |  |  | Participants | Participants | S&A Qualification |  | 6.25 | Ben Gilbert | Complete | COMPLETE |  |  |  |  |
| 2386 | 1.8.2.5.3 | Completion of Code Bodies review of Final QAD (M10-Ready) |  | 20d | 2025-05-12 A | 2025-06-06 A | 2385 | 100% | 2025-05-12 | 2025-06-06 | 19d |  |  |  |  | Code Bodies | Code Bodies | S&A Qualification |  | 6.25 | Ben Gilbert | Complete | COMPLETE |  |  |  |  |
| 2387 | 1.8.2.5.4 | **SIT / LDSO Pathway 2** |  | 16d | 2025-08-07 A | 2025-08-28 A | 1586 | 100% | 2025-08-07 | 2025-08-28 | 0d |  |  |  |  |  |  | S&A Qualification | -918.67 | 6.25 | Ben Gilbert |  |  |  |  |  |  |
| 2388 | 1.8.2.5.4.1 | QAD Sign Off Deadline + Test Reports | milestone | 0d | 2025-08-07 A | 2025-08-07 A | 2386 | 100% | 2025-08-07 | 2025-08-07 | 0d |  |  | start no earlier than 2025-08-07 |  | Participants |  | S&A Qualification |  | 6.25 | Ben Gilbert | Complete | COMPLETE |  |  |  |  |
| 2389 | 1.8.2.5.4.2 | REC Code Manager / BSC PAB Approval of Qualification (M10-Ready) | milestone | 0d | 2025-08-28 A | 2025-08-28 A | 2388FS+16d | 100% | 2025-08-28 | 2025-08-28 | 0d |  |  |  |  | Code Bodies |  | S&A Qualification |  | 6.25 | Ben Gilbert | Complete | COMPLETE |  |  |  |  |

| ID | WBS | Task | Type | Duration | Start | Finish | Predecessors | Complete | Baseline start | Baseline finish | Baseline duration | Constraint | Text9 | Task Status | Update Version | MHHS Resource Name | Responsible | Sched Status | RAG | Milestone ID | Text29 | Tier | Involved |
| --- | --- | --- | --- | --- | --- | --- | --- | --- | --- | --- | --- | --- | --- | --- | --- | --- | --- | --- | --- | --- | --- | --- | --- |
| 2390 | 1.8.2.5.5 | **SIT / LDSO Pathway 3** |  | 13d | 2025-08-22 A | 2025-09-10 A | 1589 | 100% | 2025-08-22 | 2025-09-10 | 0d |  | S&A Qualification | -918.67 | 6.25 | Ben Gilbert |  |  |  |  |  |  |  |
| 2391 | 1.8.2.5.5.1 | QAD Sign Off Deadline + Test Reports | milestone | 0d | 2025-08-22 A | 2025-08-22 A | 2386 | 100% | 2025-08-22 | 2025-08-22 | 0d | finish no earlier than 2025-08-22 | S&A Qualification |  | 6.25 | Ben Gilbert | Participants | Complete | COMPLETE |  |  |  |  |
| 2392 | 1.8.2.5.5.2 | REC Code Manager / BSC PAB Approval of Qualification (M10-Ready) |  | 2d | 2025-09-09 A | 2025-09-10 A | 2391FS+11d | 100% | 2025-09-09 | 2025-09-10 | 0d | start no earlier than 2025-09-09 | S&A Qualification |  | 6.25 | Ben Gilbert | Code Bodies | Complete | COMPLETE |  |  |  |  |
| 2393 | 1.8.2.5.5.3 | M10-Ready SIT Participants are qualified | milestone | 0d | 2025-09-10 A | 2025-09-10 A | 2392 | 100% | 2025-09-10 | 2025-09-10 | 0d | finish no earlier than 2025-09-10 | S&A Qualification |  | 6.24 | Ben Gilbert | Code Bodies | Complete | COMPLETE | T3-QU-0085 | QAG | T3 |  |
| 2394 | 1.8.2.6 | **MHHS Qualification - M11-Ready** |  | 137d? | 2025-04-07 A | 2025-10-15 A |  | 100% | 2025-04-07 | 2025-10-15 | 0d |  | S&A Qualification | -918.67 | 6.25 | Ben Gilbert |  |  |  |  |  |  |  |
| 2395 | 1.8.2.6.1 | Final QAD Submission Window opens | milestone | 0d | 2025-04-07 A | 2025-04-07 A | 2381, 2377, 2382FS+1d | 100% | 2025-04-07 | 2025-04-07 | 0d |  | S&A Qualification |  | 6.25 | Ben Gilbert | Participants | Complete | COMPLETE |  |  |  |  |
| 2396 | 1.8.2.6.2 | SIT M11-ready Participants submit Final QAD (exc Test Reports) |  | 44d | 2025-04-08 A | 2025-06-06 A | 2395 | 100% | 2025-04-08 | 2025-06-06 | 0d |  | S&A Qualification |  | 6.25 | Ben Gilbert | Participants | Complete | COMPLETE |  |  |  |  |
| 2397 | 1.8.2.6.3 | Completion of Code Bodies review of Final QAD (M11-Ready) |  | 20d? | 2025-06-09 A | 2025-07-04 A | 2396 | 100% | 2025-06-09 | 2025-07-04 | 0d |  | S&A Qualification |  | 6.25 | Ben Gilbert | Code Bodies | Complete | COMPLETE |  |  |  |  |
| 2398 | 1.8.2.6.4 | **SIT Pathway 4** |  | 16d | 2025-09-04 A | 2025-09-25 A |  | 100% | 2025-09-04 | 2025-09-25 | 0d |  | S&A Qualification | -918.67 | 6.25 | Ben Gilbert |  |  |  |  |  |  |  |
| 2399 | 1.8.2.6.4.1 | QAD Sign Off Deadline + Test Reports | milestone | 0d | 2025-09-04 A | 2025-09-04 A | 2397 | 100% | 2025-09-04 | 2025-09-04 | 0d | start no earlier than 2025-09-04 | S&A Qualification |  | 6.25 | Ben Gilbert | Participants | Complete | COMPLETE |  |  |  |  |
| 2400 | 1.8.2.6.4.2 | REC Code Manager / BSC PAB Approval of Qualification (M11-Ready) | milestone | 0d | 2025-09-25 A | 2025-09-25 A | 2399FS+16d | 100% | 2025-09-25 | 2025-09-25 | 0d |  | S&A Qualification |  | 6.25 | Ben Gilbert | Code Bodies | Complete | COMPLETE |  |  |  |  |
| 2401 | 1.8.2.6.5 | **SIT Pathway 5** |  | 16d | 2025-09-24 A | 2025-10-15 A |  | 100% | 2025-09-24 | 2025-10-15 | 0d |  | S&A Qualification | -918.67 | 6.25 | Ben Gilbert |  |  |  |  |  |  |  |
| 2402 | 1.8.2.6.5.1 | QAD Sign Off Deadline + Test Reports | milestone | 0d | 2025-09-24 A | 2025-09-24 A | 2397 | 100% | 2025-09-24 | 2025-09-24 | 0d | start no earlier than 2025-09-24 | S&A Qualification |  | 6.25 | Ben Gilbert | Participants | Complete | COMPLETE |  |  |  |  |
| 2403 | 1.8.2.6.5.2 | REC Code Manager / BSC PAB Approval of Qualification | milestone | 0d | 2025-10-15 A | 2025-10-15 A | 2402FS+16d | 100% | 2025-10-15 | 2025-10-15 | 0d |  | S&A Qualification |  | 6.25 | Ben Gilbert | Code Bodies | Complete | COMPLETE |  |  |  |  |
| 2404 | 1.8.2.6.5.3 | 'M11-Ready SIT Participants are qualified' | milestone | 0d | 2025-10-15 A | 2025-10-15 A | 2403 | 100% | 2025-10-15 | 2025-10-15 | 0d |  | Migration |  | 6.25 | Ben Gilbert | Migration | Complete | COMPLETE |  |  |  |  |
| 2405 | 1.8.2.7 | **MHHS Qualification - Not M11-Ready** |  | 313d | 2025-05-19 A | 2026-07-30 A |  | 100% | 2025-05-19 | 2025-12-17 | 129d |  | S&A Qualification | -154.67 | 6.25 | Warren Fulton | N/A |  |  |  |  |  | N/A |
| 2406 | 1.8.2.7.1 | Final QAD Submission Window opens | milestone | 0d | 2025-05-19 A | 2025-05-19 A | 2382FS+31d | 100% | 2025-05-19 | 2025-05-19 | 0d | start no earlier than 2025-04-07 | S&A Qualification |  | 6.25 | Ben Gilbert | Participants | Complete | COMPLETE |  |  |  | Participants |
| 2407 | 1.8.2.7.2 | SIT Not M11-Ready Participants submit Final QAD |  | 90d | 2025-05-19 A | 2025-09-19 A | 2406SS-1d | 100% | 2025-05-19 | 2025-09-19 | 86d |  | S&A Qualification |  | 6.25 | Ben Gilbert | Participants | Complete | COMPLETE |  |  |  | Participants |
| 2408 | 1.8.2.7.3 | Completion of Code Bodies review of Final QAD (Not M11-Ready) |  | 25d | 2025-09-22 A | 2025-10-24 A | 2407 | 100% | 2025-09-22 | 2025-10-24 | 19d |  | S&A Qualification |  | 6.25 | Ben Gilbert | Code Bodies | Complete | COMPLETE |  |  |  | Code Bodies |
| 2409 | 1.8.2.7.4 | **SIT Pathway 6** |  | 50d | 2025-10-09 A | 2025-12-18 A |  | 100% | 2025-11-27 | 2025-12-17 | 0d |  | S&A Qualification | -918.67 | 6.25 | Ben Gilbert |  |  |  |  |  |  |  |
| 2410 | 1.8.2.7.4.1 | QAD Sign Off Deadline + Test Reports | milestone | 0d | 2025-10-09 A | 2025-10-09 A |  | 100% | 2025-10-09 | 2025-10-09 | 0d | start no earlier than 2025-10-09 | S&A Qualification |  | 6.27 | Ben Gilbert | Participants | Complete | COMPLETE |  |  |  |  |
| 2411 | 1.8.2.7.4.2 | REC Code Manager / BSC PAB Approval of Qualification (first Pathway 6 PAB) | milestone | 0d | 2025-10-30 A | 2025-10-30 A | 2410FS+16d | 100% | 2025-10-30 | 2025-10-30 | 0d |  | S&A Qualification |  | 6.27 | Ben Gilbert | Code Bodies | Complete | COMPLETE |  |  |  |  |
| 2412 | 1.8.2.7.4.3 | QAD Sign Off Deadline + Test Reports | milestone | 0d | 2025-11-26 A | 2025-11-26 A |  | 100% | 2025-11-27 | 2025-11-27 | 0d | start no earlier than 2025-11-26 | S&A Qualification |  | 6.27 | Ben Gilbert | Participants | Complete | COMPLETE |  |  |  |  |
| 2413 | 1.8.2.7.4.4 | REC Code Manager / BSC PAB Approval of Qualification (final Pathway 6 PAB) | milestone | 0d | 2025-12-18 A | 2025-12-18 A | 2412FS+16d | 100% | 2025-12-18 | 2025-12-18 | 0d | start no earlier than 2025-12-18 | S&A Qualification |  | 6.27 | Ben Gilbert | Code Bodies | Complete | COMPLETE |  |  |  |  |
| 2414 | 1.8.2.7.5 | SIT Participants are Qualified | milestone | 0d | 2026-07-30 A | 2026-07-30 A |  | 100% | 2026-07-30 | 2026-07-30 | 0d | start no earlier than 2026-07-30 | S&A Qualification |  | 6.40 | Ben Gilbert | Code Bodies | Complete | COMPLETE | T3-QU-0086 | QAG | T3 | Code Bodies |

| ID | WBS | Task | Type | Duration | Start | Finish | Predecessors | Complete | Remaining | Baseline start | Baseline finish | Baseline duration | Total slack | Constraint | Baseline cost | Responsible | Involved | Text9 | Task Status | Update Version | MHHS Resource Name | Sched Status | RAG | Milestone ID | Text29 | Tier |
| --- | --- | --- | --- | --- | --- | --- | --- | --- | --- | --- | --- | --- | --- | --- | --- | --- | --- | --- | --- | --- | --- | --- | --- | --- | --- | --- |
| 2415 | 1.8.3 | **MHHS Qualification - Non-SIT LDSO (M10-Ready)** |  | 179d | 2025-01-06 A | 2025-09-11 A |  | 100% |  | 2025-01-06 | 2025-09-10 | 115d |  |  | -0 | N/A | N/A | S&A Qualification | -133.67 | 6.11 | Ben Gilbert |  |  |  |  |  |
| 2416 | 1.8.3.1 | Initial QAD Submission window opens | milestone | 0d | 2025-01-06 A | 2025-01-06 A | 2371FS+11d | 100% |  | 2025-01-06 | 2025-01-06 | 0d |  |  |  | Participants | Participants | S&A Qualification |  | 6.11 | Ben Gilbert | Complete | COMPLETE |  |  |  |
| 2417 | 1.8.3.2 | Non-SIT LDSO Participants submit initial QAD |  | 30d | 2025-01-06 A | 2025-02-14 A |  | 100% |  | 2025-01-06 | 2025-02-14 | 29d |  | start no earlier than 2025-01-06 |  | Participants | Participants | S&A Qualification |  | 6.11 | Ben Gilbert | Complete | COMPLETE |  |  |  |
| 2418 | 1.8.3.3 | Non-SIT LDSO QT Participants have submitted their initial QAD | milestone | 0d | 2025-02-14 A | 2025-02-14 A | 2417 | 100% |  | 2025-02-14 | 2025-02-14 | 0d |  |  |  | Participants | Participants | S&A Qualification |  | 6.11 | Ben Gilbert | Complete | COMPLETE | T3-QU-0087 | QAG | T3 |
| 2419 | 1.8.3.4 | Code Bodies review of Non-SIT LDSO participants Initial QAD |  | 35d | 2025-02-17 A | 2025-04-04 A | 2418 | 100% |  | 2025-02-17 | 2025-04-04 | 36d |  |  |  | Code Bodies | Code Bodies | S&A Qualification |  | 6.11 | Ben Gilbert | Complete | COMPLETE |  |  |  |
| 2420 | 1.8.3.5 | Completion of Code Bodies review of Initial QAD | milestone | 0d | 2025-04-04 A | 2025-04-04 A | 2419 | 100% |  | 2025-04-04 | 2025-04-04 | 0d |  |  |  | Code Bodies | Code Bodies | S&A Qualification |  | 6.11 | Ben Gilbert | Complete | COMPLETE |  |  |  |
| 2421 | 1.8.3.6 | Final QAD Submission window opens | milestone | 0d | 2025-04-07 A | 2025-04-07 A | 2420FS+1d | 100% |  | 2025-04-07 | 2025-04-07 | 0d |  |  |  | Participants | Participants | S&A Qualification |  | 6.11 | Ben Gilbert | Complete | COMPLETE |  |  |  |
| 2422 | 1.8.3.7 | Non-SIT LDSO Participants submit Final QAD |  | 35d | 2025-04-07 A | 2025-05-23 A | 2421SS-1d, 1922 | 100% |  | 2025-04-21 | 2025-05-23 | 26d |  | finish no earlier than 2025-05-23 |  | Participants | Participants | S&A Qualification |  | 6.19 | Ben Gilbert | Complete | COMPLETE |  |  |  |
| 2423 | 1.8.3.8 | Non-SIT LDSO QT Participants have submitted their final QAD | milestone | 0d | 2025-05-23 A | 2025-05-23 A | 2422 | 100% |  | 2025-05-23 | 2025-05-23 | 0d |  |  |  | Participants | Participants | S&A Qualification |  | 6.11 | Ben Gilbert | Complete | COMPLETE | T3-QU-0088 | QAG | T3 |
| 2424 | 1.8.3.9 | Completion of Code Bodies review of the Final QAD |  | 20d | 2025-05-26 A | 2025-06-20 A | 2423 | 100% |  | 2025-05-26 | 2025-06-20 | 19d |  |  |  | Code Bodies | Code Bodies | S&A Qualification |  | 6.11 | Ben Gilbert | Complete | COMPLETE |  |  |  |
| 2425 | 1.8.3.10 | QAD Finalisation |  | 42d | 2025-06-23 A | 2025-08-19 A | 2424 | 100% |  | 2025-06-23 | 2025-08-19 | 0d |  |  |  | Participants |  | S&A Qualification |  | 6.25 | Ben Gilbert | Complete | COMPLETE |  |  |  |
| 2426 | 1.8.3.11 | QAD Sign Off Deadline (Non-SIT LDSOs) | milestone | 0d | 2025-08-22 A | 2025-08-22 A | 2424FS+5d, 1922, 2425 | 100% |  | 2025-08-22 | 2025-08-22 | 1d |  | finish no earlier than 2025-08-22 |  | Participants | Participants | S&A Qualification |  | 6.11 | Ben Gilbert | Complete | COMPLETE |  |  |  |
| 2427 | 1.8.3.12 | BSC PAB & REC Manager approval of Qualification for Non-SIT LDSOs | milestone | 0d | 2025-09-11 A | 2025-09-11 A | 2426FS+13d | 100% |  | 2025-09-11 | 2025-09-11 | 0d |  | finish no earlier than 2025-09-11 |  | Non-SIT LDSO | Non-SIT LDSO | S&A Qualification |  | 6.12 | Nicola Farley | Complete | COMPLETE | T2-QU-0500 | QAG (Non-SIT LDSO) | T2 |
| 2428 | 1.8.4 | **MHHS Qualification - Qualification Waves** |  | 778d? | 2023-12-18 A | 2026-12-09 |  | 99% | 0d? | 2023-12-18 | 2027-01-28 | 574d | 271d |  | -0 | N/A | N/A | S&A Qualification | -131.67 | 5.24 | Ben Gilbert |  |  |  |  |  |
| 2429 | 1.8.4.1 | **Qualification Wave Prep** |  | 569d? | 2023-12-18 A | 2026-02-19 A |  | 100% |  | 2023-12-18 | 2025-12-26 | 424d |  |  | -0 | N/A | N/A | S&A Qualification | -131.67 | 5.24 | Ben Gilbert |  |  |  |  |  |
| 2430 | 1.8.4.1.1 | **Non-SIT Supplier and Agent Test Approach and Plan** |  | 119d | 2023-12-18 A | 2024-05-30 A |  | 100% |  | 2023-12-18 | 2024-05-30 | 118d |  |  | -0 | N/A | N/A | S&A Qualification | -133.67 | 5.24 | Ben Gilbert |  |  |  |  |  |
| 2431 | 1.8.4.1.1.1 | Draft Non-SIT S&A Test Approach and Plan |  | 50d | 2023-12-18 A | 2024-02-23 A |  | 100% |  | 2023-12-18 | 2024-02-23 | 50d |  | finish no earlier than 2024-02-23 |  | Non-SIT S&A QT Test Team | Non-SIT S&A QT Test Team | S&A Qualification |  | 5.24 | Ben Gilbert | Complete | COMPLETE |  |  |  |
| 2432 | 1.8.4.1.1.2 | Internal Review of Non-SIT S&A Test Approach and Plan (Code Bodies and MHHSP) |  | 10d | 2024-02-26 A | 2024-03-08 A | 2431 | 100% |  | 2024-02-26 | 2024-03-08 | 10d |  |  |  | Code Bodies, SI Team, SRO | Code Bodies, SI Team, SRO | S&A Qualification |  | 5.24 | Ben Gilbert | Complete | COMPLETE |  |  |  |
| 2433 | 1.8.4.1.1.3 | Issue Non-SIT S&A Test Approach and Plan for Consultation |  | 15d | 2024-03-18 A | 2024-04-05 A | 2432 | 100% |  | 2024-03-18 | 2024-04-05 | 15d |  | start no earlier than 2024-03-18 |  | Participants | Participants | S&A Qualification |  | 5.24 | Ben Gilbert | Complete | COMPLETE |  |  |  |
| 2434 | 1.8.4.1.1.4 | Update Non-SIT S&A Test Approach and Plan Post-Consultation |  | 10d | 2024-04-08 A | 2024-04-19 A | 2433 | 100% |  | 2024-04-08 | 2024-04-19 | 10d |  |  |  | Non-SIT S&A QT Test Team | Non-SIT S&A QT Test Team | S&A Qualification |  | 5.24 | Ben Gilbert | Complete | COMPLETE |  |  |  |
| 2435 | 1.8.4.1.1.5 | QWG Endorsement of Non-SIT S&A Test Approach and Plan |  | 1d | 2024-05-14 A | 2024-05-14 A |  | 100% |  | 2024-05-14 | 2024-05-14 | 1d |  | finish no earlier than 2024-05-14 |  | Non-SIT S&A QT Test Team | Non-SIT S&A QT Test Team | S&A Qualification |  | 5.24 | Ben Gilbert | Complete | COMPLETE |  |  |  |
| 2436 | 1.8.4.1.1.6 | QAG Approval of Non-SIT S&A Test Approach and Plan | milestone | 0d | 2024-05-23 A | 2024-05-23 A | 2435FS+7d | 100% |  | 2024-05-23 | 2024-05-23 | 0d |  |  |  | Non-SIT S&A QT Test Team | Non-SIT S&A QT Test Team | S&A Qualification |  | 5.25 | Ben Gilbert | Complete | COMPLETE | T3-QU-0089 | QAG | T3 |
| 2437 | 1.8.4.1.1.7 | BSC & REC PAB Approval of Non-SIT S&A Test Approach and Plan | milestone | 0d | 2024-05-30 A | 2024-05-30 A | 2436FS+5d | 100% |  | 2024-05-30 | 2024-05-30 | 0d |  |  |  | Code Bodies | Code Bodies | S&A Qualification |  | 5.25 | Ben Gilbert | Complete | COMPLETE | T3-QU-0090 | QAG | T3 |
| 2438 | 1.8.4.1.2 | **QT Test Data Approach and Plan** |  | 64d | 2024-04-19 A | 2024-07-18 A |  | 100% |  | 2024-04-19 | 2024-07-18 | 64d |  |  | -0 | N/A | N/A | S&A Qualification | -133.67 | 5.24 | Ben Gilbert |  |  |  |  |  |
| 2439 | 1.8.4.1.2.1 | QT Test Data Approach agreed as part of the Non-SIT Supplier and Agent Test Approach and Plan | milestone | 0d | 2024-04-19 A | 2024-04-19 A | 2434 | 100% |  | 2024-04-19 | 2024-04-19 | 0d |  |  |  | Non-SIT S&A QT Test Team, Participants | Non-SIT S&A QT Test Team, Participants | S&A Qualification |  | 5.24 | Ben Gilbert | Complete | COMPLETE |  |  |  |
| 2440 | 1.8.4.1.2.2 | Draft Test Data Approach and Plan for QT |  | 10d | 2024-05-06 A | 2024-05-17 A | 2439 | 100% |  | 2024-05-06 | 2024-05-17 | 10d |  |  |  | Non-SIT S&A QT Test Team | Non-SIT S&A QT Test Team | S&A Qualification |  | 5.24 | Ben Gilbert | Complete | COMPLETE |  |  |  |
| 2441 | 1.8.4.1.2.3 | Internal Review (Code Bodies and MHHSP) of QT Test Data Approach and Plan |  | 15d | 2024-05-20 A | 2024-06-07 A | 2440 | 100% |  | 2024-05-20 | 2024-06-07 | 10d |  |  |  | Code Bodies, SI Team, SRO | Code Bodies, SI Team, SRO | S&A Qualification |  | 5.24 | Ben Gilbert | Complete | COMPLETE |  |  |  |
| 2442 | 1.8.4.1.2.4 | Issue QT Test Data Approach and Plan for Industry Consultation |  | 10d | 2024-06-10 A | 2024-06-21 A | 2441 | 100% |  | 2024-06-10 | 2024-06-21 | 10d |  |  |  | Participants | Participants | S&A Qualification |  | 5.24 | Ben Gilbert | Complete | COMPLETE |  |  |  |
| 2443 | 1.8.4.1.2.5 | Update QT Test Approach and Plan Post Industry Consultation |  | 5d | 2024-06-24 A | 2024-06-28 A | 2442 | 100% |  | 2024-06-24 | 2024-06-28 | 10d |  |  |  | Non-SIT S&A QT Team | Non-SIT S&A QT Team | S&A Qualification |  | 5.24 | Ben Gilbert | Complete | COMPLETE |  |  |  |
| 2444 | 1.8.4.1.2.6 | QWG Endorsement of Test Data Approach and Plan |  | 1d | 2024-07-09 A | 2024-07-09 A | 2443FS+6d | 100% |  | 2024-07-09 | 2024-07-09 | 1d |  |  |  | Non-SIT S&A QT Test Team | Non-SIT S&A QT Test Team | S&A Qualification |  | 5.24 | Ben Gilbert | Complete | COMPLETE |  |  |  |
| 2445 | 1.8.4.1.2.7 | QAG Approval of QT Test Data Approach and Plan | milestone | 0d | 2024-07-18 A | 2024-07-18 A | 2444FS+7d | 100% |  | 2024-07-18 | 2024-07-18 | 0d |  |  |  | Non-SIT S&A QT Test Team | Non-SIT S&A QT Test Team | S&A Qualification |  | 5.29 | Ben Gilbert | Complete | COMPLETE | T3-QU-0091 | QAG | T3 |

| ID | WBS | Task | Type | Duration | Start | Finish | Predecessors | Complete | Baseline start | Baseline finish | Baseline duration | Constraint | Baseline cost | Responsible | Involved | Text9 | Task Status | Update Version | MHHS Resource Name | Sched Status | RAG | Milestone ID | Text29 | Tier |
| --- | --- | --- | --- | --- | --- | --- | --- | --- | --- | --- | --- | --- | --- | --- | --- | --- | --- | --- | --- | --- | --- | --- | --- | --- |
| 2446 | 1.8.4.1.3 | **QT Functional Test Scenarios and Test Cases** |  | 59d | 2024-03-04 A | 2024-05-23 A |  | 100% | 2024-03-04 | 2024-05-23 | 59d |  | -0 | N/A | N/A | S&A Qualification | -133.67 | 5.24 | Ben Gilbert |  |  |  |  |  |
| 2447 | 1.8.4.1.3.1 | Draft Test Scenarios and Test Case list - Batch 1 |  | 10d | 2024-03-04 A | 2024-03-15 A |  | 100% | 2024-03-04 | 2024-03-15 | 10d | finish no earlier than 2024-03-15 |  | Non-SIT S&A QT Test Team, Code Bodies | Non-SIT S&A QT Test Team, Code Bodies | S&A Qualification |  | 5.24 | Ben Gilbert | Complete | COMPLETE |  |  |  |
| 2448 | 1.8.4.1.3.2 | Issue Batch 1 for Consultation |  | 15d | 2024-03-18 A | 2024-04-05 A | 2447 | 100% | 2024-03-18 | 2024-04-05 | 15d | start no earlier than 2024-03-18 |  | Participants | Participants | S&A Qualification |  | 5.24 | Ben Gilbert | Complete | COMPLETE |  |  |  |
| 2449 | 1.8.4.1.3.3 | Gap analysis against QT Requirements |  | 8d | 2024-03-18 A | 2024-03-27 A | 2447 | 100% | 2024-03-18 | 2024-03-27 | 8d |  |  | Non-SIT S&A QT Test Team | Non-SIT S&A QT Test Team | S&A Qualification |  | 5.24 | Ben Gilbert | Complete | COMPLETE |  |  |  |
| 2450 | 1.8.4.1.3.4 | Update Test Scenarios and Test Case list - Batch 2 |  | 6d | 2024-03-28 A | 2024-04-04 A | 2449 | 100% | 2024-03-28 | 2024-04-04 | 6d |  |  | Non-SIT S&A QT Test Team, Code Bodies | Non-SIT S&A QT Test Team, Code Bodies | S&A Qualification |  | 5.24 | Ben Gilbert | Complete | COMPLETE |  |  |  |
| 2451 | 1.8.4.1.3.5 | Issue Batch 2 for consultation |  | 10d | 2024-04-05 A | 2024-04-18 A | 2450 | 100% | 2024-04-05 | 2024-04-18 | 10d |  |  | Participants | Participants | S&A Qualification |  | 5.24 | Ben Gilbert | Complete | COMPLETE |  |  |  |
| 2452 | 1.8.4.1.3.6 | Update Batch 2 post consultation |  | 10d | 2024-04-19 A | 2024-05-02 A | 2451 | 100% | 2024-04-19 | 2024-05-02 | 10d |  |  | Non-SIT S&A QT Test Team, Code Bodies | Non-SIT S&A QT Test Team, Code Bodies | S&A Qualification |  | 5.24 | Ben Gilbert | Complete | COMPLETE |  |  |  |
| 2453 | 1.8.4.1.3.7 | QWG Endorsement of Batch 1 and 2 |  | 1d | 2024-05-14 A | 2024-05-14 A |  | 100% | 2024-05-14 | 2024-05-14 | 1d | finish no earlier than 2024-05-14 |  | Non-SIT S&A QT Test Team | Non-SIT S&A QT Test Team, Code Bodies, Participants | S&A Qualification |  | 5.24 | Ben Gilbert | Complete | COMPLETE |  |  |  |
| 2454 | 1.8.4.1.3.8 | QAG Approval of QT Functional Test Scenarios and Test Cases Batches 1 and 2 | milestone | 0d | 2024-05-23 A | 2024-05-23 A | 2453FS+7d | 100% | 2024-05-23 | 2024-05-23 | 0d |  |  | Non-SIT S&A QT Test Team | Non-SIT S&A QT Test Team, Code Bodies, Participants | S&A Qualification |  | 5.25 | Ben Gilbert | Complete | COMPLETE | T3-QU-0092 | QAG | T3 |
| 2455 | 1.8.4.1.4 | **QT Migration Test Scenarios and Test Cases** |  | 54d | 2024-05-06 A | 2024-07-18 A |  | 100% | 2024-05-06 | 2024-07-18 | 54d |  |  | N/A | N/A | S&A Qualification |  | 5.25 | Ben Gilbert |  |  |  |  |  |
| 2456 | 1.8.4.1.4.1 | Draft Test Scenarios and Test Case list - Batch 1 |  | 20d | 2024-05-06 A | 2024-05-31 A | 987FS+12d | 100% | 2024-05-06 | 2024-05-31 | 20d |  |  | Non-SIT S&A QT Test Team, Code Bodies | Non-SIT S&A QT Test Team, Code Bodies | S&A Qualification |  | 5.25 | Ben Gilbert | Complete | COMPLETE |  |  |  |
| 2457 | 1.8.4.1.4.2 | Issue Batch 1 for Consultation |  | 10d | 2024-06-03 A | 2024-06-14 A | 2456 | 100% | 2024-06-03 | 2024-06-14 | 10d |  |  | Participants | Participants | S&A Qualification |  | 5.25 | Ben Gilbert | Complete | COMPLETE |  |  |  |
| 2458 | 1.8.4.1.4.3 | Update Batch 1 Post Consultation |  | 10d | 2024-06-17 A | 2024-06-28 A | 2457 | 100% | 2024-06-17 | 2024-06-28 | 10d |  |  | Non-SIT S&A QT Test Team | Non-SIT S&A QT Test Team | S&A Qualification |  | 5.25 | Ben Gilbert | Complete | COMPLETE |  |  |  |
| 2459 | 1.8.4.1.4.4 | QWG Endorsement of Batch 1 | milestone | 0d | 2024-07-09 A | 2024-07-09 A | 2458FS+7d | 100% | 2024-07-09 | 2024-07-09 | 0d |  |  | Non-SIT S&A QT Test Team | Non-SIT S&A QT Test Team, Code Bodies, Participants | S&A Qualification |  | 5.25 | Ben Gilbert | Complete | COMPLETE |  |  |  |
| 2460 | 1.8.4.1.4.5 | QAG Approval of QT Migration Test Scenarios and Test Cases Batches 1 | milestone | 0d | 2024-07-18 A | 2024-07-18 A | 2459FS+7d | 100% | 2024-07-18 | 2024-07-18 | 0d |  |  | Non-SIT S&A QT Test Team | Non-SIT S&A QT Test Team, Code Bodies, Participants | S&A Qualification |  | 5.29 | Ben Gilbert | Complete | COMPLETE | T3-QU-0119 | QAG | T3 |
| 2461 | 1.8.4.1.5 | **QT Functional (inc NF and Operational) Test Scenarios and Test Cases** |  | 77d | 2024-11-05 A | 2025-02-20 A |  | 100% | 2024-11-04 | 2024-12-27 | 0d |  |  | Non-SIT S&A QT Test Team |  | S&A Qualification | -721.67 |  | Ben Gilbert |  |  |  |  |  |
| 2462 | 1.8.4.1.5.1 | Draft Test Scenarios and Test Case list - Batch 3 |  | 20d | 2024-11-05 A | 2024-12-02 A | 874FS-1d | 100% | 2024-11-05 | 2024-12-02 | 0d |  |  | Non-SIT S&A QT Test Team |  | S&A Qualification |  | 6.11 | Ben Gilbert | Complete | COMPLETE |  |  |  |
| 2463 | 1.8.4.1.5.2 | Issue Batch 3 for Consultation |  | 10d | 2024-12-03 A | 2024-12-16 A | 2462 | 100% | 2024-12-03 | 2024-12-16 | 0d |  |  | Non-SIT S&A QT Test Team |  | S&A Qualification |  | 6.11 | Ben Gilbert | Complete | COMPLETE |  |  |  |
| 2464 | 1.8.4.1.5.3 | Update Batch 3 Post Consultation |  | 20d | 2024-12-17 A | 2025-01-13 A | 2463 | 100% | 2024-12-17 | 2025-01-13 | 0d |  |  | Non-SIT S&A QT Test Team |  | S&A Qualification |  | 6.11 | Ben Gilbert | Complete | COMPLETE |  |  |  |
| 2465 | 1.8.4.1.5.4 | QWG Endorsement of Batch 3 | milestone | 0d | 2025-02-11 A | 2025-02-11 A | 2464FS+21d | 100% | 2025-02-11 | 2025-02-11 | 0d |  |  | Non-SIT S&A QT Test Team |  | S&A Qualification |  | 6.11 | Ben Gilbert | Complete | COMPLETE |  |  |  |
| 2466 | 1.8.4.1.5.5 | QAG Approval of QT Functional Test Scenarios and Test Cases Batches 3 | milestone | 0d | 2025-02-20 A | 2025-02-20 A | 2465FS+6d | 100% | 2025-02-20 | 2025-02-20 | 0d | start no earlier than 2025-02-20 |  | Non-SIT S&A QT Test Team |  | S&A Qualification |  | 6.11 | Ben Gilbert | Complete | COMPLETE | T3-QU-0123 | QAG | T3 |
| 2467 | 1.8.4.1.6 | **Qualification Testing Framework (Test Stubs and Supporting UI)** |  | 539d? | 2024-01-29 A | 2026-02-19 A |  | 100% | 2024-01-29 | 2026-01-08 | 0d |  |  | Non-SIT S&A QT Test Team |  | S&A Qualification | -742.67 | 6.12 | Ben Gilbert |  |  |  |  |  |
| 2468 | 1.8.4.1.6.1 | Proof of Concept for QTF Completion |  | 45d | 2024-01-29 A | 2024-03-29 A |  | 100% | 2024-01-29 | 2024-03-29 | 0d | finish no earlier than 2024-03-29 |  | Non-SIT S&A QT Test Team |  | S&A Qualification |  | 6.12 | Ben Gilbert | Complete | COMPLETE |  |  |  |
| 2469 | 1.8.4.1.6.2 | Discovery and Mobilisation |  | 25d | 2024-04-01 A | 2024-05-03 A | 2468 | 100% | 2024-04-01 | 2024-05-03 | 0d | finish no earlier than 2024-05-03 |  | Non-SIT S&A QT Test Team |  | S&A Qualification |  | 6.12 | Ben Gilbert | Complete | COMPLETE |  |  |  |

| ID | WBS | Task | Duration | Start | Finish | Predecessors | Complete | Actual finish | Baseline start | Baseline finish | Baseline duration | Constraint | Responsible | Text9 | Task Status | Update Version | MHHS Resource Name | Sched Status | RAG |
| --- | --- | --- | --- | --- | --- | --- | --- | --- | --- | --- | --- | --- | --- | --- | --- | --- | --- | --- | --- |
| 2470 | 1.8.4.1.6.3 | **Agile DBT of Qualification Testing Framework** | 83d | 2024-04-24 A | 2024-08-16 A |  | 100% |  | 2024-04-24 | 2024-08-16 | 0d |  | Non-SIT S&A QT Test Team | S&A Qualification | -742.67 | 6.12 | Ben Gilbert |  |  |
| 2471 | 1.8.4.1.6.3.1 | **User Interface (UI)** | 48d | 2024-04-24 A | 2024-06-28 A |  | 100% |  | 2024-04-24 | 2024-06-28 | 0d |  | Non-SIT S&A QT Test Team | S&A Qualification | -742.67 | 6.12 | Ben Gilbert |  |  |
| 2472 | 1.8.4.1.6.3.1.1 | UI Wireframe | 48d | 2024-04-24 A | 2024-06-28 A |  | 100% |  | 2024-04-24 | 2024-06-28 | 0d | finish no earlier than 2024-06-28 | Non-SIT S&A QT Test Team | S&A Qualification |  | 6.12 | Ben Gilbert | Complete | COMPLETE |
| 2473 | 1.8.4.1.6.3.1.2 | UI Standards | 35d | 2024-05-13 A | 2024-06-28 A | 2472FS+13d | 100% |  | 2024-05-13 | 2024-06-28 | 0d | finish no earlier than 2024-06-28 | Non-SIT S&A QT Test Team | S&A Qualification |  | 6.12 | Ben Gilbert | Complete | COMPLETE |
| 2474 | 1.8.4.1.6.3.1.3 | Elexon Branding Sylesheet | 2d | 2024-05-17 A | 2024-05-20 A | 2473FS+10d | 100% |  | 2024-05-17 | 2024-05-20 | 0d | finish no earlier than 2024-05-20 | Non-SIT S&A QT Test Team | S&A Qualification |  | 6.12 | Ben Gilbert | Complete | COMPLETE |
| 2475 | 1.8.4.1.6.3.1.4 | Elexon Branding QTF Logo | 2d | 2024-05-31 A | 2024-06-03 A | 2474FS+20d | 100% |  | 2024-05-31 | 2024-06-03 | 0d | finish no earlier than 2024-06-03 | Non-SIT S&A QT Test Team | S&A Qualification |  | 6.12 | Ben Gilbert | Complete | COMPLETE |
| 2476 | 1.8.4.1.6.3.2 | **Design, Build, Test** | 70d | 2024-05-13 A | 2024-08-16 A |  | 100% |  | 2024-05-13 | 2024-08-16 | 0d |  | Non-SIT S&A QT Test Team | S&A Qualification | -742.67 | 6.12 | Ben Gilbert |  |  |
| 2477 | 1.8.4.1.6.3.2.1 | Core UI Screens | 60d | 2024-05-13 A | 2024-08-02 A | 2473SS | 100% |  | 2024-05-13 | 2024-08-02 | 0d | finish no earlier than 2024-08-02 | Non-SIT S&A QT Test Team | S&A Qualification |  | 6.12 | Ben Gilbert | Complete | COMPLETE |
| 2478 | 1.8.4.1.6.3.2.2 | Tooling (Trigger Files / Template Generators) | 70d | 2024-05-13 A | 2024-08-16 A | 2472SS+13d | 100% |  | 2024-05-13 | 2024-08-16 | 0d | finish no earlier than 2024-08-16 | Non-SIT S&A QT Test Team | S&A Qualification |  | 6.12 | Ben Gilbert | Complete | COMPLETE |
| 2479 | 1.8.4.1.6.3.2.3 | Database Schema | 50d | 2024-05-13 A | 2024-07-19 A | 2472SS+13d | 100% |  | 2024-05-13 | 2024-07-19 | 0d | finish no earlier than 2024-07-19 | Non-SIT S&A QT Test Team | S&A Qualification |  | 6.12 | Ben Gilbert | Complete | COMPLETE |
| 2480 | 1.8.4.1.6.3.2.4 | Core API's | 60d | 2024-05-13 A | 2024-08-02 A | 2472SS+13d | 100% |  | 2024-05-13 | 2024-08-02 | 0d | finish no earlier than 2024-08-02 | Non-SIT S&A QT Test Team | S&A Qualification |  | 6.12 | Ben Gilbert | Complete | COMPLETE |
| 2481 | 1.8.4.1.6.4 | QTF Test Cases DBT Refinement, Execution and Results Validation, Defect Management, Error Handling | 77d | 2024-11-05 A | 2025-02-20 A | 2466FF, 2460FF, 2462SS | 100% |  | 2024-11-05 | 2025-02-20 | 0d |  | Non-SIT S&A QT Test Team | S&A Qualification |  | 6.12 | Ben Gilbert | Complete | COMPLETE |
| 2482 | 1.8.4.1.6.5 | **Environments** | 339d | 2024-04-15 A | 2025-07-31 |  | 100% | 2025-03-18 | 2024-04-15 | 2025-07-31 | 0d |  | Non-SIT S&A QT Test Team | S&A Qualification | -742.67 | 6.12 | Ben Gilbert |  |  |
| 2483 | 1.8.4.1.6.5.1 | **Azure Devops** | 173d | 2024-04-15 A | 2024-12-11 A |  | 100% |  | 2024-04-15 | 2024-12-11 | 0d |  | Non-SIT S&A QT Test Team | S&A Qualification | -742.67 | 6.12 | Ben Gilbert |  |  |
| 2484 | 1.8.4.1.6.5.1.1 | **QFT ADO Development Instance** | 15d | 2024-04-15 A | 2024-05-03 A |  | 100% |  | 2024-04-15 | 2024-05-03 | 0d |  | Non-SIT S&A QT Test Team | S&A Qualification | -742.67 | 6.12 | Ben Gilbert |  |  |
| 2485 | 1.8.4.1.6.5.1.1.1 | Elexon Instance Setup for QTF Build | 5d | 2024-04-15 A | 2024-04-19 A | 2469SS+10d | 100% |  | 2024-04-15 | 2024-04-19 | 0d | finish no earlier than 2024-04-19 | Non-SIT S&A QT Test Team | S&A Qualification |  | 6.12 | Ben Gilbert | Complete | COMPLETE |
| 2486 | 1.8.4.1.6.5.1.1.2 | Configuration and User Access | 10d | 2024-04-22 A | 2024-05-03 A | 2485 | 100% |  | 2024-04-22 | 2024-05-03 | 0d | finish no earlier than 2024-05-03 | Non-SIT S&A QT Test Team | S&A Qualification |  | 6.12 | Ben Gilbert | Complete | COMPLETE |
| 2487 | 1.8.4.1.6.5.1.2 | **MHHSP ADO Instance** | 102d | 2024-07-23 A | 2024-12-11 A |  | 100% |  | 2024-07-23 | 2024-12-11 | 0d |  | Non-SIT S&A QT Test Team | S&A Qualification | -742.67 | 6.12 | Ben Gilbert |  |  |
| 2488 | 1.8.4.1.6.5.1.2.1 | MHHSP Instance Setup for QTF Production | 29d | 2024-07-23 A | 2024-08-30 A | 2494SS+41d | 100% |  | 2024-07-23 | 2024-08-30 | 0d | finish no earlier than 2024-08-30 | Non-SIT S&A QT Test Team | S&A Qualification |  | 6.12 | Ben Gilbert | Complete | COMPLETE |
| 2489 | 1.8.4.1.6.5.1.2.2 | Configuration and User Access | 73d | 2024-09-02 A | 2024-12-11 A | 2488 | 100% |  | 2024-09-02 | 2024-12-11 | 0d | finish no earlier than 2024-09-27 | Non-SIT S&A QT Test Team | S&A Qualification |  | 6.12 | Ben Gilbert | Complete | COMPLETE |
| 2490 | 1.8.4.1.6.5.2 | **Temporary Development Environment** | 35d | 2024-04-15 A | 2024-05-31 A |  | 100% |  | 2024-04-15 | 2024-05-31 | 0d |  | Non-SIT S&A QT Test Team | S&A Qualification | -742.67 | 6.12 | Ben Gilbert |  |  |
| 2491 | 1.8.4.1.6.5.2.1 | Design | 15d | 2024-04-15 A | 2024-05-03 A | 2469SS+10d | 100% |  | 2024-04-15 | 2024-05-03 | 0d | finish no earlier than 2024-05-03 | Non-SIT S&A QT Test Team | S&A Qualification |  | 6.12 | Ben Gilbert | Complete | COMPLETE |
| 2492 | 1.8.4.1.6.5.2.2 | Build and Deployment | 20d | 2024-05-06 A | 2024-05-31 A | 2486, 2491 | 100% |  | 2024-05-06 | 2024-05-31 | 0d | finish no earlier than 2024-05-31 | Non-SIT S&A QT Test Team | S&A Qualification |  | 6.12 | Ben Gilbert | Complete | COMPLETE |
| 2493 | 1.8.4.1.6.5.3 | **Dev, Test & Prod Environment Requirements + Design** | 135d | 2024-05-27 A | 2024-11-29 A |  | 100% |  | 2024-05-27 | 2024-11-29 | 0d |  | Non-SIT S&A QT Test Team | S&A Qualification | -742.67 | 6.12 | Ben Gilbert |  |  |
| 2494 | 1.8.4.1.6.5.3.1 | Design (including Security Review) | 135d | 2024-05-27 A | 2024-11-29 A | 2469FS+15d | 100% |  | 2024-05-27 | 2024-11-29 | 0d | finish no earlier than 2024-08-30 | Non-SIT S&A QT Test Team | S&A Qualification |  | 6.12 | Ben Gilbert | Complete | COMPLETE |
| 2495 | 1.8.4.1.6.5.3.2 | Hub Development Dev/Test | 20d | 2024-06-10 A | 2024-07-05 A | 2494SS+10d | 100% |  | 2024-06-10 | 2024-07-05 | 0d |  | Non-SIT S&A QT Test Team | S&A Qualification |  | 6.12 | Ben Gilbert | Complete | COMPLETE |
| 2496 | 1.8.4.1.6.5.3.3 | Hub Deployment | 20d | 2024-06-10 A | 2024-07-05 A | 2494FS+10d, 2495 | 100% |  | 2024-06-10 | 2024-07-05 | 0d | finish no earlier than 2024-07-05 | Non-SIT S&A QT Test Team | S&A Qualification |  | 6.12 | Ben Gilbert | Complete | COMPLETE |
| 2497 | 1.8.4.1.6.5.3.4 | Development Envn. Deployment | 53.8d | 2024-07-08 A | 2024-09-19 A | 2496 | 100% |  | 2024-07-08 | 2024-09-19 | 0d | finish no earlier than 2024-08-30 | Non-SIT S&A QT Test Team | S&A Qualification |  | 6.12 | Ben Gilbert | Complete | COMPLETE |
| 2498 | 1.8.4.1.6.5.3.5 | Test Envn. Deployment | 10d | 2024-09-19 A | 2024-10-03 A | 2497 | 100% |  | 2024-09-19 | 2024-10-03 | 0d | finish no earlier than 2024-09-13 | Non-SIT S&A QT Test Team | S&A Qualification |  | 6.12 | Ben Gilbert | Complete | COMPLETE |
| 2499 | 1.8.4.1.6.5.3.6 | Production Envn. Deployment | 25d | 2024-10-03 A | 2024-11-07 A | 2498 | 100% |  | 2024-10-03 | 2024-11-07 | 0d | finish no earlier than 2024-10-18 | Non-SIT S&A QT Test Team | S&A Qualification |  | 6.12 | Ben Gilbert | Complete | COMPLETE |

| ID | WBS | Task | Duration | Start | Finish | Predecessors | Complete | Actual finish | Baseline start | Baseline finish | Baseline duration | Constraint | Responsible | Text9 | Task Status | Update Version | MHHS Resource Name | Sched Status | RAG |
| --- | --- | --- | --- | --- | --- | --- | --- | --- | --- | --- | --- | --- | --- | --- | --- | --- | --- | --- | --- |
| 2500 | 1.8.4.1.6.5.4 | **QTF Deployment into Production** | 19d | 2025-02-20 A | 2025-03-18 A |  | 100% |  | 2025-02-03 | 2025-04-25 | 0d |  | Non-SIT S&A QT Test Team | S&A Qualification | -742.67 | 6.15 | Ben Gilbert |  |  |
| 2501 | 1.8.4.1.6.5.4.1 | App Deployment | 5d | 2025-02-20 A | 2025-02-26 A | 2481, 2499 | 100% |  | 2025-02-20 | 2025-02-26 | 0d | start no earlier than 2025-02-03 | Non-SIT S&A QT Test Team | S&A Qualification |  | 6.15 | Ben Gilbert | Complete | COMPLETE |
| 2502 | 1.8.4.1.6.5.4.2 | Smoke Test | 2d | 2025-02-27 A | 2025-02-28 A | 2501 | 100% |  | 2025-02-27 | 2025-02-28 | 0d | finish no earlier than 2025-02-04 | Non-SIT S&A QT Test Team | S&A Qualification |  | 6.15 | Ben Gilbert | Complete | COMPLETE |
| 2503 | 1.8.4.1.6.5.4.3 | PEN Test | 2d | 2025-03-03 A | 2025-03-04 A | 2502 | 100% |  | 2025-03-03 | 2025-03-04 | 0d | finish no earlier than 2025-02-06 | Non-SIT S&A QT Test Team | S&A Qualification |  | 6.15 | Ben Gilbert | Complete | COMPLETE |
| 2504 | 1.8.4.1.6.5.4.4 | Regression Test | 10d | 2025-03-05 A | 2025-03-18 A | 2503 | 100% |  | 2025-03-05 | 2025-03-18 | 0d | finish no earlier than 2025-02-20 | Non-SIT S&A QT Test Team | S&A Qualification |  | 6.15 | Ben Gilbert | Complete | COMPLETE |
| 2505 | 1.8.4.1.6.5.5 | **DIP Onboarding (UIT)** | 101d | 2024-07-26 A | 2024-12-13 A |  | 100% |  | 2024-07-26 | 2024-11-29 | 0d |  | Non-SIT S&A QT Test Team | S&A Qualification | -742.67 | 6.15 | Ben Gilbert |  |  |
| 2506 | 1.8.4.1.6.5.5.1 | DIP Simulator | 15d | 2024-07-26 A | 2024-08-15 A |  | 100% |  | 2024-07-26 | 2024-08-15 | 0d | finish no earlier than 2024-08-15 | Non-SIT S&A QT Test Team | S&A Qualification |  | 6.15 | Ben Gilbert | Complete | COMPLETE |
| 2507 | 1.8.4.1.6.5.5.2 | DIP (UIT) Instance available for Onboarding | 1d | 2024-08-05 A | 2024-08-05 A |  | 100% |  | 2024-08-05 | 2024-08-05 | 0d | start no earlier than 2024-08-05 | Non-SIT S&A QT Test Team | S&A Qualification |  | 6.15 | Ben Gilbert | Complete | COMPLETE |
| 2508 | 1.8.4.1.6.5.5.3 | DIP (UIT) Portal | 1d | 2024-09-03 A | 2024-09-03 A | 2507 | 100% |  | 2024-09-03 | 2024-09-03 | 0d | start no earlier than 2024-09-03 | Non-SIT S&A QT Test Team | S&A Qualification |  | 6.15 | Ben Gilbert | Complete | COMPLETE |
| 2509 | 1.8.4.1.6.5.5.4 | DIP (UIT) Onboarding for Development (incl. certificates and security compliance) | 39d | 2024-08-06 A | 2024-09-27 A | 2507 | 100% |  | 2024-08-06 | 2024-09-27 | 0d | finish no earlier than 2024-09-27 | Non-SIT S&A QT Test Team | S&A Qualification |  | 6.15 | Ben Gilbert | Complete | COMPLETE |
| 2510 | 1.8.4.1.6.5.5.5 | DIP (UIT) Onboarding for Development Connection Confirmed | 1d | 2024-09-30 A | 2024-09-30 A | 2509 | 100% |  | 2024-09-30 | 2024-09-30 | 0d | start no earlier than 2024-09-30 | Non-SIT S&A QT Test Team | S&A Qualification |  | 6.15 | Ben Gilbert | Complete | COMPLETE |
| 2511 | 1.8.4.1.6.5.5.6 | DIP (UIT) Onboarding for Test (incl. certificates and security compliance) | 5d | 2024-10-01 A | 2024-10-07 A | 2510 | 100% |  | 2024-10-01 | 2024-10-07 | 0d | finish no earlier than 2024-10-07 | Non-SIT S&A QT Test Team | S&A Qualification |  | 6.15 | Ben Gilbert | Complete | COMPLETE |
| 2512 | 1.8.4.1.6.5.5.7 | DIP (UIT) Onboarding for Test Connection Confirmed | 1d | 2024-10-08 A | 2024-10-08 A | 2511 | 100% |  | 2024-10-08 | 2024-10-08 | 0d | start no earlier than 2024-10-08 | Non-SIT S&A QT Test Team | S&A Qualification |  | 6.15 | Ben Gilbert | Complete | COMPLETE |
| 2513 | 1.8.4.1.6.5.5.8 | DIP (UIT) Onboarding for Prod (incl. certificates and security compliance) | 5d | 2024-10-09 A | 2024-10-15 A | 2512 | 100% |  | 2024-10-09 | 2024-10-15 | 0d | finish no earlier than 2024-10-15 | Non-SIT S&A QT Test Team | S&A Qualification |  | 6.15 | Ben Gilbert | Complete | COMPLETE |
| 2514 | 1.8.4.1.6.5.5.9 | DIP (UIT) Onboarding for Prod Connection Confirmed | 1d | 2024-10-16 A | 2024-10-16 A | 2513 | 100% |  | 2024-10-16 | 2024-10-16 | 0d | start no earlier than 2024-10-16 | Non-SIT S&A QT Test Team | S&A Qualification |  | 6.15 | Ben Gilbert | Complete | COMPLETE |
| 2515 | 1.8.4.1.6.5.5.10 | DIP UIT Test Stubs | 32d | 2024-10-31 A | 2024-12-13 A | 2510, 2512, 2514 | 100% |  | 2024-10-17 | 2024-11-29 | 0d | start no earlier than 2024-10-31 | Non-SIT S&A QT Test Team | S&A Qualification |  | 6.15 | Ben Gilbert | Complete | COMPLETE |
| 2516 | 1.8.4.1.6.5.6 | **DTN Onboarding** | 115d | 2024-05-20 A | 2024-10-25 A |  | 100% |  | 2024-05-20 | 2024-10-25 | 0d |  | Non-SIT S&A QT Test Team | S&A Qualification | -742.67 | 6.15 | Ben Gilbert |  |  |
| 2517 | 1.8.4.1.6.5.6.1 | DTN Request Raised for Onboarding | 25d | 2024-05-20 A | 2024-06-21 A |  | 100% |  | 2024-05-20 | 2024-06-21 | 0d | start no earlier than 2024-05-20 | Non-SIT S&A QT Test Team | S&A Qualification |  | 6.15 | Ben Gilbert | Complete | COMPLETE |
| 2518 | 1.8.4.1.6.5.6.2 | Setup, configuration of New Host and Test Flags | 5d | 2024-06-24 A | 2024-06-28 A | 2517 | 100% |  | 2024-06-24 | 2024-06-28 | 0d | start no earlier than 2024-06-24 | Non-SIT S&A QT Test Team | S&A Qualification |  | 6.15 | Ben Gilbert | Complete | COMPLETE |
| 2519 | 1.8.4.1.6.5.6.3 | New VPN Connection (Test) | 30d | 2024-08-05 A | 2024-09-13 A | 2518 | 100% |  | 2024-08-05 | 2024-09-13 | 0d | start no earlier than 2024-08-05 | Non-SIT S&A QT Test Team | S&A Qualification |  | 6.15 | Ben Gilbert | Complete | COMPLETE |
| 2520 | 1.8.4.1.6.5.6.4 | New VPN Connection (Prod) | 30d | 2024-09-16 A | 2024-10-25 A | 2519 | 100% |  | 2024-09-16 | 2024-10-25 | 0d | finish no earlier than 2024-10-25 | Non-SIT S&A QT Test Team | S&A Qualification |  | 6.15 | Ben Gilbert | Complete | COMPLETE |
| 2521 | 1.8.4.1.6.5.6.5 | DTN Test Stubs | 10d | 2024-09-16 A | 2024-09-27 A | 2519 | 100% |  | 2024-09-16 | 2024-09-27 | 0d | start no earlier than 2024-09-16 | Non-SIT S&A QT Test Team | S&A Qualification |  | 6.15 | Ben Gilbert | Complete | COMPLETE |
| 2522 | 1.8.4.1.6.5.7 | **Generate Tooling** | 334d | 2024-04-22 A | 2025-07-31 |  | 100% | 2024-09-24 | 2024-04-22 | 2025-07-31 | 0d |  | Non-SIT S&A QT Test Team | S&A Qualification | -742.67 | 6.15 | Ben Gilbert |  |  |
| 2523 | 1.8.4.1.6.5.7.1 | MPAN Core Generator | 25d | 2024-04-22 A | 2024-05-24 A |  | 100% |  | 2024-04-22 | 2024-05-24 | 0d | finish no earlier than 2024-05-24 | Non-SIT S&A QT Test Team | S&A Qualification |  | 6.15 | Ben Gilbert | Complete | COMPLETE |
| 2524 | 1.8.4.1.6.5.7.2 | MPAN File Generator | 55d | 2024-05-27 A | 2024-08-09 A | 2523 | 100% |  | 2024-05-27 | 2024-08-09 | 0d | finish no earlier than 2024-08-09 | Non-SIT S&A QT Test Team | S&A Qualification |  | 6.15 | Ben Gilbert | Complete | COMPLETE |
| 2525 | 1.8.4.1.6.5.7.3 | MPAN Template Loader | 32d | 2024-08-12 A | 2024-09-24 A | 2524 | 100% |  | 2024-08-12 | 2024-09-24 | 0d | finish no earlier than 2024-09-24 | Non-SIT S&A QT Test Team | S&A Qualification |  | 6.15 | Ben Gilbert | Complete | COMPLETE |
| 2526 | 1.8.4.1.6.5.7.4 | ADO Extract (QTC) From SIT | 30d | 2024-05-06 A | 2024-06-14 A |  | 100% |  | 2024-05-06 | 2024-06-14 | 0d | finish no earlier than 2024-06-14 | Non-SIT S&A QT Test Team | S&A Qualification |  | 6.15 | Ben Gilbert | Complete | COMPLETE |
| 2527 | 1.8.4.1.6.5.7.5 | Populate QT ADO | 40d | 2024-06-17 A | 2024-08-09 A | 2526 | 100% |  | 2024-06-17 | 2024-08-09 | 0d | finish no earlier than 2024-08-09 | Non-SIT S&A QT Test Team | S&A Qualification |  | 6.15 | Ben Gilbert | Complete | COMPLETE |
| 2528 | 1.8.4.1.6.5.7.6 | Create QTC Spreadsheets | 20d | 2024-06-03 A | 2024-06-28 A | 2526 | 100% |  | 2024-06-03 | 2024-06-28 | 0d | finish no earlier than 2024-06-28 | Non-SIT S&A QT Test Team | S&A Qualification |  | 6.15 | Ben Gilbert | Complete | COMPLETE |
| 2529 | 1.8.4.1.6.5.7.7 | Upload QTC Spreadsheets to QTF | 20d | 2024-07-01 A | 2024-07-26 A | 2528 | 100% |  | 2024-07-01 | 2024-07-26 | 0d | finish no earlier than 2024-07-26 | Non-SIT S&A QT Test Team | S&A Qualification |  | 6.15 | Ben Gilbert | Complete | COMPLETE |
| 2530 | 1.8.4.1.6.5.7.8 | Create QTC Set / Master QTC Loader | 40d | 2024-07-22 A | 2024-09-13 A | 2529 | 100% |  | 2024-07-22 | 2024-09-13 | 0d | finish no earlier than 2024-09-13 | Non-SIT S&A QT Test Team | S&A Qualification |  | 6.15 | Ben Gilbert | Complete | COMPLETE |

| ID | WBS | Task | Duration | Start | Finish | Predecessors | Complete | Actual finish | Baseline start | Baseline finish | Baseline duration | Constraint | Responsible | Text9 | Task Status | Update Version | MHHS Resource Name | Sched Status | RAG |
| --- | --- | --- | --- | --- | --- | --- | --- | --- | --- | --- | --- | --- | --- | --- | --- | --- | --- | --- | --- |
| 2531 | 1.8.4.1.6.5.8 | **Test Data** | 15d | 2024-06-10 A | 2024-06-28 A |  | 100% |  | 2024-06-10 | 2024-06-28 | 0d |  | Non-SIT S&A QT Test Team | S&A Qualification | -742.67 | 6.12 | Ben Gilbert |  |  |
| 2532 | 1.8.4.1.6.5.8.1 | Sample MPAN Data + Attributes from Suppliers | 15d | 2024-06-10 A | 2024-06-28 A |  | 100% |  | 2024-06-10 | 2024-06-28 | 0d | finish no earlier than 2024-06-28 | Non-SIT S&A QT Test Team | S&A Qualification |  | 6.12 | Ben Gilbert | Complete | COMPLETE |
| 2533 | 1.8.4.1.6.6 | **MPANs, DIP Messages, Settlement, Consumption, Reference** | 423d? | 2024-05-27 A | 2026-01-07 |  | 100% | 2026-02-19 | 2024-05-27 | 2026-01-07 | 0d |  | Non-SIT S&A QT Test Team | S&A Qualification | -742.67 | 6.12 | Ben Gilbert |  |  |
| 2534 | 1.8.4.1.6.6.1 | Create MPAN Data | 55d | 2024-05-27 A | 2024-08-09 A | 2523 | 100% |  | 2024-05-27 | 2024-08-09 | 0d | finish no earlier than 2024-08-09 | Non-SIT S&A QT Test Team | S&A Qualification |  | 6.12 | Ben Gilbert | Complete | COMPLETE |
| 2535 | 1.8.4.1.6.6.2 | Create message templates (DIP, CSS, DTN) | 40d | 2024-06-03 A | 2024-07-26 A |  | 100% |  | 2024-06-03 | 2024-07-26 | 0d | finish no earlier than 2024-07-26 | Non-SIT S&A QT Test Team | S&A Qualification |  | 6.12 | Ben Gilbert | Complete | COMPLETE |
| 2536 | 1.8.4.1.6.6.3 | Create Consumption Data Templates | 20d | 2024-09-16 A | 2024-10-11 A |  | 100% |  | 2024-09-16 | 2024-10-11 | 0d | finish no earlier than 2024-10-11 | Non-SIT S&A QT Test Team | S&A Qualification |  | 6.12 | Ben Gilbert | Complete | COMPLETE |
| 2537 | 1.8.4.1.6.6.4 | Load Consumption Data | 25d | 2024-11-11 A | 2024-12-13 A | 2536FS+20d | 100% |  | 2024-11-11 | 2024-12-06 | 0d |  | Non-SIT S&A QT Test Team | S&A Qualification |  | 6.12 | Ben Gilbert | Complete | COMPLETE |
| 2538 | 1.8.4.1.6.6.5 | Create Load Shape and Load Shape Total Templates | 20d | 2024-09-16 A | 2024-10-11 A |  | 100% |  | 2024-09-16 | 2024-10-11 | 0d | finish no earlier than 2024-10-11 | Non-SIT S&A QT Test Team | S&A Qualification |  | 6.12 | Ben Gilbert | Complete | COMPLETE |
| 2539 | 1.8.4.1.6.6.6 | Load Shape and Load Shape Total Data | 25d | 2024-11-11 A | 2024-12-13 A | 2538FS+20d | 100% |  | 2024-11-11 | 2024-12-06 | 0d |  | Non-SIT S&A QT Test Team | S&A Qualification |  | 6.12 | Ben Gilbert | Complete | COMPLETE |
| 2540 | 1.8.4.1.6.6.7 | Create Settlement Report Templates | 20d | 2024-09-16 A | 2024-10-11 A |  | 100% |  | 2024-09-16 | 2024-10-11 | 0d | finish no earlier than 2024-10-11 | Non-SIT S&A QT Test Team | S&A Qualification |  | 6.12 | Ben Gilbert | Complete | COMPLETE |
| 2541 | 1.8.4.1.6.6.8 | Load Settlement Report Data | 25d | 2024-11-11 A | 2024-12-13 A | 2540FS+20d | 100% |  | 2024-11-11 | 2024-12-06 | 0d |  | Non-SIT S&A QT Test Team | S&A Qualification |  | 6.12 | Ben Gilbert | Complete | COMPLETE |
| 2542 | 1.8.4.1.6.6.9 | Market Domain Data (MDD) For Legacy Systems | 25d | 2024-07-29 A | 2024-08-30 A |  | 100% |  | 2024-07-29 | 2024-08-30 | 0d | finish no earlier than 2024-08-30 | Non-SIT S&A QT Test Team | S&A Qualification |  | 6.12 | Ben Gilbert | Complete | COMPLETE |
| 2543 | 1.8.4.1.6.6.10 | **Industry Standing Data (ISD)** | 71d? | 2024-07-26 A | 2024-11-01 A |  | 100% |  | 2024-07-26 | 2024-11-01 | 0d |  | Non-SIT S&A QT Test Team | S&A Qualification | -742.67 | 6.12 | Ben Gilbert |  |  |
| 2544 | 1.8.4.1.6.6.10.1 | Dependant on Receiving ISD Agreed Source Data from Helix | 1d | 2024-07-26 A | 2024-07-26 A |  | 100% |  | 2024-07-26 | 2024-07-26 | 0d | start no earlier than 2024-07-26 | Non-SIT S&A QT Test Team | S&A Qualification |  | 6.12 | Ben Gilbert | Complete | COMPLETE |
| 2545 | 1.8.4.1.6.6.10.2 | Helix Dev Environment migration | 6d | 2024-07-29 A | 2024-08-05 A | 2544 | 100% |  | 2024-07-29 | 2024-08-05 | 0d | finish no earlier than 2024-08-05 | Non-SIT S&A QT Test Team | S&A Qualification |  | 6.12 | Ben Gilbert | Complete | COMPLETE |
| 2546 | 1.8.4.1.6.6.10.3 | STGi (UK) migration | 5d | 2024-09-09 A | 2024-09-13 A | 2544 | 100% |  | 2024-09-09 | 2024-09-13 | 0d | finish no earlier than 2024-09-13 | Non-SIT S&A QT Test Team | S&A Qualification |  | 6.12 | Ben Gilbert | Complete | COMPLETE |
| 2547 | 1.8.4.1.6.6.10.4 | Maintenance window between cycle 2 and 3 | 1d | 2024-09-20 A | 2024-09-20 A | 2544 | 100% |  | 2024-09-20 | 2024-09-20 | 0d | finish no earlier than 2024-09-20 | Non-SIT S&A QT Test Team | S&A Qualification |  | 6.12 | Ben Gilbert | Complete | COMPLETE |
| 2548 | 1.8.4.1.6.6.10.5 | First View of Migrated ISD Data | 5d | 2024-09-23 A | 2024-09-27 A | 2547 | 100% |  | 2024-09-23 | 2024-09-27 | 0d | finish no earlier than 2024-09-27 | Non-SIT S&A QT Test Team | S&A Qualification |  | 6.12 | Ben Gilbert | Complete | COMPLETE |
| 2549 | 1.8.4.1.6.6.10.6 | Second View of Migrated ISD Data (HXT1 (SIT B) migration) | 5d | 2024-09-23 A | 2024-09-27 A | 2547 | 100% |  | 2024-09-23 | 2024-09-27 | 0d | finish no earlier than 2024-09-27 | Non-SIT S&A QT Test Team | S&A Qualification |  | 6.12 | Ben Gilbert | Complete | COMPLETE |
| 2550 | 1.8.4.1.6.6.10.7 | Final Cycle 3 Migrated ISD Data | 5d | 2024-10-07 A | 2024-10-11 A | 2548 | 100% |  | 2024-10-07 | 2024-10-11 | 0d | finish no earlier than 2024-10-11 | Non-SIT S&A QT Test Team | S&A Qualification |  | 6.12 | Ben Gilbert | Complete | COMPLETE |
| 2551 | 1.8.4.1.6.6.10.8 | Create ISD Template inc. DIP ID | 35d? | 2024-09-16 A | 2024-11-01 A | 2547 | 100% |  | 2024-09-16 | 2024-11-01 | 0d | finish no earlier than 2024-11-01 | Non-SIT S&A QT Test Team | S&A Qualification |  | 6.12 | Ben Gilbert | Complete | COMPLETE |
| 2552 | 1.8.4.1.6.6.10.9 | Publish Qualification ISD | 10d? | 2024-10-14 A | 2024-10-25 A | 2550, 2547 | 100% |  | 2024-10-14 | 2024-10-25 | 0d | finish no earlier than 2024-10-25 | Non-SIT S&A QT Test Team | S&A Qualification |  | 6.12 | Ben Gilbert | Complete | COMPLETE |
| 2553 | 1.8.4.1.6.6.11 | **BETA Testing 1 - Test Data** | 27d | 2024-11-01 A | 2024-12-09 |  | 100% | 2025-01-22 | 2024-11-01 | 2024-11-15 | 0d |  | Non-SIT S&A QT Test Team | S&A Qualification | -169.67 | 6.12 | Ben Gilbert |  |  |
| 2554 | 1.8.4.1.6.6.11.1 | Provide Example MPAN File | 3d | 2024-11-01 A | 2024-11-05 A | 2597SS | 100% |  | 2024-11-01 | 2024-11-05 | 0d | finish no earlier than 2024-11-05 | Non-SIT S&A QT Test Team | S&A Qualification |  | 6.12 | Ben Gilbert | Complete | COMPLETE |
| 2555 | 1.8.4.1.6.6.11.2 | Load Example MPAN File | 6d | 2024-11-06 A | 2024-11-13 A | 2554 | 100% |  | 2024-11-06 | 2024-11-13 | 0d | finish no earlier than 2024-11-13 | Non-SIT S&A QT Test Team | S&A Qualification |  | 6.12 | Ben Gilbert | Complete | COMPLETE |
| 2556 | 1.8.4.1.6.6.11.3 | Industry Standing Data (ISD) | 6d | 2024-11-06 A | 2024-11-13 A | 2597SS+3d | 100% |  | 2024-11-06 | 2024-11-13 | 0d | finish no earlier than 2024-11-13 | Non-SIT S&A QT Test Team | S&A Qualification |  | 6.12 | Ben Gilbert | Complete | COMPLETE |
| 2557 | 1.8.4.1.6.6.11.4 | Market Domain Data (MDD) | 6d | 2024-11-06 A | 2024-11-13 A | 2597SS+3d | 100% |  | 2024-11-06 | 2024-11-13 | 0d | finish no earlier than 2024-11-13 | Non-SIT S&A QT Test Team | S&A Qualification |  | 6.12 | Ben Gilbert | Complete | COMPLETE |
| 2558 | 1.8.4.1.6.6.11.5 | Load ISD / MDD Data | 1d | 2024-12-06 A | 2024-12-06 A | 2556FS+16d, 2557FS+11d | 100% |  | 2024-11-14 | 2024-11-14 | 0d | start no earlier than 2024-11-14 | Non-SIT S&A QT Test Team | S&A Qualification |  | 6.12 | Ben Gilbert | Complete | COMPLETE |
| 2559 | 1.8.4.1.6.6.11.6 | Create QTC sets and Test MPANs via QTF | 1d | 2024-12-06 A | 2024-12-06 A | 2555FS+16d | 100% |  | 2024-11-14 | 2024-11-14 | 0d | start no earlier than 2024-11-14 | Non-SIT S&A QT Test Team | S&A Qualification |  | 6.12 | Ben Gilbert | Complete | COMPLETE |
| 2560 | 1.8.4.1.6.6.11.7 | Create QTC sets in ADO via QTF | 1d | 2024-12-06 A | 2024-12-06 A | 2559SS | 100% |  | 2024-11-14 | 2024-11-14 | 0d | start no earlier than 2024-11-14 | Non-SIT S&A QT Test Team | S&A Qualification |  | 6.12 | Ben Gilbert | Complete | COMPLETE |
| 2561 | 1.8.4.1.6.6.11.8 | Provide Test MPANs (Suppliers only) allocated to specfic QTC's | 1d | 2024-12-06 A | 2024-12-06 A | 2558SS | 100% |  | 2024-11-14 | 2024-11-14 | 0d | start no earlier than 2024-11-14 | Non-SIT S&A QT Test Team | S&A Qualification |  | 6.12 | Ben Gilbert | Complete | COMPLETE |
| 2562 | 1.8.4.1.6.6.11.9 | Load Test MPANs | 1d | 2024-12-09 A | 2024-12-09 A | 2561 | 100% |  | 2024-11-15 | 2024-11-15 | 0d | start no earlier than 2024-11-15 | Non-SIT S&A QT Test Team | S&A Qualification |  | 6.12 | Ben Gilbert | Complete | COMPLETE |

| ID | WBS | Task | Duration | Start | Finish | Predecessors | Complete | Actual start | Actual finish | Baseline start | Baseline finish | Baseline duration | Constraint | Responsible | Text9 | Task Status | Update Version | MHHS Resource Name | Sched Status | RAG |
| --- | --- | --- | --- | --- | --- | --- | --- | --- | --- | --- | --- | --- | --- | --- | --- | --- | --- | --- | --- | --- |
| 2563 | 1.8.4.1.6.6.11.10 | **BETA Testing 2 - Test Data** | 11d | 2025-01-08 A | 2025-01-22 A |  | 100% |  |  | 2025-01-08 | 2025-01-22 | 0d |  | Non-SIT S&A QT Test Team | S&A Qualification | -169.67 | 6.15 | Ben Gilbert |  |  |
| 2564 | 1.8.4.1.6.6.11.10.1 | Provide Example MPAN File | 3d | 2025-01-08 A | 2025-01-10 A | 2598SS | 100% |  |  | 2025-01-08 | 2025-01-10 | 0d | start no earlier than 2025-01-08 | Non-SIT S&A QT Test Team | S&A Qualification |  | 6.15 | Ben Gilbert | Complete | COMPLETE |
| 2565 | 1.8.4.1.6.6.11.10.2 | Load Example MPAN File | 6d | 2025-01-13 A | 2025-01-20 A | 2564 | 100% |  |  | 2025-01-13 | 2025-01-20 | 0d | start no earlier than 2025-01-13 | Non-SIT S&A QT Test Team | S&A Qualification |  | 6.15 | Ben Gilbert | Complete | COMPLETE |
| 2566 | 1.8.4.1.6.6.11.10.3 | Industry Standing Data (ISD) | 6d | 2025-01-08 A | 2025-01-15 A | 2552, 2598SS | 100% |  |  | 2025-01-08 | 2025-01-15 | 0d | start no earlier than 2025-01-08 | Non-SIT S&A QT Test Team | S&A Qualification |  | 6.15 | Ben Gilbert | Complete | COMPLETE |
| 2567 | 1.8.4.1.6.6.11.10.4 | Market Domain Data (MDD) | 6d | 2025-01-08 A | 2025-01-15 A | 2536, 2598SS | 100% |  |  | 2025-01-08 | 2025-01-15 | 0d | start no earlier than 2025-01-08 | Non-SIT S&A QT Test Team | S&A Qualification |  | 6.15 | Ben Gilbert | Complete | COMPLETE |
| 2568 | 1.8.4.1.6.6.11.10.5 | Load ISD / MDD Data | 1d | 2025-01-16 A | 2025-01-16 A | 2566, 2567, 2598SS | 100% |  |  | 2025-01-16 | 2025-01-16 | 0d | start no earlier than 2025-01-16 | Non-SIT S&A QT Test Team | S&A Qualification |  | 6.15 | Ben Gilbert | Complete | COMPLETE |
| 2569 | 1.8.4.1.6.6.11.10.6 | Create QTC sets and Test MPANs via QTF | 1d | 2025-01-21 A | 2025-01-21 A | 2565 | 100% |  |  | 2025-01-21 | 2025-01-21 | 0d | start no earlier than 2025-01-21 | Non-SIT S&A QT Test Team | S&A Qualification |  | 6.15 | Ben Gilbert | Complete | COMPLETE |
| 2570 | 1.8.4.1.6.6.11.10.7 | Create QTC sets in ADO via QTF | 1d | 2025-01-21 A | 2025-01-21 A | 2569SS | 100% |  |  | 2025-01-21 | 2025-01-21 | 0d | start no earlier than 2025-01-21 | Non-SIT S&A QT Test Team | S&A Qualification |  | 6.15 | Ben Gilbert | Complete | COMPLETE |
| 2571 | 1.8.4.1.6.6.11.10.8 | Provide Test MPANs (Suppliers only) allocated to specfic QTC's | 1d | 2025-01-21 A | 2025-01-21 A | 2569SS | 100% |  |  | 2025-01-21 | 2025-01-21 | 0d | start no earlier than 2025-01-21 | Non-SIT S&A QT Test Team | S&A Qualification |  | 6.15 | Ben Gilbert | Complete | COMPLETE |
| 2572 | 1.8.4.1.6.6.11.10.9 | Load Test MPANs | 1d | 2025-01-22 A | 2025-01-22 A | 2571 | 100% |  |  | 2025-01-22 | 2025-01-22 | 0d | start no earlier than 2025-01-22 | Non-SIT S&A QT Test Team | S&A Qualification |  | 6.15 | Ben Gilbert | Complete | COMPLETE |
| 2573 | 1.8.4.1.6.6.12 | **Wave 1 Test Data** | 46d | 2025-05-12 | 2025-07-15 | 2559SS | 100% | 2025-07-14 | 2025-08-15 | 2025-05-12 | 2025-07-15 | 0d |  | Non-SIT S&A QT Test Team | S&A Qualification | -168.67 | 6.18 | Ben Gilbert |  |  |
| 2574 | 1.8.4.1.6.6.12.1 | Test Data Request + Templates Completed | 2d | 2025-07-14 A | 2025-07-15 A | 2558SS | 100% |  |  | 2025-07-14 | 2025-07-15 | 0d | start no earlier than 2025-07-14 | Non-SIT S&A QT Test Team | S&A Qualification |  | 6.25 | Ben Gilbert | Complete | COMPLETE |
| 2575 | 1.8.4.1.6.6.12.2 | Test Data Generated | 2d | 2025-07-16 A | 2025-07-17 A | 2561, 2574 | 100% |  |  | 2025-07-16 | 2025-07-17 | 0d | finish no earlier than 2025-06-03 | Non-SIT S&A QT Test Team | S&A Qualification |  | 6.25 | Ben Gilbert | Complete | COMPLETE |
| 2576 | 1.8.4.1.6.6.12.3 | Test Data Loaded into QP Systems | 15d | 2025-07-18 A | 2025-08-07 A | 2575 | 100% |  |  | 2025-07-18 | 2025-08-07 | 0d | finish no earlier than 2025-06-17 | Non-SIT S&A QT Test Team | S&A Qualification |  | 6.25 | Ben Gilbert | Complete | COMPLETE |
| 2577 | 1.8.4.1.6.6.12.4 | Test Data Loaded into QTF + ADO | 5d | 2025-08-11 A | 2025-08-15 A | 2575, 2576 | 100% |  |  | 2025-08-11 | 2025-08-15 | 0d | finish no earlier than 2025-08-15 | Non-SIT S&A QT Test Team | S&A Qualification |  | 6.25 | Ben Gilbert | Complete | COMPLETE |
| 2578 | 1.8.4.1.6.6.13 | **Wave 2 Test Data** | 42d | 2025-07-07 | 2025-09-03 |  | 100% | 2025-09-17 | 2025-10-17 | 2025-07-07 | 2025-09-03 | 0d |  | Non-SIT S&A QT Test Team | S&A Qualification | -168.67 | 6.18 | Ben Gilbert |  |  |
| 2579 | 1.8.4.1.6.6.13.1 | Test Data Request + Templates Completed | 2d | 2025-09-17 A | 2025-09-18 A |  | 100% |  |  | 2025-09-17 | 2025-09-18 | 0d | start no earlier than 2025-09-17 | Non-SIT S&A QT Test Team | S&A Qualification |  | 6.18 | Ben Gilbert | Complete | COMPLETE |
| 2580 | 1.8.4.1.6.6.13.2 | Test Data Generated | 2d | 2025-09-19 A | 2025-09-22 A | 2579 | 100% |  |  | 2025-09-19 | 2025-09-22 | 0d | finish no earlier than 2025-07-29 | Non-SIT S&A QT Test Team | S&A Qualification |  | 6.18 | Ben Gilbert | Complete | COMPLETE |
| 2581 | 1.8.4.1.6.6.13.3 | Test Data Loaded into QP Systems | 15d | 2025-09-23 A | 2025-10-13 A | 2580 | 100% |  |  | 2025-09-23 | 2025-10-13 | 0d | finish no earlier than 2025-08-12 | Non-SIT S&A QT Test Team | S&A Qualification |  | 6.18 | Ben Gilbert | Complete | COMPLETE |
| 2582 | 1.8.4.1.6.6.13.4 | Test Data Loaded into QTF + ADO | 4d | 2025-10-14 A | 2025-10-17 A | 2580, 2581 | 100% |  |  | 2025-10-14 | 2025-10-17 | 0d | finish no earlier than 2025-08-12 | Non-SIT S&A QT Test Team | S&A Qualification |  | 6.18 | Ben Gilbert | Complete | COMPLETE |
| 2583 | 1.8.4.1.6.6.14 | **Wave 3 Test Data** | 45d | 2025-09-08 | 2025-11-10 |  | 100% | 2025-11-10 | 2025-12-11 | 2025-09-08 | 2025-11-10 | 0d |  | Non-SIT S&A QT Test Team | S&A Qualification | -168.67 | 6.18 | Ben Gilbert |  |  |
| 2584 | 1.8.4.1.6.6.14.1 | Test Data Request + Templates Completed | 2d | 2025-11-10 A | 2025-11-11 A |  | 100% |  |  | 2025-11-10 | 2025-11-11 | 0d | start no earlier than 2025-11-10 | Non-SIT S&A QT Test Team | S&A Qualification |  | 6.18 | Ben Gilbert | Complete | COMPLETE |
| 2585 | 1.8.4.1.6.6.14.2 | Test Data Generated | 2d | 2025-11-12 A | 2025-11-13 A | 2584 | 100% |  |  | 2025-11-12 | 2025-11-13 | 0d | finish no earlier than 2025-09-29 | Non-SIT S&A QT Test Team | S&A Qualification |  | 6.18 | Ben Gilbert | Complete | COMPLETE |
| 2586 | 1.8.4.1.6.6.14.3 | Test Data Loaded into QP Systems | 15d | 2025-11-14 A | 2025-12-04 A | 2585 | 100% |  |  | 2025-11-14 | 2025-12-04 | 0d | finish no earlier than 2025-10-13 | Non-SIT S&A QT Test Team | S&A Qualification |  | 6.18 | Ben Gilbert | Complete | COMPLETE |
| 2587 | 1.8.4.1.6.6.14.4 | Test Data Loaded into QTF + ADO | 5d | 2025-12-05 A | 2025-12-11 A | 2585, 2586 | 100% |  |  | 2025-12-05 | 2025-12-11 | 0d | finish no earlier than 2025-10-13 | Non-SIT S&A QT Test Team | S&A Qualification |  | 6.18 | Ben Gilbert | Complete | COMPLETE |

| ID | WBS | Task | Type | Duration | Start | Finish | Predecessors | Complete | Baseline start | Baseline finish | Baseline duration | Constraint | Baseline cost | Responsible | Text9 | Task Status | Update Version | MHHS Resource Name | Sched Status | RAG | Milestone ID | Text29 | Tier | Involved |
| --- | --- | --- | --- | --- | --- | --- | --- | --- | --- | --- | --- | --- | --- | --- | --- | --- | --- | --- | --- | --- | --- | --- | --- | --- |
| 2588 | 1.8.4.1.6.6.15 | **Wave 4 Test Data** |  | 24d | 2026-01-19 A | 2026-02-19 A |  | 100% | 2025-11-06 | 2026-01-08 | 0d |  |  | Non-SIT S&A QT Test Team | S&A Qualification | -168.67 | 6.18 | David Moss |  |  |  |  |  |  |
| 2589 | 1.8.4.1.6.6.15.1 | Test Data Request + Templates Completed |  | 2d | 2026-01-19 A | 2026-01-20 A |  | 100% | 2026-01-19 | 2026-01-20 | 0d | start no earlier than 2026-01-19 |  | Non-SIT S&A QT Test Team | S&A Qualification |  | 6.18 | David Moss | Complete | COMPLETE |  |  |  |  |
| 2590 | 1.8.4.1.6.6.15.2 | Test Data Generated |  | 2d | 2026-01-21 A | 2026-01-22 A | 2589 | 100% | 2026-01-21 | 2026-01-22 | 0d | finish no earlier than 2025-11-27 |  | Non-SIT S&A QT Test Team | S&A Qualification |  | 6.18 | David Moss | Complete | COMPLETE |  |  |  |  |
| 2591 | 1.8.4.1.6.6.15.3 | Test Data Loaded into QP Systems |  | 15d | 2026-01-23 A | 2026-02-12 A | 2590 | 100% | 2026-01-23 | 2026-02-12 | 0d | finish no earlier than 2025-12-11 |  | Non-SIT S&A QT Test Team | S&A Qualification |  | 6.18 | David Moss | Complete | COMPLETE |  |  |  |  |
| 2592 | 1.8.4.1.6.6.15.4 | Test Data Loaded into QTF + ADO |  | 5d | 2026-02-13 A | 2026-02-19 A | 2590, 2591 | 100% | 2026-02-13 | 2026-02-19 | 0d | finish no earlier than 2025-12-11 |  | Non-SIT S&A QT Test Team | S&A Qualification |  | 6.18 | David Moss | Complete | COMPLETE |  |  |  |  |
| 2593 | 1.8.4.1.6.6.16 | **Governance** |  | 195d | 2024-07-01 A | 2025-03-28 A |  | 100% | 2024-07-01 | 2024-12-20 | 0d |  |  | Non-SIT S&A QT Test Team | S&A Qualification | -168.67 | 6.12 | Ben Gilbert |  |  |  |  |  |  |
| 2594 | 1.8.4.1.6.6.16.1 | Onboarding Strategy and Develop Training Requirements & Materials Inc. Day in the Life |  | 120d | 2024-07-01 A | 2024-12-13 A | 2472 | 100% | 2024-07-01 | 2024-11-29 | 0d | finish no earlier than 2024-12-13 |  | Non-SIT S&A QT Test Team | S&A Qualification |  | 6.12 | Ben Gilbert | Complete | COMPLETE |  |  |  |  |
| 2595 | 1.8.4.1.6.6.16.2 | Design Approach & Set-Up ADO Tool for Test & Defect Management Tool |  | 20d | 2024-07-01 A | 2024-07-26 A | 2594SS | 100% | 2024-07-01 | 2024-07-26 | 0d |  |  | Non-SIT S&A QT Test Team | S&A Qualification |  | 6.12 | Ben Gilbert | Complete | COMPLETE |  |  |  |  |
| 2596 | 1.8.4.1.6.6.16.3 | Knowledge Transfer, Training, Demonstrations, Documentation, Governance |  | 78d | 2024-08-30 A | 2024-12-17 A | 2594SS+44d | 100% | 2024-08-30 | 2024-12-17 | 0d |  |  | Non-SIT S&A QT Test Team | S&A Qualification |  | 6.12 | Ben Gilbert | Complete | COMPLETE |  |  |  |  |
| 2597 | 1.8.4.1.6.6.16.4 | BETA Testing |  | 33d | 2024-11-01 A | 2024-12-17 A |  | 100% | 2024-11-01 | 2024-12-20 | 0d | finish no earlier than 2024-12-17 |  | Non-SIT S&A QT Test Team | S&A Qualification |  | 6.12 | Ben Gilbert | Complete | COMPLETE |  |  |  |  |
| 2598 | 1.8.4.1.6.6.16.5 | BETA Testing 2 |  | 58d | 2025-01-08 A | 2025-03-28 A | 2597 | 100% | 2025-01-08 | 2025-03-28 | 0d | start no earlier than 2025-01-08 |  | Non-SIT S&A QT Test Team | S&A Qualification |  | 6.13 | Ben Gilbert | Complete | COMPLETE |  |  |  |  |
| 2599 | 1.8.4.1.6.6.17 | Qualification Testing Framework Readiness Confirmed | milestone | 0d | 2025-03-28 A | 2025-03-28 A | 2598 | 100% | 2025-03-28 | 2025-03-28 | 0d | start no earlier than 2025-03-28 |  | Non-SIT S&A QT Test Team | S&A Qualification |  | 6.12 | Ben Gilbert | Complete | COMPLETE |  |  |  |  |
| 2600 | 1.8.4.1.6.6.18 | Qualification Testing Wave Readiness Confirmed | milestone | 0d | 2025-08-21 A | 2025-08-21 A | 2632FS-2d | 100% | 2025-08-21 | 2025-08-21 | 0d | finish no earlier than 2025-05-30 |  | Non-SIT S&A QT Test Team | S&A Qualification |  | 6.13 | Ben Gilbert | Complete | COMPLETE | T2-QU-1100 | QAG | T2 |  |
| 2601 | 1.8.4.1.7 | **Wave Allocation** |  | 129d | 2024-01-02 A | 2024-06-28 A |  | 100% | 2024-01-02 | 2024-06-28 | 128d |  | -0 | N/A | S&A Qualification | -133.67 | 5.24 | Ben Gilbert |  |  |  |  |  | N/A |
| 2602 | 1.8.4.1.7.1 | Draft Pre-Qualification Submission (PQS) document |  | 20d | 2024-01-02 A | 2024-01-29 A |  | 100% | 2024-01-02 | 2024-01-29 | 20d | finish no earlier than 2024-01-26 |  | Code Bodies | S&A Qualification |  | 5.24 | Ben Gilbert | Complete | COMPLETE |  |  |  | Code Bodies |
| 2603 | 1.8.4.1.7.2 | Publish PQS document |  | 1d | 2024-01-31 A | 2024-01-31 A |  | 100% | 2024-01-31 | 2024-01-31 | 1d | start no earlier than 2024-01-31 |  | Code Bodies | S&A Qualification |  | 5.24 | Ben Gilbert | Complete | COMPLETE |  |  |  | Code Bodies |
| 2604 | 1.8.4.1.7.3 | PQS Submission window |  | 60d | 2024-02-05 A | 2024-04-26 A |  | 100% | 2024-02-05 | 2024-04-26 | 60d | start no earlier than 2024-02-05 |  | Participants | S&A Qualification |  | 5.24 | Ben Gilbert | Complete | COMPLETE |  |  |  | Participants |
| 2605 | 1.8.4.1.7.4 | Pre-Qualification Submission and PIT Test Plan Deadline for Submission​ | milestone | 0d | 2024-04-26 A | 2024-04-26 A | 2604 | 100% | 2024-04-26 | 2024-04-26 | 0d |  |  | Participants | S&A Qualification |  | 5.25 | Ben Gilbert | Complete | COMPLETE | T3-QU-0118 | QAG | T3 | Participants |
| 2606 | 1.8.4.1.7.5 | PQS Review by Code Bodies |  | 25d | 2024-04-29 A | 2024-05-31 A | 2604, 2605 | 100% | 2024-04-29 | 2024-05-31 | 25d |  |  | Code Bodies | S&A Qualification |  | 5.24 | Ben Gilbert | Complete | COMPLETE |  |  |  | Code Bodies |
| 2607 | 1.8.4.1.7.6 | Draft Wave Allocations |  | 15d | 2024-06-03 A | 2024-06-21 A | 2606 | 100% | 2024-06-03 | 2024-06-21 | 15d |  |  | Code Bodies | S&A Qualification |  | 5.24 | Ben Gilbert | Complete | COMPLETE |  |  |  | Code Bodies |
| 2608 | 1.8.4.1.7.7 | Confirmation of participant Qualification Wave allocation | milestone | 0d | 2024-06-28 A | 2024-06-28 A | 2607FS+5d | 100% | 2024-06-28 | 2024-06-28 | 0d |  |  | Code Bodies | S&A Qualification |  | 5.28 | Ben Gilbert | Complete | COMPLETE | T3-QU-0012 | QAG | T3 | Code Bodies |
| 2609 | 1.8.4.2 | **Qualification Wave 1** |  | 248d | 2025-05-05 A | 2026-04-15 A |  | 100% | 2025-03-24 | 2026-04-10 | 229d |  | -0 | N/A | S&A Qualification | -133.67 | 6.13 | Ben Gilbert |  |  |  |  |  | N/A |
| 2610 | 1.8.4.2.1 | **Qualification Wave 1 QAD Prep** |  | 80d | 2025-05-05 A | 2025-08-22 A |  | 100% | 2025-03-24 | 2025-07-11 | 80d |  | -0 | N/A | S&A Qualification | -152.67 | 6.13 | Ben Gilbert |  |  |  |  |  | N/A |
| 2611 | 1.8.4.2.1.1 | Initial QAD Submission window opens | milestone | 0d | 2025-05-05 A | 2025-05-05 A | 2608, 2372FS+1d | 100% | 2025-05-05 | 2025-05-05 | 0d | start no earlier than 2025-03-24 |  | Participants | S&A Qualification |  | 6.13 | Ben Gilbert | Complete | COMPLETE |  |  |  | Participants |
| 2612 | 1.8.4.2.1.2 | Qualification Wave 1 Participants Submit Initial QAD |  | 50d | 2025-05-05 A | 2025-07-11 A | 2611FS-1d | 100% | 2025-05-05 | 2025-07-11 | 50d |  |  | Participants | S&A Qualification |  | 6.13 | Ben Gilbert | Complete | COMPLETE |  |  |  | Participants |
| 2613 | 1.8.4.2.1.3 | Minimum threshold of Qualification Wave 1 Participants required for QT start have submitted their initial QAD | milestone | 0d | 2025-07-14 A | 2025-07-14 A | 2612FS+1d | 100% | 2025-07-14 | 2025-07-14 | 0d |  |  | Participants | S&A Qualification |  | 6.38 | Ben Gilbert | Complete | COMPLETE | T3-QU-0094 | QAG | T3 | Participants |
| 2614 | 1.8.4.2.1.4 | All Qualification Wave 1 Participants have submitted their initial QAD | milestone | 0d | 2025-07-14 A | 2025-07-14 A | 2613 | 100% | 2025-07-14 | 2025-07-14 | 0d | start no earlier than 2025-07-14 |  | Participants |  |  | 6.38 | Ben Gilbert | Complete | COMPLETE |  |  |  |  |
| 2615 | 1.8.4.2.1.5 | Code Bodies review of Wave 1 Participants Initial QAD |  | 30d | 2025-07-14 A | 2025-08-22 A | 2612FS-1d, 2613FS-1d | 100% | 2025-07-14 | 2025-08-22 | 30d |  |  | Code Bodies | S&A Qualification |  | 6.13 | Ben Gilbert | Complete | COMPLETE |  |  |  | Code Bodies |
| 2616 | 1.8.4.2.1.6 | Completion of Code Bodies review of Initial QAD | milestone | 0d | 2025-08-22 A | 2025-08-22 A | 2615 | 100% | 2025-08-22 | 2025-08-22 | 0d |  |  | Code Bodies | S&A Qualification |  | 6.13 | Ben Gilbert | Complete | COMPLETE |  |  |  | Code Bodies |

| ID | WBS | Task | Type | Duration | Start | Finish | Predecessors | Complete | Baseline start | Baseline finish | Baseline duration | Constraint | Baseline cost | Responsible | Involved | Text9 | Task Status | Update Version | MHHS Resource Name | Sched Status | RAG | Milestone ID | Text29 | Tier |
| --- | --- | --- | --- | --- | --- | --- | --- | --- | --- | --- | --- | --- | --- | --- | --- | --- | --- | --- | --- | --- | --- | --- | --- | --- |
| 2617 | 1.8.4.2.2 | **Qualification Wave 1 Test Prep** |  | 60d | 2025-05-26 A | 2025-08-15 A |  | 100% | 2025-04-14 | 2025-07-04 | 60d |  | -0 | N/A | N/A | S&A Qualification | -555.67 | 6.13 | Ben Gilbert |  |  |  |  |  |
| 2618 | 1.8.4.2.2.1 | Confirmation from Qualification Wave 1 Participants that DIP onboarding has commenced | milestone | 0d | 2025-05-26 A | 2025-05-26 A |  | 100% | 2025-05-26 | 2025-05-26 | 0d | start no earlier than 2025-05-26 |  | Participants | Participants | S&A Qualification |  | 6.13 | Ben Gilbert | Complete | COMPLETE | T3-QU-0017 | QAG | T3 |
| 2619 | 1.8.4.2.2.2 | Qualification Wave 1 Participants DIP Onboarding Window |  | 35d | 2025-05-26 A | 2025-07-11 A | 2618 | 100% | 2025-05-26 | 2025-07-11 | 35d |  |  | Participants | Participants | S&A Qualification |  | 6.13 | Ben Gilbert | Complete | COMPLETE |  |  |  |
| 2620 | 1.8.4.2.2.3 | Confirmation from Qualification Wave 1 Participants that DIP onboarding has completed | milestone | 0d | 2025-07-11 A | 2025-07-11 A | 2619 | 100% | 2025-07-11 | 2025-07-11 | 0d |  |  | Participants | Participants | S&A Qualification |  | 6.13 | Ben Gilbert | Complete | COMPLETE | T3-QU-0133 | QAG | T3 |
| 2621 | 1.8.4.2.2.4 | Minimum threshold of Qualification Wave 1 Participants' required for QT start to provide status of PIT completion and submit QT Test Plan | milestone | 0d | 2025-07-14 A | 2025-07-14 A |  | 100% | 2025-07-14 | 2025-07-14 | 0d | start no earlier than 2025-07-14 |  | Participants | Participants | S&A Qualification |  | 6.38 | Ben Gilbert | Complete | COMPLETE | T3-QU-0095 | QAG | T3 |
| 2622 | 1.8.4.2.2.5 | All Qualification Wave 1 Participants' to provide status of PIT completion and submit QT Test Plan | milestone | 0d | 2025-07-14 A | 2025-07-14 A | 2621 | 100% | 2025-07-14 | 2025-07-14 | 0d | start no earlier than 2025-07-14 |  | Participants |  |  |  | 6.38 | Ben Gilbert | Complete | COMPLETE |  |  |  |
| 2623 | 1.8.4.2.2.6 | Review of Participants' PIT Status and QT Test Plan |  | 45d | 2025-06-16 A | 2025-08-15 A |  | 100% | 2025-06-16 | 2025-08-15 | 15d | start no earlier than 2025-06-16 |  | Code Bodies, Non-SIT S&A QT Test Team | Code Bodies, Non-SIT S&A QT Test Team | S&A Qualification |  | 6.27 | Ben Gilbert | Complete | COMPLETE |  |  |  |
| 2624 | 1.8.4.2.2.7 | Minimum threshold of Qualification Test Plans for Wave 1 Participants required for QT start approved | milestone | 0d | 2025-08-15 A | 2025-08-15 A | 2623 | 100% | 2025-08-15 | 2025-08-15 | 0d |  |  | Non-SIT S&A QT Test Team | Non-SIT S&A QT Test Team | S&A Qualification |  | 6.38 | Ben Gilbert | Complete | COMPLETE | T3-QU-0016 | QAG | T3 |
| 2625 | 1.8.4.2.2.8 | All Qualification Test Plans for Wave 1 Participants approved | milestone | 0d | 2025-08-15 A | 2025-08-15 A | 2624 | 100% | 2025-08-15 | 2025-08-15 | 0d | start no earlier than 2025-08-15 |  | Non-SIT S&A QT Test Team |  |  |  | 6.38 | Ben Gilbert | Complete | COMPLETE |  |  |  |
| 2626 | 1.8.4.2.2.9 | Minimum threshold of Qualification Wave 1 Participants required for QT start have submitted PIT Test Completion Report and evidence for QT Entry | milestone | 0d | 2025-07-14 A | 2025-07-14 A |  | 100% | 2025-07-14 | 2025-07-14 | 0d | start no earlier than 2025-07-14 |  | Participants | Participants | S&A Qualification |  | 6.38 | Ben Gilbert | Complete | COMPLETE | T3-QU-0096 | QAG | T3 |
| 2627 | 1.8.4.2.2.10 | Qualification Wave 1 Participants have submitted PIT Test Completion Report and evidence for QT Entry | milestone | 0d | 2025-07-14 A | 2025-07-14 A | 2626 | 100% | 2025-07-14 | 2025-07-14 | 0d | start no earlier than 2025-07-14 |  | Participants |  |  |  | 6.38 | Ben Gilbert | Complete | COMPLETE |  |  |  |
| 2628 | 1.8.4.2.2.11 | Review of Participants PIT Test Completion Report |  | 25d | 2025-07-14 A | 2025-08-15 A | 2626 | 100% | 2025-07-14 | 2025-08-15 | 25d |  |  | Code Bodies, Non-SIT S&A QT Test Team | Code Bodies, Non-SIT S&A QT Test Team | S&A Qualification |  | 6.13 | Ben Gilbert | Complete | COMPLETE |  |  |  |
| 2629 | 1.8.4.2.2.12 | Onboarding to QTF & ADO |  | 25d | 2025-07-14 A | 2025-08-15 A | 2628SS | 100% | 2025-07-14 | 2025-08-15 | 25d |  |  | Code Bodies, Non-SIT S&A QT Test Team | Code Bodies, Non-SIT S&A QT Test Team | S&A Qualification |  | 6.13 | Ben Gilbert | Complete | COMPLETE |  |  |  |
| 2630 | 1.8.4.2.3 | **Qualification Wave 1 QT Execution** |  | 100d | 2025-08-18 A | 2026-01-02 A |  | 100% | 2025-08-18 | 2026-01-09 | 100d |  | -0 | N/A | N/A | S&A Qualification | -152.67 | 6.13 | David Moss |  |  |  |  |  |
| 2631 | 1.8.4.2.3.1 | Review Entry Criteria Evidence for each Wave 1 Participant |  | 5d | 2025-08-18 A | 2025-08-22 A | 2616FF, 2620, 2624, 2628 | 100% | 2025-08-18 | 2025-08-22 | 5d |  |  | Non-SIT S&A QT Test Team | Non-SIT S&A QT Test Team | S&A Qualification |  | 6.13 | David Moss | Complete | COMPLETE |  |  |  |
| 2632 | 1.8.4.2.3.2 | Minimum threshold of Qualification Wave 1 Participant Test required for QT start Readiness Confirmed | milestone | 0d | 2025-08-22 A | 2025-08-22 A | 2615, 2616, 2631FF | 100% | 2025-08-22 | 2025-08-22 | 0d |  |  | Non-SIT S&A QT Test Team | Non-SIT S&A QT Test Team | S&A Qualification |  | 6.38 | David Moss | Complete | COMPLETE | T3-QU-0027 | QAG | T3 |
| 2633 | 1.8.4.2.3.3 | All Qualification Wave 1 Participant Test Readiness Confirmed | milestone | 0d | 2025-08-22 A | 2025-08-22 A | 2632 | 100% | 2025-08-22 | 2025-08-22 | 0d | start no earlier than 2025-08-22 |  | Non-SIT S&A QT Test Team |  |  |  | 6.38 | David Moss | Complete | COMPLETE |  |  |  |
| 2634 | 1.8.4.2.3.4 | Qualification Wave 1 QT Execution Start | milestone | 0d | 2025-08-25 A | 2025-08-25 A | 2632FS+1d, 2629, 2577 | 100% | 2025-08-25 | 2025-08-25 | 0d | start no earlier than 2025-07-14 |  | Participants | Participants | S&A Qualification |  | 6.13 | David Moss | Complete | COMPLETE | T3-QU-0028 | QAG | T3 |
| 2635 | 1.8.4.2.3.5 | Qualification Wave 1 QT Execution Window |  | 95d | 2025-08-25 A | 2026-01-02 A | 2634FS-1d | 100% | 2025-08-25 | 2026-01-09 | 95d |  |  | Participants | Participants | S&A Qualification |  | 6.45 | David Moss | Complete | COMPLETE |  |  |  |
| 2636 | 1.8.4.2.3.6 | Qualification Wave 1 QT Projected Execution End | milestone | 0d | 2026-01-02 A | 2026-01-02 A | 2635 | 100% | 2026-01-09 | 2026-01-09 | 0d |  |  | Participants | Participants | S&A Qualification |  | 6.45 | David Moss | Complete | COMPLETE | T3-QU-0054 | QAG | T3 |
| 2637 | 1.8.4.2.4 | **Qualification Wave 1 Exit** |  | 168d | 2025-08-25 A | 2026-04-15 A |  | 100% | 2025-08-25 | 2026-04-15 | 149d? |  | -0 | N/A | N/A | S&A Qualification | -152.67 | 6.13 | Ben Gilbert |  |  |  |  |  |
| 2638 | 1.8.4.2.4.1 | Assurance on PP Test Completion Report |  | 10d | 2026-01-05 A | 2026-01-16 A | 2636 | 100% | 2026-01-05 | 2026-01-16 | 0d |  |  | Participants |  |  |  | 6.45 | Laura Kennedy | Complete | COMPLETE |  |  |  |
| 2639 | 1.8.4.2.4.2 | Final QAD Submission window opens | milestone | 0d | 2025-08-25 A | 2025-08-25 A | 2634 | 100% | 2025-08-25 | 2025-08-25 | 0d |  |  | Participants | Participants | S&A Qualification |  | 6.13 | Ben Gilbert | Complete | COMPLETE |  |  |  |
| 2640 | 1.8.4.2.4.3 | Qualification Wave 1 Participants submit their Final QAD |  | 105d | 2025-08-25 A | 2026-01-16 A | 2639FS-1d, 2638FF | 100% | 2025-08-25 | 2026-01-16 | 100d |  |  | Participants | Participants | S&A Qualification |  | 6.13 | Laura Kennedy | Complete | COMPLETE |  |  |  |
| 2641 | 1.8.4.2.4.4 | 80% of M14 Critical Qualification Wave 1 Participants have submitted their final QAD | milestone | 0d | 2026-01-16 A | 2026-01-16 A | 2640, 2636 | 100% | 2026-01-16 | 2026-01-16 | 0d |  |  | Participants | Participants | S&A Qualification |  | 6.38 | Laura Kennedy | Complete | COMPLETE | T3-QU-0097 | QAG | T3 |
| 2642 | 1.8.4.2.4.5 | All Qualification Wave 1 Participants have submitted their final QAD | milestone | 0d | 2026-01-16 A | 2026-01-16 A | 2641 | 100% | 2026-01-16 | 2026-01-16 | 0d | start no earlier than 2026-01-16 |  | Participants |  |  |  | 6.38 | Laura Kennedy | Complete | COMPLETE |  |  |  |
| 2643 | 1.8.4.2.4.6 | Completion of Code Bodies review of Final QAD |  | 35d | 2026-01-19 A | 2026-03-06 A | 2640, 2641 | 100% | 2026-01-19 | 2026-03-06 | 20d |  |  | Code Bodies | Code Bodies | S&A Qualification |  | 6.13 | Laura Kennedy | Complete | COMPLETE |  |  |  |
| 2644 | 1.8.4.2.4.7 | QAD Sign Off deadline |  | 1d | 2026-03-20 A | 2026-03-20 A | 2643FS+9d | 100% | 2026-03-20 | 2026-03-20 | 1d |  |  | Participants | Participants | S&A Qualification |  | 6.13 | Laura Kennedy | Complete | COMPLETE |  |  |  |
| 2645 | 1.8.4.2.4.8 | 80% of M14 Critical Wave 1 Participants Qualification approved by BSC PAB and REC Manager | milestone | 0d | 2026-04-15 A | 2026-04-15 A |  | 100% | 2026-04-15 | 2026-04-15 | 0d | finish no earlier than 2026-04-15 |  | Code Bodies |  |  |  | 6.38 | Laura Kennedy | Complete | COMPLETE | T3-QU-0134 | QAG | T3 |
| 2646 | 1.8.4.2.4.9 | All M14 Critical Wave 1 Participants Qualification approved by BSC PAB and REC Manager | milestone | 0d | 2026-04-15 A | 2026-04-15 A | 2644FS+18d, 2614, 2633, 2642 | 100% | 2026-04-15 | 2026-04-15 | 0d |  |  | Code Bodies | Code Bodies | S&A Qualification |  | 6.38 | Laura Kennedy | Complete | COMPLETE | T2-QU-0150 | QAG | T2 |

| ID | WBS | Task | Type | Duration | Start | Finish | Predecessors | Complete | Baseline start | Baseline finish | Baseline duration | Constraint | Baseline cost | Responsible | Involved | Text9 | Task Status | Update Version | MHHS Resource Name | Sched Status | RAG | Milestone ID | Text29 | Tier |
| --- | --- | --- | --- | --- | --- | --- | --- | --- | --- | --- | --- | --- | --- | --- | --- | --- | --- | --- | --- | --- | --- | --- | --- | --- |
| 2647 | 1.8.4.3 | **Qualification Wave 2** |  | 254d | 2025-06-09 A | 2026-05-28 A |  | 100% | 2025-06-09 | 2026-05-28 | 249d |  | -0 | N/A | N/A | S&A Qualification | -133.67 | 6.13 | Ben Gilbert |  |  |  |  |  |
| 2648 | 1.8.4.3.1 | **Qualification Wave 2 QAD Prep** |  | 95d | 2025-06-09 A | 2025-10-17 A |  | 100% | 2025-06-09 | 2025-10-17 | 96d |  | -0 | N/A | N/A | S&A Qualification | -154.67 | 6.13 | Laura Kennedy |  |  |  |  |  |
| 2649 | 1.8.4.3.1.1 | Initial QAD Submission window opens | milestone | 0d | 2025-06-09 A | 2025-06-09 A | 2373FS+1d | 100% | 2025-06-09 | 2025-06-09 | 0d |  |  | Participants | Participants | S&A Qualification |  | 6.13 | Ben Gilbert | Complete | COMPLETE |  |  |  |
| 2650 | 1.8.4.3.1.2 | Qualification Wave 2 Participants Submit Initial QAD |  | 70d | 2025-06-09 A | 2025-09-12 A | 2649FS-1d | 100% | 2025-06-09 | 2025-09-12 | 70d |  |  | Participants | Participants | S&A Qualification |  | 6.13 | Ben Gilbert | Complete | COMPLETE |  |  |  |
| 2651 | 1.8.4.3.1.3 | Minimum threshold of Qualification Wave 2 Participants required for QT start have submitted their initial QAD | milestone | 0d | 2025-09-12 A | 2025-09-12 A | 2650 | 100% | 2025-09-12 | 2025-09-12 | 0d |  |  | Participants | Participants | S&A Qualification |  | 6.38 | Ben Gilbert | Complete | COMPLETE | T3-QU-0098 | QAG | T3 |
| 2652 | 1.8.4.3.1.4 | All Qualification Wave 2 Participants have submitted their initial QAD | milestone | 0d | 2025-09-12 A | 2025-09-12 A | 2651 | 100% | 2025-09-12 | 2025-09-12 | 0d | start no earlier than 2025-09-12 |  | Participants |  |  |  | 6.38 | Ben Gilbert | Complete | COMPLETE |  |  |  |
| 2653 | 1.8.4.3.1.5 | Code Bodies review of Wave 2 Participants' Initial QAD |  | 25d | 2025-09-15 A | 2025-10-17 A | 2651 | 100% | 2025-09-15 | 2025-10-17 | 26d |  |  | Code Bodies | Code Bodies | S&A Qualification |  | 6.13 | Laura Kennedy | Complete | COMPLETE |  |  |  |
| 2654 | 1.8.4.3.1.6 | Completion of Code Bodies review of Initial QAD | milestone | 0d | 2025-10-17 A | 2025-10-17 A | 2653 | 100% | 2025-10-17 | 2025-10-17 | 0d |  |  | Code Bodies | Code Bodies | S&A Qualification |  | 6.13 | Laura Kennedy | Complete | COMPLETE |  |  |  |
| 2655 | 1.8.4.3.2 | **Qualification Wave 2 Test Prep** |  | 60d | 2025-07-21 A | 2025-10-10 A |  | 100% | 2025-07-21 | 2025-10-10 | 60d |  | -0 | N/A | N/A | S&A Qualification | -555.67 | 6.13 | Ben Gilbert |  |  |  |  |  |
| 2656 | 1.8.4.3.2.1 | Confirmation from Qualification Wave 2 Participants that DIP Onboarding has commenced | milestone | 0d | 2025-07-21 A | 2025-07-21 A |  | 100% | 2025-07-21 | 2025-07-21 | 0d | start no earlier than 2025-07-21 |  | Participants | Participants | S&A Qualification |  | 6.13 | Ben Gilbert | Complete | COMPLETE | T3-QU-0021 | QAG | T3 |
| 2657 | 1.8.4.3.2.2 | Qualification Wave 2 Participants DIP Onboarding Window |  | 35d | 2025-07-21 A | 2025-09-05 A | 2656 | 100% | 2025-07-21 | 2025-09-05 | 40d |  |  | Participants | Participants | S&A Qualification |  | 6.13 | Ben Gilbert | Complete | COMPLETE |  |  |  |
| 2658 | 1.8.4.3.2.3 | Confirmation from Qualificiation Wave 2 Participants that DIP onboarding has completed | milestone | 0d | 2025-09-05 A | 2025-09-05 A | 2657 | 100% | 2025-09-05 | 2025-09-05 | 0d |  |  | Participants | Participants | S&A Qualification |  | 6.13 | Ben Gilbert | Complete | COMPLETE |  |  |  |
| 2659 | 1.8.4.3.2.4 | Minimum threshold of Qualification Wave 2 Participants' required for QT start to provide status of PIT completion and submit QT Test Plan | milestone | 0d | 2025-08-18 A | 2025-08-18 A |  | 100% | 2025-08-18 | 2025-08-18 | 0d | start no earlier than 2025-08-18 |  | Participants | Participants | S&A Qualification |  | 6.38 | Ben Gilbert | Complete | COMPLETE | T3-QU-0099 | QAG | T3 |
| 2660 | 1.8.4.3.2.5 | All Qualification Wave 2 Participants' to provide status of PIT completion and submit QT Test Plan | milestone | 0d | 2025-08-18 A | 2025-08-18 A | 2659 | 100% | 2025-08-18 | 2025-08-18 | 0d |  |  | Participants |  |  |  | 6.38 | Ben Gilbert | Complete | COMPLETE |  |  |  |
| 2661 | 1.8.4.3.2.6 | Review of Participants' PIT Status and QT Test Plan |  | 15d | 2025-08-18 A | 2025-09-05 A | 2659 | 100% | 2025-08-18 | 2025-09-05 | 15d | start no earlier than 2025-07-07 |  | Code Bodies, Non-SIT S&A QT Test Team | Code Bodies, Non-SIT S&A QT Test Team | S&A Qualification |  | 6.13 | Ben Gilbert | Complete | COMPLETE |  |  |  |
| 2662 | 1.8.4.3.2.7 | Minimum threshold of Qualification Test Plans for Wave 2 Participants required for QT start approved | milestone | 0d | 2025-09-05 A | 2025-09-05 A | 2661 | 100% | 2025-09-05 | 2025-09-05 | 0d | start no earlier than 2025-07-25 |  | Non-SIT S&A QT Test Team | Non-SIT S&A QT Test Team | S&A Qualification |  | 6.38 | Ben Gilbert | Complete | COMPLETE | T3-QU-0020 | QAG | T3 |
| 2663 | 1.8.4.3.2.8 | All Qualification Test Plans for Wave 2 Participants approved | milestone | 0d | 2025-09-05 A | 2025-09-05 A | 2662 | 100% | 2025-09-05 | 2025-09-05 | 0d |  |  | Non-SIT S&A QT Test Team |  |  |  | 6.38 | Ben Gilbert | Complete | COMPLETE |  |  |  |
| 2664 | 1.8.4.3.2.9 | Minimum threshold of Qualification Wave 2 Participants required for QT start have submitted PIT Test Completion Report and evidence for QT entry | milestone | 0d | 2025-09-08 A | 2025-09-08 A |  | 100% | 2025-09-08 | 2025-09-08 | 0d | start no earlier than 2025-09-08 |  | Participants | Participants | S&A Qualification |  | 6.38 | Ben Gilbert | Complete | COMPLETE | T3-QU-0100 | QAG | T3 |
| 2665 | 1.8.4.3.2.10 | All Qualification Wave 2 Participants have submitted PIT Test Completion Report and evidence for QT entry | milestone | 0d | 2025-09-08 A | 2025-09-08 A | 2664 | 100% | 2025-09-08 | 2025-09-08 | 0d |  |  | Participants |  |  |  | 6.38 | Ben Gilbert | Complete | COMPLETE |  |  |  |
| 2666 | 1.8.4.3.2.11 | Review of Participants' PIT Test Completion Report |  | 25d | 2025-09-08 A | 2025-10-10 A | 2664 | 100% | 2025-09-08 | 2025-10-10 | 25d |  |  | Code Bodies, Non-SIT S&A QT Test Team | Code Bodies, Non-SIT S&A QT Test Team | S&A Qualification |  | 6.13 | Ben Gilbert | Complete | COMPLETE |  |  |  |
| 2667 | 1.8.4.3.2.12 | Onboarding to QTF & ADO |  | 25d | 2025-09-08 A | 2025-10-10 A | 2666SS | 100% | 2025-09-08 | 2025-10-10 | 25d |  |  | Code Bodies, Non-SIT S&A QT Test Team | Code Bodies, Non-SIT S&A QT Test Team | S&A Qualification |  | 6.13 | Ben Gilbert | Complete | COMPLETE |  |  |  |
| 2668 | 1.8.4.3.3 | **Qualification Wave 2 QT Execution** |  | 95d | 2025-10-13 A | 2026-02-20 A |  | 100% | 2025-10-13 | 2026-02-27 | 99d |  | -0 | N/A | N/A | S&A Qualification | -154.67 | 6.13 | David Moss |  |  |  |  |  |
| 2669 | 1.8.4.3.3.1 | Review Entry Criteria Evidence for each Wave 2 Participant |  | 5d | 2025-10-13 A | 2025-10-17 A | 2654FF, 2658, 2662, 2666 | 100% | 2025-10-13 | 2025-10-17 | 5d |  |  | Non-SIT S&A QT Test Team | Non-SIT S&A QT Test Team | S&A Qualification |  | 6.13 | David Moss | Complete | COMPLETE |  |  |  |
| 2670 | 1.8.4.3.3.2 | Minimum threshold of Qualification Wave 2 Participant required for QT start Test Readiness Confirmed | milestone | 0d | 2025-10-17 A | 2025-10-17 A | 2669, 2654 | 100% | 2025-10-17 | 2025-10-17 | 0d |  |  | Non-SIT S&A QT Test Team | Non-SIT S&A QT Test Team | S&A Qualification |  | 6.38 | David Moss | Complete | COMPLETE | T3-QU-0033 | QAG | T3 |
| 2671 | 1.8.4.3.3.3 | All Qualification Wave 2 Participant Test Readiness Confirmed | milestone | 0d | 2025-10-17 A | 2025-10-17 A | 2670 | 100% | 2025-10-17 | 2025-10-17 | 0d |  |  | Non-SIT S&A QT Test Team |  |  |  | 6.38 | David Moss | Complete | COMPLETE |  |  |  |
| 2672 | 1.8.4.3.3.4 | Qualification Wave 2 Execution Start | milestone | 0d | 2025-10-20 A | 2025-10-20 A | 2670FS+1d, 2667, 2582 | 100% | 2025-10-20 | 2025-10-20 | 0d |  |  | Participants | Participants | S&A Qualification |  | 6.13 | David Moss | Complete | COMPLETE | T3-QU-0034 | QAG | T3 |
| 2673 | 1.8.4.3.3.5 | Qualification Wave 2 QT Execution Window |  | 90d | 2025-10-20 A | 2026-02-20 A | 2672SS-1d | 100% | 2025-10-20 | 2026-02-27 | 94d |  |  | Participants | Participants | S&A Qualification |  | 6.45 | David Moss | Complete | COMPLETE |  |  |  |
| 2674 | 1.8.4.3.3.6 | Qualification Wave 2 QT Projected Execution End |  | 1d | 2026-02-20 A | 2026-02-20 A | 2673 | 100% | 2026-02-27 | 2026-02-27 | 0d |  |  | Participants | Participants | S&A Qualification |  | 6.50 | David Moss | Complete | COMPLETE | T3-QU-0055 | QAG | T3 |

Notes:
- 2674: 01/05/26: Task name updated from 'Qualification Wave 2 QT Execution End' to 'Qualification Wave 2 QT Projected Execution End' to align and to ensure consistency across the plan.

| ID | WBS | Task | Type | Duration | Start | Finish | Predecessors | Complete | Baseline start | Baseline finish | Baseline duration | Constraint | Baseline cost | Responsible | Involved | Text9 | Task Status | Update Version | MHHS Resource Name | Sched Status | RAG | Milestone ID | Text29 | Tier |
| --- | --- | --- | --- | --- | --- | --- | --- | --- | --- | --- | --- | --- | --- | --- | --- | --- | --- | --- | --- | --- | --- | --- | --- | --- |
| 2675 | 1.8.4.3.4 | **Qualification Wave 2 Exit** |  | 159d | 2025-10-20 A | 2026-05-28 A |  | 100% | 2025-10-20 | 2026-05-28 | 153d |  | -0 | N/A | N/A | S&A Qualification | -154.67 | 6.13 | Ben Gilbert |  |  |  |  |  |
| 2676 | 1.8.4.3.4.1 | Assurance on PP Test Completion Report |  | 10d | 2026-02-23 A | 2026-03-06 A | 2674 | 100% | 2026-02-23 | 2026-03-06 | 0d |  |  | Participants |  |  |  | 6.45 | Laura Kennedy | Complete | COMPLETE |  |  |  |
| 2677 | 1.8.4.3.4.2 | Final QAD Submission window opens | milestone | 0d | 2025-10-20 A | 2025-10-20 A | 2672 | 100% | 2025-10-20 | 2025-10-20 | 0d |  |  | Participants | Participants | S&A Qualification |  | 6.13 | Ben Gilbert | Complete | COMPLETE |  |  |  |
| 2678 | 1.8.4.3.4.3 | Qualification Wave 2 Participants submit their Final QAD |  | 100d | 2025-10-20 A | 2026-03-06 A | 2677FS-1d, 2676FF | 100% | 2025-10-20 | 2026-03-06 | 99d |  |  | Participants | Participants | S&A Qualification |  | 6.13 | Laura Kennedy | Complete | COMPLETE |  |  |  |
| 2679 | 1.8.4.3.4.4 | 80% of M14 Critical Qualification Wave 2 Participants have submitted their final QAD | milestone | 0d | 2026-03-06 A | 2026-03-06 A | 2678, 2674 | 100% | 2026-03-06 | 2026-03-06 | 0d |  |  | Participants | Participants | S&A Qualification |  | 6.38 | Laura Kennedy | Complete | COMPLETE | T3-QU-0101 | QAG | T3 |
| 2680 | 1.8.4.3.4.5 | All Qualification Wave 2 Participants have submitted their final QAD | milestone | 0d | 2026-03-06 A | 2026-03-06 A | 2679 | 100% | 2026-03-06 | 2026-03-06 | 0d |  |  | Participants |  |  |  | 6.38 | Laura Kennedy | Complete | COMPLETE |  |  |  |
| 2681 | 1.8.4.3.4.6 | Completion of Code Bodies review of Final QAD |  | 26d | 2026-03-09 A | 2026-04-13 A | 2679 | 100% | 2026-03-09 | 2026-04-13 | 27d |  |  | Code Bodies | Code Bodies | S&A Qualification |  | 6.13 | Laura Kennedy | Complete | COMPLETE |  |  |  |
| 2682 | 1.8.4.3.4.7 | QAD Sign Off deadline |  | 1d | 2026-04-20 A | 2026-04-20 A | 2681FS+4d | 100% | 2026-04-20 | 2026-04-20 | 1d |  |  | Participants | Participants | S&A Qualification |  | 6.13 | Laura Kennedy | Complete | COMPLETE |  |  |  |
| 2683 | 1.8.4.3.4.8 | 80% of M14 Critical Wave 2 Participants Qualification approved by BSC PAB and REC Manager | milestone | 0d | 2026-05-28 A | 2026-05-28 A |  | 100% | 2026-05-28 | 2026-05-28 | 0d | start no earlier than 2026-05-28 |  | Code Bodies |  |  |  | 6.38 | Laura Kennedy | Complete | COMPLETE | T3-QU-0135 | QAG | T3 |
| 2684 | 1.8.4.3.4.9 | All M14 Critical Wave 2 Participants Qualification approved by BSC PAB and REC Manager | milestone | 0d | 2026-05-28 A | 2026-05-28 A | 2682FS+28d, 2652, 2660, 2665, 2671, 2680 | 100% | 2026-05-28 | 2026-05-28 | 0d |  |  | Code Bodies | Code Bodies | S&A Qualification |  | 6.38 | Laura Kennedy | Complete | COMPLETE | T2-QU-0200 | QAG | T2 |
| 2685 | 1.8.4.4 | **Qualification Wave 3** |  | 254d | 2025-08-11 A | 2026-07-30 A |  | 100% | 2025-08-11 | 2026-07-30 | 239d |  | -0 | N/A | N/A | S&A Qualification | -133.67 | 6.13 | Laura Kennedy |  |  |  |  |  |
| 2686 | 1.8.4.4.1 | **Qualification Wave 3 QAD Prep** |  | 95d | 2025-08-11 A | 2025-12-19 A |  | 100% | 2025-08-11 | 2025-12-19 | 95d |  | -0 | N/A | N/A | S&A Qualification | -154.67 | 6.13 | Laura Kennedy |  |  |  |  |  |
| 2687 | 1.8.4.4.1.1 | Initial QAD Submission window opens | milestone | 0d | 2025-08-11 A | 2025-08-11 A | 2374FS+1d | 100% | 2025-08-11 | 2025-08-11 | 0d |  |  | Participants | Participants | S&A Qualification |  | 6.13 | Ben Gilbert | Complete | COMPLETE |  |  |  |
| 2688 | 1.8.4.4.1.2 | Qualification Wave 3 Participants Submit Initial QAD |  | 65d | 2025-08-11 A | 2025-11-07 A | 2687FS-1d | 100% | 2025-08-11 | 2025-11-07 | 65d |  |  | Participants | Participants | S&A Qualification |  | 6.13 | Laura Kennedy | Complete | COMPLETE |  |  |  |
| 2689 | 1.8.4.4.1.3 | Minimum threshold of Qualification Wave 3 Participants required for QT start have submitted their initial QAD | milestone | 0d | 2025-11-07 A | 2025-11-07 A | 2688 | 100% | 2025-11-07 | 2025-11-07 | 0d |  |  | Participants | Participants | S&A Qualification |  | 6.38 | Ben Gilbert | Complete | COMPLETE | T3-QU-0102 | QAG | T3 |
| 2690 | 1.8.4.4.1.4 | All Qualification Wave 3 Participants have submitted their initial QAD | milestone | 0d | 2025-11-07 A | 2025-11-07 A | 2689 | 100% | 2025-11-07 | 2025-11-07 | 0d | start no earlier than 2025-11-07 |  | Participants |  |  |  | 6.38 | Laura Kennedy | Complete | COMPLETE |  |  |  |
| 2691 | 1.8.4.4.1.5 | Code Bodies review of Wave 3 Participants' Initial QAD |  | 30d | 2025-11-10 A | 2025-12-19 A | 2689 | 100% | 2025-11-10 | 2025-12-19 | 30d |  |  | Code Bodies | Code Bodies | S&A Qualification |  | 6.13 | Laura Kennedy | Complete | COMPLETE |  |  |  |
| 2692 | 1.8.4.4.1.6 | Completion of Code Bodies review of Initial QAD | milestone | 0d | 2025-12-19 A | 2025-12-19 A | 2691 | 100% | 2025-12-19 | 2025-12-19 | 0d |  |  | Code Bodies | Code Bodies | S&A Qualification |  | 6.13 | Laura Kennedy | Complete | COMPLETE |  |  |  |
| 2693 | 1.8.4.4.2 | **Qualification Wave 3 Test Prep** |  | 65d | 2025-09-15 A | 2025-12-12 A |  | 100% | 2025-09-15 | 2025-12-12 | 65d |  | -0 | N/A | N/A | S&A Qualification | -555.67 | 6.13 | Laura Kennedy |  |  |  |  |  |
| 2694 | 1.8.4.4.2.1 | Confirmation from Qualification Wave 3 Participants that DIP Onboarding has commenced | milestone | 0d | 2025-09-15 A | 2025-09-15 A |  | 100% | 2025-09-15 | 2025-09-15 | 0d | start no earlier than 2025-09-15 |  | Participants | Participants | S&A Qualification |  | 6.13 | Ben Gilbert | Complete | COMPLETE | T3-QU-0025 | QAG | T3 |
| 2695 | 1.8.4.4.2.2 | Qualification Wave 3 Participants DIP Onboarding window |  | 35d | 2025-09-15 A | 2025-10-31 A | 2694 | 100% | 2025-09-15 | 2025-10-31 | 40d | start no earlier than 2025-08-04 |  | Participants | Participants | S&A Qualification |  | 6.13 | Ben Gilbert | Complete | COMPLETE |  |  |  |
| 2696 | 1.8.4.4.2.3 | Confirmation from Qualification Wave 3 Participants that DIP onboarding has completed | milestone | 0d | 2025-10-31 A | 2025-10-31 A | 2695 | 100% | 2025-10-31 | 2025-10-31 | 0d | start no earlier than 2025-09-22 |  | Participants | Participants | S&A Qualification |  | 6.13 | Ben Gilbert | Complete | COMPLETE |  |  |  |
| 2697 | 1.8.4.4.2.4 | Minimum threshold of Qualification Wave 3 Participants' required for QT start to provide status of PIT completion and submit QT Test Plan | milestone | 0d | 2025-10-20 A | 2025-10-20 A |  | 100% | 2025-10-20 | 2025-10-20 | 0d | start no earlier than 2025-10-20 |  | Participants | Participants | S&A Qualification |  | 6.38 | Ben Gilbert | Complete | COMPLETE | T3-QU-0103 | QAG | T3 |
| 2698 | 1.8.4.4.2.5 | All Qualification Wave 3 Participants' to provide status of PIT completion and submit QT Test Plan | milestone | 0d | 2025-10-20 A | 2025-10-20 A | 2697 | 100% | 2025-10-20 | 2025-10-20 | 0d | start no earlier than 2025-10-20 |  | Participants |  |  |  | 6.38 | Ben Gilbert | Complete | COMPLETE |  |  |  |
| 2699 | 1.8.4.4.2.6 | Review of Participants' PIT Status and QT Test Plan |  | 15d | 2025-10-20 A | 2025-11-07 A | 2697 | 100% | 2025-10-20 | 2025-11-07 | 15d | start no earlier than 2025-09-08 |  | Code Bodies, Non-SIT S&A QT Test Team | Code Bodies, Non-SIT S&A QT Test Team | S&A Qualification |  | 6.13 | Laura Kennedy | Complete | COMPLETE |  |  |  |
| 2700 | 1.8.4.4.2.7 | Minimum threshold of Qualification Test Plans for Wave 3 Participants required for QT start approved | milestone | 0d | 2025-11-07 A | 2025-11-07 A | 2699 | 100% | 2025-11-07 | 2025-11-07 | 0d | start no earlier than 2025-09-26 |  | Non-SIT S&A QT Test Team | Non-SIT S&A QT Test Team | S&A Qualification |  | 6.38 | Ben Gilbert | Complete | COMPLETE | T3-QU-0024 | QAG | T3 |
| 2701 | 1.8.4.4.2.8 | All Qualification Test Plans for Wave 3 Participants approved | milestone | 0d | 2025-11-07 A | 2025-11-07 A | 2700 | 100% | 2025-11-07 | 2025-11-07 | 0d | start no earlier than 2025-11-07 |  | Non-SIT S&A QT Test Team |  |  |  | 6.38 | Laura Kennedy | Complete | COMPLETE |  |  |  |
| 2702 | 1.8.4.4.2.9 | Minimum threshold of Qualification Wave 3 Participants required for QT start have submitted PIT Test Completion Report and evidence for QT Entry | milestone | 0d | 2025-11-10 A | 2025-11-10 A |  | 100% | 2025-11-10 | 2025-11-10 | 0d | start no earlier than 2025-11-10 |  | Participants | Participants | S&A Qualification |  | 6.38 | Ben Gilbert | Complete | COMPLETE | T3-QU-0104 | QAG | T3 |
| 2703 | 1.8.4.4.2.10 | All Qualification Wave 3 Participants have submitted PIT Test Completion Report and evidence for QT Entry | milestone | 0d | 2025-11-10 A | 2025-11-10 A | 2702 | 100% | 2025-11-10 | 2025-11-10 | 0d | start no earlier than 2025-11-10 |  | Participants |  |  |  | 6.38 | Laura Kennedy | Complete | COMPLETE |  |  |  |
| 2704 | 1.8.4.4.2.11 | Review of Participants' PIT Test Completion Report |  | 25d | 2025-11-10 A | 2025-12-12 A | 2702 | 100% | 2025-11-10 | 2025-12-12 | 30d | start no earlier than 2025-09-29 |  | Code Bodies, Non-SIT S&A QT Test Team | Code Bodies, Non-SIT S&A QT Test Team | S&A Qualification |  | 6.13 | Laura Kennedy | Complete | COMPLETE |  |  |  |
| 2705 | 1.8.4.4.2.12 | Onboarding to QTF & ADO |  | 25d | 2025-11-10 A | 2025-12-12 A | 2704SS | 100% | 2025-11-10 | 2025-12-12 | 30d | finish no earlier than 2025-10-31 |  | Code Bodies, Non-SIT S&A QT Test Team |  | S&A Qualification |  | 6.13 | Laura Kennedy | Complete | COMPLETE |  |  |  |

Notes:
- 2681: 08/05/26: Milestone now complete, just pending final director sign-off. / 05/05/26: Waiting on 2/19 to finalise, the team are following up on final comments.
- 2682: 11/05/26: Final QAD approved in wave 2 including director sign-off, PAB 13/05/26. / 05/05/26: Waiting on 2/19 to finalise, the team are following up on final comments.
- 2683: 10/06/26: Milestone complete following qualification of all remaining Wave 2 participants at 10/06/26 PAB. / 01/06/26: Milestone subject to final PAB approvals on 10/06 on the basis that 14 of 18 (78%) Wave 2 Participant Roles have been approved by BSC PAB and REC Manager, with the final 4 participant roles pending approval at PAB on 10/06.
- 2684: 10/06/26: Milestone complete following qualification of all remaining Wave 2 participants at 10/06/26 PAB.
- 2691: 16/06/26: All PPs have now submitted their Initial QAD.
- 2692: 16/06/26: All Wave 3 Initial QADs have now been reviewed.
- 2704: 11/05/26: PIT evidence received from 15/15 wave 3 participants, activity complete.

| ID | WBS | Task | Type | Duration | Start | Finish | Predecessors | Complete | Remaining | Baseline start | Baseline finish | Baseline duration | Total slack | Constraint | Baseline cost | Responsible | Involved | Text9 | Task Status | Update Version | MHHS Resource Name | Sched Status | RAG | Milestone ID | Text29 | Tier |
| --- | --- | --- | --- | --- | --- | --- | --- | --- | --- | --- | --- | --- | --- | --- | --- | --- | --- | --- | --- | --- | --- | --- | --- | --- | --- | --- |
| 2706 | 1.8.4.4.3 | **Qualification Wave 3 QT Execution** |  | 105d | 2025-12-15 A | 2026-05-08 A |  | 100% |  | 2025-12-15 | 2026-05-15 | 100d |  |  | -0 | N/A | N/A | S&A Qualification | -154.67 | 6.13 | David Moss |  |  |  |  |  |
| 2707 | 1.8.4.4.3.1 | Review Entry Criteria Evidence for each Wave 3 Participant |  | 5d | 2025-12-15 A | 2025-12-19 A | 2696, 2692FF, 2705 | 100% |  | 2025-12-15 | 2025-12-19 | 5d |  | start no earlier than 2025-11-03 |  | Non-SIT S&A QT Test Team | Non-SIT S&A QT Test Team | S&A Qualification |  | 6.13 | David Moss | Complete | COMPLETE |  |  |  |
| 2708 | 1.8.4.4.3.2 | Minimum threshold of Qualification Wave 3 Participant required for QT start Test Readiness confirmed | milestone | 0d | 2025-12-19 A | 2025-12-19 A | 2696, 2707 | 100% |  | 2025-12-19 | 2025-12-19 | 0d |  |  |  | Non-SIT S&A QT Test Team | Non-SIT S&A QT Test Team | S&A Qualification |  | 6.38 | David Moss | Complete | COMPLETE | T3-QU-0038 | QAG | T3 |
| 2709 | 1.8.4.4.3.3 | All Qualification Wave 3 Participant Test Readiness confirmed | milestone | 0d | 2025-12-19 A | 2025-12-19 A | 2708 | 100% |  | 2025-12-19 | 2025-12-19 | 0d |  |  |  | Non-SIT S&A QT Test Team |  |  |  | 6.38 | David Moss | Complete | COMPLETE |  |  |  |
| 2710 | 1.8.4.4.3.4 | Qualification Wave 3 Execution Start | milestone | 0d | 2026-01-12 A | 2026-01-12 A | 2708FS+16d, 2705FS+1d, 2587 | 100% |  | 2026-01-12 | 2026-01-12 | 0d |  | start no earlier than 2025-11-03 |  | Participants | Participants | S&A Qualification |  | 6.13 | David Moss | Complete | COMPLETE | T3-QU-0039 | QAG | T3 |
| 2711 | 1.8.4.4.3.5 | Qualification Wave 3 QT Execution Window |  | 85d | 2026-01-12 A | 2026-05-08 A | 2707, 2710FS-1d | 100% |  | 2026-01-12 | 2026-05-15 | 95d |  |  |  | Participants | Participants | S&A Qualification |  | 6.45 | David Moss | Complete | COMPLETE |  |  |  |
| 2712 | 1.8.4.4.3.6 | Qualification Wave 3 Projected Execution End | milestone | 0d | 2026-05-08 A | 2026-05-08 A | 2711 | 100% |  | 2026-05-15 | 2026-05-15 | 0d |  |  |  | Participants | Participants | S&A Qualification |  | 6.45 | David Moss | Complete | COMPLETE | T3-QU-0056 | QAG | T3 |
| 2713 | 1.8.4.4.4 | **Qualification Wave 3 Exit** |  | 144d | 2026-01-12 A | 2026-07-30 A |  | 100% |  | 2026-01-12 | 2026-07-30 | 144d |  |  | -0 | N/A | N/A | S&A Qualification | -154.67 | 6.13 | Laura Kennedy |  |  |  |  |  |
| 2714 | 1.8.4.4.4.1 | Assurance on PP Test Completion Report |  | 10d | 2026-05-11 A | 2026-05-22 A | 2712 | 100% |  | 2026-05-11 | 2026-05-22 | 0d |  |  |  | Participants |  |  |  | 6.45 | Laura Kennedy | Complete | COMPLETE |  |  |  |
| 2715 | 1.8.4.4.4.2 | Final QAD Submission window opens | milestone | 0d | 2026-01-12 A | 2026-01-12 A | 2710 | 100% |  | 2026-01-12 | 2026-01-12 | 0d |  |  |  | Participants | Participants | S&A Qualification |  | 6.13 | Laura Kennedy | Complete | COMPLETE |  |  |  |
| 2716 | 1.8.4.4.4.3 | Qualification Wave 3 Participants submit their Final QAD |  | 95d | 2026-01-12 A | 2026-05-22 A | 2715FS-1d, 2714FF | 100% |  | 2026-01-12 | 2026-05-22 | 100d |  |  |  | Participants | Participants | S&A Qualification |  | 6.13 | Laura Kennedy | Complete | COMPLETE |  |  |  |
| 2717 | 1.8.4.4.4.4 | 80% of M14 Critical Qualification Wave 3 Participants have submitted their Final QAD | milestone | 0d | 2026-05-22 A | 2026-05-22 A | 2716, 2712 | 100% |  | 2026-05-22 | 2026-05-22 | 0d |  |  |  | Code Bodies | Participants | S&A Qualification |  | 6.38 | Laura Kennedy | Complete | COMPLETE | T3-QU-0105 | QAG | T3 |
| 2718 | 1.8.4.4.4.5 | All Qualification Wave 3 Participants have submitted their Final QAD | milestone | 0d | 2026-05-22 A | 2026-05-22 A | 2717 | 100% |  | 2026-05-22 | 2026-05-22 | 0d |  | finish no earlier than 2026-05-22 |  | Participants |  |  |  | 6.38 | Laura Kennedy | Complete | COMPLETE |  |  |  |
| 2719 | 1.8.4.4.4.6 | Completion of Code Bodies review of Final QAD |  | 20d | 2026-05-25 A | 2026-06-19 A | 2717 | 100% |  | 2026-05-25 | 2026-06-19 | 20d |  |  |  | Code Bodies | Code Bodies | S&A Qualification |  | 6.13 | Laura Kennedy | Complete | COMPLETE |  |  |  |
| 2720 | 1.8.4.4.4.7 | QAD Sign Off deadline |  | 1d | 2026-06-26 A | 2026-06-26 A | 2719FS+4d | 100% |  | 2026-06-26 | 2026-06-26 | 1d |  |  |  | Participants | Participants | S&A Qualification |  | 6.13 | Laura Kennedy | Complete | COMPLETE |  |  |  |
| 2721 | 1.8.4.4.4.8 | 80% of M14 Critical Wave 3 Participants Qualification approved by BSC PAB and REC Manager | milestone | 0d | 2026-07-30 A | 2026-07-30 A |  | 100% |  | 2026-07-30 | 2026-07-30 | 0d |  | start no earlier than 2026-07-30 |  | Code Bodies |  |  |  | 6.38 | Laura Kennedy | Complete | COMPLETE | T3-QU-0136 | QAG | T3 |
| 2722 | 1.8.4.4.4.9 | All M14 Critical Wave 3 Participants Qualification approved by BSC PAB and REC Manager | milestone | 0d | 2026-07-30 A | 2026-07-30 A | 2720FS+24d, 2690, 2698, 2703, 2709, 2718 | 100% |  | 2026-07-30 | 2026-07-30 | 0d |  |  |  | Code Bodies | Code Bodies | S&A Qualification |  | 6.38 | Laura Kennedy | Complete | COMPLETE | T2-QU-0250 | QAG | T2 |
| 2723 | 1.8.4.5 | **Qualification Wave 4** |  | 490d | 2025-01-23 A | 2026-12-09 |  | 99% | 0d | 2025-10-20 | 2027-01-28 | 249d | 271d |  | -0 | N/A | N/A | S&A Qualification | -133.67 | 6.13 | Laura Kennedy |  |  |  |  |  |
| 2724 | 1.8.4.5.1 | **Qualification Wave 4 QAD Prep** |  | 95d | 2025-10-20 A | 2026-02-27 A |  | 100% |  | 2025-10-20 | 2026-02-27 | 99d |  |  | -0 | N/A | N/A | S&A Qualification | -155.67 | 6.13 | Laura Kennedy |  |  |  |  |  |
| 2725 | 1.8.4.5.1.1 | Initial QAD Submission window opens | milestone | 0d | 2025-10-20 A | 2025-10-20 A | 2375FS+1d | 100% |  | 2025-10-20 | 2025-10-20 | 0d |  |  |  | Participants | Participants | S&A Qualification |  | 6.13 | Laura Kennedy | Complete | COMPLETE |  |  |  |
| 2726 | 1.8.4.5.1.2 | Qualification Wave 4 Participants Submit Initial QAD |  | 65d | 2025-10-20 A | 2026-01-16 A | 2725FS-1d | 100% |  | 2025-10-20 | 2026-01-16 | 70d |  |  |  | Participants | Participants | S&A Qualification |  | 6.13 | Laura Kennedy | Complete | COMPLETE |  |  |  |
| 2727 | 1.8.4.5.1.3 | Qualification Wave 4 Participants have submitted their Initial QAD | milestone | 0d | 2026-01-16 A | 2026-01-16 A | 2726 | 100% |  | 2026-01-16 | 2026-01-16 | 0d |  |  |  | Participants | Participants | S&A Qualification |  | 6.13 | Laura Kennedy | Complete | COMPLETE | T3-QU-0106 | QAG | T3 |
| 2728 | 1.8.4.5.1.4 | Code Bodies review of Wave 4 Participants' Initial QAD |  | 30d | 2026-01-19 A | 2026-02-27 A | 2727 | 100% |  | 2026-01-19 | 2026-02-27 | 29d |  |  |  | Code Bodies | Code Bodies | S&A Qualification |  | 6.13 | Laura Kennedy | Complete | COMPLETE |  |  |  |
| 2729 | 1.8.4.5.1.5 | Completion of Code Bodies review of Initial QAD | milestone | 0d | 2026-02-27 A | 2026-02-27 A | 2728 | 100% |  | 2026-02-27 | 2026-02-27 | 0d |  |  |  | Code Bodies | Code Bodies | S&A Qualification |  | 6.13 | Laura Kennedy | Complete | COMPLETE |  |  |  |

Notes:
- 2711: 19/05/26: Wave 3 QT Testing and Assurance activities complete.
- 2712: 19/05/26: Wave 3 QT Testing and Assurance activities complete.
- 2716: 07/07/26: 31/31 final QADs submitted.
- 2717: 30/06/26: On the basis that 30 of 31 (97%) Wave 3 Final QADs have now been submitted, QAG approved the completion of T3-QU-0105 on 17/06/26.
- 2718: 07/07/26: All (31/31) participants have submitted their Final QAD.
- 2719: 29/07/26: 27/27 Final QADs reviewed by the Code Bodies (100%). Two participants have moved from Wave 3 to Wave 4 reducing the total number of participants in Wave 3 from 29 to 27.
- 2720: 29/07/26: 27/27 Final QADs signed off by Directors (100%). Two participants have moved from Wave 3 to Wave 4 reducing the total number of participants in Wave 3 from 29 to 27.
- 2721: 19/08/26: On the basis that all 27/27 Wave 3 participants have been BSC PAB and REC Manager approved, Milestone T3-QU-0136 was formally approved at QAG on 19/08/26.
- 2722: 19/08/26: On the basis that all 27/27 Wave 3 participants have been BSC PAB and REC Manager approved, Milestone T2-QU-0250 was formally approved at QAG on 19/08/26.
- 2728: 16/06/26: Code Bodies have completed review of all Wave 4 Initial QADs.
- 2729: 24/07/26: 40/40 initial QADs received by the Code Bodies. / 21/07/26: 34/41 initial QADs reviewed by Code Bodies (83%). 7 still pending and being chased daily. 2 participants have withdrawn from Wave 4.

| ID | WBS | Task | Type | Duration | Start | Finish | Predecessors | Complete | Baseline start | Baseline finish | Baseline duration | Constraint | Baseline cost | Responsible | Involved | Text9 | Task Status | Update Version | MHHS Resource Name | Sched Status | RAG | Milestone ID | Text29 | Tier |
| --- | --- | --- | --- | --- | --- | --- | --- | --- | --- | --- | --- | --- | --- | --- | --- | --- | --- | --- | --- | --- | --- | --- | --- | --- |
| 2730 | 1.8.4.5.2 | **Qualification Wave 4 Test Prep** |  | 75d | 2025-11-03 A | 2026-02-13 A |  | 100% | 2025-11-03 | 2026-02-13 | 67d |  | -0 | N/A | N/A | S&A Qualification | -555.67 | 6.13 | Laura Kennedy |  |  |  |  |  |
| 2731 | 1.8.4.5.2.1 | Confirmation from Qualification 4 Participants that DIP Onboarding has commenced | milestone | 0d | 2025-11-03 A | 2025-11-03 A |  | 100% | 2025-11-03 | 2025-11-03 | 0d | start no earlier than 2025-11-03 |  | Participants | Participants | S&A Qualification |  | 6.13 | Laura Kennedy | Complete | COMPLETE | T3-QU-0031 | QAG | T3 |
| 2732 | 1.8.4.5.2.2 | Qualification Wave 4 Participants DIP Onboarding Window |  | 35d | 2025-11-03 A | 2025-12-19 A | 2731 | 100% | 2025-11-03 | 2025-12-19 | 42d |  |  | Participants | Participants | S&A Qualification |  | 6.13 | Laura Kennedy | Complete | COMPLETE |  |  |  |
| 2733 | 1.8.4.5.2.3 | Confirmation from Qualification Wave 4 Participants that DIP onboarding has completed | milestone | 0d | 2025-12-19 A | 2025-12-19 A | 2732 | 100% | 2025-12-19 | 2025-12-19 | 0d |  |  | Participants | Participants | S&A Qualification |  | 6.13 | Laura Kennedy | Complete | COMPLETE |  |  |  |
| 2734 | 1.8.4.5.2.4 | Qualification Wave 4 Participants' to provide status of PIT completion and submit QT Test Plan | milestone | 0d | 2025-12-08 A | 2025-12-08 A |  | 100% | 2025-12-08 | 2025-12-08 | 0d | start no earlier than 2025-12-08 |  | Participants | Participants | S&A Qualification |  | 6.13 | Laura Kennedy | Complete | COMPLETE | T3-QU-0107 | QAG | T3 |
| 2735 | 1.8.4.5.2.5 | Review of Participants' PIT Status and QT Test Plan |  | 25d | 2025-12-08 A | 2026-01-09 A | 2734 | 100% | 2025-12-08 | 2026-01-09 | 16d |  |  | Code Bodies, Non-SIT S&A QT Test Team | Code Bodies, Non-SIT S&A QT Test Team | S&A Qualification |  | 6.13 | Laura Kennedy | Complete | COMPLETE |  |  |  |
| 2736 | 1.8.4.5.2.6 | Qualification Test Plans for Qualification Wave 4 Participants approved | milestone | 0d | 2026-01-09 A | 2026-01-09 A | 2735 | 100% | 2026-01-09 | 2026-01-09 | 0d |  |  | Non-SIT S&A QT Test Team | Non-SIT S&A QT Test Team | S&A Qualification |  | 6.13 | Laura Kennedy | Complete | COMPLETE | T3-QU-0030 | QAG | T3 |
| 2737 | 1.8.4.5.2.7 | Qualification Wave 4 Participants have submitted PIT Test Completion Report and evidence for QT entry | milestone | 0d | 2026-01-09 A | 2026-01-09 A | 2736 | 100% | 2026-01-09 | 2026-01-09 | 0d |  |  | Participants | Participants | S&A Qualification |  | 6.13 | Laura Kennedy | Complete | COMPLETE | T3-QU-0108 | QAG | T3 |
| 2738 | 1.8.4.5.2.8 | Review of Participants' PIT Test Completion Report |  | 25d | 2026-01-12 A | 2026-02-13 A | 2737 | 100% | 2026-01-12 | 2026-02-13 | 30d |  |  | Code Bodies, Non-SIT S&A QT Test Team | Code Bodies, Non-SIT S&A QT Test Team | S&A Qualification |  | 6.13 | Laura Kennedy | Complete | COMPLETE |  |  |  |
| 2739 | 1.8.4.5.2.9 | Onboarding to QTF & ADO |  | 25d | 2026-01-12 A | 2026-02-13 A | 2738SS | 100% | 2026-01-12 | 2026-02-13 | 30d | start no earlier than 2025-11-24 |  | Code Bodies, Non-SIT S&A QT Test Team | Code Bodies, Non-SIT S&A QT Test Team | S&A Qualification |  | 6.13 | Laura Kennedy | Complete | COMPLETE |  |  |  |
| 2740 | 1.8.4.5.3 | **Qualification Wave 4 QT Execution** |  | 95d | 2026-03-02 A | 2026-07-10 A |  | 100% | 2026-03-02 | 2026-07-17 | 101d |  | -0 | N/A | N/A | S&A Qualification | -155.67 | 6.13 | David Moss |  |  |  |  |  |
| 2741 | 1.8.4.5.3.1 | Review Entry Criteria Evidence for each Wave 4 Participant |  | 5d | 2026-03-02 A | 2026-03-06 A | 2729FF+5d, 2733 | 100% | 2026-03-02 | 2026-03-06 | 5d |  |  | Non-SIT S&A QT Test Team | Non-SIT S&A QT Test Team | S&A Qualification |  | 6.13 | David Moss | Complete | COMPLETE |  |  |  |
| 2742 | 1.8.4.5.3.2 | Qualification Wave 4 Participant Test Readiness Confirmed | milestone | 0d | 2026-03-06 A | 2026-03-06 A | 2733, 2741 | 100% | 2026-03-06 | 2026-03-06 | 0d |  |  | Non-SIT S&A QT Test Team | Non-SIT S&A QT Test Team | S&A Qualification |  | 6.13 | David Moss | Complete | COMPLETE | T3-QU-0043 | QAG | T3 |
| 2743 | 1.8.4.5.3.3 | Qualification Wave 4 QT Execution Start | milestone | 0d | 2026-03-09 A | 2026-03-09 A | 2742FS+1d, 2739, 2592 | 100% | 2026-03-09 | 2026-03-09 | 0d | start no earlier than 2026-01-07 |  | Participants | Participants | S&A Qualification |  | 6.13 | David Moss | Complete | COMPLETE | T3-QU-0044 | QAG | T3 |
| 2744 | 1.8.4.5.3.4 | Qualification Wave 4 QT Execution Window |  | 90d | 2026-03-09 A | 2026-07-10 A | 2743FS-1d, 2741 | 100% | 2026-03-09 | 2026-07-10 | 96d |  |  | Participants | Participants | S&A Qualification |  | 6.45 | David Moss | Complete | COMPLETE |  |  |  |
| 2745 | 1.8.4.5.3.5 | Qualification Wave 4 Projected Execution End | milestone | 0d | 2026-07-10 A | 2026-07-10 A | 2744 | 100% | 2026-07-10 | 2026-07-10 | 0d |  |  | Participants | Participants | S&A Qualification |  | 6.49 | David Moss | Complete | COMPLETE | T3-QU-0057 | QAG | T3 |
| 2746 | 1.8.4.5.4 | **Qualification Wave 4 Exit** |  | 144d | 2026-03-09 A | 2026-09-24 A |  | 100% | 2026-03-09 | 2026-09-24 | 150d |  | -0 | N/A | N/A | S&A Qualification | -155.67 | 6.13 | Laura Kennedy |  |  |  |  |  |
| 2747 | 1.8.4.5.4.1 | Assurance on PP Test Completion Report |  | 10d | 2026-07-13 A | 2026-07-24 A | 2745 | 100% | 2026-07-13 | 2026-07-24 | 0d |  |  | Participants |  |  |  | 6.45 | Laura Kennedy | Complete | COMPLETE |  |  |  |
| 2748 | 1.8.4.5.4.2 | Final QAD Submission window opens | milestone | 0d | 2026-03-09 A | 2026-03-09 A | 2743 | 100% | 2026-03-09 | 2026-03-09 | 0d |  |  | Participants | Participants | S&A Qualification |  | 6.13 | Laura Kennedy | Complete | COMPLETE |  |  |  |
| 2749 | 1.8.4.5.4.3 | Qualification Wave 4 Participants submit their Final QAD |  | 100d | 2026-03-09 A | 2026-07-24 A | 2748FS-1d, 2747FF | 100% | 2026-03-09 | 2026-07-24 | 101d |  |  | Participants | Participants | S&A Qualification |  | 6.13 | Laura Kennedy | Complete | COMPLETE |  |  |  |
| 2750 | 1.8.4.5.4.4 | Qualification Wave 4 Participants have submitted their Final QAD | milestone | 0d | 2026-07-24 A | 2026-07-24 A | 2749, 2745 | 100% | 2026-07-24 | 2026-07-24 | 0d |  |  | Participants | Participants | S&A Qualification |  | 6.13 | Laura Kennedy | Complete | COMPLETE | T3-QU-0109 | QAG | T3 |
| 2751 | 1.8.4.5.4.5 | Completion of Code Bodies review of Final QAD |  | 20d | 2026-07-27 A | 2026-08-21 A | 2750 | 100% | 2026-07-27 | 2026-08-21 | 25d |  |  | Code Bodies | Code Bodies | S&A Qualification |  | 6.13 | Laura Kennedy | Complete | COMPLETE |  |  |  |
| 2752 | 1.8.4.5.4.6 | QAD Sign Off deadline |  | 1d | 2026-08-28 A | 2026-08-28 A | 2751FS+4d | 100% | 2026-08-28 | 2026-08-28 | 1d |  |  | Participants | Participants | S&A Qualification |  | 6.13 | Laura Kennedy | Complete | COMPLETE |  |  |  |
| 2753 | 1.8.4.5.4.7 | Qualification Wave 4 Participants Qualification approved by BSC PAB and REC Manager | milestone | 0d | 2026-09-24 A | 2026-09-24 A | 2752FS+19d | 100% | 2026-09-24 | 2026-09-24 | 0d |  |  | Code Bodies | Code Bodies | S&A Qualification |  | 6.13 | Laura Kennedy | Complete | COMPLETE | T2-QU-0300 | QAG | T3 |

Notes:
- 2744: 11/06/26: Wave 4 testing completed 4 weeks ahead of plan.
- 2745: 11/06/26: Wave 4 testing completed 4 weeks ahead of plan.
- 2749: 24/07/26: 40/40 Final QADs received by the Code Bodies.
- 2750: 24/07/26: Wave 4 Final QAD submission is now complete, with 40/40 Final QADs submitted to the Code Bodies. / 14/07/26: Wave 4 overall at risk due to volume of remaining QAD submissions - tracking amber. Escalation process is being used to identify and support participants who are behind schedule, no risk to M14 currently identified.
- 2751: 06/10/26: 42/42 (100%) Final QADs reviewed and approved by the Code Bodies.
- 2752: 06/10/26: 42/42 (100%) Final QAD Director sign-offs complete.
- 2753: 14/10/27: Final PP qualified following 14/10 PAB. / 06/10/26: One participant remains outstanding, with a recovery plan in place. PAB pre-review was successfully completed on 24/09, with formal approval targeted for PAB on 14/10.

| ID | WBS | Task | Type | Duration | Start | Finish | Predecessors | Complete | Remaining | Baseline start | Baseline finish | Baseline duration | Baseline 1 start | Baseline 1 finish | Total slack | Constraint | Responsible | Text9 | Task Status | Update Version | Involved | Sched Status | MHHS Resource Name | MHHS Programme Phase | RAG | Milestone ID | Text29 | Tier |
| --- | --- | --- | --- | --- | --- | --- | --- | --- | --- | --- | --- | --- | --- | --- | --- | --- | --- | --- | --- | --- | --- | --- | --- | --- | --- | --- | --- | --- |
| 2754 | 1.8.4.5.5 | **Qualification Tier 1 Milestone** |  | 0d | 2026-10-28 | 2026-10-28 |  |  |  | 2026-10-28 | 2027-01-28 | 0d |  |  | 301d |  | CPT | S&A Qualification | -686.67 | 6.13 |  |  |  |  |  |  |  |  |
| 2755 | 1.8.4.5.5.1 | All suppliers must be able to access MPANs under the new TOM (M14) | milestone | 0d | 2026-10-28 | 2026-10-28 | 2753FS+24d, 3725 |  |  | 2026-10-28 | 2026-10-28 | 0d | 2026-03-16 | 2026-03-16 | 301d | start no earlier than 2026-03-12 | CPT | S&A Qualification | 7.71 | 6.13 | CPT | Green | CPT | Migration | GREEN | T1-MI-5000 | PSG | T1 |
| 2756 | 1.8.4.5.6 | **PAB dates** |  | 490d | 2025-01-23 A | 2026-12-09 |  | 99% | 0d | 2025-01-23 | 2025-12-18 | 0d |  |  | 271d |  | S&A Qualification | S&A Qualification | -834.67 | 6.18 |  |  |  |  |  |  |  |  |
| 2757 | 1.8.4.5.6.1 | PAB288 | milestone | 0d | 2025-01-23 A | 2025-01-23 A |  | 100% |  | 2025-01-23 | 2025-01-23 | 0d |  |  |  | start no earlier than 2025-01-23 | S&A Qualification | S&A Qualification |  | 6.18 |  | Complete | BSC Qualification |  | COMPLETE |  | PAB |  |
| 2758 | 1.8.4.5.6.2 | PAB289 |  | 2d | 2025-02-26 A | 2025-02-27 A |  | 100% |  | 2025-02-26 | 2025-02-27 | 0d |  |  |  | start no earlier than 2025-02-26 | S&A Qualification | S&A Qualification |  | 6.18 |  | Complete | BSC Qualification |  | COMPLETE |  | PAB |  |
| 2759 | 1.8.4.5.6.3 | PAB290 | milestone | 0d | 2025-03-12 A | 2025-03-12 A |  | 100% |  | 2025-03-12 | 2025-03-12 | 0d |  |  |  | start no earlier than 2025-03-12 | S&A Qualification | S&A Qualification |  | 6.18 |  | Complete | BSC Qualification |  | COMPLETE |  | PAB |  |
| 2760 | 1.8.4.5.6.4 | PAB291 | milestone | 0d | 2025-03-27 A | 2025-03-27 A |  | 100% |  | 2025-03-27 | 2025-03-27 | 0d |  |  |  | start no earlier than 2025-03-27 | S&A Qualification | S&A Qualification |  | 6.18 |  | Complete | BSC Qualification |  | COMPLETE |  | PAB |  |
| 2761 | 1.8.4.5.6.5 | PAB292 | milestone | 0d | 2025-04-09 A | 2025-04-09 A |  | 100% |  | 2025-04-09 | 2025-04-09 | 0d |  |  |  | start no earlier than 2025-04-09 | S&A Qualification | S&A Qualification |  | 6.18 |  | Complete | BSC Qualification |  | COMPLETE |  | PAB |  |
| 2762 | 1.8.4.5.6.6 | PAB293 | milestone | 0d | 2025-04-24 A | 2025-04-24 A |  | 100% |  | 2025-04-24 | 2025-04-24 | 0d |  |  |  | start no earlier than 2025-04-24 | S&A Qualification | S&A Qualification |  | 6.18 |  | Complete | BSC Qualification |  | COMPLETE |  | PAB |  |
| 2763 | 1.8.4.5.6.7 | PAB294 | milestone | 0d | 2025-05-14 A | 2025-05-14 A |  | 100% |  | 2025-05-14 | 2025-05-14 | 0d |  |  |  | start no earlier than 2025-05-14 | S&A Qualification | S&A Qualification |  | 6.18 |  | Complete | BSC Qualification |  | COMPLETE |  | PAB |  |
| 2764 | 1.8.4.5.6.8 | PAB295 | milestone | 0d | 2025-05-29 A | 2025-05-29 A |  | 100% |  | 2025-05-29 | 2025-05-29 | 0d |  |  |  | start no earlier than 2025-05-29 | S&A Qualification | S&A Qualification |  | 6.18 |  | Complete | BSC Qualification |  | COMPLETE |  | PAB |  |
| 2765 | 1.8.4.5.6.9 | PAB296 | milestone | 0d | 2025-06-11 A | 2025-06-11 A |  | 100% |  | 2025-06-11 | 2025-06-11 | 0d |  |  |  | start no earlier than 2025-06-11 | S&A Qualification | S&A Qualification |  | 6.18 |  | Complete | BSC Qualification |  | COMPLETE |  | PAB |  |
| 2766 | 1.8.4.5.6.10 | PAB297 | milestone | 0d | 2025-06-26 A | 2025-06-26 A |  | 100% |  | 2025-06-26 | 2025-06-26 | 0d |  |  |  | start no earlier than 2025-06-26 | S&A Qualification | S&A Qualification |  | 6.18 |  | Complete | BSC Qualification |  | COMPLETE |  | PAB |  |
| 2767 | 1.8.4.5.6.11 | PAB298 | milestone | 0d | 2025-07-16 A | 2025-07-16 A |  | 100% |  | 2025-07-16 | 2025-07-16 | 0d |  |  |  | start no earlier than 2025-07-16 | S&A Qualification | S&A Qualification |  | 6.18 |  | Complete | BSC Qualification |  | COMPLETE |  | PAB |  |
| 2768 | 1.8.4.5.6.12 | PAB299 | milestone | 0d | 2025-07-31 A | 2025-07-31 A |  | 100% |  | 2025-07-31 | 2025-07-31 | 0d |  |  |  | start no earlier than 2025-07-31 | S&A Qualification | S&A Qualification |  | 6.18 |  | Complete | BSC Qualification |  | COMPLETE |  | PAB |  |
| 2769 | 1.8.4.5.6.13 | PAB300 | milestone | 0d | 2025-08-13 A | 2025-08-13 A |  | 100% |  | 2025-08-13 | 2025-08-13 | 0d |  |  |  | start no earlier than 2025-08-13 | S&A Qualification | S&A Qualification |  | 6.18 |  | Complete | BSC Qualification |  | COMPLETE |  | PAB |  |
| 2770 | 1.8.4.5.6.14 | PAB301 |  | 2d | 2025-08-27 A | 2025-08-28 A |  | 100% |  | 2025-08-28 | 2025-08-28 | 0d |  |  |  | start no earlier than 2025-08-27 | S&A Qualification | S&A Qualification |  | 6.32 |  | Complete | BSC Qualification |  | COMPLETE |  | PAB |  |
| 2771 | 1.8.4.5.6.15 | PAB302 | milestone | 0d | 2025-09-10 A | 2025-09-10 A |  | 100% |  | 2025-09-10 | 2025-09-10 | 0d |  |  |  | start no earlier than 2025-09-10 | S&A Qualification | S&A Qualification |  | 6.18 |  | Complete | BSC Qualification |  | COMPLETE |  | PAB |  |
| 2772 | 1.8.4.5.6.16 | PAB303 | milestone | 0d | 2025-09-25 A | 2025-09-25 A |  | 100% |  | 2025-09-25 | 2025-09-25 | 0d |  |  |  | start no earlier than 2025-09-25 | S&A Qualification | S&A Qualification |  | 6.18 |  | Complete | BSC Qualification |  | COMPLETE |  | PAB |  |
| 2773 | 1.8.4.5.6.17 | PAB304 | milestone | 0d | 2025-10-15 A | 2025-10-15 A |  | 100% |  | 2025-10-15 | 2025-10-15 | 0d |  |  |  | start no earlier than 2025-10-15 | S&A Qualification | S&A Qualification |  | 6.18 |  | Complete | BSC Qualification |  | COMPLETE |  | PAB |  |
| 2774 | 1.8.4.5.6.18 | PAB305 | milestone | 0d | 2025-10-30 A | 2025-10-30 A |  | 100% |  | 2025-10-30 | 2025-10-30 | 0d |  |  |  | start no earlier than 2025-10-30 | S&A Qualification | S&A Qualification |  | 6.18 |  | Complete | BSC Qualification |  | COMPLETE |  | PAB |  |
| 2775 | 1.8.4.5.6.19 | PAB306 | milestone | 0d | 2025-11-12 A | 2025-11-12 A |  | 100% |  | 2025-11-12 | 2025-11-12 | 0d |  |  |  | start no earlier than 2025-11-12 | S&A Qualification | S&A Qualification |  | 6.18 |  | Complete | BSC Qualification |  | COMPLETE |  | PAB |  |
| 2776 | 1.8.4.5.6.20 | PAB307 | milestone | 0d | 2025-11-27 A | 2025-11-27 A |  | 100% |  | 2025-11-27 | 2025-11-27 | 0d |  |  |  | start no earlier than 2025-11-27 | S&A Qualification | S&A Qualification |  | 6.18 |  | Complete | BSC Qualification |  | COMPLETE |  | PAB |  |
| 2777 | 1.8.4.5.6.21 | PAB308 | milestone | 0d | 2025-12-18 A | 2025-12-18 A |  | 100% |  | 2025-12-18 | 2025-12-18 | 0d |  |  |  | start no earlier than 2025-12-18 | S&A Qualification | S&A Qualification |  | 6.18 |  | Complete | BSC Qualification |  | COMPLETE |  | PAB |  |
| 2778 | 1.8.4.5.6.22 | PAB2026/01 | milestone | 0d | 2026-01-29 A | 2026-01-29 A |  | 100% |  | 2026-01-29 | 2026-01-29 | 0d |  |  |  | finish no earlier than 2026-01-29 | S&A Qualification |  |  | 6.39 |  | Complete | BSC Qualification |  | COMPLETE |  | PAB |  |
| 2779 | 1.8.4.5.6.23 | PAB2026/02 | milestone | 0d | 2026-02-11 A | 2026-02-11 A |  | 100% |  | 2026-02-11 | 2026-02-11 | 0d |  |  |  | finish no earlier than 2026-02-11 | S&A Qualification |  |  | 6.39 |  | Complete | BSC Qualification |  | COMPLETE |  | PAB |  |
| 2780 | 1.8.4.5.6.24 | PAB2026/03 | milestone | 0d | 2026-02-26 A | 2026-02-26 A |  | 100% |  | 2026-02-26 | 2026-02-26 | 0d |  |  |  | finish no earlier than 2026-02-26 | S&A Qualification |  |  | 6.39 |  | Complete | BSC Qualification |  | COMPLETE |  | PAB |  |
| 2781 | 1.8.4.5.6.25 | PAB2026/04 | milestone | 0d | 2026-03-11 A | 2026-03-11 A |  | 100% |  | 2026-03-11 | 2026-03-11 | 0d |  |  |  | finish no earlier than 2026-03-11 | S&A Qualification |  |  | 6.39 |  | Complete | BSC Qualification |  | COMPLETE |  | PAB |  |
| 2782 | 1.8.4.5.6.26 | PAB2026/05 | milestone | 0d | 2026-03-26 A | 2026-03-26 A |  | 100% |  | 2026-03-26 | 2026-03-26 | 0d |  |  |  | finish no earlier than 2026-03-26 | S&A Qualification |  |  | 6.39 |  | Complete | BSC Qualification |  | COMPLETE |  | PAB |  |
| 2783 | 1.8.4.5.6.27 | PAB2026/06 | milestone | 0d | 2026-04-15 A | 2026-04-15 A |  | 100% |  | 2026-04-15 | 2026-04-15 | 0d |  |  |  | finish no earlier than 2026-04-15 | S&A Qualification |  |  | 6.39 |  | Complete | BSC Qualification |  | COMPLETE |  | PAB |  |
| 2784 | 1.8.4.5.6.28 | PAB2026/07 | milestone | 0d | 2026-04-30 A | 2026-04-30 A |  | 100% |  | 2026-04-30 | 2026-04-30 | 0d |  |  |  | finish no earlier than 2026-04-30 | S&A Qualification |  |  | 6.39 |  | Complete | BSC Qualification |  | COMPLETE |  | PAB |  |
| 2785 | 1.8.4.5.6.29 | PAB2026/08 | milestone | 0d | 2026-05-13 A | 2026-05-13 A |  | 100% |  | 2026-05-13 | 2026-05-13 | 0d |  |  |  | finish no earlier than 2026-05-13 | S&A Qualification |  |  | 6.39 |  | Complete | BSC Qualification |  | COMPLETE |  | PAB |  |
| 2786 | 1.8.4.5.6.30 | PAB2026/09 | milestone | 0d | 2026-05-28 A | 2026-05-28 A |  | 100% |  | 2026-05-28 | 2026-05-28 | 0d |  |  |  | finish no earlier than 2026-05-28 | S&A Qualification |  |  | 6.39 |  | Complete | BSC Qualification |  | COMPLETE |  | PAB |  |
| 2787 | 1.8.4.5.6.31 | PAB2026/10 | milestone | 0d | 2026-06-10 A | 2026-06-10 A |  | 100% |  | 2026-06-10 | 2026-06-10 | 0d |  |  |  | finish no earlier than 2026-06-10 | S&A Qualification |  |  | 6.39 |  | Complete | BSC Qualification |  | COMPLETE |  | PAB |  |
| 2788 | 1.8.4.5.6.32 | PAB2026/11 | milestone | 0d | 2026-06-25 A | 2026-06-25 A |  | 100% |  | 2026-06-25 | 2026-06-25 | 0d |  |  |  | finish no earlier than 2026-06-25 | S&A Qualification |  |  | 6.39 |  | Complete | BSC Qualification |  | COMPLETE |  | PAB |  |
| 2789 | 1.8.4.5.6.33 | PAB2026/12 | milestone | 0d | 2026-07-15 A | 2026-07-15 A |  | 100% |  | 2026-07-15 | 2026-07-15 | 0d |  |  |  | finish no earlier than 2026-07-15 | S&A Qualification |  |  | 6.39 |  | Complete | BSC Qualification |  | COMPLETE |  | PAB |  |
| 2790 | 1.8.4.5.6.34 | PAB2026/13 | milestone | 0d | 2026-07-30 A | 2026-07-30 A |  | 100% |  | 2026-07-30 | 2026-07-30 | 0d |  |  |  | finish no earlier than 2026-07-30 | S&A Qualification |  |  | 6.39 |  | Complete | BSC Qualification |  | COMPLETE |  | PAB |  |
| 2791 | 1.8.4.5.6.35 | PAB2026/14 | milestone | 0d | 2026-08-12 A | 2026-08-12 A |  | 100% |  | 2026-08-12 | 2026-08-12 | 0d |  |  |  | finish no earlier than 2026-08-12 | S&A Qualification |  |  | 6.39 |  | Complete | BSC Qualification |  | COMPLETE |  | PAB |  |
| 2792 | 1.8.4.5.6.36 | PAB2026/15 | milestone | 0d | 2026-08-27 A | 2026-08-27 A |  | 100% |  | 2026-08-27 | 2026-08-27 | 0d |  |  |  | finish no earlier than 2026-08-27 | S&A Qualification |  |  | 6.39 |  | Complete | BSC Qualification |  | COMPLETE |  | PAB |  |
| 2793 | 1.8.4.5.6.37 | PAB2026/16 | milestone | 0d | 2026-09-09 A | 2026-09-09 A |  | 100% |  | 2026-09-09 | 2026-09-09 | 0d |  |  |  | finish no earlier than 2026-09-09 | S&A Qualification |  |  | 6.39 |  | Complete | BSC Qualification |  | COMPLETE |  | PAB |  |
| 2794 | 1.8.4.5.6.38 | PAB2026/17 | milestone | 0d | 2026-09-24 A | 2026-09-24 A |  | 100% |  | 2026-09-24 | 2026-09-24 | 0d |  |  |  | finish no earlier than 2026-09-24 | S&A Qualification |  |  | 6.39 |  | Complete | BSC Qualification |  | COMPLETE |  | PAB |  |
| 2795 | 1.8.4.5.6.39 | PAB2026/18 | milestone | 0d | 2026-10-14 A | 2026-10-14 A |  | 100% |  | 2026-10-14 | 2026-10-14 | 0d |  |  |  | finish no earlier than 2026-10-14 | S&A Qualification |  |  | 6.39 |  | Complete | BSC Qualification |  | COMPLETE |  | PAB |  |
| 2796 | 1.8.4.5.6.40 | PAB2026/19 | milestone | 0d | 2026-10-29 | 2026-10-29 |  |  |  | 2026-10-29 | 2026-10-29 | 0d |  |  | 300d | finish no earlier than 2026-10-29 | S&A Qualification |  | 8.71 | 6.39 |  | Green | BSC Qualification |  | GREEN |  | PAB |  |
| 2797 | 1.8.4.5.6.41 | PAB2026/20 | milestone | 0d | 2026-11-11 | 2026-11-11 |  |  |  | 2026-11-11 | 2026-11-11 | 0d |  |  | 291d | finish no earlier than 2026-11-11 | S&A Qualification |  | 21.71 | 6.39 |  | Green | BSC Qualification |  | GREEN |  | PAB |  |
| 2798 | 1.8.4.5.6.42 | PAB2026/21 | milestone | 0d | 2026-11-26 | 2026-11-26 |  |  |  | 2026-11-26 | 2026-11-26 | 0d |  |  | 280d | finish no earlier than 2026-11-26 | S&A Qualification |  | 36.71 | 6.39 |  | Green | BSC Qualification |  | GREEN |  | PAB |  |
| 2799 | 1.8.4.5.6.43 | PAB2026/22 | milestone | 0d | 2026-12-09 | 2026-12-09 |  |  |  | 2026-12-09 | 2026-12-09 | 0d |  |  | 271d | finish no earlier than 2026-12-09 | S&A Qualification |  | 49.71 | 6.39 |  | Green | BSC Qualification |  | GREEN |  | PAB |  |

Notes:
- 2755: Future RAG: All suppliers must be able to accept MPANs under the new TOM (one way gate)

| ID | WBS | Task | Type | Duration | Start | Finish | Predecessors | Complete | Baseline start | Baseline finish | Baseline duration | Baseline 1 start | Baseline 1 finish | Constraint | Baseline cost | Responsible | Involved | Text9 | Update Version | MHHS Resource Name | MHHS Programme Phase | Sched Status | RAG | Task Status | Artefact ID | Milestone ID | Text29 | Tier |
| --- | --- | --- | --- | --- | --- | --- | --- | --- | --- | --- | --- | --- | --- | --- | --- | --- | --- | --- | --- | --- | --- | --- | --- | --- | --- | --- | --- | --- |
| 2800 | 1.9 | **REGULATORY** |  | 823d | 2022-10-31 A | 2025-12-24 A |  | 100% | 2022-10-31 | 2025-12-24 | 680d | 2022-10-31 | 2025-03-07 |  | -0 | N/A | N/A | Regulatory | 6.18 | N/A | Regulatory |  |  |  |  |  |  |  |
| 2801 | 1.9.1 | **Baseline MHHS Code Changes** |  | 475d | 2022-10-31 A | 2024-08-23 A |  | 100% | 2022-10-31 | 2024-08-23 | 475d | 2022-10-31 | 2024-08-23 |  | -0 | N/A | N/A | Regulatory | 5.0 | N/A | Regulatory |  |  |  |  |  |  |  |
| 2802 | 1.9.1.1 | **Preparation and planning** |  | 35d | 2022-10-31 A | 2022-12-16 A |  | 100% | 2022-10-31 | 2022-12-16 | 35d | 2022-10-31 | 2022-12-16 |  |  | N/A | N/A | Regulatory | 5.0 | N/A | Regulatory |  |  |  |  |  |  |  |
| 2803 | 1.9.1.1.1 | Impact assessment of Programme design on codes to determine required changes |  | 20d | 2022-10-31 A | 2022-11-25 A | 47 | 100% | 2022-10-31 | 2022-11-25 | 20d | 2022-10-31 | 2022-11-25 |  |  | Code Bodies,SRO Code Drafters | Code Drafting PM | Regulatory | 5.0 | Andrew Margan | Regulatory | Complete | COMPLETE |  |  |  |  |  |
| 2804 | 1.9.1.1.2 | Become 'code draft ready' |  | 35d | 2022-10-31 A | 2022-12-16 A |  | 100% | 2022-10-31 | 2022-12-16 | 35d | 2022-10-31 | 2022-12-16 |  |  | Code Bodies,SRO Code Drafters | Code Drafting PM | Regulatory | 5.0 | Andrew Margan | Regulatory | Complete | COMPLETE |  |  |  |  |  |
| 2805 | 1.9.1.1.3 | Soft start drafting where possible |  | 35d | 2022-10-31 A | 2022-12-16 A |  | 100% | 2022-10-31 | 2022-12-16 | 35d | 2022-10-31 | 2022-12-16 |  |  | Code Bodies,SRO Code Drafters | Code Drafting PM | Regulatory | 5.0 | Andrew Margan | Regulatory | Complete | COMPLETE |  |  |  |  |  |
| 2806 | 1.9.1.2 | **Code drafting** |  | 443d | 2022-12-12 A | 2024-08-21 A |  | 100% | 2022-12-12 | 2024-08-21 | 445d | 2022-12-12 | 2024-08-23 |  | -0 | N/A | N/A | Regulatory | 5.0 | N/A | Regulatory |  |  | M6 |  |  |  |  |
| 2807 | 1.9.1.2.1 | **Data Services (BSC driven)** |  | 118d | 2022-12-12 A | 2023-05-24 A |  | 100% | 2022-12-12 | 2023-05-24 | 118d | 2022-12-12 | 2023-05-24 |  |  | N/A | N/A | Regulatory | 5.0 | N/A | Regulatory |  |  | M6 |  |  |  |  |
| 2808 | 1.9.1.2.1.1 | Pre Code Drafting activities |  | 5d | 2022-12-12 A | 2022-12-16 A |  | 100% | 2022-12-12 | 2022-12-16 | 5d | 2022-12-12 | 2022-12-16 | start no earlier than 2022-12-12 |  | Code Drafting PM |  | Regulatory | 5.0 | Andrew Margan | Regulatory | Complete | COMPLETE |  |  |  |  |  |
| 2809 | 1.9.1.2.1.2 | Code and subsidiary document drafting takes place offline |  | 19d | 2023-01-03 A | 2023-01-27 A | 2808FS+11d | 100% | 2023-01-03 | 2023-01-27 | 19d | 2023-01-03 | 2023-01-27 |  |  | Code Bodies,SRO Design | Code Drafting PM | Regulatory | 5.0 | Andrew Margan | Regulatory | Complete | COMPLETE |  |  |  |  |  |
| 2810 | 1.9.1.2.1.3 | Internal review and cross-checking of drafting across code drafters |  | 11d | 2023-01-30 A | 2023-02-13 A | 2809 | 100% | 2023-01-30 | 2023-02-13 | 11d | 2023-01-30 | 2023-02-13 |  |  | Code Bodies,SRO Design | Code Drafting PM | Regulatory | 5.0 | Andrew Margan | Regulatory | Complete | COMPLETE |  |  |  |  |  |
| 2811 | 1.9.1.2.1.4 | External industry review via consultation |  | 20d | 2023-02-14 A | 2023-03-13 A | 2810 | 100% | 2023-02-14 | 2023-03-13 | 20d | 2023-02-14 | 2023-03-13 |  |  | PP | Code Drafting PM | Regulatory | 5.0 | Andrew Margan | Regulatory | Complete | COMPLETE |  |  |  |  |  |
| 2812 | 1.9.1.2.1.5 | Triage and action comments |  | 19d | 2023-03-10 A | 2023-04-05 A | 2811FS-2d | 100% | 2023-03-10 | 2023-04-05 | 19d | 2023-03-10 | 2023-04-05 |  |  | Code Bodies,SRO Design | Code Drafting PM | Regulatory | 5.0 | Andrew Margan | Regulatory | Complete | COMPLETE |  |  |  |  |  |
| 2813 | 1.9.1.2.1.6 | CDWG review |  | 30d | 2023-04-06 A | 2023-05-17 A | 2812 | 100% | 2023-04-06 | 2023-05-17 | 30d | 2023-04-06 | 2023-05-17 |  |  | PP | Code Drafting PM | Regulatory | 5.0 | Andrew Margan | Regulatory | Complete | COMPLETE |  |  |  |  |  |
| 2814 | 1.9.1.2.1.7 | CCAG review |  | 5d | 2023-05-18 A | 2023-05-24 A | 2813 | 100% | 2023-05-18 | 2023-05-24 | 5d | 2023-05-18 | 2023-05-24 |  |  | PP |  | Regulatory | 5.0 | Andrew Margan | Regulatory | Complete | COMPLETE |  |  |  |  |  |
| 2815 | 1.9.1.2.1.8 | Code drafting for Data Services topic area approved | milestone | 0d | 2023-05-24 A | 2023-05-24 A | 2814 | 100% | 2023-05-24 | 2023-05-24 | 0d | 2023-05-24 | 2023-05-24 |  |  | PP | Code Drafting PM | Regulatory | 5.0 | Andrew Margan | Regulatory | Complete | COMPLETE |  | MHHS-ART060 | T2-RE-0100 | CCAG | T2 |
| 2816 | 1.9.1.2.2 | **Metering (REC driven)** |  | 118d | 2022-12-12 A | 2023-05-24 A |  | 100% | 2022-12-12 | 2023-05-24 | 118d | 2022-12-12 | 2023-05-24 |  |  | N/A | N/A | Regulatory | 5.0 | N/A | Regulatory |  |  | M6 |  |  |  |  |
| 2817 | 1.9.1.2.2.1 | Pre Code Drafting activities |  | 5d | 2022-12-12 A | 2022-12-16 A | 2808SS | 100% | 2022-12-12 | 2022-12-16 | 5d | 2022-12-12 | 2022-12-16 |  |  | Code Drafting PM |  | Regulatory | 5.0 | Andrew Margan | Regulatory | Complete | COMPLETE |  |  |  |  |  |
| 2818 | 1.9.1.2.2.2 | Code and subsidiary document drafting takes place offline |  | 19d | 2023-01-03 A | 2023-01-27 A | 2817FS+11d | 100% | 2023-01-03 | 2023-01-27 | 19d | 2023-01-03 | 2023-01-27 |  |  | Code Bodies,SRO Design | Code Drafting PM | Regulatory | 5.0 | Andrew Margan | Regulatory | Complete | COMPLETE |  |  |  |  |  |
| 2819 | 1.9.1.2.2.3 | Internal review and cross-checking of drafting across code drafters |  | 11d | 2023-01-30 A | 2023-02-13 A | 2818 | 100% | 2023-01-30 | 2023-02-13 | 11d | 2023-01-30 | 2023-02-13 |  |  | Code Bodies,SRO Design | Code Drafting PM | Regulatory | 5.0 | Andrew Margan | Regulatory | Complete | COMPLETE |  |  |  |  |  |
| 2820 | 1.9.1.2.2.4 | External industry review via consultation |  | 20d | 2023-02-14 A | 2023-03-13 A | 2819 | 100% | 2023-02-14 | 2023-03-13 | 20d | 2023-02-14 | 2023-03-13 |  |  | PP | Code Drafting PM | Regulatory | 5.0 | Andrew Margan | Regulatory | Complete | COMPLETE |  |  |  |  |  |
| 2821 | 1.9.1.2.2.5 | Triage and action comments |  | 19d | 2023-03-10 A | 2023-04-05 A | 2820FS-2d | 100% | 2023-03-10 | 2023-04-05 | 19d | 2023-03-10 | 2023-04-05 |  |  | Code Bodies,SRO Design | Code Drafting PM | Regulatory | 5.0 | Andrew Margan | Regulatory | Complete | COMPLETE |  |  |  |  |  |
| 2822 | 1.9.1.2.2.6 | CDWG review |  | 30d | 2023-04-06 A | 2023-05-17 A | 2821 | 100% | 2023-04-06 | 2023-05-17 | 30d | 2023-04-06 | 2023-05-17 |  |  | PP | Code Drafting PM | Regulatory | 5.0 | Andrew Margan | Regulatory | Complete | COMPLETE |  |  |  |  |  |
| 2823 | 1.9.1.2.2.7 | CCAG review |  | 5d | 2023-05-18 A | 2023-05-24 A | 2822 | 100% | 2023-05-18 | 2023-05-24 | 5d | 2023-05-18 | 2023-05-24 |  |  | PP |  | Regulatory | 5.0 | Andrew Margan | Regulatory | Complete | COMPLETE |  |  |  |  |  |
| 2824 | 1.9.1.2.2.8 | Code drafting for Metering topic area approved | milestone | 0d | 2023-05-24 A | 2023-05-24 A | 2823 | 100% | 2023-05-24 | 2023-05-24 | 0d | 2023-05-24 | 2023-05-24 |  |  | PP | Code Drafting PM | Regulatory | 5.0 | Andrew Margan | Regulatory | Complete | COMPLETE |  | MHHS-ART060 | T2-RE-0150 | CCAG | T2 |

| ID | WBS | Task | Type | Duration | Start | Finish | Predecessors | Complete | Baseline start | Baseline finish | Baseline duration | Baseline 1 start | Baseline 1 finish | Constraint | Responsible | Involved | Text9 | Task Status | Update Version | MHHS Resource Name | MHHS Programme Phase | Sched Status | RAG | Artefact ID | Milestone ID | Text29 | Tier |
| --- | --- | --- | --- | --- | --- | --- | --- | --- | --- | --- | --- | --- | --- | --- | --- | --- | --- | --- | --- | --- | --- | --- | --- | --- | --- | --- | --- |
| 2825 | 1.9.1.2.3 | **BSC Central Services (BSC driven)** |  | 156d | 2023-02-22 A | 2023-09-27 A |  | 100% | 2023-02-22 | 2023-09-27 | 156d | 2023-02-22 | 2023-09-14 |  | N/A | N/A | Regulatory | M6 | 5.0 | N/A | Regulatory |  |  |  |  |  |  |
| 2826 | 1.9.1.2.3.1 | Pre Code Drafting activities |  | 5d | 2023-02-22 A | 2023-02-28 A | 2827SS-5d | 100% | 2023-02-22 | 2023-02-28 | 5d | 2023-02-22 | 2023-02-28 |  | Code Drafting PM |  | Regulatory |  | 5.0 | Andrew Margan | Regulatory | Complete | COMPLETE |  |  |  |  |
| 2827 | 1.9.1.2.3.2 | Code Drafting (offline) |  | 80d | 2023-03-01 A | 2023-06-20 A | 2811SS | 100% | 2023-03-01 | 2023-06-20 | 80d | 2023-03-01 | 2023-06-20 | must start on 2023-03-01 | Code Bodies,SRO Design | Code Drafting PM | Regulatory |  | 5.0 | Andrew Margan | Regulatory | Complete | COMPLETE |  |  |  |  |
| 2828 | 1.9.1.2.3.3 | Internal review and cross-checking of drafting across code drafters |  | 70d | 2023-03-15 A | 2023-06-20 A | 2827SS+10d | 100% | 2023-03-15 | 2023-06-20 | 70d | 2023-03-15 | 2023-06-20 |  | Code Bodies,SRO Design | Code Drafting PM | Regulatory |  | 5.0 | Andrew Margan | Regulatory | Complete | COMPLETE |  |  |  |  |
| 2829 | 1.9.1.2.3.4 | External industry review via consultation |  | 15d | 2023-06-21 A | 2023-07-11 A | 2828 | 100% | 2023-06-21 | 2023-07-11 | 15d | 2023-06-21 | 2023-07-11 |  | PP | Code Drafting PM | Regulatory |  | 5.0 | Andrew Margan | Regulatory | Complete | COMPLETE |  |  |  |  |
| 2830 | 1.9.1.2.3.5 | Triage and action comments |  | 19d | 2023-07-10 A | 2023-08-03 A | 2829FS-2d | 100% | 2023-07-10 | 2023-08-03 | 19d | 2023-07-10 | 2023-08-03 |  | Code Bodies,SRO Design | Code Drafting PM | Regulatory |  | 5.0 | Andrew Margan | Regulatory | Complete | COMPLETE |  |  |  |  |
| 2831 | 1.9.1.2.3.6 | CDWG review |  | 28d | 2023-08-04 A | 2023-09-12 A | 2830 | 100% | 2023-08-04 | 2023-09-12 | 28d | 2023-08-04 | 2023-09-07 |  | PP | Code Drafting PM | Regulatory |  | 5.0 | Andrew Margan | Regulatory | Complete | COMPLETE |  |  |  |  |
| 2832 | 1.9.1.2.3.7 | CCAG review |  | 11d | 2023-09-13 A | 2023-09-27 A | 2831 | 100% | 2023-09-13 | 2023-09-27 | 11d | 2023-09-08 | 2023-09-14 |  | PP |  | Regulatory |  | 5.0 | Andrew Margan | Regulatory | Complete | COMPLETE |  |  |  |  |
| 2833 | 1.9.1.2.3.8 | Code drafting for BSC Central Services topic area approved | milestone | 0d | 2023-09-27 A | 2023-09-27 A | 2832 | 100% | 2023-09-27 | 2023-09-27 | 0d | 2023-09-14 | 2023-09-14 |  | PP | Code Drafting PM | Regulatory |  | 5.0 | Andrew Margan | Regulatory | Complete | COMPLETE | MHHS-ART060 | T2-RE-0200 | CCAG | T2 |
| 2834 | 1.9.1.2.4 | **Registration (BSC & REC driven)** |  | 131d | 2023-02-22 A | 2023-08-23 A |  | 100% | 2023-02-22 | 2023-08-23 | 131d | 2023-02-22 | 2023-08-23 |  | N/A | N/A | Regulatory | M6 | 5.0 | N/A | Regulatory |  |  |  |  |  |  |
| 2835 | 1.9.1.2.4.1 | Pre Code Drafting activities |  | 5d | 2023-02-22 A | 2023-02-28 A | 2836SS-5d | 100% | 2023-02-22 | 2023-02-28 | 5d | 2023-02-22 | 2023-02-28 |  | Code Drafting PM |  | Regulatory |  | 5.0 | Andrew Margan | Regulatory | Complete | COMPLETE |  |  |  |  |
| 2836 | 1.9.1.2.4.2 | Code Drafting (offline) |  | 65d | 2023-03-01 A | 2023-05-30 A | 2810, 2819 | 100% | 2023-03-01 | 2023-05-30 | 65d | 2023-03-01 | 2023-05-30 | must start on 2023-03-01 | Code Bodies,SRO Design | Code Drafting PM | Regulatory |  | 5.0 | Andrew Margan | Regulatory | Complete | COMPLETE |  |  |  |  |
| 2837 | 1.9.1.2.4.3 | Internal review and cross-checking of drafting across code drafters |  | 55d | 2023-03-15 A | 2023-05-30 A | 2836SS+10d | 100% | 2023-03-15 | 2023-05-30 | 55d | 2023-03-15 | 2023-05-30 |  | Code Bodies,SRO Design | Code Drafting PM | Regulatory |  | 5.0 | Andrew Margan | Regulatory | Complete | COMPLETE |  |  |  |  |
| 2838 | 1.9.1.2.4.4 | External industry review via consultation |  | 15d | 2023-05-31 A | 2023-06-20 A | 2837 | 100% | 2023-05-31 | 2023-06-20 | 15d | 2023-05-31 | 2023-06-20 |  | PP | Code Drafting PM | Regulatory |  | 5.0 | Andrew Margan | Regulatory | Complete | COMPLETE |  |  |  |  |
| 2839 | 1.9.1.2.4.5 | Triage and action comments |  | 19d | 2023-06-19 A | 2023-07-13 A | 2838FS-2d | 100% | 2023-06-19 | 2023-07-13 | 19d | 2023-06-19 | 2023-07-13 |  | Code Bodies,SRO Design | Code Drafting PM | Regulatory |  | 5.0 | Andrew Margan | Regulatory | Complete | COMPLETE |  |  |  |  |
| 2840 | 1.9.1.2.4.6 | CDWG review |  | 18d | 2023-07-14 A | 2023-08-08 A | 2839 | 100% | 2023-07-14 | 2023-08-08 | 18d | 2023-07-14 | 2023-08-16 |  | PP | Code Drafting PM | Regulatory |  | 5.0 | Andrew Margan | Regulatory | Complete | COMPLETE |  |  |  |  |
| 2841 | 1.9.1.2.4.7 | CCAG review |  | 11d | 2023-08-09 A | 2023-08-23 A | 2840 | 100% | 2023-08-09 | 2023-08-23 | 11d | 2023-08-17 | 2023-08-23 |  | PP |  | Regulatory |  | 5.0 | Andrew Margan | Regulatory | Complete | COMPLETE |  |  |  |  |
| 2842 | 1.9.1.2.4.8 | Code drafting for Registration topic area approved | milestone | 0d | 2023-08-23 A | 2023-08-23 A | 2841 | 100% | 2023-08-23 | 2023-08-23 | 0d | 2023-08-23 | 2023-08-23 |  | PP | Code Drafting PM | Regulatory |  | 5.0 | Andrew Margan | Regulatory | Complete | COMPLETE | MHHS-ART060 | T2-RE-0250 | CCAG | T2 |
| 2843 | 1.9.1.2.5 | **Governance and Qualification (BSC & REC driven)** |  | 130d | 2023-05-25 A | 2023-11-22 A |  | 100% | 2023-05-25 | 2023-11-22 | 130d | 2023-05-25 | 2023-11-13 |  | N/A | N/A | Regulatory | M6 | 5.0 | N/A | Regulatory |  |  |  |  |  |  |
| 2844 | 1.9.1.2.5.1 | Pre Code Drafting activities |  | 5d | 2023-05-25 A | 2023-05-31 A | 2845SS-5d | 100% | 2023-05-25 | 2023-05-31 | 5d | 2023-05-25 | 2023-05-31 |  | Code Drafting PM |  | Regulatory |  | 5.0 | Andrew Margan | Regulatory | Complete | COMPLETE |  |  |  |  |
| 2845 | 1.9.1.2.5.2 | Code Drafting (offline) |  | 55d | 2023-06-01 A | 2023-08-16 A | 2838SS+1d | 100% | 2023-06-01 | 2023-08-16 | 55d | 2023-06-01 | 2023-08-16 |  | Code Bodies,SRO Design | Code Drafting PM | Regulatory |  | 5.0 | Andrew Margan | Regulatory | Complete | COMPLETE |  |  |  |  |
| 2846 | 1.9.1.2.5.3 | Internal review and cross-checking of drafting across code drafters |  | 45d | 2023-06-15 A | 2023-08-16 A | 2845SS+10d | 100% | 2023-06-15 | 2023-08-16 | 45d | 2023-06-15 | 2023-08-16 |  | Code Bodies,SRO Design | Code Drafting PM | Regulatory |  | 5.0 | Andrew Margan | Regulatory | Complete | COMPLETE |  |  |  |  |
| 2847 | 1.9.1.2.5.4 | External industry review via consultation |  | 15d | 2023-08-18 A | 2023-09-07 A | 2846FS+1d | 100% | 2023-08-18 | 2023-09-07 | 15d | 2023-08-18 | 2023-09-07 |  | PP | Code Drafting PM | Regulatory |  | 5.0 | Andrew Margan | Regulatory | Complete | COMPLETE |  |  |  |  |
| 2848 | 1.9.1.2.5.5 | Triage and action comments |  | 19d | 2023-09-06 A | 2023-10-02 A | 2847FS-2d | 100% | 2023-09-06 | 2023-10-02 | 19d | 2023-09-06 | 2023-10-02 |  | Code Bodies,SRO Design | Code Drafting PM | Regulatory |  | 5.0 | Andrew Margan | Regulatory | Complete | COMPLETE |  |  |  |  |
| 2849 | 1.9.1.2.5.6 | CDWG review |  | 31d | 2023-10-03 A | 2023-11-14 A | 2848 | 100% | 2023-10-03 | 2023-11-14 | 31d | 2023-10-03 | 2023-11-06 |  | PP | Code Drafting PM | Regulatory |  | 5.0 | Andrew Margan | Regulatory | Complete | COMPLETE |  |  |  |  |
| 2850 | 1.9.1.2.5.7 | CCAG review |  | 6d | 2023-11-15 A | 2023-11-22 A | 2849 | 100% | 2023-11-15 | 2023-11-22 | 6d | 2023-11-07 | 2023-11-13 |  | PP |  | Regulatory |  | 5.0 | Andrew Margan | Regulatory | Complete | COMPLETE |  |  |  |  |
| 2851 | 1.9.1.2.5.8 | Code drafting for Governance and Qualification topic areas approved | milestone | 0d | 2023-11-22 A | 2023-11-22 A | 2850 | 100% | 2023-11-22 | 2023-11-22 | 0d | 2023-11-13 | 2023-11-13 |  | PP | Code Drafting PM | Regulatory |  | 5.12 | Andrew Margan | Regulatory | Complete | COMPLETE | MHHS-ART060 | T3-RE-0300 | CCAG | T2 |

| ID | WBS | Task | Type | Duration | Start | Finish | Predecessors | Complete | Baseline start | Baseline finish | Baseline duration | Baseline 1 start | Baseline 1 finish | Constraint | Baseline cost | Responsible | Involved | Text9 | Task Status | Update Version | MHHS Resource Name | MHHS Programme Phase | Sched Status | RAG | Artefact ID | Milestone ID | Text29 | Tier |
| --- | --- | --- | --- | --- | --- | --- | --- | --- | --- | --- | --- | --- | --- | --- | --- | --- | --- | --- | --- | --- | --- | --- | --- | --- | --- | --- | --- | --- |
| 2852 | 1.9.1.2.6 | **Interfaces / Data Specification (REC driven)** |  | 174d | 2023-05-25 A | 2024-01-23 A |  | 100% | 2023-05-25 | 2024-01-23 | 175d | 2023-05-25 | 2023-11-13 |  |  | N/A | N/A | Regulatory | M6 | 5.2 | N/A | Regulatory |  |  |  |  |  |  |
| 2853 | 1.9.1.2.6.1 | Pre Code Drafting activities |  | 5d | 2023-05-25 A | 2023-05-31 A | 2854SS-5d | 100% | 2023-05-25 | 2023-05-31 | 5d | 2023-05-25 | 2023-05-31 |  |  | Code Drafting PM |  | Regulatory |  | 5.0 | Andrew Margan | Regulatory | Complete | COMPLETE |  |  |  |  |
| 2854 | 1.9.1.2.6.2 | Code Drafting (offline) |  | 94d | 2023-06-01 A | 2023-10-10 A | 2838SS+1d | 100% | 2023-06-01 | 2023-10-10 | 94d | 2023-06-01 | 2023-08-16 |  |  | Code Bodies,SRO Design | Code Drafting PM | Regulatory |  | 5.2 | Andrew Margan | Regulatory | Complete | COMPLETE |  |  |  |  |
| 2855 | 1.9.1.2.6.3 | Internal review and cross-checking of drafting across code drafters |  | 84d | 2023-06-15 A | 2023-10-10 A | 2854SS+10d | 100% | 2023-06-15 | 2023-10-10 | 84d | 2023-06-15 | 2023-08-16 |  |  | Code Bodies,SRO Design | Code Drafting PM | Regulatory |  | 5.2 | Andrew Margan | Regulatory | Complete | COMPLETE |  |  |  |  |
| 2856 | 1.9.1.2.6.4 | External industry review via consultation |  | 15d | 2023-10-11 A | 2023-10-31 A | 2855 | 100% | 2023-10-11 | 2023-10-31 | 15d | 2023-08-18 | 2023-09-07 |  |  | PP | Code Drafting PM | Regulatory |  | 5.2 | Andrew Margan | Regulatory | Complete | COMPLETE |  |  |  |  |
| 2857 | 1.9.1.2.6.5 | Triage and action comments |  | 20d | 2023-10-30 A | 2023-11-24 A | 2856FS-2d | 100% | 2023-10-30 | 2023-11-24 | 20d | 2023-09-06 | 2023-10-02 |  |  | Code Bodies,SRO Design | Code Drafting PM | Regulatory |  | 5.2 | Andrew Margan | Regulatory | Complete | COMPLETE |  |  |  |  |
| 2858 | 1.9.1.2.6.6 | CDWG review |  | 37d | 2023-11-27 A | 2024-01-16 A | 2857 | 100% | 2023-11-27 | 2024-01-16 | 32d | 2023-10-03 | 2023-11-06 |  |  | PP | Code Drafting PM | Regulatory |  | 5.2 | Andrew Margan | Regulatory | Complete | COMPLETE |  |  |  |  |
| 2859 | 1.9.1.2.6.7 | CCAG review |  | 5d | 2024-01-17 A | 2024-01-23 A | 2858 | 100% | 2024-01-17 | 2024-01-23 | 11d | 2023-11-07 | 2023-11-13 |  |  | PP | Code Drafting PM | Regulatory |  | 5.2 | Andrew Margan | Regulatory | Complete | COMPLETE |  |  |  |  |
| 2860 | 1.9.1.2.6.8 | Code drafting for Interfaces / Data Specification topic areas approved | milestone | 0d | 2024-01-23 A | 2024-01-23 A | 2859 | 100% | 2024-01-23 | 2024-01-23 | 0d | 2023-11-13 | 2023-11-13 |  |  | PP | Code Drafting PM | Regulatory |  | 5.16 | Andrew Margan | Regulatory | Complete | COMPLETE | MHHS-ART060 | T3-RE-0350 | CCAG | T2 |
| 2861 | 1.9.1.2.7 | **Migration (BSC & REC driven)** |  | 130d | 2023-05-25 A | 2023-11-22 A |  | 100% | 2023-05-25 | 2023-11-22 | 130d | 2023-05-25 | 2023-11-13 |  |  | N/A | N/A | Regulatory | M6 | 5.0 | N/A | Regulatory |  |  |  |  |  |  |
| 2862 | 1.9.1.2.7.1 | Pre Code Drafting activities |  | 5d | 2023-05-25 A | 2023-05-31 A | 2863SS-5d | 100% | 2023-05-25 | 2023-05-31 | 5d | 2023-05-25 | 2023-05-31 |  |  | Code Drafting PM |  | Regulatory |  | 5.0 | Andrew Margan | Regulatory | Complete | COMPLETE |  |  |  |  |
| 2863 | 1.9.1.2.7.2 | Code Drafting (offline) |  | 55d | 2023-06-01 A | 2023-08-16 A | 2838SS+1d | 100% | 2023-06-01 | 2023-08-16 | 55d | 2023-06-01 | 2023-08-16 |  |  | Code Bodies,SRO Design | Code Drafting PM | Regulatory |  | 5.0 | Andrew Margan | Regulatory | Complete | COMPLETE |  |  |  |  |
| 2864 | 1.9.1.2.7.3 | Internal review and cross-checking of drafting across code drafters |  | 45d | 2023-06-15 A | 2023-08-16 A | 2863SS+10d | 100% | 2023-06-15 | 2023-08-16 | 45d | 2023-06-15 | 2023-08-16 |  |  | Code Bodies,SRO Design | Code Drafting PM | Regulatory |  | 5.0 | Andrew Margan | Regulatory | Complete | COMPLETE |  |  |  |  |
| 2865 | 1.9.1.2.7.4 | External industry review via consultation |  | 15d | 2023-08-18 A | 2023-09-07 A | 2864FS+1d | 100% | 2023-08-18 | 2023-09-07 | 15d | 2023-08-18 | 2023-09-07 |  |  | PP | Code Drafting PM | Regulatory |  | 5.0 | Andrew Margan | Regulatory | Complete | COMPLETE |  |  |  |  |
| 2866 | 1.9.1.2.7.5 | Triage and action comments |  | 19d | 2023-09-06 A | 2023-10-02 A | 2865FS-2d | 100% | 2023-09-06 | 2023-10-02 | 19d | 2023-09-06 | 2023-10-02 |  |  | Code Bodies,SRO Design | Code Drafting PM | Regulatory |  | 5.0 | Andrew Margan | Regulatory | Complete | COMPLETE |  |  |  |  |
| 2867 | 1.9.1.2.7.6 | CDWG review |  | 31d | 2023-10-03 A | 2023-11-14 A | 2866 | 100% | 2023-10-03 | 2023-11-14 | 31d | 2023-10-03 | 2023-11-06 |  |  | PP | Code Drafting PM | Regulatory |  | 5.0 | Andrew Margan | Regulatory | Complete | COMPLETE |  |  |  |  |
| 2868 | 1.9.1.2.7.7 | CCAG review |  | 6d | 2023-11-15 A | 2023-11-22 A | 2867 | 100% | 2023-11-15 | 2023-11-22 | 6d | 2023-11-07 | 2023-11-13 |  |  | PP | Code Drafting PM | Regulatory |  | 5.0 | Andrew Margan | Regulatory | Complete | COMPLETE |  |  |  |  |
| 2869 | 1.9.1.2.7.8 | Code drafting for Migration topic area approved | milestone | 0d | 2023-11-22 A | 2023-11-22 A | 2868 | 100% | 2023-11-22 | 2023-11-22 | 0d | 2023-11-13 | 2023-11-13 |  |  | PP | Code Drafting PM | Regulatory |  | 5.12 | Andrew Margan | Regulatory | Complete | COMPLETE | MHHS-ART060 | T3-RE-0400 | CCAG | T2 |
| 2870 | 1.9.1.2.8 | **Consequential Code Change** |  | 109d | 2023-10-11 A | 2024-03-11 A |  | 100% | 2023-10-11 | 2024-03-11 | 108d | 2023-08-18 | 2024-03-08 |  | -0 | N/A | N/A | Regulatory |  | 5.0 | N/A | Regulatory |  |  |  |  |  |  |
| 2871 | 1.9.1.2.8.1 | External industry review via consultation - drop 1 (DCUSA) |  | 15d | 2023-10-11 A | 2023-10-31 A | 2877SS | 100% | 2023-10-11 | 2023-10-31 | 15d | 2023-08-18 | 2023-09-07 |  |  | Code Bodies | PP | Regulatory |  | 5.2 | Andrew Margan | Regulatory | Complete | COMPLETE |  |  |  |  |
| 2872 | 1.9.1.2.8.2 | External industry review via consultation - drop 2 (Elexon) |  | 16d | 2024-02-19 A | 2024-03-11 A | 2887SS | 100% | 2024-02-19 | 2024-03-11 | 15d | 2023-10-16 | 2023-11-03 | start no earlier than 2024-02-19 |  | Code Bodies | PP | Regulatory |  | 5.2 | Andrew Margan | Regulatory | Complete | COMPLETE |  |  |  |  |
| 2873 | 1.9.1.2.9 | **Transition Text (all codes)** |  | 118d | 2023-08-11 A | 2024-01-23 A |  | 100% | 2023-08-11 | 2024-01-23 | 119d | 2023-08-11 | 2024-01-25 |  |  | N/A | N/A | Regulatory | M6 | 5.2 | N/A | Regulatory |  |  |  |  |  |  |
| 2874 | 1.9.1.2.9.1 | Pre Code Drafting activities |  | 8d | 2023-08-11 A | 2023-08-22 A | 2875SS-5d | 100% | 2023-08-11 | 2023-08-22 | 8d | 2023-08-11 | 2023-08-17 |  |  | Code Drafting PM |  | Regulatory |  | 5.0 | Andrew Margan | Regulatory | Complete | COMPLETE |  |  |  |  |
| 2875 | 1.9.1.2.9.2 | Code Drafting (offline) |  | 38d | 2023-08-18 A | 2023-10-10 A | 2865SS | 100% | 2023-08-18 | 2023-10-10 | 38d | 2023-08-18 | 2023-10-12 |  |  | Code Bodies,SRO Design | Code Drafting PM | Regulatory |  | 5.2 | Andrew Margan | Regulatory | Complete | COMPLETE |  |  |  |  |
| 2876 | 1.9.1.2.9.3 | Internal review and cross-checking of drafting across code drafters |  | 28d | 2023-09-01 A | 2023-10-10 A | 2875SS+10d | 100% | 2023-09-01 | 2023-10-10 | 28d | 2023-09-01 | 2023-10-12 |  |  | Code Bodies,SRO Design | Code Drafting PM | Regulatory |  | 5.2 | Andrew Margan | Regulatory | Complete | COMPLETE |  |  |  |  |
| 2877 | 1.9.1.2.9.4 | External industry review via consultation |  | 15d | 2023-10-11 A | 2023-10-31 A | 2876 | 100% | 2023-10-11 | 2023-10-31 | 15d | 2023-10-16 | 2023-11-03 |  |  | PP | Code Drafting PM | Regulatory |  | 5.2 | Andrew Margan | Regulatory | Complete | COMPLETE |  |  |  |  |
| 2878 | 1.9.1.2.9.5 | Triage and action comments |  | 20d | 2023-10-30 A | 2023-11-24 A | 2877FS-2d | 100% | 2023-10-30 | 2023-11-24 | 20d | 2023-11-02 | 2023-11-21 |  |  | Code Bodies,SRO Design | Code Drafting PM | Regulatory |  | 5.2 | Andrew Margan | Regulatory | Complete | COMPLETE |  |  |  |  |
| 2879 | 1.9.1.2.9.6 | CDWG review |  | 37d | 2023-11-27 A | 2024-01-16 A | 2878 | 100% | 2023-11-27 | 2024-01-16 | 37d | 2023-11-22 | 2024-01-17 |  |  | PP | Code Drafting PM | Regulatory |  | 5.2 | Andrew Margan | Regulatory | Complete | COMPLETE |  |  |  |  |
| 2880 | 1.9.1.2.9.7 | CCAG review |  | 5d | 2024-01-17 A | 2024-01-23 A | 2879 | 100% | 2024-01-17 | 2024-01-23 | 6d | 2024-01-18 | 2024-01-25 |  |  | PP | Code Drafting PM | Regulatory |  | 5.2 | Andrew Margan | Regulatory | Complete | COMPLETE |  |  |  |  |
| 2881 | 1.9.1.2.9.8 | Code drafting for Transition Text topic area approved | milestone | 0d | 2024-01-23 A | 2024-01-23 A | 2880 | 100% | 2024-01-23 | 2024-01-23 | 0d | 2024-01-25 | 2024-01-25 |  |  | PP | Code Drafting PM | Regulatory |  | 5.16 | Andrew Margan | Regulatory | Complete | COMPLETE | MHHS-ART060 | T3-RE-0450 | CCAG | T2 |

Notes:
- 2875: Guidance: 14/8/23 - RECCo transition drafting activity is expected to take the full 38 days, noting BSE co-drafting will be expected to take approx. 21 days

| ID | WBS | Task | Type | Duration | Start | Finish | Predecessors | Complete | Baseline start | Baseline finish | Baseline duration | Baseline 1 start | Baseline 1 finish | Baseline cost | Responsible | Involved | Text9 | Task Status | Update Version | MHHS Resource Name | MHHS Programme Phase | Sched Status | RAG | Artefact ID | Milestone ID | Text29 | Tier |
| --- | --- | --- | --- | --- | --- | --- | --- | --- | --- | --- | --- | --- | --- | --- | --- | --- | --- | --- | --- | --- | --- | --- | --- | --- | --- | --- | --- |
| 2882 | 1.9.1.2.10 | **Final Code Drafting (mop-up) (all codes)** |  | 199d | 2023-08-18 A | 2024-05-22 A |  | 100% | 2023-08-18 | 2024-05-22 | 199d | 2023-08-18 | 2024-05-13 |  | N/A | N/A | Regulatory | M6 | 5.0 | N/A | Regulatory |  |  |  |  |  |  |
| 2883 | 1.9.1.2.10.1 | Forward look and confirm remaining plan |  | 15d | 2023-08-18 A | 2023-09-07 A | 2875SS | 100% | 2023-08-18 | 2023-09-07 | 15d | 2023-08-18 | 2023-09-07 |  | Code Drafting PM |  | Regulatory |  | 5.0 | Andrew Margan | Regulatory | Complete | COMPLETE |  |  |  |  |
| 2884 | 1.9.1.2.10.2 | Identify remaining or additional areas of code (e.g. consequential change requirements) to be completed |  | 15d | 2023-08-18 A | 2023-09-07 A | 2883SS | 100% | 2023-08-18 | 2023-09-07 | 15d | 2023-08-18 | 2023-09-07 |  | Code Bodies,SRO Design | Code Drafting PM | Regulatory |  | 5.0 | Andrew Margan | Regulatory | Complete | COMPLETE |  |  |  |  |
| 2885 | 1.9.1.2.10.3 | Code Drafting (offline) Interim Consultation (1) |  | 60d | 2023-09-08 A | 2023-11-30 A | 2884 | 100% | 2023-09-08 | 2023-11-30 | 60d | 2023-09-08 | 2024-02-15 |  | Code Bodies,SRO Design | Code Drafting PM | Regulatory |  | 5.0 | Andrew Margan | Regulatory | Complete | COMPLETE |  |  |  |  |
| 2886 | 1.9.1.2.10.4 | Internal review and cross-checking of drafting across code drafters Interim Consultation (1) |  | 50d | 2023-09-22 A | 2023-11-30 A | 2885SS+10d | 100% | 2023-09-22 | 2023-11-30 | 50d | 2023-09-22 | 2024-02-15 |  | Code Bodies,SRO Design | Code Drafting PM | Regulatory |  | 5.0 | Andrew Margan | Regulatory | Complete | COMPLETE |  |  |  |  |
| 2887 | 1.9.1.2.10.5 | External industry review via consultation Interim Consultation (1) |  | 23d | 2023-12-01 A | 2024-01-02 A | 2886 | 100% | 2023-12-01 | 2024-01-02 | 23d | 2024-02-19 | 2024-03-08 |  | PP | Code Drafting PM | Regulatory |  | 5.0 | Andrew Margan | Regulatory | Complete | COMPLETE |  |  |  |  |
| 2888 | 1.9.1.2.10.6 | Code Drafting (offline) Final Consultation (2) |  | 55d | 2023-12-01 A | 2024-02-15 A | 2886 | 100% | 2023-12-01 | 2024-02-15 | 55d | 2023-09-08 | 2024-02-15 |  | Code Bodies,SRO Design | Code Drafting PM | Regulatory |  | 5.0 | Andrew Margan | Regulatory | Complete | COMPLETE |  |  |  |  |
| 2889 | 1.9.1.2.10.7 | Internal review and cross-checking of drafting across code drafters Final Consultation (2) |  | 45d | 2023-12-15 A | 2024-02-15 A | 2888SS+10d | 100% | 2023-12-15 | 2024-02-15 | 45d | 2023-09-22 | 2024-02-15 |  | Code Bodies,SRO Design | Code Drafting PM | Regulatory |  | 5.0 | Andrew Margan | Regulatory | Complete | COMPLETE |  |  |  |  |
| 2890 | 1.9.1.2.10.8 | External industry review via consultation Final Consultation (2) |  | 16d | 2024-02-19 A | 2024-03-11 A | 2889FS+1d | 100% | 2024-02-19 | 2024-03-11 | 15d | 2024-02-19 | 2024-03-08 |  | PP | Code Drafting PM | Regulatory |  | 5.0 | Andrew Margan | Regulatory | Complete | COMPLETE |  |  |  |  |
| 2891 | 1.9.1.2.10.9 | Triage and action comments |  | 18d | 2024-03-11 A | 2024-04-03 A | 2890FS-1d | 100% | 2024-03-11 | 2024-04-03 | 18d | 2024-03-07 | 2024-04-03 |  | Code Bodies,SRO Design | Code Drafting PM | Regulatory |  | 5.0 | Andrew Margan | Regulatory | Complete | COMPLETE |  |  |  |  |
| 2892 | 1.9.1.2.10.10 | CDWG review |  | 29d | 2024-04-04 A | 2024-05-14 A | 2891 | 100% | 2024-04-04 | 2024-05-14 | 31d | 2024-04-04 | 2024-05-03 |  | PP | Code Drafting PM | Regulatory |  | 5.0 | Andrew Margan | Regulatory | Complete | COMPLETE |  |  |  |  |
| 2893 | 1.9.1.2.10.11 | CCAG review |  | 6d | 2024-05-15 A | 2024-05-22 A | 2892 | 100% | 2024-05-15 | 2024-05-22 | 6d | 2024-05-06 | 2024-05-13 |  | PP | Code Drafting PM | Regulatory |  | 5.0 | Andrew Margan | Regulatory | Complete | COMPLETE |  |  |  |  |
| 2894 | 1.9.1.2.10.12 | Final code drafting (mop-up) approved | milestone | 0d | 2024-05-22 A | 2024-05-22 A | 2893 | 100% | 2024-05-22 | 2024-05-22 | 0d | 2024-05-13 | 2024-05-13 |  | PP | Code Drafting PM | Regulatory |  | 5.25 | Andrew Margan | Regulatory | Complete | COMPLETE | MHHS-ART060 | T3-RE-0500 | CCAG | T2 |
| 2895 | 1.9.1.2.11 | **Final code review, consistency check and approval** |  | 100d | 2024-04-04 A | 2024-08-21 A |  | 100% | 2024-04-04 | 2024-08-21 | 102d | 2024-05-06 | 2024-08-23 | -0 | N/A | N/A | Regulatory | M6 | 5.0 | N/A | Regulatory |  |  |  |  |  |  |
| 2896 | 1.9.1.2.11.1 | Gap analysis of final code against design artefacts (reverse process to code drafting) |  | 38d | 2024-04-04 A | 2024-05-27 A | 2892SS | 100% | 2024-04-04 | 2024-05-27 | 38d | 2024-05-06 | 2024-05-17 |  | Code Bodies,SRO Design | Code Drafting PM | Regulatory |  | 5.0 | Andrew Margan | Regulatory | Complete | COMPLETE |  |  |  |  |
| 2897 | 1.9.1.2.11.2 | Outputs of gap analysis actioned offline |  | 11d | 2024-05-28 A | 2024-06-11 A | 2896 | 100% | 2024-05-28 | 2024-06-11 | 11d | 2024-05-20 | 2024-06-07 |  | Code Bodies,SRO Design | Code Drafting PM | Regulatory |  | 5.0 | Andrew Margan | Regulatory | Complete | COMPLETE |  |  |  |  |
| 2898 | 1.9.1.2.11.3 | Final documentation collated for final consultation |  | 8d | 2024-06-12 A | 2024-06-21 A | 2897 | 100% | 2024-06-12 | 2024-06-21 | 9d | 2024-06-10 | 2024-06-13 |  | Code Drafting PM | Code Bodies,SRO Design | Regulatory |  | 5.23 | Andrew Margan | Regulatory | Complete | COMPLETE |  |  |  |  |
| 2899 | 1.9.1.2.11.4 | External industry review via consultation |  | 15d | 2024-06-24 A | 2024-07-12 A | 2898 | 100% | 2024-06-24 | 2024-07-12 | 20d | 2024-06-14 | 2024-07-04 |  | PP | Code Drafting PM | Regulatory |  | 5.0 | Andrew Margan | Regulatory | Complete | COMPLETE |  |  |  |  |
| 2900 | 1.9.1.2.11.5 | Triage and action comments |  | 10d | 2024-07-15 A | 2024-07-26 A | 2899 | 100% | 2024-07-15 | 2024-07-26 | 13d | 2024-07-03 | 2024-07-19 |  | Code Bodies,SRO Design | Code Drafting PM | Regulatory |  | 5.0 | Andrew Margan | Regulatory | Complete | COMPLETE |  |  |  |  |
| 2901 | 1.9.1.2.11.6 | Final CDWG review |  | 8d | 2024-08-02 A | 2024-08-13 A | 2900FS+4d | 100% | 2024-08-02 | 2024-08-13 | 6d | 2024-07-22 | 2024-08-16 |  | PP | Code Drafting PM | Regulatory |  | 5.0 | Andrew Margan | Regulatory | Complete | COMPLETE |  |  |  |  |
| 2902 | 1.9.1.2.11.7 | Final CCAG review |  | 6d | 2024-08-14 A | 2024-08-21 A | 2901 | 100% | 2024-08-14 | 2024-08-21 | 8d | 2024-08-19 | 2024-08-23 |  | PP | Code Drafting PM | Regulatory |  | 5.0 | Andrew Margan | Regulatory | Complete | COMPLETE |  |  |  |  |
| 2903 | 1.9.1.2.11.8 | CCAG recommend final code to PSG for baselining | milestone | 0d | 2024-08-21 A | 2024-08-21 A | 2902 | 100% | 2024-08-21 | 2024-08-21 | 0d | 2024-08-23 | 2024-08-23 |  | PP | Code Drafting PM | Regulatory |  | 5.9 | Andrew Margan | Regulatory | Complete | COMPLETE | MHHS-ART060 | T3-RE-0550 | CCAG | T2 |
| 2904 | 1.9.1.3 | Code changes baselined (M6) | milestone | 0d | 2024-08-23 A | 2024-08-23 A | 2902FS+2d, 2894, 2881, 2869, 2860, 2851, 2842, 2833, 2824, 2815 | 100% | 2024-08-23 | 2024-08-23 | 0d | 2024-08-23 | 2024-08-23 |  | CPT | PP | Regulatory |  | 5.0 | Andrew Margan | Regulatory | Complete | COMPLETE | MHHS-ART012 | T1-RE-1000 | PSG | T1 |
| 2905 | 1.9.2 | **Ofgem preparation and enactment of SCR powers** |  | 225d | 2024-02-05 A | 2024-12-13 A |  | 100% | 2024-02-05 | 2024-12-13 | 225d | 2024-01-26 | 2024-11-12 | -0 | N/A | N/A | Regulatory | M7 | 5.0 | N/A | Regulatory |  |  |  |  |  |  |
| 2906 | 1.9.2.1 | **Preparation and enactment of SCR Powers** |  | 223d | 2024-02-05 A | 2024-12-11 A |  | 100% | 2024-02-05 | 2024-12-11 | 223d | 2024-01-26 | 2024-11-11 | -0 | N/A | N/A | Regulatory |  | 5.0 | N/A | Regulatory |  |  |  |  |  |  |
| 2907 | 1.9.2.1.1 | Ofgem to keep Ofgem legal informed of process followed and nature of Code drafting to ensure that prepared for SCR go/no go decision |  | 101d | 2024-02-05 A | 2024-06-24 A | 2908SF | 100% | 2024-02-05 | 2024-06-24 | 101d | 2024-01-26 | 2024-06-14 |  | Ofgem | Code Bodies | Regulatory |  | 5.0 | Andrew Margan | Regulatory | Complete | COMPLETE |  |  |  |  |
| 2908 | 1.9.2.1.2 | OFGEM Legal to review Code Artefacts deliver policy intent and process followed and confirm that SCR powers are appropriate to use rather than SMAP - SCR go/no go |  | 14d | 2024-06-24 A | 2024-07-11 A | 2899SS | 100% | 2024-06-24 | 2024-07-11 | 15d | 2024-06-14 | 2024-07-04 |  | Ofgem | Code Bodies | Regulatory |  | 5.0 | Andrew Margan | Regulatory | Complete | COMPLETE |  |  |  |  |
| 2909 | 1.9.2.1.3 | Code Bodies to draft MOD proposal forms |  | 20d | 2024-07-12 A | 2024-08-08 A | 2908 | 100% | 2024-07-12 | 2024-08-08 | 20d | 2024-07-05 | 2024-08-01 |  | Code Bodies | Ofgem | Regulatory |  | 5.0 | Andrew Margan | Regulatory | Complete | COMPLETE |  |  |  |  |
| 2910 | 1.9.2.1.4 | Ofgem discuss and agree code mod timetable with code bodies (and MHHSP in relation to the dates for expected decisions) |  | 20d | 2024-07-12 A | 2024-08-08 A | 2908 | 100% | 2024-07-12 | 2024-08-08 | 20d | 2024-07-05 | 2024-08-01 |  | Ofgem | Code Bodies | Regulatory |  | 5.0 | Andrew Margan | Regulatory | Complete | COMPLETE |  |  |  |  |
| 2911 | 1.9.2.1.5 | Ofgem to publish each Direction to each code body specifying the timetable for each modification |  | 1d | 2024-08-28 A | 2024-08-28 A | 2910FS+13d | 100% | 2024-08-28 | 2024-08-28 | 1d | 2024-08-28 | 2024-08-28 |  | Ofgem | Code Bodies | Regulatory |  | 5.0 | Andrew Margan | Regulatory | Complete | COMPLETE |  |  |  |  |
| 2912 | 1.9.2.1.6 | Formally submit (by separate email) Modification Proposal Forms and legal texts to each code body |  | 1d | 2024-08-28 A | 2024-08-28 A | 2910FS+13d | 100% | 2024-08-28 | 2024-08-28 | 1d | 2024-08-28 | 2024-08-28 |  | Ofgem | Code Bodies | Regulatory |  | 5.0 | Andrew Margan | Regulatory | Complete | COMPLETE |  |  |  |  |
| 2913 | 1.9.2.1.7 | Each Code Body publishes and issues Modification Proposal Forms |  | 3d | 2024-08-29 A | 2024-09-02 A | 2912, 2911 | 100% | 2024-08-29 | 2024-09-02 | 3d | 2024-08-29 | 2024-09-02 |  | Code Bodies | Ofgem | Regulatory |  | 5.0 | Andrew Margan | Regulatory | Complete | COMPLETE |  |  |  |  |
| 2914 | 1.9.2.1.8 | Each Code Body sends Modification Proposal Forms to Panel to approve Mod to go to consultation |  | 10d | 2024-09-03 A | 2024-09-16 A | 2913 | 100% | 2024-09-03 | 2024-09-16 | 10d | 2024-09-03 | 2024-09-16 |  | Code Bodies | Ofgem | Regulatory |  | 5.0 | Andrew Margan | Regulatory | Complete | COMPLETE |  |  |  |  |
| 2915 | 1.9.2.1.9 | Modification Proposal approved by Panel for Consultation |  | 1d | 2024-09-17 A | 2024-09-17 A | 2914 | 100% | 2024-09-17 | 2024-09-17 | 1d | 2024-09-17 | 2024-09-17 |  | Code Bodies | Ofgem | Regulatory |  | 5.0 | Andrew Margan | Regulatory | Complete | COMPLETE |  |  |  |  |
| 2916 | 1.9.2.1.10 | Draft Modification Report issued for consultation |  | 1d | 2024-09-18 A | 2024-09-18 A | 2915 | 100% | 2024-09-18 | 2024-09-18 | 1d | 2024-09-18 | 2024-09-18 |  | Code Bodies | Ofgem | Regulatory |  | 5.0 | Andrew Margan | Regulatory | Complete | COMPLETE |  |  |  |  |
| 2917 | 1.9.2.1.11 | Consultation Close-out for representations |  | 15d | 2024-09-19 A | 2024-10-09 A | 2916 | 100% | 2024-09-19 | 2024-10-09 | 15d | 2024-09-19 | 2024-10-09 |  | Code Bodies | Ofgem | Regulatory |  | 5.0 | Andrew Margan | Regulatory | Complete | COMPLETE |  |  |  |  |
| 2918 | 1.9.2.1.12 | Each Code Body reviews consultation response and drafts Modification Report |  | 10d | 2024-10-10 A | 2024-10-23 A | 2917 | 100% | 2024-10-10 | 2024-10-23 | 10d | 2024-10-10 | 2024-10-23 |  | Code Bodies | Ofgem | Regulatory |  | 5.0 | Andrew Margan | Regulatory | Complete | COMPLETE |  |  |  |  |
| 2919 | 1.9.2.1.13 | Final Modification Report sent to Panel for decision with recommendation to approve |  | 1d | 2024-10-24 A | 2024-10-24 A | 2918 | 100% | 2024-10-24 | 2024-10-24 | 1d | 2024-10-24 | 2024-10-24 |  | Code Bodies | Ofgem | Regulatory |  | 6.11 | Andrew Margan | Regulatory | Complete | COMPLETE |  |  |  |  |
| 2920 | 1.9.2.1.14 | Modification Panel decision |  | 1d | 2024-11-07 A | 2024-11-07 A | 2919FS+9d | 100% | 2024-11-07 | 2024-11-07 | 1d | 2024-11-07 | 2024-11-07 |  | Code Bodies | Ofgem | Regulatory |  | 6.11 | Andrew Margan | Regulatory | Complete | COMPLETE |  |  |  |  |
| 2921 | 1.9.2.1.15 | Code Bodies Submit Final Modification/Change Reports |  | 1d | 2024-11-08 A | 2024-11-08 A | 2920 | 100% | 2024-11-08 | 2024-11-08 | 1d |  |  |  | Code Bodies | Ofgem | Regulatory |  | 6.11 | Andrew Margan |  | Complete | COMPLETE |  |  |  |  |
| 2922 | 1.9.2.1.16 | Ofgem Reviews Final Modification/Change Reports |  | 10d | 2024-11-11 A | 2024-11-22 A | 2921 | 100% | 2024-11-11 | 2024-11-22 | 10d |  |  |  | Ofgem | Code Bodies | Regulatory |  | 6.11 | Andrew Margan |  | Complete | COMPLETE |  |  |  |  |
| 2923 | 1.9.2.1.17 | Ofgem Drafts Decision/Direction Letters |  | 17d | 2024-11-18 A | 2024-12-10 A | 2922SS+5d | 100% | 2024-11-18 | 2024-12-10 | 17d |  |  |  | Ofgem | Code Bodies | Regulatory |  | 6.11 | Andrew Margan |  | Complete | COMPLETE |  |  |  |  |
| 2924 | 1.9.2.1.18 | Ofgem Internally Signs Off the Decision/Direction Letters and Sends Them to the Code Bodies |  | 1d | 2024-12-11 A | 2024-12-11 A | 2923 | 100% | 2024-12-11 | 2024-12-11 | 1d |  |  |  | Ofgem | Code Bodies | Regulatory |  | 6.11 | Andrew Margan |  | Complete | COMPLETE |  |  |  |  |
| 2925 | 1.9.2.2 | Ofgem decisions on M6 baselined code modification proposals (M7) | milestone | 0d | 2024-12-11 A | 2024-12-11 A | 2904, 2924 | 100% | 2024-12-11 | 2024-12-11 | 0d | 2024-11-11 | 2024-11-11 |  | CPT | PP | Regulatory |  | 6.11 | Andrew Margan | Regulatory | Complete | COMPLETE | MHHS-ART012 | T2-RE-0600 | CCAG | T2 |
| 2926 | 1.9.2.3 | Ofgem Publishes the Decisions/Directions |  | 2d | 2024-12-12 A | 2024-12-13 A | 2925 | 100% | 2024-12-12 | 2024-12-13 | 2d |  |  |  | Ofgem | Code Bodies | Regulatory |  | 6.11 | Andrew Margan |  | Complete | COMPLETE |  |  |  |  |

Notes:
- 2925: Guidance: 5/8/25 - CR no52 and going to PSG on 7/8/24. 21/8/24: Milestone name and date change approved at psg on 7/8/24

| ID | WBS | Task | Type | Duration | Start | Finish | Predecessors | Complete | Baseline start | Baseline finish | Baseline duration | Baseline 1 start | Baseline 1 finish | Constraint | Responsible | Involved | Text9 | Task Status | Update Version | MHHS Resource Name | MHHS Programme Phase | Sched Status | RAG | Milestone ID | Text29 | Artefact ID | Tier |
| --- | --- | --- | --- | --- | --- | --- | --- | --- | --- | --- | --- | --- | --- | --- | --- | --- | --- | --- | --- | --- | --- | --- | --- | --- | --- | --- | --- |
| 2927 | 1.9.3 | **Deliver MHHS Code Changes** |  | 292d | 2024-11-12 A | 2025-12-24 A |  | 100% | 2024-11-12 | 2025-12-24 | 149d | 2024-11-12 | 2025-03-07 |  | N/A | N/A | Regulatory | M8 | 6.11 | N/A | Regulatory |  |  |  |  |  |  |
| 2928 | 1.9.3.1 | **Releases** |  | 78d | 2024-11-12 A | 2025-02-27 A |  | 100% | 2024-11-12 | 2025-12-24 | 149d | 2024-11-12 | 2025-03-07 |  | N/A | N/A | Regulatory |  | 6.11 | N/A | Regulatory |  |  |  |  |  |  |
| 2929 | 1.9.3.1.1 | Impacted codes make resourcing provisions and prepare to implement new Code via internal code body change processes |  | 78d | 2024-11-12 A | 2025-02-27 A |  | 100% | 2024-11-12 | 2025-02-27 | 78d | 2024-11-12 | 2025-02-27 | start no earlier than 2024-11-12 | Code Bodies |  | Regulatory |  | 6.11 | Andrew Margan | Regulatory | Complete | COMPLETE |  |  |  |  |
| 2930 | 1.9.3.2 | **M8 Code Change Preperation** |  | 155d | 2025-01-31 A | 2025-09-05 A |  | 100% | 2025-01-31 | 2025-12-24 | 0d |  |  |  |  |  | Regulatory | -876.67 | 6.21 | Andrew Margan |  |  |  |  |  |  |  |
| 2931 | 1.9.3.2.1 | Resources confirmed | milestone | 0d | 2025-01-31 A | 2025-01-31 A |  | 100% | 2025-01-31 | 2025-01-31 | 0d |  |  | finish no earlier than 2025-01-31 | All |  | Regulatory |  | 6.21 | Andrew Margan |  | Complete | COMPLETE | T3-RE-0600 | CCAG |  |  |
| 2932 | 1.9.3.2.2 | CDWG Endorsement | milestone | 0d | 2025-06-10 A | 2025-06-10 A |  | 100% | 2025-06-10 | 2025-06-10 | 0d |  |  | finish no earlier than 2025-06-10 | All |  | Regulatory |  | 6.21 | Andrew Margan |  | Complete | COMPLETE | T3-RE-0650 | CCAG |  |  |
| 2933 | 1.9.3.2.3 | CCAG Endorsement | milestone | 0d | 2025-06-25 A | 2025-06-25 A |  | 100% | 2025-06-25 | 2025-06-25 | 0d |  |  | finish no earlier than 2025-06-25 | All |  | Regulatory |  | 6.21 | Andrew Margan |  | Complete | COMPLETE | T3-RE-0700 | CCAG |  |  |
| 2934 | 1.9.3.2.4 | Send to Ofgem for SCR Direction | milestone | 0d | 2025-06-25 A | 2025-06-25 A |  | 100% | 2025-06-25 | 2025-06-25 | 0d |  |  | finish no earlier than 2025-06-25 | All |  | Regulatory |  | 6.21 | Andrew Margan |  | Complete | COMPLETE | T3-RE-0750 | CCAG |  |  |
| 2935 | 1.9.3.2.5 | Freeze M8 Change Control Log 1.0 and create V2.0 | milestone | 0d | 2025-07-02 A | 2025-07-02 A |  | 100% | 2025-07-02 | 2025-07-02 | 0d |  |  | finish no earlier than 2025-07-02 | Code Bodies |  | Regulatory |  | 6.21 | Andrew Margan |  | Complete | COMPLETE | T3-RE-0800 | CCAG |  |  |
| 2936 | 1.9.3.2.6 | Agree Fast Track Code Change Process | milestone | 0d | 2025-07-02 A | 2025-07-02 A |  | 100% | 2025-07-02 | 2025-07-02 | 0d |  |  | finish no earlier than 2025-07-02 | MHHSP |  | Regulatory |  | 6.21 | Andrew Margan |  | Complete | COMPLETE | T3-RE-0850 | CCAG |  |  |
| 2937 | 1.9.3.2.7 | Ofgem direct SCR Code change | milestone | 0d | 2025-07-03 A | 2025-07-03 A |  | 100% | 2025-07-03 | 2025-07-03 | 0d |  |  | finish no earlier than 2025-07-03 | Code Bodies |  | Regulatory |  | 6.21 | Andrew Margan |  | Complete | COMPLETE | T3-RE-0900 | CCAG |  |  |
| 2938 | 1.9.3.2.8 | Present to Panel | milestone | 0d | 2025-07-10 A | 2025-07-10 A |  | 100% | 2025-07-10 | 2025-07-10 | 0d |  |  | finish no earlier than 2025-07-10 | Ofgem/Code Bodies |  | Regulatory |  | 6.21 | Andrew Margan |  | Complete | COMPLETE | T3-RE-0950 | CCAG |  |  |
| 2939 | 1.9.3.2.9 | Code Change Industry Consultation | milestone | 0d | 2025-07-29 A | 2025-07-29 A |  | 100% | 2025-07-29 | 2025-07-29 | 0d |  |  | finish no earlier than 2025-07-29 | All |  | Regulatory |  | 6.21 | Andrew Margan |  | Complete | COMPLETE | T3-RE-1000 | CCAG |  |  |
| 2940 | 1.9.3.2.10 | Panel Recommendation | milestone | 0d | 2025-08-14 A | 2025-08-14 A |  | 100% | 2025-08-14 | 2025-08-14 | 0d |  |  | finish no earlier than 2025-08-14 | Code Bodies |  | Regulatory |  | 6.21 | Andrew Margan |  | Complete | COMPLETE | T3-RE-1050 | CCAG |  |  |
| 2941 | 1.9.3.2.11 | Ofgem Decision | milestone | 0d | 2025-09-05 A | 2025-09-05 A |  | 100% | 2025-09-05 | 2025-09-05 | 0d |  |  | finish no earlier than 2025-09-05 | Ofgem |  | Regulatory |  | 6.21 | Andrew Margan |  | Complete | COMPLETE | T3-RE-1100 | CCAG |  |  |
| 2942 | 1.9.3.3 | **Main Code Release** |  | 73d | 2025-09-15 A | 2025-12-24 A |  | 100% | 2025-09-17 | 2025-12-24 | 71d | 2025-02-28 | 2025-03-07 |  | N/A | N/A | Regulatory |  | 6.11 | N/A | Regulatory |  |  |  |  |  |  |
| 2943 | 1.9.3.3.1 | Release preparation (e.g. preparing release documentation) |  | 6d | 2025-09-15 A | 2025-09-22 A | 2944SF | 100% | 2025-09-17 | 2025-09-24 | 5d | 2025-02-28 | 2025-03-07 |  | Code Bodies |  | Regulatory |  | 6.11 | Andrew Margan | Regulatory | Complete | COMPLETE |  |  |  |  |
| 2944 | 1.9.3.3.2 | Implement new code on day of code release | milestone | 0d | 2025-09-22 A | 2025-09-22 A | 2945SF | 100% | 2025-09-24 | 2025-09-24 | 1d | 2025-03-07 | 2025-03-07 |  | Code Bodies |  | Regulatory |  | 6.11 | Andrew Margan | Regulatory | Complete | COMPLETE |  |  |  |  |
| 2945 | 1.9.3.3.3 | Code changes delivered (M8) | milestone | 0d | 2025-09-22 A | 2025-09-22 A | 2925, 2904, 1802SS-3d, 2941 | 100% | 2025-09-22 | 2025-09-22 | 0d | 2025-03-07 | 2025-03-07 | finish no earlier than 2025-09-22 | CPT | Code Bodies,PP | Regulatory |  | 6.21 | Andrew Margan | Regulatory | Complete | COMPLETE | T2-RE-0650 | CCAG | MHHS-ART060 | T2 |
| 2946 | 1.9.3.3.4 | Code changes delivered (M8*) late exit | milestone | 0d | 2025-12-24 A | 2025-12-24 A | 2945FS+67d | 100% | 2025-12-24 | 2025-12-24 | 0d |  |  |  | CPT | Code Bodies,PP | Regulatory |  | 6.11 | Andrew Margan | Regulatory | Complete | COMPLETE | T2-RE-0700 | CCAG | MHHS-ART060 | T2 |
| 2947 | 1.9.4 | **External Programme Dependency Management** |  | 38d | 2023-12-01 A | 2024-01-24 A |  | 100% | 2023-12-01 | 2024-01-24 | 38d | 2023-09-08 | 2024-01-24 |  | N/A | N/A | Regulatory |  | 5.0 | N/A | Regulatory |  |  |  |  |  |  |
| 2948 | 1.9.4.1 | **DCP397** |  | 38d | 2023-12-01 A | 2024-01-24 A |  | 100% | 2023-12-01 | 2024-01-24 | 38d | 2023-09-08 | 2024-01-24 |  | N/A | N/A | Regulatory |  | 5.0 | N/A | Regulatory |  |  |  |  |  |  |
| 2949 | 1.9.4.1.1 | Ensure DCP397 drafting included in mop-up code drafting activity (link to mop-up) |  | 20d | 2023-12-01 A | 2023-12-28 A | 2888SS, 2885SS | 100% | 2023-12-01 | 2023-12-28 | 20d | 2023-09-08 | 2023-10-05 |  | CPT | Code Bodies,SRO Design, Code Drafting PM | Regulatory |  | 5.0 | Andrew Margan | Regulatory | Complete | COMPLETE |  |  |  |  |
| 2950 | 1.9.4.1.2 | Implementation of DCP397 | milestone | 0d | 2024-01-24 A | 2024-01-24 A |  | 100% | 2024-01-24 | 2024-01-24 | 0d | 2024-01-24 | 2024-01-24 | start no earlier than 2024-01-24 | Code Bodies |  | Regulatory |  | 5.0 | Andrew Margan | Regulatory | Complete | COMPLETE |  |  |  |  |

| ID | WBS | Task | Type | Duration | Start | Finish | Predecessors | Complete | Remaining | Baseline start | Baseline finish | Baseline duration | Baseline 1 start | Baseline 1 finish | Total slack | Constraint | Baseline cost | Responsible | Involved | Future RAG | Text9 | MHHS Resource Name | MHHS Programme Phase | Text29 | Update Version | Sched Status | RAG | Task Status | Guidance | Milestone ID | Tier |
| --- | --- | --- | --- | --- | --- | --- | --- | --- | --- | --- | --- | --- | --- | --- | --- | --- | --- | --- | --- | --- | --- | --- | --- | --- | --- | --- | --- | --- | --- | --- | --- |
| 2951 | 1.10 | **MIGRATION** |  | 1189d? | 2022-10-31 A | 2027-05-20 |  | 96% | 46.16d? | 2022-10-31 | 2027-08-09 | 1092d | 2022-10-31 | 2027-01-05 | 155d |  | -0 | N/A | N/A | 1 Oct 2024 - 31 Oct 2025 | Migration | N/A | Migration | MCAG (Migration) |  |  |  |  |  |  |  |
| 2952 | 1.10.1 | **Regulatory Governance** |  | 713d | 2024-04-01 A | 2026-12-23 |  | 99% | 3.92d | 2024-04-01 | 2025-01-01 | 173d |  |  | 261d |  | -0 | N/A | N/A |  | Migration | Warren Fulton |  | MCAG (Migration) | 5.28 |  |  |  |  |  |  |
| 2953 | 1.10.1.1 | Incentive Mods Created |  | 110d | 2024-04-01 A | 2024-08-30 A |  | 100% |  | 2024-04-01 | 2024-08-30 | 85d |  |  |  | start no earlier than 2024-04-01 |  | SRO Migration | SRO Migration,Code Bodies,PP |  | Migration | Warren Fulton |  | MCAG (Migration) | 5.28 | Complete | COMPLETE |  |  |  |  |
| 2954 | 1.10.1.2 | BSC Panel Ruling | milestone | 0d | 2025-06-12 A | 2025-06-12 A | 2953 | 100% |  | 2025-06-12 | 2025-06-12 | 88d |  |  |  | finish no earlier than 2025-06-12 |  | Code Bodies | Code Bodies,SRO Migration |  | Migration | Warren Fulton |  | MCAG (Migration) | 6.27 | Complete | COMPLETE |  |  |  |  |
| 2955 | 1.10.1.3 | Ofgem Incentives Approval |  | 230d | 2025-06-13 A | 2026-04-30 A | 2954 | 100% |  | 2025-06-13 | 2026-04-30 | 0d |  |  |  | finish no earlier than 2026-04-30 |  | SRO Migration |  |  | Migration | Warren Fulton |  | MCAG (Migration) | 6.45 | Complete | COMPLETE |  |  |  |  |
| 2956 | 1.10.1.4 | Incentives Implementation | milestone | 0d | 2026-06-25 A | 2026-06-25 A | 2955 | 100% |  | 2026-06-25 | 2026-06-25 | 0d |  |  |  | finish no earlier than 2026-06-25 |  | SRO Migration |  |  | Migration | Warren Fulton |  | MCAG (Migration) | 6.45 | Complete | COMPLETE |  |  |  |  |
| 2957 | 1.10.1.5 | **CR065** |  | 22d | 2026-06-01 A | 2026-07-01 A |  | 100% |  | 2026-06-01 | 2026-07-01 | 0d |  |  |  |  |  | SRO Migration |  |  |  | Warren Fulton |  | MCAG (Migration) | 6.59 | Complete | COMPLETE | -1421.67 |  |  |  |
| 2958 | 1.10.1.5.1 | CR065 Webinar |  | 1d | 2026-06-01 A | 2026-06-01 A |  | 100% |  | 2026-06-01 | 2026-06-01 | 0d |  |  |  | start no earlier than 2026-06-01 |  | SRO Migration |  |  |  | Warren Fulton |  | MCAG (Migration) | 6.51 | Complete | COMPLETE |  |  |  |  |
| 2959 | 1.10.1.5.2 | CR065 Impact Assessment Window |  | 10d | 2026-06-01 A | 2026-06-12 A |  | 100% |  | 2026-06-01 | 2026-06-12 | 0d |  |  |  | start no earlier than 2026-06-01 |  | SRO Migration |  |  |  | Warren Fulton |  | MCAG (Migration) | 6.51 | Complete | COMPLETE |  |  |  |  |
| 2960 | 1.10.1.5.3 | CR065 PSG Approval | milestone | 0d | 2026-07-01 A | 2026-07-01 A |  | 100% |  | 2026-07-01 | 2026-07-01 | 0d |  |  |  | start no earlier than 2026-07-01 |  | SRO Migration |  |  |  | Warren Fulton |  | PSG | 6.51 | Complete | COMPLETE |  |  |  |  |
| 2961 | 1.10.1.6 | **CR067** |  | 63d | 2026-09-28 A | 2026-12-23 |  | 85% | 9.69d | 2026-09-28 | 2026-12-23 | 0d |  |  |  |  |  |  |  |  |  | Warren Fulton |  | MCAG (Migration) | 6.59 | Overdue Start | GREEN | -1421.67 |  |  |  |
| 2962 | 1.10.1.6.1 | CR067 Webinar |  | 1d | 2026-09-28 A | 2026-09-28 A |  | 100% |  | 2026-09-28 | 2026-10-09 | 0d |  |  |  | start no earlier than 2026-09-28 |  |  |  |  |  | Warren Fulton |  | MCAG (Migration) | 6.59 | Complete | COMPLETE |  |  |  |  |
| 2963 | 1.10.1.6.2 | CR067 Impact Assessment Window |  | 10d | 2026-09-28 A | 2026-10-09 A |  | 100% |  | 2026-09-28 | 2026-10-09 | 0d |  |  |  | start no earlier than 2026-09-28 |  |  |  |  |  | Warren Fulton |  | MCAG (Migration) | 6.59 | Complete | COMPLETE |  |  |  |  |
| 2964 | 1.10.1.6.3 | CR067 PSG Approval |  | 1d | 2026-11-04 | 2026-11-04 |  |  |  | 2026-11-04 | 2026-11-04 | 0d |  |  | 296d | start no earlier than 2026-11-04 |  |  |  |  |  | Warren Fulton |  | PSG | 6.59 | Green | GREEN | 14.33 |  |  |  |
| 2965 | 1.10.1.6.4 | CR067 Ofgem Approval |  | 1d | 2026-12-23 | 2026-12-23 |  |  |  | 2026-12-23 | 2026-12-23 | 0d |  |  | 261d | start no earlier than 2026-12-23 |  |  |  |  |  | Warren Fulton |  | MCAG (Migration) | 6.59 | Green | GREEN | 63.33 |  |  |  |
| 2966 | 1.10.2 | **Migration Framework Agreed and Implemented** |  | 324d? | 2024-02-01 A | 2025-04-29 A |  | 100% |  | 2024-02-01 | 2025-01-23 | 214d |  |  |  |  | -0 | N/A | N/A |  | Migration | Warren Fulton |  | MCAG (Migration) | 5.28 |  |  |  |  |  |  |
| 2967 | 1.10.2.1 | **Consultation 1 - Schedule** |  | 70d | 2024-02-01 A | 2024-05-08 A |  | 100% |  | 2024-02-01 | 2024-05-08 | 70d |  |  |  |  |  | N/A | N/A |  | Migration | Warren Fulton |  | MCAG (Migration) | 5.28 |  |  |  |  |  |  |
| 2968 | 1.10.2.1.1 | Prepare Artefacts for Consultation |  | 33d | 2024-02-01 A | 2024-03-18 A |  | 100% |  | 2024-02-01 | 2024-03-18 | 33d |  |  |  |  |  | SI Migration |  |  | Migration | Warren Fulton |  | MCAG (Migration) | 5.28 | Complete | COMPLETE |  |  |  |  |
| 2969 | 1.10.2.1.2 | Industry Consultation |  | 16d | 2024-03-18 A | 2024-04-08 A |  | 100% |  | 2024-03-18 | 2024-04-08 | 16d |  |  |  |  |  | SI Migration |  |  | Migration | Warren Fulton |  | MCAG (Migration) | 5.28 | Complete | COMPLETE |  |  |  |  |
| 2970 | 1.10.2.1.3 | Triage and Action Comments |  | 10d | 2024-04-08 A | 2024-04-19 A |  | 100% |  | 2024-04-08 | 2024-04-19 | 10d |  |  |  |  |  | SI Migration |  |  | Migration | Warren Fulton |  | MCAG (Migration) | 5.28 | Complete | COMPLETE |  |  |  |  |
| 2971 | 1.10.2.1.4 | Industry Assurance Review |  | 6d | 2024-04-19 A | 2024-04-26 A |  | 100% |  | 2024-04-19 | 2024-04-26 | 6d |  |  |  |  |  | SI Migration |  |  | Migration | Warren Fulton |  | MCAG (Migration) | 5.28 | Complete | COMPLETE |  |  |  |  |
| 2972 | 1.10.2.1.5 | MWG Recommendation |  | 1d | 2024-04-26 A | 2024-04-26 A |  | 100% |  | 2024-04-26 | 2024-04-26 | 1d |  |  |  |  |  | SI Migration |  |  | Migration | Warren Fulton |  | MCAG (Migration) | 5.28 | Complete | COMPLETE |  |  |  |  |
| 2973 | 1.10.2.1.6 | MCAG Interim Approval Artefacts |  | 1d | 2024-05-08 A | 2024-05-08 A |  | 100% |  | 2024-05-08 | 2024-05-08 | 1d |  |  |  |  |  | SI Migration |  |  | Migration | Warren Fulton |  | MCAG (Migration) | 5.28 | Complete | COMPLETE |  |  |  |  |
| 2974 | 1.10.2.2 | **Consultation 2 - Control** |  | 79d | 2024-04-08 A | 2024-07-25 A |  | 100% |  | 2024-04-08 | 2024-07-25 | 79d |  |  |  |  | -0 | N/A | N/A |  | Migration | Warren Fulton |  | MCAG (Migration) | 5.28 |  |  |  |  |  |  |
| 2975 | 1.10.2.2.1 | Prepare Artefacts for Consultation |  | 49d | 2024-04-08 A | 2024-06-13 A |  | 100% |  | 2024-04-08 | 2024-06-13 | 49d |  |  |  |  |  | SRO Migration |  |  | Migration | Warren Fulton |  | MCAG (Migration) | 5.28 | Complete | COMPLETE |  |  |  |  |
| 2976 | 1.10.2.2.2 | Industry Consultation |  | 11d | 2024-06-14 A | 2024-06-28 A | 2975 | 100% |  | 2024-06-14 | 2024-06-28 | 11d |  |  |  |  |  | PP |  |  | Migration | Warren Fulton |  | MCAG (Migration) | 5.28 | Complete | COMPLETE |  |  |  |  |
| 2977 | 1.10.2.2.3 | Triage and Action Comments |  | 9d | 2024-07-01 A | 2024-07-11 A | 2976 | 100% |  | 2024-07-01 | 2024-07-11 | 9d |  |  |  |  |  | SRO Migration | SRO Migration |  | Migration | Warren Fulton |  | MCAG (Migration) | 5.28 | Complete | COMPLETE |  |  |  |  |
| 2978 | 1.10.2.2.4 | Industry Assurance Review |  | 5d | 2024-07-12 A | 2024-07-18 A | 2977 | 100% |  | 2024-07-12 | 2024-07-18 | 5d |  |  |  |  |  | PP | PP,SRO Migration |  | Migration | Warren Fulton |  | MCAG (Migration) | 5.28 | Complete | COMPLETE |  |  |  |  |
| 2979 | 1.10.2.2.5 | MWG Recommendation | milestone | 0d | 2024-07-18 A | 2024-07-18 A | 2978 | 100% |  | 2024-07-18 | 2024-07-18 | 0d |  |  |  |  |  | PP | PP,SRO Migration |  | Migration | Warren Fulton |  | MCAG (Migration) | 5.28 | Complete | COMPLETE |  |  |  |  |
| 2980 | 1.10.2.2.6 | Consultation 2 - Control - MCAG Approval of Interim Artefacts | milestone | 0d | 2024-07-25 A | 2024-07-25 A | 2979FS+5d | 100% |  | 2024-07-25 | 2024-07-25 | 0d |  |  |  |  |  | PP | PP,SRO Migration |  | Migration | Warren Fulton |  | MCAG (Migration) | 5.30 | Complete | COMPLETE |  | 25/7/24: New Milestone approved at MCAG on 25/7/24 | T3-MI-0037 | T3 |

Notes:
- 2955: 02/06/26: Party responsible changed from Code Bodies to SRO Migration. / 11/05/26: Ofgem approved P487 with the implementation date of 25/06/26. / 05/05/26 - Awaiting formal OFGEM decision. Troublesome MPANs report provided to OFGEM to support with decision making on the MOD.
- 2956: 23/06/26: BSC have published the June 26 release, notification of final scope. All on track for 26/06. / 02/06/26: Party responsible changed from Code Bodies to SRO Migration. / 19/05/26: Following Ofgem approval the Programme is working on the implementation approach. This line item will be developed shortly. / 11/05/26: Task date rebaslined to align with the new Ofgem approved implementation date of 25/06/26. / 05/05/26 - Awaiting formal OFGEM decision. Troublesome MPANs report provided to OFGEM to support with decision making on the MOD.

| ID | WBS | Task | Type | Duration | Start | Finish | Predecessors | Complete | Baseline start | Baseline finish | Baseline duration | Constraint | Baseline cost | Responsible | Involved | Text9 | Update Version | MHHS Resource Name | Text29 | Sched Status | RAG | Milestone ID | Tier | Task Status |
| --- | --- | --- | --- | --- | --- | --- | --- | --- | --- | --- | --- | --- | --- | --- | --- | --- | --- | --- | --- | --- | --- | --- | --- | --- |
| 2981 | 1.10.2.3 | **Consultation 3 - Parameters** |  | 71d | 2024-11-18 A | 2025-02-25 A |  | 100% | 2024-11-18 | 2025-02-25 | 76d |  | -0 | N/A | N/A | Migration | 6.14 | Warren Fulton | MCAG (Migration) |  |  |  |  |  |
| 2982 | 1.10.2.3.1 | Prepare Artefacts for Consultation |  | 24d | 2024-11-18 A | 2024-12-19 A |  | 100% | 2024-11-18 | 2024-12-19 | 36d |  |  | SRO Migration | SRO Migration | Migration | 6.14 | Warren Fulton | MCAG (Migration) | Complete | COMPLETE |  |  |  |
| 2983 | 1.10.2.3.2 | Industry Consultation |  | 21d | 2024-12-20 A | 2025-01-17 A | 2982 | 100% | 2024-12-20 | 2025-01-17 | 10d |  |  | PP | PP,SRO Migration | Migration | 6.14 | Warren Fulton | MCAG (Migration) | Complete | COMPLETE |  |  |  |
| 2984 | 1.10.2.3.3 | Triage Response |  | 10d | 2025-01-20 A | 2025-01-31 A | 2983 | 100% | 2025-01-20 | 2025-01-31 | 10d |  |  | SRO Migration | SRO Migration | Migration | 6.14 | Warren Fulton | MCAG (Migration) | Complete | COMPLETE |  |  |  |
| 2985 | 1.10.2.3.4 | MWG paper day | milestone | 0d | 2025-02-06 A | 2025-02-06 A | 2984 | 100% | 2025-02-06 | 2025-02-06 | 0d | start no earlier than 2025-02-06 |  | SRO Migration |  | Migration | 6.18 |  | MCAG (Migration) | Complete | COMPLETE |  |  |  |
| 2986 | 1.10.2.3.5 | MWG Recommendation | milestone | 0d | 2025-02-13 A | 2025-02-13 A | 2985FS+6d | 100% | 2025-02-21 | 2025-02-21 | 0d |  |  | PP | PP,SRO Migration | Migration | 6.14 | Warren Fulton | MCAG (Migration) | Complete | COMPLETE |  |  |  |
| 2987 | 1.10.2.3.6 | MCAG Paper Day | milestone | 0d | 2025-02-18 A | 2025-02-18 A | 2986FS+3d | 100% | 2025-02-25 | 2025-02-25 | 0d |  |  | SRO Migration |  | Migration | 6.14 | Warren Fulton | MCAG (Migration) | Complete | COMPLETE |  |  |  |
| 2988 | 1.10.2.3.7 | MCAG Approval of Consultation 3 | milestone | 0d | 2025-02-25 A | 2025-02-25 A | 2986, 2987 | 100% | 2025-02-25 | 2025-02-25 | 0d | start no earlier than 2025-02-25 |  | PP | PP,SRO Migration | Migration | 6.17 | Warren Fulton | MCAG (Migration) | Complete | COMPLETE | T3-MI-0017 | T3 |  |
| 2989 | 1.10.2.4 | **Consultation 4** |  | 72d? | 2025-01-20 A | 2025-04-29 A |  | 100% | 2025-01-07 | 2025-05-07 | 0d |  |  | SI Migration |  | Migration | 6.17 | Warren Fulton | MCAG (Migration) |  |  |  |  | -770.67 |
| 2990 | 1.10.2.4.1 | Agree Consultation 4 Plan |  | 15d | 2025-01-20 A | 2025-02-07 A |  | 100% | 2025-01-20 | 2025-02-07 | 0d |  |  | SI Migration |  | Migration | 6.17 | Warren Fulton | MCAG (Migration) | Complete | COMPLETE |  |  |  |
| 2991 | 1.10.2.4.2 | Book MWG | milestone | 0d | 2025-02-07 A | 2025-02-07 A | 2990 | 100% | 2025-02-07 | 2025-02-07 | 0d |  |  | SI Migration |  | Migration | 6.18 | Warren Fulton | MCAG (Migration) | Complete | COMPLETE |  |  |  |
| 2992 | 1.10.2.4.3 | Prepare Consultation 4 content |  | 9d | 2025-02-10 A | 2025-02-20 A | 2991 | 100% | 2025-02-10 | 2025-02-20 | 0d |  |  | SI Migration |  | Migration | 6.18 | Warren Fulton | MCAG (Migration) | Complete | COMPLETE |  |  |  |
| 2993 | 1.10.2.4.4 | MWG paper day | milestone | 0d | 2025-02-20 A | 2025-02-20 A | 2992 | 100% | 2025-02-20 | 2025-02-20 | 0d |  |  | SI Migration |  | Migration | 6.18 | Warren Fulton | MCAG (Migration) | Complete | COMPLETE |  |  |  |
| 2994 | 1.10.2.4.5 | MWG recommend Consultation 4 content go for industry consultation | milestone | 0d | 2025-03-04 A | 2025-03-04 A | 2993FS+8d | 100% | 2025-02-27 | 2025-02-27 | 0d |  |  | SI Migration |  | Migration | 6.18 | Warren Fulton | MCAG (Migration) | Complete | COMPLETE |  |  |  |
| 2995 | 1.10.2.4.6 | Industry Consultation |  | 10d? | 2025-03-03 A | 2025-03-14 A | 2992 | 100% | 2025-03-12 | 2025-03-25 | 0d | finish no earlier than 2025-03-14 |  | PP |  | Migration | 6.17 | Warren Fulton | MCAG (Migration) | Complete | COMPLETE |  |  |  |
| 2996 | 1.10.2.4.7 | Comment responses by PPs |  | 10d? | 2025-03-17 A | 2025-03-28 A | 2995 | 100% | 2025-03-26 | 2025-04-08 | 0d | finish no earlier than 2025-03-28 |  | SI Migration |  | Migration | 6.17 | Warren Fulton | MCAG (Migration) | Complete | COMPLETE |  |  |  |
| 2997 | 1.10.2.4.8 | Respond to comments and issue artefacts |  | 10d? | 2025-03-31 A | 2025-04-11 A | 2996 | 100% | 2025-03-31 | 2025-04-11 | 0d | finish no earlier than 2025-04-11 |  | SI Migration |  | Migration | 6.18 | Warren Fulton | MCAG (Migration) | Complete | COMPLETE |  |  |  |
| 2998 | 1.10.2.4.9 | Assurance meeting | milestone | 0d | 2025-04-22 A | 2025-04-22 A | 2997FS+5d | 100% | 2025-04-09 | 2025-04-22 | 0d | finish no earlier than 2025-04-22 |  | SI Migration |  | Migration | 6.17 | Warren Fulton | MCAG (Migration) | Complete | COMPLETE |  |  |  |
| 2999 | 1.10.2.4.10 | MCAG paper day | milestone | 0d | 2025-04-22 A | 2025-04-22 A | 2998 | 100% | 2025-04-22 | 2025-04-22 | 0d | finish no earlier than 2025-04-22 |  | SI Migration |  | Migration | 6.18 | Warren Fulton | MCAG (Migration) | Complete | COMPLETE |  |  |  |
| 3000 | 1.10.2.4.11 | MCAG Approval of Consultation 4 | milestone | 0d | 2025-04-29 A | 2025-04-29 A | 2999FS+5d | 100% | 2025-04-29 | 2025-04-29 | 0d | finish no earlier than 2025-04-29 |  | SI Migration |  | Migration | 6.17 | Warren Fulton | MCAG (Migration) | Complete | COMPLETE | T3-MI-0041 | T3 |  |
| 3001 | 1.10.2.5 | Framework Baselined at MCAG | milestone | 0d | 2025-04-29 A | 2025-04-29 A | 3000 | 100% | 2025-04-29 | 2025-04-29 | 0d | finish no earlier than 2025-04-29 |  | SI Migration |  | Migration | 6.17 | Warren Fulton | MCAG (Migration) | Complete | COMPLETE | T2-MI-7000 | T2 |  |
| 3002 | 1.10.3 | **Migration Schedule Agreed and Maintained** |  | 125d? | 2024-07-01 A | 2024-12-20 A |  | 100% | 2022-10-31 | 2024-12-20 | 207d |  | -0 | SI Migration | N/A | Migration | 6.17 | Warren Fulton | MCAG (Migration) |  |  |  |  |  |
| 3003 | 1.10.3.1 | Schedule Production |  | 125d? | 2024-07-01 A | 2024-12-20 A |  | 100% | 2024-07-01 | 2024-12-20 | 0d | start no earlier than 2024-11-18 |  | SI Migration |  | Migration | 6.14 | Warren Fulton | MCAG (Migration) | Complete | COMPLETE |  | T3 |  |
| 3004 | 1.10.3.2 | Schedule Production Complete | milestone | 0d | 2024-12-20 A | 2024-12-20 A | 3003 | 100% | 2024-12-20 | 2024-12-20 | 0d |  |  | SI Migration |  | Migration | 6.14 | Warren Fulton | MCAG (Migration) | Complete | COMPLETE | T3-MI-0042 | T3 |  |

Notes:
- 2988: Guidance: 25/7/24: Milestone name and date change approved at MCAG on 25/7/24. Date from 2/8/24 to 22/10/24. Name from 'Migration Processes & Procedures approved' to 'MCAG Approval of Migration Framework Artefacts (Baselined)’

| ID | WBS | Task | Type | Duration | Start | Finish | Predecessors | Complete | Baseline start | Baseline finish | Baseline duration | Constraint | Responsible | Text9 | Task Status | Update Version | MHHS Resource Name | Text29 | Sched Status | RAG | Milestone ID | Tier |
| --- | --- | --- | --- | --- | --- | --- | --- | --- | --- | --- | --- | --- | --- | --- | --- | --- | --- | --- | --- | --- | --- | --- |
| 3005 | 1.10.4 | **V1.0 of Migration Schedule Baseline** |  | 81d | 2025-04-01 A | 2025-07-22 A |  | 100% | 2025-04-01 | 2025-07-22 | 0d |  | SI Migration | Migration | -833.67 | 6.18 | Warren Fulton | MCAG (Migration) |  |  |  |  |
| 3006 | 1.10.4.1 | Confirm Supplier Migration start dates, MPID groups (SIT & NonSIT) | milestone | 0d | 2025-04-01 A | 2025-04-01 A |  | 100% | 2025-04-01 | 2025-04-01 | 0d | start no earlier than 2025-04-01 | SI Migration | Migration |  | 6.18 | Warren Fulton | MCAG (Migration) | Complete | COMPLETE |  |  |
| 3007 | 1.10.4.2 | V1.0 of Migration Schedule Baseline Approved at MCAG | milestone | 0d | 2025-07-22 A | 2025-07-22 A | 3006FS+81d | 100% | 2025-07-22 | 2025-07-22 | 0d |  | SI Migration | Migration |  | 6.17 | Warren Fulton | MCAG (Migration) | Complete | COMPLETE | T2-MI-7500 | T2 |
| 3008 | 1.10.5 | **Supplier Submission Support** |  | 38d? | 2025-04-25 A | 2025-06-18 A |  | 100% | 2025-04-25 | 2025-06-04 | 0d |  | SI Migration | Migration | 247.71 | 6.17 | Warren Fulton | MCAG (Migration) |  |  |  | T2 |
| 3009 | 1.10.5.1 | Support guides issued |  | 1d? | 2025-04-25 A | 2025-04-25 A |  | 100% | 2025-04-25 | 2025-04-25 | 0d | start no earlier than 2025-04-25 | SI Migration | Migration |  | 6.18 | Warren Fulton | MCAG (Migration) | Complete | COMPLETE |  |  |
| 3010 | 1.10.5.2 | Envelope webinar | milestone | 0d | 2025-05-02 A | 2025-05-02 A | 3009FS+5d | 100% | 2025-05-02 | 2025-05-02 | 0d |  | SI Migration | Migration |  | 6.18 | Warren Fulton | MCAG (Migration) | Complete | COMPLETE |  |  |
| 3011 | 1.10.5.3 | De-minimus webinar | milestone | 0d | 2025-05-02 A | 2025-05-02 A | 3010 | 100% | 2025-05-02 | 2025-05-02 | 0d |  | SI Migration | Migration |  | 6.18 | Warren Fulton | MCAG (Migration) | Complete | COMPLETE |  |  |
| 3012 | 1.10.5.4 | Drop-in session 1 | milestone | 0d | 2025-05-14 A | 2025-05-14 A | 3011FS+8d | 100% | 2025-05-14 | 2025-05-14 | 0d |  | SI Migration | Migration |  | 6.18 | Warren Fulton | MCAG (Migration) | Complete | COMPLETE |  |  |
| 3013 | 1.10.5.5 | Drop-in session 2 | milestone | 0d | 2025-05-28 A | 2025-05-28 A | 3012FS+10d | 100% | 2025-05-28 | 2025-05-28 | 0d |  | SI Migration | Migration |  | 6.18 | Warren Fulton | MCAG (Migration) | Complete | COMPLETE |  |  |
| 3014 | 1.10.5.6 | Drop-in session 3 | milestone | 0d | 2025-06-11 A | 2025-06-11 A | 3013FS+5d | 100% | 2025-06-11 | 2025-06-11 | 0d | start no earlier than 2025-06-11 | SI Migration | Migration |  | 6.26 | Warren Fulton | MCAG (Migration) | Complete | COMPLETE |  |  |
| 3015 | 1.10.5.7 | Drop-in session 4 | milestone | 0d | 2025-06-18 A | 2025-06-18 A | 3014FS+5d | 100% | 2025-06-18 | 2025-06-18 | 0d | start no earlier than 2025-06-18 | SI Migration | Migration |  | 6.26 | Warren Fulton | MCAG (Migration) | Complete | COMPLETE |  |  |
| 3016 | 1.10.6 | **MCC Stood up** |  | 265d? | 2024-11-18 A | 2025-11-21 A |  | 100% | 2024-11-18 | 2025-11-21 | 0d |  | SI Migration | Migration | -771.67 | 6.17 | Warren Fulton | MCAG (Migration) |  |  |  |  |
| 3017 | 1.10.6.1 | Migration Planning Management Tool Delivery | manual | 265d | 2024-11-18 A | 2025-11-21 A |  | 100% | 2024-11-18 | 2025-11-21 | 0d |  | SI Migration | Migration |  | 6.17 | Warren Fulton | MCAG (Migration) | Complete | COMPLETE |  |  |
| 3018 | 1.10.6.2 | **MCC Operational** |  | 98d | 2025-04-23 A | 2025-09-05 A |  | 100% | 2025-04-18 | 2025-08-29 | 0d |  | SI Migration | Migration | 220.71 | 6.17 | Warren Fulton | MCAG (Migration) |  |  |  |  |
| 3019 | 1.10.6.2.1 | **MCC Dress Rehersal 1 - Initialise Schedule (Weekly) Drop 1, 2** |  | 65d | 2025-04-23 A | 2025-07-22 A |  | 100% | 2025-04-18 | 2025-07-15 | 0d |  | SI Migration | Migration | -84.67 | 6.17 | Warren Fulton | MCAG (Migration) |  |  |  |  |
| 3020 | 1.10.6.2.1.1 | Issue Dress Rehearsal support information to all Suppliers (SIT & Non-SIT) | milestone | 0d | 2025-04-23 A | 2025-04-23 A |  | 100% | 2025-04-23 | 2025-04-23 | 0d | start no earlier than 2025-04-23 | SI Migration | Migration |  | 6.18 | Warren Fulton | MCAG (Migration) | Complete | COMPLETE |  |  |
| 3021 | 1.10.6.2.1.2 | Kestrel Webinar 1 | milestone | 0d | 2025-04-23 A | 2025-04-23 A | 3020 | 100% | 2025-04-23 | 2025-04-23 | 0d |  | SI Migration | Migration |  | 6.18 | Warren Fulton | MCAG (Migration) | Complete | COMPLETE |  |  |
| 3022 | 1.10.6.2.1.3 | Onboard and connectivity testing - Dress Rehearsal with Suppliers (All SIT and Wave 1 mandatory) | milestone | 0d | 2025-04-25 A | 2025-04-25 A | 3021FS+3d | 100% | 2025-04-25 | 2025-04-25 | 0d |  | SI Migration | Migration |  | 6.18 | Warren Fulton | MCAG (Migration) | Complete | COMPLETE |  |  |
| 3023 | 1.10.6.2.1.4 | Test Scripts shared with Participants | milestone | 0d | 2025-06-02 A | 2025-06-02 A |  | 100% | 2025-06-02 | 2025-06-02 | 0d | start no earlier than 2025-06-02 | SI Migration | Migration |  | 6.26 | Warren Fulton | MCAG (Migration) | Complete | COMPLETE |  |  |
| 3024 | 1.10.6.2.1.5 | Dress rehearsal 1 start | milestone | 0d | 2025-06-09 A | 2025-06-09 A |  | 100% | 2025-06-09 | 2025-06-09 | 0d | start no earlier than 2025-06-09 | SI Migration | Migration |  | 6.26 | Warren Fulton | MCAG (Migration) | Complete | COMPLETE |  |  |
| 3025 | 1.10.6.2.1.6 | Supplier Schedule Submission #2 complete |  | 1d | 2025-06-20 A | 2025-06-20 A |  | 100% | 2025-06-20 | 2025-06-20 | 0d | start no earlier than 2025-06-20 | SI Migration | Migration |  | 6.26 | Warren Fulton | MCAG (Migration) | Complete | COMPLETE | T3-MI-0043 |  |
| 3026 | 1.10.6.2.1.7 | Consolidate baseline schedule |  | 15d | 2025-06-23 A | 2025-07-11 A | 3025 | 100% | 2025-06-23 | 2025-07-11 | 0d |  | SI Migration | Migration |  | 6.26 | Warren Fulton | MCAG (Migration) | Complete | COMPLETE |  |  |
| 3027 | 1.10.6.2.1.8 | Consolidated baseline schedule published to industry | milestone | 0d | 2025-07-11 A | 2025-07-11 A | 3026 | 100% | 2025-07-11 | 2025-07-11 | 0d |  | SI Migration | Migration |  | 6.26 | Warren Fulton | MCAG (Migration) | Complete | COMPLETE |  |  |
| 3028 | 1.10.6.2.1.9 | Baselined Schedule available for download |  | 1d | 2025-07-14 A | 2025-07-14 A | 3027 | 100% | 2025-07-14 | 2025-07-14 | 0d |  | SI Migration | Migration |  | 6.26 | Warren Fulton | MCAG (Migration) | Complete | COMPLETE |  |  |
| 3029 | 1.10.6.2.1.10 | Test execution report (weekly) | milestone | 0d | 2025-07-15 A | 2025-07-15 A |  | 100% | 2025-07-15 | 2025-07-15 | 0d |  | SI Migration | Migration |  | 6.18 | Warren Fulton | MCAG (Migration) | Complete | COMPLETE |  |  |
| 3030 | 1.10.6.2.1.11 | Dress rehearsal completion report | milestone | 0d | 2025-07-15 A | 2025-07-15 A | 3029, 3026 | 100% | 2025-07-15 | 2025-07-15 | 0d |  | SI Migration | Migration |  | 6.18 | Warren Fulton | MCAG (Migration) | Complete | COMPLETE |  |  |
| 3031 | 1.10.6.2.1.12 | MCC Dress Rehersal 1 - complete | milestone | 0d | 2025-07-15 A | 2025-07-15 A | 3030 | 100% | 2025-07-15 | 2025-07-15 | 0d |  | SI Migration | Migration |  | 6.17 | Warren Fulton | MCAG (Migration) | Complete | COMPLETE | T3-MI-0044 | T3 |
| 3032 | 1.10.6.2.1.13 | MCAG approval of Baseline Migration schedule | milestone | 0d | 2025-07-22 A | 2025-07-22 A | 3031 | 100% | 2025-07-22 | 2025-07-22 | 0d | finish no earlier than 2025-07-22 | SI Migration |  |  | 6.26 | Warren Fulton | MCAG (Migration) | Complete | COMPLETE |  |  |

| ID | WBS | Task | Type | Duration | Start | Finish | Predecessors | Complete | Baseline start | Baseline finish | Baseline duration | Baseline 1 start | Baseline 1 finish | Constraint | Baseline cost | Responsible | Text9 | Task Status | Update Version | MHHS Resource Name | Text29 | Sched Status | RAG | Milestone ID | Tier | Notes (2) | Involved | MHHS Programme Phase | Artefact ID |
| --- | --- | --- | --- | --- | --- | --- | --- | --- | --- | --- | --- | --- | --- | --- | --- | --- | --- | --- | --- | --- | --- | --- | --- | --- | --- | --- | --- | --- | --- |
| 3033 | 1.10.6.2.2 | **MCC Dress Rehersal 2 - complete** |  | 40d | 2025-07-14 A | 2025-09-05 A |  | 100% | 2025-07-14 | 2025-08-29 | 0d |  |  |  |  | SI Migration | Migration | 199.33 | 6.17 | Warren Fulton | MCAG (Migration) |  |  |  |  |  |  |  |  |
| 3034 | 1.10.6.2.2.1 | Issue Dress Rehearsal support information to Participants | milestone | 0d | 2025-07-14 A | 2025-07-14 A |  | 100% | 2025-07-14 | 2025-07-14 | 0d |  |  | start no earlier than 2025-07-14 |  | SI Migration | Migration |  | 6.18 | Warren Fulton | MCAG (Migration) | Complete | COMPLETE |  |  |  |  |  |  |
| 3035 | 1.10.6.2.2.2 | Kestrel Webinar 1 | milestone | 0d | 2025-07-14 A | 2025-07-14 A | 3034 | 100% | 2025-07-14 | 2025-07-14 | 0d |  |  |  |  | SI Migration | Migration |  | 6.18 | Warren Fulton | MCAG (Migration) | Complete | COMPLETE |  |  |  |  |  |  |
| 3036 | 1.10.6.2.2.3 | Kestrel Webinar 2 | milestone | 0d | 2025-08-06 A | 2025-08-06 A |  | 100% | 2025-08-06 | 2025-08-06 | 0d |  |  | finish no earlier than 2025-08-06 |  | SI Migration | Migration |  | 6.29 | Warren Fulton | MCAG (Migration) | Complete | COMPLETE |  |  |  |  |  |  |
| 3037 | 1.10.6.2.2.4 | Onboard and connectivity testing - Dress Rehearsal with Suppliers (remaining suppliers and non-supplier PPs) | milestone | 0d | 2025-08-11 A | 2025-08-11 A | 3035FS+6d | 100% | 2025-08-11 | 2025-08-11 | 0d |  |  | start no earlier than 2025-08-11 |  | SI Migration | Migration |  | 6.29 | Warren Fulton | MCAG (Migration) | Complete | COMPLETE |  |  |  |  |  |  |
| 3038 | 1.10.6.2.2.5 | **MCC Dress Rehersal 2** |  | 20d | 2025-08-11 A | 2025-09-05 A | 3037 | 100% | 2025-08-11 | 2025-08-11 | 0d |  |  |  |  | SI Migration | Migration | 20.71 | 6.29 | Warren Fulton | MCAG (Migration) |  |  |  |  |  |  |  |  |
| 3039 | 1.10.6.2.2.5.1 | MCC Dress Rehersal 2 start |  | 1d | 2025-08-11 A | 2025-08-11 A |  | 100% | 2025-08-11 | 2025-08-11 | 0d |  |  | finish no earlier than 2025-08-11 |  | SI Migration | Migration |  | 6.29 | Warren Fulton | MCAG (Migration) | Complete | COMPLETE |  |  |  |  |  |  |
| 3040 | 1.10.6.2.2.5.2 | Test execution report (weekly) |  | 20d | 2025-08-11 A | 2025-09-05 A |  | 100% | 2025-08-29 | 2025-08-29 | 0d |  |  | finish no earlier than 2025-08-11 |  | SI Migration | Migration |  | 6.33 | Warren Fulton | MCAG (Migration) | Complete | COMPLETE |  |  |  |  |  |  |
| 3041 | 1.10.6.2.2.5.3 | Dress rehearsal completion report available | milestone | 0d | 2025-09-05 A | 2025-09-05 A | 3040 | 100% | 2025-08-29 | 2025-08-29 | 0d |  |  | finish no earlier than 2025-08-29 |  | SI Migration | Migration |  | 6.33 | Warren Fulton | MCAG (Migration) | Complete | COMPLETE |  |  |  |  |  |  |
| 3042 | 1.10.6.2.2.5.4 | PPs return test scripts | milestone | 0d | 2025-09-05 A | 2025-09-05 A |  | 100% | 2025-08-29 | 2025-08-29 | 0d |  |  | finish no earlier than 2025-09-05 |  | PP |  |  | 6.33 | Warren Fulton | MCAG (Migration) | Complete | COMPLETE |  |  |  |  |  |  |
| 3043 | 1.10.6.2.2.5.5 | MCC Dress Rehearsal 2 - complete | milestone | 0d | 2025-09-05 A | 2025-09-05 A | 3041 | 100% | 2025-08-29 | 2025-08-29 | 0d |  |  | finish no earlier than 2025-09-05 |  | SI Migration | Migration |  | 6.32 | Warren Fulton | MCAG (Migration) | Complete | COMPLETE | T3-MI-0045 | T3 |  |  |  |  |
| 3044 | 1.10.6.3 | MCC Operational Complete | milestone | 0d | 2025-09-05 A | 2025-09-05 A | 3033, 3043 | 100% | 2025-08-29 | 2025-08-29 | 0d |  |  | finish no earlier than 2025-08-29 |  | SI Migration | Migration |  | 6.32 | Warren Fulton | MCAG (Migration) | Complete | COMPLETE | T2-MI-0500 | T2 |  |  |  |  |
| 3045 | 1.10.7 | **M11 Readiness Checkpoint** |  | 36d | 2025-08-29 A | 2025-10-20 A |  | 100% | 2025-07-28 | 2025-08-28 | 0d |  |  |  |  | SI Migration | Migration | -7.67 | 6.31 | Warren Fulton | MCAG (Migration) |  |  |  |  |  |  |  |  |
| 3046 | 1.10.7.1 | Supplier Readiness Assessments for Sprint 0 Day 1 |  | 20d | 2025-08-29 A | 2025-09-25 A |  | 100% | 2025-08-29 | 2025-09-25 | 0d |  |  | start no earlier than 2025-08-29 |  | SI Migration | Migration |  | 6.34 | Warren Fulton | MCAG (Migration) | Complete | COMPLETE |  |  |  |  |  |  |
| 3047 | 1.10.7.2 | MCAG Approve Sprint 0 Day 1 Baseline Schedule | milestone | 0d | 2025-10-20 A | 2025-10-20 A |  | 100% | 2025-10-20 | 2025-10-20 | 0d |  |  | start no earlier than 2025-10-20 |  | SI Migration |  |  | 6.34 | Warren Fulton | MCAG (Migration) | Complete | COMPLETE |  |  |  |  |  |  |
| 3048 | 1.10.7.3 | **Legacy Settlement run stability assessment** |  | 16d | 2025-09-26 A | 2025-10-17 A |  | 100% | 2025-09-26 | 2025-10-17 | 0d |  |  |  |  | SI Migration | Migration | 51.33 | 6.31 | Warren Fulton | MCAG (Migration) |  |  |  |  | Link to parallel run and M10 |  |  |  |
| 3049 | 1.10.7.3.1 | Legacy Settlement run stability assessment |  | 16d | 2025-09-26 A | 2025-10-17 A | 1802, 2306 | 100% | 2025-09-26 | 2025-10-17 | 0d |  |  | start no earlier than 2025-09-26 |  | SI Migration |  |  | 6.31 | Warren Fulton | MCAG (Migration) | Complete | COMPLETE |  |  |  |  |  |  |
| 3050 | 1.10.7.3.2 | Checkpoint 1 | milestone | 0d | 2025-10-03 A | 2025-10-03 A |  | 100% | 2025-10-03 | 2025-10-03 | 0d |  |  | finish no earlier than 2025-10-03 |  | SI Migration |  |  | 6.32 | Warren Fulton | MCAG (Migration) | Complete | COMPLETE |  |  |  |  |  |  |
| 3051 | 1.10.7.3.3 | Checkpoint 2 | milestone | 0d | 2025-10-10 A | 2025-10-10 A |  | 100% | 2025-10-10 | 2025-10-10 | 0d |  |  | finish no earlier than 2025-10-10 |  | SI Migration |  |  | 6.32 | Warren Fulton | MCAG (Migration) | Complete | COMPLETE |  |  |  |  |  |  |
| 3052 | 1.10.7.3.4 | Checkpoint 3 | milestone | 0d | 2025-10-17 A | 2025-10-17 A |  | 100% | 2025-10-17 | 2025-10-17 | 0d |  |  | finish no earlier than 2025-10-17 |  | SI Migration |  |  | 6.32 | Warren Fulton | MCAG (Migration) | Complete | COMPLETE |  |  |  |  |  |  |
| 3053 | 1.10.8 | **Migration Artefact Development and Publication** |  | 1043d | 2022-10-31 A | 2026-10-28 A |  | 100% | 2022-10-31 | 2025-09-03 | 635d | 2022-10-31 | 2025-04-04 |  | -0 | N/A | Migration |  | 5.0 | Warren Fulton | MCAG (Migration) |  |  |  |  |  | N/A | Migration |  |
| 3054 | 1.10.8.1 | **Migration Approach** |  | 28d | 2022-10-31 A | 2022-12-07 A |  | 100% | 2022-10-31 | 2022-12-07 | 28d | 2022-10-31 | 2022-12-07 |  |  | N/A | Migration |  | 5.0 | Warren Fulton | MCAG (Migration) |  |  |  |  |  | N/A | Migration |  |
| 3055 | 1.10.8.1.1 | Option analysis (via MWG and PPIR) and recommendation |  | 23d | 2022-10-31 A | 2022-11-30 A |  | 100% | 2022-10-31 | 2022-11-30 | 23d | 2022-10-31 | 2022-11-30 |  |  | PP | Migration |  | 5.0 | John Wiggins,Matthew Breen |  | Complete | COMPLETE |  |  |  | SI Migration | Migration |  |
| 3056 | 1.10.8.1.2 | Migration Approach approved | milestone | 0d | 2022-12-07 A | 2022-12-07 A | 3055FS+5d | 100% | 2022-12-07 | 2022-12-07 | 0d | 2022-12-07 | 2022-12-07 |  |  | SI Migration | Migration |  | 5.0 | John Wiggins,Matthew Breen | PSG | Complete | COMPLETE | T3-MI-0010 | T3 |  | PP,IPA | Migration | MHHS-DEL770 |

| ID | WBS | Task | Type | Duration | Start | Finish | Predecessors | Complete | Baseline start | Baseline finish | Baseline duration | Baseline 1 start | Baseline 1 finish | Baseline cost | Responsible | Involved | Text9 | Update Version | MHHS Resource Name | MHHS Programme Phase | Sched Status | RAG | Milestone ID | Text29 | Tier | Guidance |
| --- | --- | --- | --- | --- | --- | --- | --- | --- | --- | --- | --- | --- | --- | --- | --- | --- | --- | --- | --- | --- | --- | --- | --- | --- | --- | --- |
| 3057 | 1.10.8.2 | **Migration Design** |  | 100d | 2022-11-14 A | 2023-03-31 A |  | 100% | 2022-11-14 | 2023-03-31 | 100d | 2022-11-14 | 2023-03-31 |  | N/A | N/A | Migration | 5.0 | N/A | Migration |  |  |  |  |  |  |
| 3058 | 1.10.8.2.1 | Review and update existing design artefacts and socialise with participants ahead of MDSG |  | 10d | 2022-11-14 A | 2022-11-25 A |  | 100% | 2022-11-14 | 2022-11-25 | 10d | 2022-11-14 | 2022-11-25 |  | SI Migration | SRO Design,CPT | Migration | 5.0 | John Wiggins,Matthew Breen | Migration | Complete | COMPLETE |  |  |  |  |
| 3059 | 1.10.8.2.2 | Develop design artefacts and supporting technical documents in line with MDSG |  | 53d | 2022-11-30 A | 2023-02-10 A | 3058FS+2d | 100% | 2022-11-30 | 2023-02-10 | 53d | 2022-11-30 | 2023-02-10 |  | SI Migration | PP,SRO Function,CPT | Migration | 5.0 | John Wiggins,Matthew Breen | Migration | Complete | COMPLETE |  |  |  |  |
| 3060 | 1.10.8.2.3 | Migration design artefacts issued for consultation | milestone | 0d | 2023-02-13 A | 2023-02-13 A | 3059FS+1d | 100% | 2023-02-13 | 2023-02-13 | 0d | 2023-02-13 | 2023-02-13 |  | SI Migration | PP,SRO Function,CPT | Migration | 5.0 | John Wiggins,Matthew Breen | Migration | Complete | COMPLETE | T3-MI-0011 | DAG | T3 |  |
| 3061 | 1.10.8.2.4 | Industry consultation |  | 5d | 2023-02-14 A | 2023-02-20 A | 3060SS | 100% | 2023-02-14 | 2023-02-20 | 5d | 2023-02-14 | 2023-02-20 |  | PP | SI Migration | Migration | 5.0 | John Wiggins,Matthew Breen | Migration | Complete | COMPLETE |  |  |  |  |
| 3062 | 1.10.8.2.5 | Review consultation feedback, address comments and update artefacts |  | 5d | 2023-02-21 A | 2023-02-27 A | 3061 | 100% | 2023-02-21 | 2023-02-27 | 5d | 2023-02-21 | 2023-02-27 |  | SI Migration | PP | Migration | 5.0 | John Wiggins,Matthew Breen | Migration | Complete | COMPLETE |  |  |  |  |
| 3063 | 1.10.8.2.6 | Internal artefact review and comms preparation |  | 3d | 2023-02-28 A | 2023-03-02 A | 3062 | 100% | 2023-02-28 | 2023-03-02 | 3d | 2023-02-28 | 2023-03-02 |  | SI Migration | SRO Function | Migration | 5.0 | John Wiggins,Matthew Breen | Migration | Complete | COMPLETE |  |  |  |  |
| 3064 | 1.10.8.2.7 | Updated Migration Design artefacts issued to PPs for assurance review | milestone | 0d | 2023-03-03 A | 2023-03-03 A | 3063FS+1d | 100% | 2023-03-03 | 2023-03-03 | 0d | 2023-03-03 | 2023-03-03 |  | SI Migration | PP | Migration | 5.0 | John Wiggins,Matthew Breen | Migration | Complete | COMPLETE | T3-MI-0013 | DAG | T3 |  |
| 3065 | 1.10.8.2.8 | Final Migration Design artefacts walkthrough with PPs | milestone | 0d | 2023-03-22 A | 2023-03-22 A | 3064FS+13d | 100% | 2023-03-22 | 2023-03-22 | 0d | 2023-03-22 | 2023-03-22 |  | SI Migration | PP | Migration | 5.0 | John Wiggins,Matthew Breen | Migration | Complete | COMPLETE |  |  |  |  |
| 3066 | 1.10.8.2.9 | Migration Design approved | milestone | 0d | 2023-03-31 A | 2023-03-31 A | 3065FS+7d | 100% | 2023-03-31 | 2023-03-31 | 0d | 2023-03-31 | 2023-03-31 |  | SI Migration | PP,SRO Function,CPT | Migration | 5.0 | John Wiggins,Matthew Breen | Migration | Complete | COMPLETE | T2-MI-0050 | DAG | T2 |  |
| 3067 | 1.10.8.3 | **Transition Design** |  | 186d | 2023-03-01 A | 2023-11-15 A |  | 100% | 2023-03-01 | 2023-11-15 | 186d | 2023-03-01 | 2023-08-03 | -0 | N/A | N/A | Migration | 5.0 | N/A | Migration |  |  |  |  |  |  |
| 3068 | 1.10.8.3.1 | **Tranche 1** |  | 56d | 2023-03-01 A | 2023-05-17 A |  | 100% | 2023-03-01 | 2023-05-17 | 56d | 2023-03-01 | 2023-05-17 |  | N/A | N/A | Migration | 5.0 | N/A | Migration |  |  |  |  |  |  |
| 3069 | 1.10.8.3.1.1 | Develop design artefacts and supporting technical details with participants |  | 50d | 2023-03-01 A | 2023-05-09 A |  | 100% | 2023-03-01 | 2023-05-09 | 50d | 2023-03-01 | 2023-05-09 |  | SI Design | PP | Migration | 5.0 | Andrew Margan | Migration | Complete | COMPLETE |  |  |  |  |
| 3070 | 1.10.8.3.1.2 | Issue Material for DAG approval |  | 1d | 2023-05-10 A | 2023-05-10 A | 3069 | 100% | 2023-05-10 | 2023-05-10 | 1d | 2023-05-10 | 2023-05-10 |  | PP | SI Design | Migration | 5.0 | Andrew Margan | Migration | Complete | COMPLETE |  |  |  |  |
| 3071 | 1.10.8.3.1.3 | Tranche 1 Transition Design approved | milestone | 0d | 2023-05-17 A | 2023-05-17 A | 3070FS+5d | 100% | 2023-05-17 | 2023-05-17 | 0d | 2023-05-17 | 2023-05-17 |  | SI Design | PP | Migration | 5.0 | Andrew Margan | Migration | Complete | COMPLETE | T2-DB-0150 | DAG | T2 |  |
| 3072 | 1.10.8.3.2 | **Tranche 2** |  | 130d | 2023-05-18 A | 2023-11-15 A |  | 100% | 2023-05-18 | 2023-11-15 | 130d | 2023-05-18 | 2023-08-03 | -0 | N/A | N/A | Migration | 5.0 | N/A | Migration |  |  |  |  |  |  |
| 3073 | 1.10.8.3.2.1 | Develop Initial design artefacts and supporting technical details |  | 76d | 2023-05-18 A | 2023-08-31 A | 3071 | 100% | 2023-05-18 | 2023-08-31 | 76d | 2023-05-18 | 2023-07-26 |  | SRO | PP, CPT, SRO Design | Migration | 5.5 | Andrew Margan | Migration | Complete | COMPLETE |  |  |  |  |
| 3074 | 1.10.8.3.2.2 | Communicate Initial Design Artefacts with Industry (MTDSG) |  | 1d | 2023-09-01 A | 2023-09-01 A | 3073 | 100% | 2023-09-01 | 2023-09-01 | 1d |  |  |  | SRO | PP, CPT, SRO Design | Migration | 5.5 | Andrew Margan | Migration | Complete | COMPLETE |  |  |  |  |
| 3075 | 1.10.8.3.2.3 | Host MTDSG |  | 1d | 2023-09-11 A | 2023-09-11 A | 3074FS+5d | 100% | 2023-09-11 | 2023-09-11 | 1d |  |  |  | SRO | PP, CPT, SRO Design | Migration | 5.5 | Andrew Margan | Migration | Complete | COMPLETE |  |  |  |  |
| 3076 | 1.10.8.3.2.4 | Process MTDSG Feedback and Amend Design Artefacts |  | 4d | 2023-09-12 A | 2023-09-15 A | 3075 | 100% | 2023-09-12 | 2023-09-15 | 4d |  |  |  | SRO | PP, CPT, SRO Design | Migration | 5.5 | Andrew Margan | Migration | Complete | COMPLETE |  |  |  |  |
| 3077 | 1.10.8.3.2.5 | Communicate Amended Design Artefacts with Industry |  | 1d | 2023-09-15 A | 2023-09-15 A | 3076FF | 100% | 2023-09-15 | 2023-09-15 | 1d |  |  |  | SRO | PP, CPT, SRO Design | Migration | 5.5 | Andrew Margan | Migration | Complete | COMPLETE |  |  |  |  |
| 3078 | 1.10.8.3.2.6 | Host MTDSG |  | 1d | 2023-09-26 A | 2023-09-26 A | 3077FS+6d | 100% | 2023-09-26 | 2023-09-26 | 1d |  |  |  | SRO | PP, CPT, SRO Design | Migration | 5.5 | Andrew Margan | Migration | Complete | COMPLETE |  |  |  |  |
| 3079 | 1.10.8.3.2.7 | Make Final Amendments to Design Artefact |  | 5d | 2023-09-27 A | 2023-10-03 A | 3078 | 100% | 2023-09-27 | 2023-10-03 | 5d |  |  |  | SRO | PP, CPT, SRO Design | Migration | 5.5 | Andrew Margan | Migration | Complete | COMPLETE |  |  |  |  |
| 3080 | 1.10.8.3.2.8 | Request DAG Consultation |  | 1d | 2023-10-04 A | 2023-10-04 A | 3079 | 100% | 2023-10-04 | 2023-10-04 | 1d |  |  |  | SRO | PP, CPT, SRO Design | Migration | 5.5 | Andrew Margan | Migration | Complete | COMPLETE |  |  |  |  |
| 3081 | 1.10.8.3.2.9 | Consultation Period |  | 11d | 2023-10-04 A | 2023-10-18 A | 3080SS | 100% | 2023-10-04 | 2023-10-18 | 11d |  |  |  | SRO | PP, CPT, SRO Design | Migration | 5.5 | Andrew Margan | Migration | Complete | COMPLETE |  |  |  |  |
| 3082 | 1.10.8.3.2.10 | Action Consultation Comments |  | 5d | 2023-10-19 A | 2023-10-25 A | 3081 | 100% | 2023-10-19 | 2023-10-25 | 5d |  |  |  | SRO | PP, CPT, SRO Design | Migration | 5.5 | Andrew Margan | Migration | Complete | COMPLETE |  |  |  |  |
| 3083 | 1.10.8.3.2.11 | Post Consultation Industry Assurance |  | 5d | 2023-10-26 A | 2023-11-01 A | 3082 | 100% | 2023-10-26 | 2023-11-01 | 5d |  |  |  | SRO | PP, CPT, SRO Design | Migration | 5.5 | Andrew Margan | Migration | Complete | COMPLETE |  |  |  |  |
| 3084 | 1.10.8.3.2.12 | Request DAG Approval |  | 1d | 2023-11-01 A | 2023-11-01 A | 3083FF | 100% | 2023-11-01 | 2023-11-01 | 1d |  |  |  | SRO | PP, CPT, SRO Design | Migration | 5.5 | Andrew Margan | Migration | Complete | COMPLETE |  |  |  |  |
| 3085 | 1.10.8.3.2.13 | DAG Transition Design Approved |  | 1d | 2023-11-08 A | 2023-11-08 A | 3084FS+4d | 100% | 2023-11-08 | 2023-11-08 | 1d |  |  |  | SRO | PP, CPT, SRO Design | Migration | 5.5 | Andrew Margan | Migration | Complete | COMPLETE |  |  |  |  |
| 3086 | 1.10.8.3.2.14 | Update Transition Design Admin |  | 5d | 2023-11-09 A | 2023-11-15 A | 3085 | 100% | 2023-11-09 | 2023-11-15 | 5d |  |  |  | SRO | PP, CPT, SRO Design | Migration | 5.5 | Andrew Margan | Migration | Complete | COMPLETE |  |  |  |  |
| 3087 | 1.10.8.3.2.15 | Tranche 2 Transition Design Baselined | milestone | 0d | 2023-11-15 A | 2023-11-15 A | 3086 | 100% | 2023-11-15 | 2023-11-15 | 0d | 2023-08-03 | 2023-08-03 |  | SRO | PP, CPT, SRO Design | Migration | 5.12 | Andrew Margan | Migration | Complete | COMPLETE | T2-DB-0250 | DAG | T2 | 14/8 - Date aligns with DAG |

Notes:
- 3087: Action: 2/8/23 - needs to be replanned to 15//11/23. AM to raise CR as T2 milestone

| ID | WBS | Task | Type | Duration | Start | Finish | Predecessors | Complete | Baseline start | Baseline finish | Baseline duration | Baseline 1 start | Baseline 1 finish | Constraint | Baseline cost | Responsible | Involved | Text9 | Update Version | MHHS Resource Name | MHHS Programme Phase | Sched Status | RAG | Milestone ID | Text29 | Tier |
| --- | --- | --- | --- | --- | --- | --- | --- | --- | --- | --- | --- | --- | --- | --- | --- | --- | --- | --- | --- | --- | --- | --- | --- | --- | --- | --- |
| 3088 | 1.10.8.4 | **Data Assessment Report** |  | 61d | 2022-12-06 A | 2023-02-28 A |  | 100% | 2022-12-06 | 2023-02-28 | 61d | 2022-12-06 | 2023-02-28 |  |  | N/A | N/A | Migration | 5.0 | N/A | Migration |  |  |  |  |  |
| 3089 | 1.10.8.4.1 | Develop document with MWG |  | 49d | 2022-12-06 A | 2023-02-10 A |  | 100% | 2022-12-06 | 2023-02-10 | 49d | 2022-12-06 | 2023-02-10 |  |  | SI Migration |  | Migration | 5.0 | John Wiggins,Matthew Breen | Migration | Complete | COMPLETE |  |  |  |
| 3090 | 1.10.8.4.2 | Artefact review (via TMAG) and updates |  | 25d | 2023-01-18 A | 2023-02-21 A | 3089FS-18d | 100% | 2023-01-18 | 2023-02-21 | 25d | 2023-01-18 | 2023-02-21 |  |  | PP | IPA,SI Migration | Migration | 5.0 | John Wiggins,Matthew Breen | Migration | Complete | COMPLETE |  |  |  |
| 3091 | 1.10.8.4.3 | Data Assessment Report approved | milestone | 0d | 2023-02-28 A | 2023-02-28 A | 3090FS+5d | 100% | 2023-02-28 | 2023-02-28 | 0d | 2023-02-28 | 2023-02-28 |  |  | SI Migration | PP,IPA | Migration | 5.0 | John Wiggins,Matthew Breen | Migration | Complete | COMPLETE | T3-MI-0012 | MCAG | T3 |
| 3092 | 1.10.8.5 | **Migration, Cutover & Data Strategy (incl. Migration Entry Criteria)** |  | 102d | 2022-12-08 A | 2023-04-28 A |  | 100% | 2022-12-08 | 2023-04-28 | 102d | 2022-12-08 | 2023-04-28 |  |  | N/A | N/A | Migration | 5.0 | N/A | Migration |  |  |  |  |  |
| 3093 | 1.10.8.5.1 | Develop document with MWG |  | 67d | 2022-12-08 A | 2023-03-10 A | 3056 | 100% | 2022-12-08 | 2023-03-10 | 67d | 2022-12-08 | 2023-03-10 |  |  | SI Migration | PP | Migration | 5.0 | John Wiggins,Matthew Breen | Migration | Complete | COMPLETE |  |  |  |
| 3094 | 1.10.8.5.2 | Artefact review (via TMAG) and updates |  | 28d | 2023-03-15 A | 2023-04-21 A | 3093FS+2d | 100% | 2023-03-15 | 2023-04-21 | 28d | 2023-03-15 | 2023-04-21 |  |  | PP | SI Migration | Migration | 5.0 | John Wiggins,Matthew Breen | Migration | Complete | COMPLETE |  |  |  |
| 3095 | 1.10.8.5.3 | Migration, Cutover & Data Strategy approved | milestone | 0d | 2023-04-28 A | 2023-04-28 A | 3094FF+5d | 100% | 2023-04-28 | 2023-04-28 | 0d | 2023-04-28 | 2023-04-28 |  |  | SI Migration | PP | Migration | 5.0 | John Wiggins,Matthew Breen | Migration | Complete | COMPLETE | T3-MI-0014 | MCAG | T3 |
| 3096 | 1.10.8.6 | **Data Cleanse Plan** |  | 670d | 2023-03-02 A | 2025-09-24 A |  | 100% | 2023-03-02 | 2025-09-03 | 547d | 2023-03-02 | 2025-04-04 |  | -0 | N/A | N/A | Migration | 5.0 | N/A | Migration |  |  |  |  |  |
| 3097 | 1.10.8.6.1 | Develop document with MWG |  | 50d | 2023-03-02 A | 2023-05-10 A |  | 100% | 2023-03-02 | 2023-05-10 | 50d | 2023-03-02 | 2023-05-10 |  |  | SI Migration | PP | Migration | 5.0 | John Wiggins,Matthew Breen | Migration | Complete | COMPLETE |  |  |  |
| 3098 | 1.10.8.6.2 | Artefact review (via TMAG) and updates |  | 20d | 2023-05-11 A | 2023-06-07 A | 3097 | 100% | 2023-05-11 | 2023-06-07 | 20d | 2023-05-11 | 2023-06-07 |  |  | PP | SI Migration,IPA | Migration | 5.0 | John Wiggins,Matthew Breen | Migration | Complete | COMPLETE |  |  |  |
| 3099 | 1.10.8.6.3 | Data Cleanse Plan approved | milestone | 0d | 2023-07-19 A | 2023-07-19 A | 3098FS+30d | 100% | 2023-07-19 | 2023-07-19 | 0d | 2023-06-14 | 2023-06-14 |  |  | SI Migration | PP | Migration | 5.0 | John Wiggins,Matthew Breen | Migration | Complete | COMPLETE | T3-MI-0020 | MCAG | T3 |
| 3100 | 1.10.8.6.4 | Monitor Programme Participant adherence to Data Cleanse Plan |  | 467d | 2023-06-15 A | 2025-03-28 A | 3099 | 100% | 2023-06-15 | 2025-03-28 | 467d | 2023-06-15 | 2025-03-28 |  |  | SI Migration | PP | Migration | 5.0 | Matthew Breen | Migration | Complete | COMPLETE |  |  |  |
| 3101 | 1.10.8.6.5 | **MTDs** |  | 241d | 2024-08-16 A | 2025-07-21 A |  | 100% | 2024-08-16 | 2025-01-31 | 91d |  |  |  | -0 | N/A | N/A | Transition | 5.4 | N/A | Migration |  |  |  |  |  |
| 3102 | 1.10.8.6.5.1 | **ESME ID** |  | 195d | 2024-08-16 A | 2025-05-16 A |  | 100% | 2024-08-16 | 2024-12-20 | 90d |  |  |  | -0 | N/A | N/A | Transition | 5.4 | N/A | Migration |  |  |  |  |  |
| 3103 | 1.10.8.6.5.1.1 | DCC to extract ESME ID and share with LDSO | milestone | 0d | 2024-08-16 A | 2024-08-16 A | 3099FS+282d | 100% | 2024-08-16 | 2024-08-16 | 0d |  |  |  |  | DCC/SI |  | Transition | 5.5 | Matthew Breen | Migration | Complete | COMPLETE | T3-MI-0024 | MCAG (Transition) | T3 |
| 3104 | 1.10.8.6.5.1.2 | LDSO ‘full refresh’ between their Registration Service and the EES (ESME ID) |  | 16d | 2024-10-21 A | 2024-11-11 A | 3103FS+45d | 100% | 2024-10-21 | 2024-11-11 | 0d |  |  |  |  | LDSO/EES |  | Transition | 5.5 | Matthew Breen | Migration | Complete | COMPLETE | T3-MI-0025 | MCAG (Transition) | T3 |
| 3105 | 1.10.8.6.5.1.3 | Suppliers complete investigation of exceptions and resolution of exceptions |  | 1d | 2024-12-20 A | 2024-12-20 A | 3104FS+28d | 100% | 2024-12-20 | 2024-12-20 | 1d |  |  |  |  | Supplier |  | Transition | 5.4 | Matthew Breen | Migration | Complete | COMPLETE |  |  |  |
| 3106 | 1.10.8.6.5.1.4 | Suppliers complete Work Off plans |  | 105d | 2024-12-23 A | 2025-05-16 A | 3105 | 100% | 2024-12-23 | 2025-05-16 | 0d |  |  | start no earlier than 2024-12-23 |  | Supplier |  | Transition | 6.19 | Matthew Breen |  | Complete | COMPLETE |  |  |  |
| 3107 | 1.10.8.6.5.1.5 | ESME ID Complete | milestone | 0d | 2025-05-16 A | 2025-05-16 A | 3106 | 100% | 2025-05-16 | 2025-05-16 | 0d |  |  |  |  | SI Transition |  | Transition | 6.19 | Matthew Breen | Migration | Complete | COMPLETE |  |  |  |
| 3108 | 1.10.8.6.5.2 | **Meter Location and Number of Displayed Register Digits** |  | 222d | 2024-09-13 A | 2025-07-21 A |  | 100% | 2024-09-13 | 2025-01-31 | 91d |  |  |  |  | N/A | N/A | Transition | 5.4 | N/A | Migration |  |  |  |  |  |
| 3109 | 1.10.8.6.5.2.1 | MEM to extract data and share with LDSO |  | 6d | 2024-09-13 A | 2024-09-20 A | 3099FS+301d | 100% | 2024-09-13 | 2024-09-20 | 1d |  |  |  |  | MEM/SI |  | Transition | 5.4 | Matthew Breen | Migration | Complete | COMPLETE |  |  |  |
| 3110 | 1.10.8.6.5.2.2 | LDSO ‘full refresh’ between their Registration Service and the EES (Meter Location and Number of Displayed Register Digits) |  | 16d | 2024-10-21 A | 2024-11-15 A | 3109FS+25d | 100% | 2024-10-28 | 2024-11-18 | 0d |  |  |  |  | LDSO /EES |  | Transition | 5.5 | Matthew Breen | Migration | Complete | COMPLETE | T3-MI-0026 | MCAG (Transition) | T3 |
| 3111 | 1.10.8.6.5.2.3 | Suppliers complete investigation of exceptions and resolution of exceptions |  | 1d | 2025-01-24 A | 2025-01-24 A | 3110FS+49d | 100% | 2025-01-31 | 2025-01-31 | 1d |  |  |  |  | Supplier |  | Transition | 5.4 | Matthew Breen | Migration | Complete | COMPLETE |  |  |  |
| 3112 | 1.10.8.6.5.2.4 | Suppliers complete Work Off plans |  | 123d | 2025-01-29 A | 2025-07-18 A | 3111 | 100% | 2025-01-29 | 2025-07-18 | 0d |  |  | finish no earlier than 2025-07-18 |  | Supplier |  | Transition | 6.19 | Matthew Breen |  | Complete | COMPLETE |  |  |  |
| 3113 | 1.10.8.6.5.2.5 | Meter Location and Number of Displayed Register Digits Complete |  | 1d | 2025-07-21 A | 2025-07-21 A | 3111, 3112 | 100% | 2025-07-18 | 2025-07-18 | 0d |  |  |  |  | SI Transition |  | Transition | 6.19 | Matthew Breen | Migration | Complete | COMPLETE |  |  |  |

Notes:
- 3107: Action: 2/8/24: is date right as different to baseline? Why was it 23rd?

| ID | WBS | Task | Type | Duration | Start | Finish | Predecessors | Complete | Baseline start | Baseline finish | Baseline duration | Constraint | Responsible | Involved | Text9 | Update Version | MHHS Resource Name | MHHS Programme Phase | Sched Status | RAG | Milestone ID | Text29 | Tier | Guidance | Task Status |
| --- | --- | --- | --- | --- | --- | --- | --- | --- | --- | --- | --- | --- | --- | --- | --- | --- | --- | --- | --- | --- | --- | --- | --- | --- | --- |
| 3114 | 1.10.8.6.6 | **Registration Data** |  | 274d | 2024-09-06 A | 2025-09-24 A |  | 100% | 2024-09-06 | 2025-09-03 | 147d |  | N/A | N/A | Transition | 5.4 | N/A | Migration |  |  |  |  |  |  |  |
| 3115 | 1.10.8.6.6.1 | **Connection Type** |  | 47d | 2024-09-06 A | 2024-11-11 A |  | 100% | 2024-09-06 | 2024-11-11 | 16d |  | N/A | N/A | Transition | 5.4 | N/A | Migration |  |  |  |  |  |  |  |
| 3116 | 1.10.8.6.6.1.1 | Automated Population of Connection Type for Measurement Classes ‘B’, ‘D’, ‘F’ & ‘G’ | milestone | 0d | 2024-10-04 A | 2024-10-04 A | 3099FS+317d | 100% | 2024-10-04 | 2024-10-04 | 0d | start no earlier than 2024-09-13 | LDSO |  | Transition | 5.5 | Matthew Breen | Migration | Complete | COMPLETE | T3-MI-0027 | MCAG (Transition) | T3 |  |  |
| 3117 | 1.10.8.6.6.1.2 | BAU Population of Connection Type for Site Specific LLFCs within Measurement Classes ‘C’ & ‘E’ | milestone | 0d | 2024-10-04 A | 2024-10-04 A | 3099FS+317d | 100% | 2024-10-04 | 2024-10-04 | 0d |  | LDSO |  | Transition | 5.5 | Matthew Breen | Migration | Complete | COMPLETE | T3-MI-0028 | MCAG (Transition) | T3 |  |  |
| 3118 | 1.10.8.6.6.1.3 | Automated Population of Connection Type for Smart Meters within Measurement Class ‘A’ | milestone | 0d | 2024-10-04 A | 2024-10-04 A | 3099FS+317d | 100% | 2024-10-04 | 2024-10-04 | 0d |  | LDSO |  | Transition | 5.5 | Matthew Breen | Migration | Complete | COMPLETE | T3-MI-0029 | MCAG (Transition) | T3 |  |  |
| 3119 | 1.10.8.6.6.1.4 | Population of Connection Type for Traditional and Advanced Meters within Measurement Class ‘A’ |  | 1d | 2024-09-06 A | 2024-09-06 A | 3099FS+296d | 100% | 2024-09-06 | 2024-09-06 | 1d |  | Suppliers |  | Transition | 5.4 | Matthew Breen | Migration | Complete | COMPLETE |  |  |  |  |  |
| 3120 | 1.10.8.6.6.1.5 | Automated Population of Null Connection Type | milestone | 0d | 2024-10-04 A | 2024-10-04 A | 3099FS+317d | 100% | 2024-10-04 | 2024-10-04 | 0d |  | LDSO |  | Transition | 5.5 | Matthew Breen | Migration | Complete | COMPLETE | T3-MI-0030 | MCAG (Transition) | T3 |  |  |
| 3121 | 1.10.8.6.6.1.6 | Full MPAN refresh to ESS |  | 16d | 2024-10-21 A | 2024-11-11 A | 3099FS+327d | 100% | 2024-10-21 | 2024-11-11 | 1d |  | LDSO/EES |  | Transition | 5.4 | Matthew Breen | Migration | Complete | COMPLETE |  |  |  | Actually takes place on 29/9/24 which is a Sunday |  |
| 3122 | 1.10.8.6.6.1.7 | Connection Type Complete | milestone | 0d | 2024-11-11 A | 2024-11-11 A | 3116, 3117, 3118, 3119, 3120, 3121 | 100% | 2024-11-11 | 2024-11-11 | 0d |  | SI Transition |  | Transition | 5.4 | Matthew Breen | Migration | Complete | COMPLETE |  |  |  |  |  |
| 3123 | 1.10.8.6.6.2 | **Domestic Premises Indicator** |  | 14d | 2025-09-05 A | 2025-09-24 A |  | 100% | 2025-08-08 | 2025-09-03 | 17d |  | N/A | N/A | Transition | 5.4 | N/A | Migration |  |  |  |  |  |  |  |
| 3124 | 1.10.8.6.6.2.1 | The DCC to extract Domestic Premises Indicator from the CSS and provide a file to each LDSO and EES. |  | 2d | 2025-09-05 A | 2025-09-08 A |  | 100% | 2025-09-05 | 2025-09-08 | 1d | start no earlier than 2025-09-05 | DCC |  | Transition | 6.22 | Matthew Breen | Migration | Complete | COMPLETE |  | MCAG (Transition) |  | 27/7 - needs to end on date of M10 7/3/25 |  |
| 3125 | 1.10.8.6.6.2.2 | Each LDSO notifies the MHHS Programme SI of any exceptions which have occurred because of the data load and the reason for that exception |  | 1d | 2025-09-24 A | 2025-09-24 A | 3124 | 100% | 2025-09-24 | 2025-09-24 | 1d | start no earlier than 2025-09-24 | LDSO |  | Transition | 6.22 | Matthew Breen | Migration | Complete | COMPLETE |  | MCAG (Transition) |  | 27/7 - needs to end on date of M10 7/3/25 |  |
| 3126 | 1.10.8.6.6.2.3 | Domestic Premises Indicator Complete | milestone | 0d | 2025-09-24 A | 2025-09-24 A | 3125 | 100% | 2025-09-24 | 2025-09-24 | 0d | finish no earlier than 2025-09-24 | SI Transition |  | Transition | 6.22 | Matthew Breen | Migration | Complete | COMPLETE |  | MCAG (Transition) |  |  |  |
| 3127 | 1.10.8.7 | **Connection Type and Meter Type Misalignments** |  | 433d | 2025-03-03 A | 2026-10-28 A |  | 100% | 2025-03-03 | 2026-10-28 | 0d |  | SI Transition |  | Transition | 6.22 | Matthew Breen |  |  |  |  |  |  |  |  |
| 3128 | 1.10.8.7.1 | **Traditional Meters installed on Current Transformers** |  | 433d | 2025-03-03 A | 2026-10-28 A |  | 100% | 2025-03-03 | 2026-10-28 | 0d |  | SI Transition |  | Transition | 6.22 | Matthew Breen |  |  |  |  |  |  |  | -890.67 |
| 3129 | 1.10.8.7.1.1 | Suppliers investigate all MPANs with Traditional Meters installed on a Current Transformer Connection Type |  | 65d | 2025-03-03 A | 2025-05-30 A |  | 100% | 2025-03-03 | 2025-05-30 | 0d | finish no earlier than 2025-05-30 | SI Transition |  | Transition | 6.22 | Matthew Breen |  | Complete | COMPLETE |  | MCAG (Transition) |  |  |  |
| 3130 | 1.10.8.7.1.2 | Suppliers to raise the relevant SDEP cases with LDSOs in pot 3 | milestone | 0d | 2025-05-30 A | 2025-05-30 A |  | 100% | 2025-05-30 | 2025-05-30 | 0d | finish no earlier than 2025-05-30 | SI Transition |  | Transition | 6.22 | Matthew Breen |  | Complete | COMPLETE |  | MCAG (Transition) |  |  |  |
| 3131 | 1.10.8.7.1.3 | Suppliers to have ensured that Meter Operators have sent the necessary D0312s for MPANs in pot 2 |  | 21d | 2025-06-02 A | 2025-06-30 A | 3129 | 100% | 2025-06-02 | 2025-06-30 | 0d | start no earlier than 2025-06-02 | SI Transition |  | Transition | 6.22 | Matthew Breen |  | Complete | COMPLETE |  | MCAG (Transition) |  |  |  |
| 3132 | 1.10.8.7.1.4 | LDSOs will be required to have corrected all of these Connection Types in pot 3 |  | 40d | 2025-06-02 A | 2025-07-25 A | 3130 | 100% | 2025-06-02 | 2025-07-25 | 0d | start no earlier than 2025-06-02 | SI Transition |  | Transition | 6.22 | Matthew Breen |  | Complete | COMPLETE |  | MCAG (Transition) |  |  |  |
| 3133 | 1.10.8.7.1.5 | Suppliers to have completed meter exchanges for those MPANs in pot 1 |  | 368d | 2025-06-02 A | 2026-10-28 A | 3129 | 100% | 2025-06-02 | 2026-10-28 | 0d | start no earlier than 2025-06-02 | SI Transition |  | Transition | 6.48 | Warren Fulton |  | Complete | COMPLETE |  | MCAG (Transition) |  |  |  |
| 3134 | 1.10.8.7.1.6 | Traditional Meters installed on Current Transformers complete | milestone | 0d | 2026-10-28 A | 2026-10-28 A | 3133 | 100% | 2026-10-28 | 2026-10-28 | 0d | finish no earlier than 2026-10-28 | SI Transition |  | Transition | 6.48 | Warren Fulton |  | Complete | COMPLETE |  | MCAG (Transition) |  |  |  |
| 3135 | 1.10.8.7.2 | **CHECK Meters** |  | 66d | 2025-03-03 A | 2025-06-02 A |  | 100% | 2025-05-30 | 2025-06-02 | 0d |  | SI Transition |  | Transition | 6.22 | Matthew Breen |  |  |  |  |  |  |  | -890.67 |
| 3136 | 1.10.8.7.2.1 | Suppliers and their appointed Meter Operator investigate MPANs within their portfolio that have incorrectly populated meters with the Meter Type CHECK within MPRS. Meter Operators are required to send a D0312 to remove the CHECK meter from MPRS. |  | 65d | 2025-03-03 A | 2025-05-30 A |  | 100% | 2025-03-03 | 2025-05-30 | 0d | finish no earlier than 2025-05-30 | SI Transition |  | Transition | 6.22 | Matthew Breen |  | Complete | COMPLETE |  | MCAG (Transition) |  |  |  |
| 3137 | 1.10.8.7.2.2 | Once CHECK meters are either removed from MPRS or the Meter Type is changed to a valid Meter Type, the LDSO should check that the Connection Type assigned to the MPAN is still valid. |  | 65d | 2025-03-03 A | 2025-05-30 A |  | 100% | 2025-03-03 | 2025-05-30 | 0d | finish no earlier than 2025-05-30 | SI Transition |  | Transition | 6.22 | Matthew Breen |  | Complete | COMPLETE |  | MCAG (Transition) |  |  |  |
| 3138 | 1.10.8.7.2.3 | Suppliers confirm to the Programme that they have completed this activity | milestone | 0d | 2025-06-02 A | 2025-06-02 A | 3136 | 100% | 2025-06-02 | 2025-06-02 | 0d | finish no earlier than 2025-06-02 | SI Transition |  | Transition | 6.22 | Matthew Breen |  | Complete | COMPLETE |  | MCAG (Transition) |  |  |  |
| 3139 | 1.10.8.7.2.4 | CHECK Meters complete | milestone | 0d | 2025-06-02 A | 2025-06-02 A | 3137 | 100% | 2025-06-02 | 2025-06-02 | 0d | finish no earlier than 2025-06-02 | SI Transition |  | Transition | 6.22 | Matthew Breen |  | Complete | COMPLETE |  | MCAG (Transition) |  |  |  |

Notes:
- 3133: 21/04/26: This activity is now being monitored by the Migration Exclusion list.
- 3134: 21/04/26: This activity is now being monitored by the Migration Exclusion list.

| ID | WBS | Task | Type | Duration | Start | Finish | Predecessors | Complete | Baseline start | Baseline finish | Baseline duration | Baseline 1 start | Baseline 1 finish | Constraint | Baseline cost | Responsible | Text9 | Task Status | Update Version | MHHS Resource Name | Sched Status | RAG | Text29 | Involved | MHHS Programme Phase | Milestone ID | Tier |
| --- | --- | --- | --- | --- | --- | --- | --- | --- | --- | --- | --- | --- | --- | --- | --- | --- | --- | --- | --- | --- | --- | --- | --- | --- | --- | --- | --- |
| 3140 | 1.10.8.7.3 | **Smart Meter Types installed on CT Connection Types** |  | 90d | 2025-03-21 A | 2025-07-25 A |  | 100% | 2025-03-21 | 2025-07-25 | 0d |  |  |  |  | SI Transition | Transition | -890.67 | 6.22 | Matthew Breen |  |  |  |  |  |  |  |
| 3141 | 1.10.8.7.3.1 | Programme shares data via email with LDSOs and Suppliers on the total number of misalignments to inform work they will have to complete | milestone | 0d | 2025-03-21 A | 2025-03-21 A |  | 100% | 2025-03-21 | 2025-03-21 | 0d |  |  | finish no earlier than 2025-03-21 |  | SI Transition | Transition |  | 6.22 | Matthew Breen | Complete | COMPLETE | MCAG (Transition) |  |  |  |  |
| 3142 | 1.10.8.7.3.2 | LDSOs investigate Connection Type misalignments and correct where appropriate |  | 50d | 2025-03-24 A | 2025-05-30 A | 3141 | 100% | 2025-03-24 | 2025-05-30 | 0d |  |  | finish no earlier than 2025-05-30 |  | SI Transition | Transition |  | 6.22 | Matthew Breen | Complete | COMPLETE | MCAG (Transition) |  |  |  |  |
| 3143 | 1.10.8.7.3.3 | LDSOs raise SDEP queries with Suppliers where they believe there is an issue | milestone | 0d | 2025-05-30 A | 2025-05-30 A | 3142 | 100% | 2025-05-30 | 2025-05-30 | 0d |  |  | finish no earlier than 2025-05-30 |  | SI Transition | Transition |  | 6.22 | Matthew Breen | Complete | COMPLETE | MCAG (Transition) |  |  |  |  |
| 3144 | 1.10.8.7.3.4 | Suppliers resolve all issues |  | 40d | 2025-06-02 A | 2025-07-25 A | 3143 | 100% | 2025-06-02 | 2025-07-25 | 0d |  |  | finish no earlier than 2025-07-25 |  | SI Transition | Transition |  | 6.22 | Matthew Breen | Complete | COMPLETE | MCAG (Transition) |  |  |  |  |
| 3145 | 1.10.8.7.3.5 | Smart Meter Types installed on CT Connection Types complete | milestone | 0d | 2025-07-25 A | 2025-07-25 A | 3144 | 100% | 2025-07-25 | 2025-07-25 | 0d |  |  | finish no earlier than 2025-07-25 |  | SI Transition | Transition |  | 6.22 | Matthew Breen | Complete | COMPLETE | MCAG (Transition) |  |  |  |  |
| 3146 | 1.10.8.7.4 | **Linked Import / Export MPANs** |  | 105d | 2025-03-03 A | 2025-07-25 A |  | 100% | 2025-03-03 | 2025-07-25 | 0d |  |  |  |  | SI Transition | Transition | -890.67 | 6.22 | Matthew Breen |  |  |  |  |  |  |  |
| 3147 | 1.10.8.7.4.1 | LDSOs review and correct linked Import / Export MPANs with Different Connection Types |  | 105d | 2025-03-03 A | 2025-07-25 A |  | 100% | 2025-03-03 | 2025-07-25 | 0d |  |  | finish no earlier than 2025-07-25 |  | SI Transition | Transition |  | 6.22 | Matthew Breen | Complete | COMPLETE | MCAG (Transition) |  |  |  |  |
| 3148 | 1.10.8.7.4.2 | LDSOs, Import and Export Suppliers review and correct linked Import / Export MPANs with meters in the Advanced and Traditional or Smart Meter Groups |  | 105d | 2025-03-03 A | 2025-07-25 A |  | 100% | 2025-03-03 | 2025-07-25 | 0d |  |  | finish no earlier than 2025-07-25 |  | SI Transition | Transition |  | 6.22 | Matthew Breen | Complete | COMPLETE | MCAG (Transition) |  |  |  |  |
| 3149 | 1.10.8.7.4.3 | Linked Import / Export MPANs complete | milestone | 0d | 2025-07-25 A | 2025-07-25 A | 3147, 3148 | 100% | 2025-07-25 | 2025-07-25 | 0d |  |  | finish no earlier than 2025-07-25 |  | SI Transition | Transition |  | 6.22 | Matthew Breen | Complete | COMPLETE | MCAG (Transition) |  |  |  |  |
| 3150 | 1.10.8.7.5 | **Related MPANs** |  | 105d | 2025-03-03 A | 2025-07-25 A |  | 100% | 2025-03-03 | 2025-07-25 | 0d |  |  |  |  | SI Transition | Transition | -890.67 | 6.22 | Matthew Breen |  |  |  |  |  |  |  |
| 3151 | 1.10.8.7.5.1 | LDSOs review and correct related MPANs with different Connection Types |  | 80d | 2025-03-03 A | 2025-06-20 A |  | 100% | 2025-03-03 | 2025-06-20 | 0d |  |  |  |  | SI Transition | Transition |  | 6.22 | Matthew Breen | Complete | COMPLETE | MCAG (Transition) |  |  |  |  |
| 3152 | 1.10.8.7.5.2 | Suppliers unrelate any MPANs required |  | 25d | 2025-06-23 A | 2025-07-25 A | 3151 | 100% | 2025-06-23 | 2025-07-25 | 0d |  |  | finish no earlier than 2025-07-25 |  | SI Transition | Transition |  | 6.22 | Matthew Breen | Complete | COMPLETE | MCAG (Transition) |  |  |  |  |
| 3153 | 1.10.8.7.5.3 | Suppliers should investigate Related MPANs within different meter groups and verify that they are correct or request that their Meter Operators update the Meter Types where they are incorrect |  | 105d | 2025-03-03 A | 2025-07-25 A |  | 100% | 2025-03-03 | 2025-07-25 | 0d |  |  | start no earlier than 2025-03-03 |  | SI Transition | Transition |  | 6.22 | Matthew Breen | Complete | COMPLETE | MCAG (Transition) |  |  |  |  |
| 3154 | 1.10.8.7.5.4 | Related MPANs complete | milestone | 0d | 2025-07-25 A | 2025-07-25 A | 3152, 3153 | 100% | 2025-07-25 | 2025-07-25 | 0d |  |  | finish no earlier than 2025-07-25 |  | SI Transition | Transition |  | 6.22 | Matthew Breen | Complete | COMPLETE | MCAG (Transition) |  |  |  |  |
| 3155 | 1.10.8.8 | **Export / Import MPANs** |  | 392d | 2024-03-22 A | 2025-09-22 A |  | 100% | 2024-03-22 | 2024-10-18 | 151d |  |  |  |  | N/A | Transition |  | 5.4 | N/A |  |  |  | N/A | Migration |  |  |
| 3156 | 1.10.8.8.1 | **Linking of Export / Import MPANS** |  | 151d | 2024-03-22 A | 2024-10-18 A |  | 100% | 2024-03-22 | 2024-10-18 | 151d |  |  |  |  | N/A | Transition |  | 5.4 | N/A |  |  |  | N/A | Migration |  |  |
| 3157 | 1.10.8.8.1.1 | LDSO utilises BAU processing (DB05s) to populate each import/export association |  | 1d | 2024-03-22 A | 2024-03-22 A | 3099FS+176d | 100% | 2024-03-22 | 2024-03-22 | 1d |  |  |  |  | LDSO | Transition |  | 5.4 | Matthew Breen | Complete | COMPLETE |  |  | Migration |  |  |
| 3158 | 1.10.8.8.1.2 | Each LDSO notifies the Registered Supplier of any exceptions |  | 1d | 2024-04-19 A | 2024-04-19 A | 3157FS+19d | 100% | 2024-04-19 | 2024-04-19 | 1d |  |  |  |  | LDSO | Transition |  | 5.4 | Matthew Breen | Complete | COMPLETE |  |  | Migration |  |  |
| 3159 | 1.10.8.8.1.3 | Each Supplier completes investigation and resolution of exceptions |  | 1d | 2024-08-23 A | 2024-08-23 A | 3158FS+89d | 100% | 2024-08-23 | 2024-08-23 | 1d |  |  |  |  | Supplier | Transition |  | 5.4 | Matthew Breen | Complete | COMPLETE |  |  | Migration |  |  |
| 3160 | 1.10.8.8.1.4 | Each LDSO has linked al relevant import/export MPANS | milestone | 0d | 2024-10-18 A | 2024-10-18 A | 3159FS+40d | 100% | 2024-10-18 | 2024-10-18 | 0d |  |  |  |  | LDSO | Transition |  | 5.5 | Matthew Breen | Complete | COMPLETE | MCAG (Transition) |  | Migration | T3-MI-0031 | T3 |
| 3161 | 1.10.8.8.1.5 | Linking of Export / Import MPANS Complete | milestone | 0d | 2024-10-18 A | 2024-10-18 A | 3160 | 100% | 2024-10-18 | 2024-10-18 | 0d |  |  |  |  | SI Transition | Transition |  | 5.4 | Matthew Breen | Complete | COMPLETE |  |  | Migration |  |  |
| 3162 | 1.10.8.8.2 | Pre-migration data cleanse complete | milestone | 0d | 2025-09-22 A | 2025-09-22 A |  | 100% | 2025-09-22 | 2025-09-22 | 0d | 2025-04-04 | 2025-04-04 | finish no earlier than 2025-09-22 |  | SI Migration | Transition |  | 6.33 | Matthew Breen | Complete | COMPLETE | MCAG (Transition) | PP | Migration | T2-MI-0450 | T2 |
| 3163 | 1.10.9 | **Migration Period Planning** |  | 242d | 2023-07-03 A | 2024-06-04 A |  | 100% | 2023-07-03 | 2024-11-26 | 851d | 2023-07-03 | 2026-10-05 |  | -0 | N/A | Transition | M10 | 5.0 | N/A |  |  |  | N/A | Migration |  |  |
| 3164 | 1.10.9.1 | **Migration Implementation Plan (incl. Migration Exit Criteria)** |  | 242d | 2023-07-03 A | 2024-06-04 A |  | 100% | 2023-07-03 | 2024-11-26 | 851d | 2023-07-03 | 2026-10-05 |  | -0 | N/A | Transition |  | 5.0 | N/A |  |  |  | N/A | Migration |  |  |
| 3165 | 1.10.9.1.1 | **Migration Threshold Volumes** |  | 101d | 2023-07-03 A | 2023-11-20 A |  | 100% | 2023-07-03 | 2023-11-20 | 98d | 2023-07-03 | 2023-08-31 |  | -0 | N/A | Transition |  | 5.0 | N/A |  |  |  | N/A | Migration |  |  |
| 3166 | 1.10.9.1.1.1 | Threshold volumes reviewed by MWG |  | 54d | 2023-07-03 A | 2023-09-14 A |  | 100% | 2023-07-03 | 2023-09-14 | 54d | 2023-07-03 | 2023-07-28 |  |  | SI Migration | Transition |  | 5.6 | John Wiggins,Matthew Breen | Complete | COMPLETE |  | PP | Migration |  |  |
| 3167 | 1.10.9.1.1.2 | Artefact review (via TMAG) and updates |  | 47d | 2023-09-15 A | 2023-11-20 A | 3166 | 100% | 2023-09-15 | 2023-11-20 | 44d | 2023-07-31 | 2023-08-31 |  |  | PP | Transition |  | 5.9 | John Wiggins,Matthew Breen | Complete | COMPLETE |  | SI Migration | Migration |  |  |
| 3168 | 1.10.9.1.1.3 | Threshold volumes approved at TMAG | milestone | 0d | 2023-11-20 A | 2023-11-20 A | 3167 | 100% | 2023-11-20 | 2023-11-20 | 0d | 2023-08-31 | 2023-08-31 |  |  | SI Migration | Transition |  | 5.12 | John Wiggins,Matthew Breen | Complete | COMPLETE | SITAG | PP | Migration | T3-MI-0021 | T3 |

| ID | WBS | Task | Type | Duration | Start | Finish | Predecessors | Complete | Remaining | Baseline start | Baseline finish | Baseline duration | Baseline 1 start | Baseline 1 finish | Total slack | Constraint | Baseline cost | Responsible | Involved | Text9 | Update Version | MHHS Resource Name | MHHS Programme Phase | Sched Status | RAG | Milestone ID | Text29 | Tier | Task Status |
| --- | --- | --- | --- | --- | --- | --- | --- | --- | --- | --- | --- | --- | --- | --- | --- | --- | --- | --- | --- | --- | --- | --- | --- | --- | --- | --- | --- | --- | --- |
| 3169 | 1.10.9.1.2 | **Define acceptance criteria for M15** |  | 78d | 2023-09-04 A | 2023-12-20 A |  | 100% |  | 2023-09-04 | 2023-12-20 | 78d | 2023-09-04 | 2023-11-30 |  |  | -0 | N/A | N/A | Transition | 5.0 | N/A | Migration |  |  |  |  |  |  |
| 3170 | 1.10.9.1.2.1 | Review acceptance criteria and reporting requirements with MWG |  | 49d | 2023-09-04 A | 2023-11-09 A |  | 100% |  | 2023-09-04 | 2023-11-09 | 40d | 2023-09-04 | 2023-10-27 |  | start no earlier than 2023-09-04 |  | SI Migration |  | Transition | 5.0 | John Wiggins,Matthew Breen | Migration | Complete | COMPLETE |  |  |  |  |
| 3171 | 1.10.9.1.2.2 | Artefact review (via TMAG) and updates |  | 29d | 2023-11-10 A | 2023-12-20 A | 3170 | 100% |  | 2023-11-10 | 2023-12-20 | 29d | 2023-10-30 | 2023-11-30 |  | start no earlier than 2023-10-30 |  | PP | SI Migration | Transition | 5.0 | John Wiggins,Matthew Breen | Migration | Complete | COMPLETE |  |  |  |  |
| 3172 | 1.10.9.1.2.3 | Acceptance criteria for M15 agreed at TMAG | milestone | 0d | 2023-12-20 A | 2023-12-20 A | 3171 | 100% |  | 2023-12-20 | 2023-12-20 | 0d | 2023-11-30 | 2023-11-30 |  | finish no earlier than 2023-11-30 |  | SI Migration |  | Transition | 5.14 | John Wiggins,Matthew Breen | Migration | Complete | COMPLETE | T3-MI-0022 | SITAG | T3 |  |
| 3173 | 1.10.9.1.3 | **M10/M11 cut-over plan** |  | 119d | 2023-12-21 A | 2024-06-04 A |  | 100% |  | 2023-12-21 | 2024-06-04 | 119d | 2024-01-01 | 2024-05-31 |  |  | -0 | N/A | N/A | Transition | 5.16 | N/A | Migration |  |  |  |  |  |  |
| 3174 | 1.10.9.1.3.1 | Draft Document |  | 84d | 2023-12-21 A | 2024-04-16 A | 3172 | 100% |  | 2023-12-21 | 2024-04-16 | 84d |  |  |  |  |  | SI Transition | SI Transition,PP,SRO | Transition | 5.16 | Matthew Breen | Migration | Complete | COMPLETE |  |  |  |  |
| 3175 | 1.10.9.1.3.2 | Share Document with SRO |  | 1d | 2024-04-17 A | 2024-04-17 A | 3174 | 100% |  | 2024-04-17 | 2024-04-17 | 1d |  |  |  |  |  | SI Transition | SI Transition,PP,SRO | Transition | 5.16 | Matthew Breen | Migration | Complete | COMPLETE |  |  |  |  |
| 3176 | 1.10.9.1.3.3 | Industry Consultation |  | 11d | 2024-04-23 A | 2024-05-07 A | 3175FS+3d | 100% |  | 2024-04-23 | 2024-05-07 | 11d |  |  |  |  |  | SI Transition | SI Transition,PP,SRO | Transition | 5.16 | Matthew Breen | Migration | Complete | COMPLETE |  |  |  |  |
| 3177 | 1.10.9.1.3.4 | Assurance Meeting |  | 1d | 2024-05-21 A | 2024-05-21 A | 3176FS+9d | 100% |  | 2024-05-21 | 2024-05-21 | 1d |  |  |  |  |  | SI Transition | SI Transition,PP,SRO | Transition | 5.16 | Matthew Breen | Migration | Complete | COMPLETE |  |  |  |  |
| 3178 | 1.10.9.1.3.5 | MCAG Approval of M10/M11 Cut-over Plan | milestone | 0d | 2024-06-04 A | 2024-06-04 A | 3177FS+10d | 100% |  | 2024-06-04 | 2024-06-04 | 0d | 2024-05-31 | 2024-05-31 |  |  |  | SI Transition | SI Transition,PP,SRO | Transition | 5.26 | Matthew Breen | Migration | Complete | COMPLETE | T3-MI-0023 | MCAG | T3 |  |
| 3179 | 1.10.10 | **Preparation for Cutover to Live** |  | 774d? | 2024-06-03 A | 2027-05-20 |  | 78% | 168.76d? | 2024-06-28 | 2025-10-22 | 201d | 2025-02-07 | 2025-04-04 | 155d |  | -0 | N/A | N/A | Transition | 6.11 | N/A | Migration |  |  |  |  |  |  |
| 3180 | 1.10.10.1 | **Central Systems Prepare for Cutover to Live** |  | 363d? | 2024-06-03 A | 2025-10-22 A |  | 100% |  | 2024-06-28 | 2025-09-26 | 186d | 2025-02-07 | 2025-03-07 |  |  | -0 | N/A | N/A | Transition | 6.11 | N/A | Migration |  |  |  |  |  | M13 |
| 3181 | 1.10.10.1.1 | DCC (Functionality available June 2024) | milestone | 0d | 2024-06-28 A | 2024-06-28 A |  | 100% |  | 2024-06-28 | 2024-06-28 | 0d |  |  |  | start no earlier than 2024-06-28 |  | DCC |  | Transition | 6.11 | Matthew Breen |  | Complete | COMPLETE |  |  |  |  |
| 3182 | 1.10.10.1.2 | **Development of Comms Approach and Declaration Guidance** |  | 79d | 2025-04-28 A | 2025-08-14 A |  | 100% |  | 2025-04-28 | 2025-08-14 | 79d |  |  |  |  |  | N/A | N/A | Transition | 6.11 | N/A |  |  |  |  |  |  | 95.33 |
| 3183 | 1.10.10.1.2.1 | Draft Cutover Comms Approach |  | 59d | 2025-04-28 A | 2025-07-17 A |  | 100% |  | 2025-04-28 | 2025-07-17 | 59d |  |  |  | start no earlier than 2025-04-28 |  | SI Transition | SI Transition | Transition | 6.11 | Matthew Breen |  | Complete | COMPLETE |  |  |  |  |
| 3184 | 1.10.10.1.2.2 | Draft Cutover Comms Approach shared | milestone | 0d | 2025-07-17 A | 2025-07-17 A | 3183 | 100% |  | 2025-07-17 | 2025-07-17 | 0d |  |  |  |  |  | SI Transition | SI Transition | Transition | 6.11 | Matthew Breen |  | Complete | COMPLETE |  |  |  |  |
| 3185 | 1.10.10.1.2.3 | Finalised Cutover Comms Approach shared | milestone | 0d | 2025-08-14 A | 2025-08-14 A | 3184FS+20d | 100% |  | 2025-08-14 | 2025-08-14 | 0d |  |  |  |  |  | SI Transition | SI Transition | Transition | 6.11 | Matthew Breen |  | Complete | COMPLETE |  |  |  |  |
| 3186 | 1.10.10.1.3 | **Development of Cutover Plan requirements with Participants** |  | 139d | 2025-04-11 A | 2025-10-22 A |  | 100% |  | 2025-03-03 | 2025-08-06 | 59d |  |  |  |  |  | N/A | N/A | Transition | 6.11 | N/A |  |  |  |  |  |  | -605.67 |
| 3187 | 1.10.10.1.3.1 | Development of Central Parties Cutover Plans |  | 26d | 2025-04-11 A | 2025-05-16 A |  | 100% |  | 2025-04-11 | 2025-05-16 | 59d |  |  |  | start no earlier than 2025-04-11 |  | SI Transition | SI Transition | Transition | 6.23 | Matthew Breen |  | Complete | COMPLETE |  |  |  |  |
| 3188 | 1.10.10.1.3.2 | Development of Programme Participant Cutover Plans |  | 66d | 2025-04-11 A | 2025-07-11 A | 3187SS | 100% |  | 2025-04-11 | 2025-07-11 | 0d |  |  |  | finish no earlier than 2025-07-11 |  | SI Transition | SI Transition | Transition | 6.28 | Matthew Breen |  | Complete | COMPLETE |  |  |  |  |
| 3189 | 1.10.10.1.3.3 | Central Party Cutover Plan Assurance |  | 45d | 2025-04-14 A | 2025-06-13 A | 3187FF | 100% |  | 2025-04-14 | 2025-06-13 | 0d |  |  |  | start no earlier than 2025-04-14 |  | SI Transition |  | Transition | 6.23 | Matthew Breen |  | Complete | COMPLETE |  |  |  |  |
| 3190 | 1.10.10.1.3.4 | Consolidated MHHS Cutover Plan Developed |  | 30d | 2025-05-19 A | 2025-06-27 A | 3187 | 100% |  | 2025-05-19 | 2025-06-27 | 0d |  |  |  | start no earlier than 2025-05-19 |  | SI Transition |  | Transition | 6.23 | Matthew Breen |  | Complete | COMPLETE |  |  |  |  |
| 3191 | 1.10.10.1.3.5 | LDSO Cutover Plan Assurance |  | 15d | 2025-07-14 A | 2025-08-01 A | 3188 | 100% |  | 2025-07-14 | 2025-08-01 | 0d |  |  |  | start no earlier than 2025-06-30 |  | SI Transition |  | Transition | 6.28 | Matthew Breen |  | Complete | COMPLETE |  |  |  |  |
| 3192 | 1.10.10.1.3.6 | SIT Supplier and SIT Agent Cutover Plan Assurance |  | 30d | 2025-07-14 A | 2025-08-22 A | 3188 | 100% |  | 2025-06-30 | 2025-08-22 | 0d |  |  |  | start no earlier than 2025-06-30 |  | SI Transition |  | Transition | 6.28 | Matthew Breen |  | Complete | COMPLETE |  |  |  |  |
| 3193 | 1.10.10.1.3.7 | Monitor Participant Cutover Plan reporting |  | 56d | 2025-08-06 A | 2025-10-22 A |  | 100% |  | 2025-08-06 | 2025-10-22 | 0d |  |  |  | start no earlier than 2025-08-06 |  | SI Transition |  |  | 6.34 | Matthew Breen |  | Complete | COMPLETE |  |  |  |  |

| ID | WBS | Task | Type | Duration | Start | Finish | Predecessors | Complete | Actual start | Actual finish | Baseline start | Baseline finish | Baseline duration | Constraint | Baseline cost | Text9 | Task Status | Update Version | MHHS Resource Name | Responsible | Sched Status | RAG | Involved | Milestone ID | Text29 | Tier |
| --- | --- | --- | --- | --- | --- | --- | --- | --- | --- | --- | --- | --- | --- | --- | --- | --- | --- | --- | --- | --- | --- | --- | --- | --- | --- | --- |
| 3194 | 1.10.10.1.4 | **M10/M11 Cutover Activities** |  | 120d? | 2025-04-14 | 2025-09-26 |  | 100% | 2024-06-03 | 2025-10-22 | 2025-04-14 | 2025-09-26 | 15d |  | -0 | Transition | -608.67 | 6.11 | Matthew Breen |  |  |  |  |  |  |  |
| 3195 | 1.10.10.1.4.1 | Load Shaping Service (LSS) |  | 10d | 2025-07-14 A | 2025-07-25 A |  | 100% |  |  | 2025-07-14 | 2025-07-25 | 0d | start no earlier than 2025-07-14 |  | Transition |  | 6.30 | Matthew Breen | Elexon and Elexon Service Providers | Complete | COMPLETE |  |  |  |  |
| 3196 | 1.10.10.1.4.2 | Volume Allocation Service (VAS) |  | 10d | 2025-07-14 A | 2025-07-25 A |  | 100% |  |  | 2025-07-14 | 2025-07-25 | 0d | start no earlier than 2025-07-14 |  | Transition |  | 6.30 | Matthew Breen | Elexon and Elexon Service Providers | Complete | COMPLETE |  |  |  |  |
| 3197 | 1.10.10.1.4.3 | Market-wide Data Service (MDS) |  | 10d | 2025-07-14 A | 2025-07-25 A |  | 100% |  |  | 2025-07-14 | 2025-07-25 | 0d | start no earlier than 2025-07-14 |  | Transition |  | 6.30 | Matthew Breen | Elexon and Elexon Service Providers | Complete | COMPLETE |  |  |  |  |
| 3198 | 1.10.10.1.4.4 | Deployment of Industry Standing Data (ISD) Work Package (WP3) source code |  | 10d | 2025-07-14 A | 2025-07-25 A |  | 100% |  |  | 2025-07-14 | 2025-07-25 | 0d | start no earlier than 2025-07-14 |  | Transition |  | 6.30 | Matthew Breen | Elexon and Elexon Service Providers | Complete | COMPLETE |  |  |  |  |
| 3199 | 1.10.10.1.4.5 | ISD Service Activation | milestone | 0d | 2025-08-05 A | 2025-08-05 A | 3198 | 100% |  |  | 2025-08-05 | 2025-08-05 | 0d | start no earlier than 2025-08-05 |  | Transition |  | 6.30 | Matthew Breen | Elexon and Elexon Service Providers | Complete | COMPLETE |  |  |  |  |
| 3200 | 1.10.10.1.4.6 | ISD Data Migration (PR-3) |  | 14d | 2025-08-05 A | 2025-08-22 A | 3199 | 100% |  |  | 2025-08-05 | 2025-08-12 | 0d | start no earlier than 2025-08-05 |  | Transition |  | 6.30 | Matthew Breen | Elexon and Elexon Service Providers | Complete | COMPLETE |  |  |  |  |
| 3201 | 1.10.10.1.4.7 | ISD Data Migration (PR-4) |  | 11d | 2025-08-15 A | 2025-08-29 A |  | 100% |  |  | 2025-08-15 | 2025-08-22 | 0d | start no earlier than 2025-08-15 |  | Transition |  | 6.30 | Matthew Breen | Elexon and Elexon Service Providers | Complete | COMPLETE |  |  |  |  |
| 3202 | 1.10.10.1.4.8 | ISD Catalogue Published | milestone | 0d | 2025-09-11 A | 2025-09-11 A | 3201 | 100% |  |  | 2025-09-11 | 2025-09-11 | 0d | start no earlier than 2025-09-11 |  | Transition |  | 6.30 | Matthew Breen | Elexon and Elexon Service Providers | Complete | COMPLETE |  |  |  |  |
| 3203 | 1.10.10.1.4.9 | DIP Production Environment stood up | milestone | 0d | 2025-07-18 A | 2025-07-18 A |  | 100% |  |  | 2025-07-18 | 2025-07-18 | 0d | start no earlier than 2025-07-18 |  | Transition |  | 6.30 | Matthew Breen | DIP Manager, Elexon | Complete | COMPLETE |  |  |  |  |
| 3204 | 1.10.10.1.4.10 | Production DIP Portal (DIP Deployment) |  | 2d | 2025-08-01 A | 2025-08-04 A |  | 100% |  |  | 2025-08-01 | 2025-08-04 | 0d | start no earlier than 2025-08-01 |  | Transition |  | 6.30 | Matthew Breen | Elexon,DIP Manager | Complete | COMPLETE |  |  |  |  |
| 3205 | 1.10.10.1.4.11 | Production Certificates (DIP Deployment) |  | 2d | 2025-08-01 A | 2025-08-04 A |  | 100% |  |  | 2025-08-01 | 2025-08-04 | 0d | start no earlier than 2025-08-01 |  | Transition |  | 6.30 | Matthew Breen | Elexon,DIP Manager | Complete | COMPLETE |  |  |  |  |
| 3206 | 1.10.10.1.4.12 | Service Management Go-Live | milestone | 0d | 2025-07-31 A | 2025-07-31 A |  | 100% |  |  | 2025-07-31 | 2025-07-31 | 0d | start no earlier than 2025-07-31 |  | Transition |  | 6.30 | Matthew Breen | Elexon | Complete | COMPLETE |  |  |  |  |
| 3207 | 1.10.10.1.4.13 | DIP Onboarding |  | 15d | 2025-08-04 A | 2025-08-22 A |  | 100% |  |  | 2025-08-04 | 2025-08-22 | 0d | start no earlier than 2025-08-04 |  | Transition |  | 6.30 | Matthew Breen | LDSOs, DIP Manager | Complete | COMPLETE |  |  |  |  |
| 3208 | 1.10.10.1.4.14 | Deployment of MPRS 9 |  | 19d | 2025-08-06 A | 2025-09-01 A |  | 100% |  |  | 2025-08-06 | 2025-09-12 | 0d | start no earlier than 2025-08-06 |  | Transition |  | 6.30 | Matthew Breen | LDSOs, St Clements | Complete | COMPLETE |  |  |  |  |
| 3209 | 1.10.10.1.4.15 | ISD Population | milestone | 0d | 2025-09-11 A | 2025-09-11 A |  | 100% |  |  | 2025-09-11 | 2025-09-11 | 0d | start no earlier than 2025-09-11 |  | Transition |  | 6.30 | Matthew Breen | LDSOs | Complete | COMPLETE |  |  |  |  |
| 3210 | 1.10.10.1.4.16 | Population of Market Segment (95%) |  | 28d | 2025-08-06 A | 2025-09-12 A | 3208SS | 100% |  |  | 2025-08-06 | 2025-09-12 | 0d | start no earlier than 2025-08-06 |  | Transition |  | 6.30 | Matthew Breen | LDSOs, St Clements | Complete | COMPLETE |  |  |  |  |
| 3211 | 1.10.10.1.4.17 | Population of Market Segment (100%) |  | 7d | 2025-09-12 A | 2025-09-22 A | 3210FS-1d | 100% |  |  | 2025-09-12 | 2025-09-22 | 0d | start no earlier than 2025-09-12 |  | Transition |  | 6.30 | Matthew Breen | LDSOs, St Clements | Complete | COMPLETE |  |  |  |  |
| 3212 | 1.10.10.1.4.18 | Population of Domestic Premises Indicator (Weekend start) |  | 2d | 2025-09-05 A | 2025-09-08 A |  | 100% |  |  | 2025-09-08 | 2025-09-09 | 0d | start no earlier than 2025-09-05 |  | Transition |  | 6.30 | Matthew Breen | PP,DCC,SI Transition | Complete | COMPLETE |  |  |  |  |
| 3213 | 1.10.10.1.4.19 | Completion of the pre-M10 MHHS Data Cleanse | milestone | 0d | 2025-09-22 A | 2025-09-22 A |  | 100% |  |  | 2025-09-22 | 2025-09-22 | 0d | finish no earlier than 2025-09-22 |  | Transition |  | 6.30 | Matthew Breen | PP,DCC,SI Transition | Complete | COMPLETE |  |  |  |  |
| 3214 | 1.10.10.1.4.20 | Early Life Support Implemented | milestone | 0d | 2025-09-19 A | 2025-09-19 A |  | 100% |  |  | 2025-09-19 | 2025-09-19 | 0d | start no earlier than 2025-09-19 |  | Transition |  | 6.30 | Matthew Breen | SI Transition,Elexon,Central Services | Complete | COMPLETE |  |  |  |  |
| 3215 | 1.10.10.1.4.21 | MCC Tested and Ready to Operate |  | 31d | 2025-08-08 A | 2025-09-19 A |  | 100% |  |  | 2025-08-08 | 2025-09-19 | 0d | start no earlier than 2025-08-08 |  | Transition |  | 6.30 | Matthew Breen | SI Migration | Complete | COMPLETE |  |  |  |  |
| 3216 | 1.10.10.1.4.22 | Market-wide Participant MHHS Supporting Functionality Ready - Confirmation from Code Bodies | milestone | 0d | 2025-09-15 A | 2025-09-15 A |  | 100% |  |  | 2025-09-15 | 2025-09-15 | 0d | start no earlier than 2025-09-15 |  | Transition |  | 6.30 | Matthew Breen | Code Bodies | Complete | COMPLETE |  |  |  |  |
| 3217 | 1.10.10.1.4.23 | Market-wide Participant MHHS Supporting Functionality Ready | milestone | 0d | 2025-09-22 A | 2025-09-22 A |  | 100% |  |  | 2025-09-22 | 2025-09-22 | 0d | start no earlier than 2025-09-22 |  | Transition |  | 6.30 | Matthew Breen | PP | Complete | COMPLETE |  |  |  |  |
| 3218 | 1.10.10.1.4.24 | Pre-M10 Service Activation - LDSOs |  | 6d | 2025-09-11 A | 2025-09-18 A |  | 100% |  |  | 2025-09-11 | 2025-09-18 | 0d | start no earlier than 2025-09-11 |  | Transition |  | 6.30 | Matthew Breen | DIP Manager, Service Activation Team, LDSOs | Complete | COMPLETE |  |  |  |  |
| 3219 | 1.10.10.1.4.25 | Pre-M10 Service Activation - Suppliers and Agents |  | 25d | 2025-09-11 A | 2025-10-15 A |  | 100% |  |  | 2025-09-11 | 2025-10-15 | 0d | start no earlier than 2025-09-11 |  | Transition |  | 6.34 | Matthew Breen | DIP Manager, Service Activation Team, Suppliers, Agents | Complete | COMPLETE |  |  |  |  |
| 3220 | 1.10.10.1.4.26 | Load Shaping Service (LSS) |  | 2d | 2025-09-19 A | 2025-09-22 A | 3195 | 100% |  |  | 2025-09-19 | 2025-09-22 | 0d | start no earlier than 2025-09-19 |  | Transition |  | 6.30 | Matthew Breen | Elexon and Elexon Service Providers | Complete | COMPLETE |  |  |  |  |
| 3221 | 1.10.10.1.4.27 | Volume Allocation Service (VAS) |  | 2d | 2025-09-19 A | 2025-09-22 A | 3196 | 100% |  |  | 2025-09-19 | 2025-09-22 | 0d | start no earlier than 2025-09-19 |  | Transition |  | 6.30 | Matthew Breen | Elexon and Elexon Service Providers | Complete | COMPLETE |  |  |  |  |
| 3222 | 1.10.10.1.4.28 | Market-wide Data Service (MDS) |  | 2d | 2025-09-19 A | 2025-09-22 A | 3197 | 100% |  |  | 2025-09-19 | 2025-09-22 | 0d | start no earlier than 2025-09-19 |  | Transition |  | 6.30 | Matthew Breen | Elexon and Elexon Service Providers | Complete | COMPLETE |  |  |  |  |
| 3223 | 1.10.10.1.4.29 | DTS |  | 2d | 2025-09-19 A | 2025-09-22 A |  | 100% |  |  | 2025-09-19 | 2025-09-22 | 0d | start no earlier than 2025-09-19 |  | Transition |  | 6.30 | Matthew Breen | Electralink, RECCo | Complete | COMPLETE |  |  |  |  |
| 3224 | 1.10.10.1.4.30 | EES |  | 2d | 2025-09-19 A | 2025-09-22 A |  | 100% |  |  | 2025-09-19 | 2025-09-22 | 0d | start no earlier than 2025-09-19 |  | Transition |  | 6.30 | Matthew Breen | RECCo | Complete | COMPLETE |  |  |  |  |
| 3225 | 1.10.10.1.4.31 | DCC |  | 20d | 2024-06-03 A | 2024-06-28 A |  | 100% |  |  | 2024-06-03 | 2024-06-28 | 0d | start no earlier than 2024-06-01 |  | Transition |  | 6.30 | Matthew Breen | DCC | Complete | COMPLETE |  |  |  |  |
| 3226 | 1.10.10.1.4.32 | MPRS – Registration Services, UMSO Role, LDSO Role |  | 2d | 2025-09-19 A | 2025-09-22 A |  | 100% |  |  | 2025-09-19 | 2025-09-22 | 0d | start no earlier than 2025-09-19 |  | Transition |  | 6.30 | Matthew Breen | LDSOs, St Clements | Complete | COMPLETE |  |  |  |  |
| 3227 | 1.10.10.1.4.33 | Qualification Pathway 4 Service Activation |  | 6d | 2025-09-26 A | 2025-10-03 A |  | 100% |  |  | 2025-09-26 | 2025-10-03 | 0d | start no earlier than 2025-09-26 |  | Transition |  | 6.30 | Matthew Breen | DIP Manager, Service Activation Team, Suppliers, Agents | Complete | COMPLETE |  |  |  |  |
| 3228 | 1.10.10.1.4.34 | Qualification Pathway 5 Service Activation |  | 5d | 2025-10-16 A | 2025-10-22 A |  | 100% |  |  | 2025-10-16 | 2025-10-22 | 0d | start no earlier than 2025-10-16 |  | Transition |  | 6.30 | Matthew Breen | DIP Manager, Service Activation Team, Suppliers, Agents | Complete | COMPLETE |  |  |  |  |
| 3229 | 1.8.4.1.4 | Central Systems live and Codes designated at 00:00 | milestone | 0d | 2025-09-22 A | 2025-09-22 A | 3181FS+1d | 100% |  |  | 2025-09-22 | 2025-09-22 | 0d | finish no earlier than 2025-09-22 |  | Transition |  | 6.11 | Matthew Breen | SI Transition | Complete | COMPLETE | SI Transition | T3-MI-0034 | MCAG (Transition) | T3 |
| 3230 | 1.10.10.1.4.36 | IF-047 sent at 9am on Monday 22nd September by Elexon via the DIP to all LDSOs and EES | milestone | 0d | 2025-09-22 A | 2025-09-22 A |  | 100% |  |  | 2025-09-22 | 2025-09-22 | 0d | start no earlier than 2025-09-22 |  | Transition |  | 6.30 | Matthew Breen | Elexon | Complete | COMPLETE |  |  |  |  |
| 3231 | 1.10.10.1.4.37 | All LDSOs and EES to load ISD files via the URL published within the IF-047 via the Elexon data store (note, this should contain the same ISD file as uploaded to the Elexon portal following 11th September, therefore it may not need to be applied by each p | milestone | 0d | 2025-09-22 A | 2025-09-22 A |  | 100% |  |  | 2025-09-22 | 2025-09-22 | 0d | start no earlier than 2025-09-22 |  | Transition |  | 6.30 | Matthew Breen | LDSOs, EES | Complete | COMPLETE |  |  |  |  |
| 3232 | 1.10.10.1.4.38 | Following successful loading of ISD data LDSOs can process New Connections via their DB01 interface to MPRS | milestone | 0d | 2025-09-22 A | 2025-09-22 A | 3231 | 100% |  |  | 2025-09-22 | 2025-09-22 | 0d | start no earlier than 2025-09-22 |  | Transition |  | 6.30 | Matthew Breen | LDSOs | Complete | COMPLETE |  |  |  |  |
| 3233 | 1.10.10.1.4.39 | Each LDSO will track successful sending of the IF-050 message to the DIP | milestone | 0d | 2025-09-22 A | 2025-09-22 A | 3232 | 100% |  |  | 2025-09-22 | 2025-09-22 | 0d | start no earlier than 2025-09-22 |  | Transition |  | 6.30 | Matthew Breen | LDSOs | Complete | COMPLETE |  |  |  |  |
| 3234 | 1.10.10.1.4.40 | EES will track successful receipt and processing of the IF-050 | milestone | 0d | 2025-09-22 A | 2025-09-22 A | 3233 | 100% |  |  | 2025-09-22 | 2025-09-22 | 0d | start no earlier than 2025-09-22 |  | Transition |  | 6.30 | Matthew Breen | EES | Complete | COMPLETE |  |  |  |  |
| 3235 | 1.10.10.1.4.41 | IF-047 sent at 9am on Wednesday 22nd October by Elexon via the DIP | milestone | 0d | 2025-10-22 A | 2025-10-22 A |  | 100% |  |  | 2025-10-22 | 2025-10-22 | 0d | start no earlier than 2025-10-22 |  | Transition |  | 6.30 | Matthew Breen | Elexon | Complete | COMPLETE |  |  |  |  |

Notes:
- 3229: Guidance: 25/7/24: New Milestone approved at MCAG on 25/7/24. It was initially approved at MCAG on 4/6 but didn't follow the usual process so addded to July MCAG for noting

| ID | WBS | Task | Type | Duration | Start | Finish | Complete | Baseline start | Baseline finish | Baseline duration | Constraint | Involved | Text9 | Task Status | Update Version | MHHS Resource Name | Sched Status | RAG | Milestone ID |
| --- | --- | --- | --- | --- | --- | --- | --- | --- | --- | --- | --- | --- | --- | --- | --- | --- | --- | --- | --- |
| 3236 | 1.10.10.2 | **Cutover Governance M10** |  | 23d | 2025-08-22 A | 2025-09-24 A | 100% | 2025-07-30 | 2025-09-24 | 27d |  | N/A | Transition | -595.67 | 6.11 | N/A |  |  |  |
| 3237 | 1.10.10.2.1 | Confirmation from all LDSOs that DIP onboarding has taken place | milestone | 0d | 2025-08-22 A | 2025-08-22 A | 100% | 2025-08-22 | 2025-08-22 | 0d | start no earlier than 2025-08-22 |  | Transition |  | 6.30 | Matthew Breen | Complete | COMPLETE |  |
| 3238 | 1.10.10.2.2 | Confirmation that all LDSOs have deployed MPRS 9 to production | milestone | 0d | 2025-09-01 A | 2025-09-01 A | 100% | 2025-09-01 | 2025-09-01 | 0d | start no earlier than 2025-09-01 |  | Transition |  | 6.30 | Matthew Breen | Complete | COMPLETE |  |
| 3239 | 1.10.10.2.3 | Confirmation that population of Domestic Premises Indicator is complete | milestone | 0d | 2025-09-08 A | 2025-09-08 A | 100% | 2025-09-08 | 2025-09-08 | 0d | start no earlier than 2025-09-08 |  | Transition |  | 6.30 | Matthew Breen | Complete | COMPLETE |  |
| 3240 | 1.10.10.2.4 | Confirmation that Market Segment has been populated for 95% of LDSO portfolios | milestone | 0d | 2025-09-12 A | 2025-09-12 A | 100% | 2025-09-12 | 2025-09-12 | 0d | start no earlier than 2025-09-12 |  | Transition |  | 6.30 | Matthew Breen | Complete | COMPLETE |  |
| 3241 | 1.10.10.2.5 | Confirmation of all pre-M10 parties | milestone | 0d | 2025-09-15 A | 2025-09-15 A | 100% | 2025-09-15 | 2025-09-15 | 0d | start no earlier than 2025-09-15 |  | Transition |  | 6.30 | Matthew Breen | Complete | COMPLETE |  |
| 3242 | 1.10.10.2.6 | Confirmation that all LDSOs have populated the ISD | milestone | 0d | 2025-09-15 A | 2025-09-15 A | 100% | 2025-09-15 | 2025-09-15 | 0d | start no earlier than 2025-09-15 |  | Transition |  | 6.30 | Matthew Breen | Complete | COMPLETE |  |
| 3243 | 1.10.10.2.7 | Declaration from all Central Services and LDSOs that they are in a position to move forwards | milestone | 0d | 2025-09-15 A | 2025-09-15 A | 100% | 2025-09-15 | 2025-09-15 | 0d | start no earlier than 2025-09-15 |  | Transition |  | 6.30 | Matthew Breen | Complete | COMPLETE |  |
| 3244 | 1.10.10.2.8 | Market-wide Participant MHHS Migration Supporting Functionality is ready to be deployed | milestone | 0d | 2025-09-15 A | 2025-09-15 A | 100% | 2025-09-15 | 2025-09-15 | 0d | start no earlier than 2025-09-15 |  | Transition |  | 6.30 | Matthew Breen | Complete | COMPLETE |  |
| 3245 | 1.10.10.2.9 | Recommendation from TORWG that the Programme should enter M10 | milestone | 0d | 2025-09-17 A | 2025-09-17 A | 100% | 2025-09-17 | 2025-09-17 | 0d | start no earlier than 2025-09-17 |  | Transition |  | 6.30 | Matthew Breen | Complete | COMPLETE |  |
| 3246 | 1.10.10.2.10 | Production Service Activation Activities have taken place for all pre-M10 qualified parties | milestone | 0d | 2025-09-18 A | 2025-09-18 A | 100% | 2025-09-18 | 2025-09-18 | 0d | start no earlier than 2025-09-18 |  | Transition |  | 6.30 | Matthew Breen | Complete | COMPLETE |  |
| 3247 | 1.10.10.2.11 | Early Life Support model is in place | milestone | 0d | 2025-09-19 A | 2025-09-19 A | 100% | 2025-09-19 | 2025-09-19 | 0d | start no earlier than 2025-09-19 |  | Transition |  | 6.30 | Matthew Breen | Complete | COMPLETE |  |
| 3248 | 1.10.10.2.12 | MCC Operational | milestone | 0d | 2025-09-19 A | 2025-09-19 A | 100% | 2025-09-19 | 2025-09-19 | 0d | start no earlier than 2025-09-19 |  | Transition |  | 6.30 | Matthew Breen | Complete | COMPLETE |  |
| 3249 | 1.10.10.2.13 | MCAG (Confirm that the Programme can Enter M10) | milestone | 0d | 2025-09-19 A | 2025-09-19 A | 100% | 2025-09-19 | 2025-09-19 | 0d | start no earlier than 2025-09-19 |  | Transition |  | 6.30 | Matthew Breen | Complete | COMPLETE | T3-MI-0035 |
| 3250 | 1.10.10.2.14 | Self-Declaration from all Central Services and LDSOs that Cutover activities have been successfully carried out | milestone | 0d | 2025-09-22 A | 2025-09-22 A | 100% | 2025-09-22 | 2025-09-22 | 0d | start no earlier than 2025-09-22 |  | Transition |  | 6.30 | Matthew Breen | Complete | COMPLETE |  |
| 3251 | 1.10.10.2.15 | Confirmation that DIP and ECS have been deployed, Service management is active, ISD has been populated | milestone | 0d | 2025-09-22 A | 2025-09-22 A | 100% | 2025-09-22 | 2025-09-22 | 0d | start no earlier than 2025-09-22 |  | Transition |  | 6.30 | Matthew Breen | Complete | COMPLETE |  |
| 3252 | 1.10.10.2.16 | Confirmation that Market Segment has been populated for 100% of LDSO portfolios | milestone | 0d | 2025-09-22 A | 2025-09-22 A | 100% | 2025-09-22 | 2025-09-22 | 0d | start no earlier than 2025-09-22 |  | Transition |  | 6.30 | Matthew Breen | Complete | COMPLETE |  |
| 3253 | 1.10.10.2.17 | IF-047 message has been sent | milestone | 0d | 2025-09-22 A | 2025-09-22 A | 100% | 2025-09-22 | 2025-09-22 | 0d | start no earlier than 2025-09-22 |  | Transition |  | 6.30 | Matthew Breen | Complete | COMPLETE |  |
| 3254 | 1.10.10.2.18 | LDSOs have received the IF-047 message | milestone | 0d | 2025-09-22 A | 2025-09-22 A | 100% | 2025-09-22 | 2025-09-22 | 0d | start no earlier than 2025-09-22 |  | Transition |  | 6.30 | Matthew Breen | Complete | COMPLETE |  |
| 3255 | 1.10.10.2.19 | EES has received the IF-047 message and loaded the ISD file | milestone | 0d | 2025-09-22 A | 2025-09-22 A | 100% | 2025-09-22 | 2025-09-22 | 0d | start no earlier than 2025-09-22 |  | Transition |  | 6.30 | Matthew Breen | Complete | COMPLETE |  |
| 3256 | 1.10.10.2.20 | Confirmation that the IF-050 has been sent and the number sent | milestone | 0d | 2025-09-22 A | 2025-09-22 A | 100% | 2025-09-22 | 2025-09-22 | 0d | start no earlier than 2025-09-22 |  | Transition |  | 6.30 | Matthew Breen | Complete | COMPLETE |  |
| 3257 | 1.10.10.2.21 | Confirmation of the number of IF-050s | milestone | 0d | 2025-09-22 A | 2025-09-22 A | 100% | 2025-09-22 | 2025-09-22 | 0d | start no earlier than 2025-09-22 |  | Transition |  | 6.30 | Matthew Breen | Complete | COMPLETE |  |
| 3258 | 1.10.10.2.22 | Recommendation from TORWG that the M10 acceptance criteria have been met | milestone | 0d | 2025-09-23 A | 2025-09-23 A | 100% | 2025-09-23 | 2025-09-23 | 0d | start no earlier than 2025-09-23 |  | Transition |  | 6.30 | Matthew Breen | Complete | COMPLETE |  |
| 3259 | 1.10.10.2.23 | PSG (OFGEM and PSG to Approve That Conditions of M10 and M13 Have Been Met) | milestone | 0d | 2025-09-24 A | 2025-09-24 A | 100% | 2025-09-24 | 2025-09-24 | 0d | start no earlier than 2025-09-24 |  | Transition |  | 6.30 | Matthew Breen | Complete | COMPLETE | T3-MI-0048 |

Notes:
- 3236: Responsible: N/A
- 3237: Responsible: LDSOs
- 3238: Responsible: LDSOs
- 3239: Responsible: LDSOs, RECCo
- 3240: Responsible: LDSOs
- 3241: Responsible: Code Bodies
- 3242: Responsible: LDSOs
- 3243: Responsible: DIP Manager, Elexon (ECS, ISD, Service Management), Electralink (DTS), RECCo (EES), DCC (CSS, DSP), LDSOs (MPRS, UMSO role, LDSO role)
- 3244: Responsible: Code Bodies
- 3245: Responsible: TORWG Members, MHHS Transition Team
- 3246: Responsible: Service Activation Team
- 3247: Responsible: MHHS Programme
- 3248: Responsible: MHHS Programme
- 3249: Responsible: MCAG Members, MHHS Transition Team
- 3250: Responsible: Electralink (DTS), RECCo (EES), DCC (CSS, DSP), LDSOs (MPRS, UMSO role, LDSO role)
- 3251: Responsible: Elexon (ECS, ISD, Service Management), DIP Manager
- 3252: Responsible: LDSOs
- 3253: Responsible: Elexon
- 3254: Responsible: LDSOs
- 3255: Responsible: EES
- 3256: Responsible: LDSOs
- 3257: Responsible: EES
- 3258: Responsible: TORWG Members, MHHS Transition Team, PSG
- 3259: Responsible: PSG, Ofgem

| ID | WBS | Task | Type | Duration | Start | Finish | Predecessors | Complete | Remaining | Baseline start | Baseline finish | Baseline duration | Total slack | Constraint | Text9 | Task Status | Update Version | MHHS Resource Name | Responsible | Sched Status | RAG | Milestone ID | Text29 | Tier | Notes (2) |
| --- | --- | --- | --- | --- | --- | --- | --- | --- | --- | --- | --- | --- | --- | --- | --- | --- | --- | --- | --- | --- | --- | --- | --- | --- | --- |
| 3260 | 1.10.10.3 | **Cutover Governance M11** |  | 6d | 2025-10-14 A | 2025-10-22 A |  | 100% |  | 2025-09-26 | 2025-10-22 | 0d |  |  | Transition | -687.67 | 6.11 | Matthew Breen |  |  |  |  |  |  |  |
| 3261 | 1.10.10.3.1 | Self-Declaration that MHHS Functionality will be deployed to Production by Qualified parties | milestone | 0d | 2025-10-14 A | 2025-10-14 A |  | 100% |  | 2025-10-14 | 2025-10-14 | 0d |  | start no earlier than 2025-10-14 | Transition |  | 6.30 | Matthew Breen | All Qualified Parties | Complete | COMPLETE |  |  |  |  |
| 3262 | 1.10.10.3.2 | Qualification of all pre-M11 parties | milestone | 0d | 2025-10-16 A | 2025-10-16 A |  | 100% |  | 2025-10-16 | 2025-10-16 | 0d |  | start no earlier than 2025-10-16 | Transition |  | 6.30 | Matthew Breen | Code Bodies | Complete | COMPLETE |  |  |  |  |
| 3263 | 1.10.10.3.3 | Self-Declaration that ISD file has been manually accessed and applied by all qualified Suppliers and Agents | milestone | 0d | 2025-10-16 A | 2025-10-16 A |  | 100% |  | 2025-10-16 | 2025-10-16 | 0d |  | start no earlier than 2025-10-16 | Transition |  | 6.30 | Matthew Breen | All Qualified Parties | Complete | COMPLETE |  |  |  |  |
| 3264 | 1.10.10.3.4 | Confirmation of Qualified Parties from TORWG and their readiness | milestone | 0d | 2025-10-17 A | 2025-10-17 A |  | 100% |  | 2025-10-17 | 2025-10-17 | 0d |  | start no earlier than 2025-10-17 | Transition |  | 6.30 | Matthew Breen | TORWG Members, MHHS Transition Team | Complete | COMPLETE |  |  |  |  |
| 3265 | 1.10.10.3.5 | Recommendation from MCAG that the Programme can approve M11 / M12 | milestone | 0d | 2025-10-20 A | 2025-10-20 A |  | 100% |  | 2025-10-20 | 2025-10-20 | 0d |  | start no earlier than 2025-10-20 | Transition |  | 6.30 | Matthew Breen | MCAG Members, MHHS Transition Team | Complete | COMPLETE | T3-MI-0036 |  |  |  |
| 3266 | 1.10.10.3.6 | PSG (OFGEM and PSG Decision to Confirm M11 and M12) | milestone | 0d | 2025-10-22 A | 2025-10-22 A |  | 100% |  | 2025-10-22 | 2025-10-22 | 0d |  | start no earlier than 2025-10-22 | Transition |  | 6.30 | Matthew Breen | PSG, Ofgem | Complete | COMPLETE |  |  |  |  |
| 3267 | 1.10.10.4 | **Migration Exclusion PPIR** |  | 20d | 2026-02-16 A | 2026-03-13 A |  | 100% |  | 2026-02-16 | 2026-03-13 | 0d |  |  |  | -1183.67 | 6.42 | Warren Fulton | SI Migration |  |  |  |  |  |  |
| 3268 | 1.10.10.4.1 | Publication of migration exclusion PPIR | milestone | 0d | 2026-02-16 A | 2026-02-16 A |  | 100% |  | 2026-02-16 | 2026-02-16 | 0d |  | start no earlier than 2026-02-16 |  |  | 6.42 | Warren Fulton | SI Migration | Complete | COMPLETE |  |  |  |  |
| 3269 | 1.10.10.4.2 | Participant response window for PPIR |  | 20d | 2026-02-16 A | 2026-03-13 A | 3268 | 100% |  | 2026-02-16 | 2026-03-13 | 0d |  |  |  |  | 6.42 | Warren Fulton | SI Migration | Complete | COMPLETE |  |  |  |  |
| 3270 | 1.10.10.4.3 | PPIR consultation window closed | milestone | 0d | 2026-03-13 A | 2026-03-13 A | 3269 | 100% |  | 2026-03-13 | 2026-03-13 | 0d |  |  |  |  | 6.42 | Warren Fulton | SI Migration | Complete | COMPLETE |  |  |  |  |
| 3271 | 1.10.10.5 | **Migration Sprints** |  | 432d | 2025-09-24 A | 2027-05-20 |  | 57% | 186.36d | 2025-09-24 | 2027-05-05 | 0d | 155d |  |  | -846.67 | 6.19 | Warren Fulton | SI Migration |  |  |  |  |  |  |
| 3272 | 1.10.10.5.1 | **Migration Sprint 0** |  | 105d | 2025-09-24 A | 2026-02-17 A |  | 100% |  | 2025-09-25 | 2026-02-03 | 0d |  |  | Migration | -833.67 | 6.18 | Warren Fulton | SI Migration |  |  |  |  |  |  |
| 3273 | 1.10.10.5.1.1 | Sprint 0 Planning start date |  | 6d | 2025-09-24 A | 2025-10-01 A |  | 100% |  | 2025-09-25 | 2025-10-02 | 0d |  | start no earlier than 2025-09-24 | Migration |  | 6.32 | Warren Fulton | SI Migration | Complete | COMPLETE |  |  |  |  |
| 3274 | 1.10.10.5.1.2 | Issue Envelope | milestone | 0d | 2025-10-01 A | 2025-10-01 A | 3273 | 100% |  | 2025-10-02 | 2025-10-02 | 0d |  |  | Migration |  | 6.32 | Warren Fulton | SI Migration | Complete | COMPLETE |  |  |  |  |
| 3275 | 1.10.10.5.1.3 | Supplier Submission Deadline | milestone | 0d | 2025-10-08 A | 2025-10-08 A | 3274FS+5d | 100% |  | 2025-10-09 | 2025-10-09 | 0d |  |  | Migration |  | 6.32 | Warren Fulton | SI Migration, SIT PP | Complete | COMPLETE |  |  |  |  |
| 3276 | 1.10.10.5.1.4 | Baseline Schedule Publication | milestone | 0d | 2025-10-15 A | 2025-10-15 A | 3275FS+5d | 100% |  | 2025-10-16 | 2025-10-16 | 0d |  |  | Migration |  | 6.32 | Warren Fulton | SI Migration | Complete | COMPLETE |  |  |  |  |
| 3277 | 1.10.10.5.1.5 | Migration Sprint 0 Schedule Baselined | milestone | 0d | 2025-10-16 A | 2025-10-16 A | 3276 | 100% |  | 2025-10-16 | 2025-10-16 | 0d |  | finish no earlier than 2025-10-16 | Migration |  | 6.18 | Warren Fulton | SI Migration | Complete | COMPLETE | T2-MI-8000 | MCAG (Migration) | T2 |  |
| 3278 | 1.10.10.5.1.6 | Sprint Execution Start | milestone | 0d | 2025-10-22 A | 2025-10-22 A | 3277FS+4d, 3383 | 100% |  | 2025-10-23 | 2025-10-23 | 0d |  | start no earlier than 2025-10-22 | Migration |  | 6.32 | Warren Fulton | SI Migration | Complete | COMPLETE |  |  |  |  |
| 3279 | 1.10.10.5.1.7 | Sprint Execution |  | 75d | 2025-10-22 A | 2026-02-03 A |  | 100% |  | 2025-10-24 | 2026-02-03 | 0d |  | start no earlier than 2025-10-22 | Migration |  | 6.32 | Warren Fulton | SI Migration, SIT PP | Complete | COMPLETE |  |  |  |  |
| 3280 | 1.10.10.5.1.8 | Sprint Execution End | milestone | 0d | 2026-02-03 A | 2026-02-03 A | 3279 | 100% |  | 2026-02-03 | 2026-02-03 | 0d |  |  | Migration |  | 6.18 | Warren Fulton | SI Migration | Complete | COMPLETE |  |  |  |  |
| 3281 | 1.10.10.5.1.9 | Sprint 0 Retro |  | 10d | 2026-02-04 A | 2026-02-17 A | 3280 | 100% |  | 2026-02-04 | 2026-02-17 | 0d |  | start no earlier than 2026-02-04 |  |  | 6.43 |  |  | Complete | COMPLETE |  |  |  |  |
| 3282 | 1.10.10.5.2 | **Migration Sprint 1** |  | 70d | 2026-01-07 A | 2026-04-14 A |  | 100% |  | 2026-01-07 | 2026-03-31 | 0d |  |  | Migration | -833.67 | 6.18 | Warren Fulton | SI Migration |  |  |  |  |  |  |
| 3283 | 1.10.10.5.2.1 | Sprint 1 Planning start date |  | 6d | 2026-01-07 A | 2026-01-14 A |  | 100% |  | 2026-01-07 | 2026-01-14 | 0d |  | start no earlier than 2026-01-07 | Migration |  | 6.18 | Warren Fulton | SI Migration | Complete | COMPLETE |  |  |  |  |
| 3284 | 1.10.10.5.2.2 | Issue Envelope | milestone | 0d | 2026-01-14 A | 2026-01-14 A | 3283 | 100% |  | 2026-01-14 | 2026-01-14 | 0d |  |  | Migration |  | 6.18 | Warren Fulton | SI Migration | Complete | COMPLETE |  |  |  |  |
| 3285 | 1.10.10.5.2.3 | Supplier Submission Deadline | milestone | 0d | 2026-01-21 A | 2026-01-21 A | 3284FS+5d | 100% |  | 2026-01-21 | 2026-01-21 | 0d |  |  | Migration |  | 6.18 | Warren Fulton | SI Migration, SIT PP | Complete | COMPLETE |  |  |  |  |
| 3286 | 1.10.10.5.2.4 | Baseline Schedule Publication | milestone | 0d | 2026-01-28 A | 2026-01-28 A | 3285FS+5d | 100% |  | 2026-01-28 | 2026-01-28 | 0d |  |  | Migration |  | 6.18 | Warren Fulton | SI Migration | Complete | COMPLETE |  |  |  |  |
| 3287 | 1.10.10.5.2.5 | Migration Sprint 1 Schedule Baselined | milestone | 0d | 2026-01-28 A | 2026-01-28 A | 3286 | 100% |  | 2026-01-28 | 2026-01-28 | 0d |  |  | Migration |  | 6.18 | Warren Fulton | SI Migration | Complete | COMPLETE |  |  |  |  |
| 3288 | 1.10.10.5.2.6 | Sprint Execution Start | milestone | 0d | 2026-02-04 A | 2026-02-04 A | 3287FS+5d | 100% |  | 2026-02-04 | 2026-02-04 | 0d |  |  | Migration |  | 6.18 | Warren Fulton | SI Migration | Complete | COMPLETE |  |  |  | ELS completion/exit as predecessor |
| 3289 | 1.10.10.5.2.7 | Sprint Execution |  | 39d | 2026-02-05 A | 2026-03-31 A | 3288 | 100% |  | 2026-02-05 | 2026-03-31 | 0d |  |  | Migration |  | 6.18 | Warren Fulton | SI Migration, SIT PP | Complete | COMPLETE |  |  |  |  |
| 3290 | 1.10.10.5.2.8 | Sprint Execution End | milestone | 0d | 2026-03-31 A | 2026-03-31 A | 3289 | 100% |  | 2026-03-31 | 2026-03-31 | 0d |  |  | Migration |  | 6.18 | Warren Fulton | SI Migration | Complete | COMPLETE |  |  |  |  |
| 3291 | 1.10.10.5.2.9 | Sprint 1 Retro |  | 10d | 2026-04-01 A | 2026-04-14 A | 3290 | 100% |  | 2026-04-01 | 2026-04-14 | 0d |  | start no earlier than 2026-04-01 |  |  | 6.43 |  |  | Complete | COMPLETE |  |  |  |  |

| ID | WBS | Task | Type | Duration | Start | Finish | Predecessors | Complete | Baseline start | Baseline finish | Baseline duration | Constraint | Responsible | Text9 | Task Status | Update Version | MHHS Resource Name | Sched Status | RAG | Milestone ID | Text29 | Tier |
| --- | --- | --- | --- | --- | --- | --- | --- | --- | --- | --- | --- | --- | --- | --- | --- | --- | --- | --- | --- | --- | --- | --- |
| 3292 | 1.10.10.5.3 | **Migration Sprint 2** |  | 75d | 2026-03-04 A | 2026-06-16 A |  | 100% | 2026-03-04 | 2026-06-02 | 0d |  | SI Migration | Migration | -833.67 | 6.18 | Warren Fulton |  |  |  |  |  |
| 3293 | 1.10.10.5.3.1 | Sprint 2 Planning start date |  | 6d | 2026-03-04 A | 2026-03-11 A |  | 100% | 2026-03-04 | 2026-03-11 | 0d | start no earlier than 2026-03-04 | SI Migration | Migration |  | 6.18 | Warren Fulton | Complete | COMPLETE |  |  |  |
| 3294 | 1.10.10.5.3.2 | Issue Envelope | milestone | 0d | 2026-03-11 A | 2026-03-11 A | 3293 | 100% | 2026-03-11 | 2026-03-11 | 0d |  | SI Migration, PP | Migration |  | 6.18 | Warren Fulton | Complete | COMPLETE |  |  |  |
| 3295 | 1.10.10.5.3.3 | Supplier Submission Deadline | milestone | 0d | 2026-03-18 A | 2026-03-18 A | 3294FS+5d | 100% | 2026-03-18 | 2026-03-18 | 0d |  | SI Migration | Migration |  | 6.18 | Warren Fulton | Complete | COMPLETE |  |  |  |
| 3296 | 1.10.10.5.3.4 | Baseline Schedule Publication | milestone | 0d | 2026-03-25 A | 2026-03-25 A | 3295FS+5d | 100% | 2026-03-25 | 2026-03-25 | 0d |  | SI Migration | Migration |  | 6.18 | Warren Fulton | Complete | COMPLETE |  |  |  |
| 3297 | 1.10.10.5.3.5 | Migration Sprint 2 Schedule Baselined | milestone | 0d | 2026-03-25 A | 2026-03-25 A | 3296 | 100% | 2026-03-25 | 2026-03-25 | 0d |  | SI Migration | Migration |  | 6.18 | Warren Fulton | Complete | COMPLETE |  |  |  |
| 3298 | 1.10.10.5.3.6 | Sprint Execution Start | milestone | 0d | 2026-04-01 A | 2026-04-01 A | 3297FS+5d | 100% | 2026-04-01 | 2026-04-01 | 0d |  | SI Migration | Migration |  | 6.18 | Warren Fulton | Complete | COMPLETE |  |  |  |
| 3299 | 1.10.10.5.3.7 | Sprint Execution |  | 44d | 2026-04-02 A | 2026-06-02 A | 3298 | 100% | 2026-04-02 | 2026-06-02 | 0d |  | SI Migration, PP | Migration |  | 6.18 | Warren Fulton | Complete | COMPLETE |  |  |  |
| 3300 | 1.10.10.5.3.8 | Non-SIT Participants Migration Start | milestone | 0d | 2026-05-15 A | 2026-05-15 A |  | 100% | 2026-05-15 | 2026-05-15 | 0d | finish no earlier than 2026-05-15 | SI Migration | Migration |  | 6.18 | Warren Fulton | Complete | COMPLETE | T2-MI-8500 | MCAG (Migration) | T2 |
| 3301 | 1.10.10.5.3.9 | Sprint Execution End | milestone | 0d | 2026-06-02 A | 2026-06-02 A | 3299 | 100% | 2026-06-02 | 2026-06-02 | 0d |  | SI Migration | Migration |  | 6.18 | Warren Fulton | Complete | COMPLETE |  |  |  |
| 3302 | 1.10.10.5.3.10 | Sprint 2 Retro |  | 10d | 2026-06-03 A | 2026-06-16 A | 3301 | 100% | 2026-06-03 | 2026-06-16 | 0d |  |  |  |  | 6.43 |  | Complete | COMPLETE |  |  |  |
| 3303 | 1.10.10.5.4 | **Migration Sprint 3** |  | 75d | 2026-05-06 A | 2026-08-18 A |  | 100% | 2026-05-06 | 2026-08-04 | 0d |  | SI Migration | Migration | -833.67 | 6.20 | Warren Fulton |  |  |  |  |  |
| 3304 | 1.10.10.5.4.1 | Sprint 3 Planning start date |  | 6d | 2026-05-06 A | 2026-05-13 A |  | 100% | 2026-05-06 | 2026-05-13 | 0d | start no earlier than 2026-05-06 | SI Migration | Migration |  | 6.20 | Warren Fulton | Complete | COMPLETE |  |  |  |
| 3305 | 1.10.10.5.4.2 | Issue Envelope | milestone | 0d | 2026-05-13 A | 2026-05-13 A | 3304 | 100% | 2026-05-13 | 2026-05-13 | 0d |  | SI Migration, PP | Migration |  | 6.20 | Warren Fulton | Complete | COMPLETE |  |  |  |
| 3306 | 1.10.10.5.4.3 | Supplier Submission Deadline | milestone | 0d | 2026-05-20 A | 2026-05-20 A | 3305FS+5d | 100% | 2026-05-20 | 2026-05-20 | 0d |  | SI Migration | Migration |  | 6.20 | Warren Fulton | Complete | COMPLETE |  |  |  |
| 3307 | 1.10.10.5.4.4 | Baseline Schedule Publication | milestone | 0d | 2026-05-27 A | 2026-05-27 A | 3306FS+5d | 100% | 2026-05-27 | 2026-05-27 | 0d |  | SI Migration | Migration |  | 6.20 | Warren Fulton | Complete | COMPLETE |  |  |  |
| 3308 | 1.10.10.5.4.5 | Migration Sprint 3 Schedule Baselined | milestone | 0d | 2026-05-27 A | 2026-05-27 A | 3307 | 100% | 2026-05-27 | 2026-05-27 | 0d |  | SI Migration | Migration |  | 6.20 | Warren Fulton | Complete | COMPLETE |  |  |  |
| 3309 | 1.10.10.5.4.6 | Sprint Execution Start | milestone | 0d | 2026-06-03 A | 2026-06-03 A | 3308FS+5d | 100% | 2026-06-03 | 2026-06-03 | 0d |  | SI Migration | Migration |  | 6.20 | Warren Fulton | Complete | COMPLETE |  |  |  |
| 3310 | 1.10.10.5.4.7 | Sprint Execution |  | 44d | 2026-06-04 A | 2026-08-04 A | 3309 | 100% | 2026-06-04 | 2026-08-04 | 0d |  | SI Migration, PP | Migration |  | 6.20 | Warren Fulton | Complete | COMPLETE |  |  |  |
| 3311 | 1.10.10.5.4.8 | Sprint Execution End | milestone | 0d | 2026-08-04 A | 2026-08-04 A | 3310 | 100% | 2026-08-04 | 2026-08-04 | 0d |  | SI Migration | Migration |  | 6.20 | Warren Fulton | Complete | COMPLETE |  |  |  |
| 3312 | 1.10.10.5.4.9 | Sprint 3 Retro |  | 10d | 2026-08-05 A | 2026-08-18 A | 3311 | 100% | 2026-08-05 | 2026-08-18 | 0d |  |  |  |  | 6.43 |  | Complete | COMPLETE |  |  |  |
| 3313 | 1.10.10.5.5 | **Migration Sprint 4** |  | 75d | 2026-07-08 A | 2026-10-20 A |  | 100% | 2026-07-08 | 2026-10-06 | 0d |  | SI Migration | Migration | -833.67 | 6.18 | Warren Fulton |  |  |  |  |  |
| 3314 | 1.10.10.5.5.1 | Sprint 4 Planning start date |  | 6d | 2026-07-08 A | 2026-07-15 A |  | 100% | 2026-07-08 | 2026-07-15 | 0d | start no earlier than 2026-07-08 | SI Migration | Migration |  | 6.18 | Warren Fulton | Complete | COMPLETE |  |  |  |
| 3315 | 1.10.10.5.5.2 | Issue Envelope | milestone | 0d | 2026-07-15 A | 2026-07-15 A | 3314 | 100% | 2026-07-15 | 2026-07-15 | 0d |  | SI Migration, PP | Migration |  | 6.18 | Warren Fulton | Complete | COMPLETE |  |  |  |
| 3316 | 1.10.10.5.5.3 | Supplier Submission Deadline | milestone | 0d | 2026-07-22 A | 2026-07-22 A | 3315FS+5d | 100% | 2026-07-22 | 2026-07-22 | 0d |  | SI Migration | Migration |  | 6.18 | Warren Fulton | Complete | COMPLETE |  |  |  |
| 3317 | 1.10.10.5.5.4 | Baseline Schedule Publication | milestone | 0d | 2026-07-29 A | 2026-07-29 A | 3316FS+5d | 100% | 2026-07-29 | 2026-07-29 | 0d |  | SI Migration | Migration |  | 6.18 | Warren Fulton | Complete | COMPLETE |  |  |  |
| 3318 | 1.10.10.5.5.5 | Migration Sprint 4 Schedule Baselined | milestone | 0d | 2026-07-29 A | 2026-07-29 A | 3317 | 100% | 2026-07-29 | 2026-07-29 | 0d |  | SI Migration | Migration |  | 6.18 | Warren Fulton | Complete | COMPLETE |  |  |  |
| 3319 | 1.10.10.5.5.6 | Sprint Execution Start | milestone | 0d | 2026-08-05 A | 2026-08-05 A | 3318FS+5d | 100% | 2026-08-05 | 2026-08-05 | 0d |  | SI Migration | Migration |  | 6.18 | Warren Fulton | Complete | COMPLETE |  |  |  |
| 3320 | 1.10.10.5.5.7 | Sprint Execution |  | 44d | 2026-08-06 A | 2026-10-06 A | 3319 | 100% | 2026-08-06 | 2026-10-06 | 0d |  | SI Migration, PP | Migration |  | 6.18 | Warren Fulton | Complete | COMPLETE |  |  |  |
| 3321 | 1.10.10.5.5.8 | Sprint Execution End | milestone | 0d | 2026-10-06 A | 2026-10-06 A | 3320 | 100% | 2026-10-06 | 2026-10-06 | 0d |  | SI Migration | Migration |  | 6.18 | Warren Fulton | Complete | COMPLETE |  |  |  |
| 3322 | 1.10.10.5.5.9 | Sprint 4 Retro |  | 10d | 2026-10-07 A | 2026-10-20 A | 3321 | 100% | 2026-10-07 | 2026-10-20 | 0d |  |  |  |  | 6.43 |  | Complete | COMPLETE |  |  |  |

Notes:
- 3300: 11/05/26: Milestone marked as complete following MCAG 28/04/26.
- 3302: 02/06/26: Sprint retro completed 15/06/26.

| ID | WBS | Task | Type | Duration | Start | Finish | Predecessors | Complete | Remaining | Baseline start | Baseline finish | Baseline duration | Total slack | Free slack | Constraint | Responsible | Text9 | Task Status | Update Version | MHHS Resource Name | Sched Status | RAG |
| --- | --- | --- | --- | --- | --- | --- | --- | --- | --- | --- | --- | --- | --- | --- | --- | --- | --- | --- | --- | --- | --- | --- |
| 3323 | 1.10.10.5.6 | **Migration Sprint 5** |  | 70d | 2026-09-09 A | 2026-12-15 |  | 29% | 49.64d | 2026-09-09 | 2026-12-01 | 0d | 267d |  |  | SI Migration | Migration | -833.67 | 6.18 | Warren Fulton |  |  |
| 3324 | 1.10.10.5.6.1 | Sprint 5 Planning start date |  | 6d | 2026-09-09 A | 2026-09-16 A |  | 100% |  | 2026-09-09 | 2026-09-16 | 0d |  |  | start no earlier than 2026-09-09 | SI Migration | Migration |  | 6.18 | Warren Fulton | Complete | COMPLETE |
| 3325 | 1.10.10.5.6.2 | Issue Envelope | milestone | 0d | 2026-09-16 A | 2026-09-16 A | 3324 | 100% |  | 2026-09-16 | 2026-09-16 | 0d |  |  |  | SI Migration, PP | Migration |  | 6.18 | Warren Fulton | Complete | COMPLETE |
| 3326 | 1.10.10.5.6.3 | Supplier Submission Deadline | milestone | 0d | 2026-09-23 A | 2026-09-23 A | 3325FS+5d | 100% |  | 2026-09-23 | 2026-09-23 | 0d |  |  |  | SI Migration | Migration |  | 6.18 | Warren Fulton | Complete | COMPLETE |
| 3327 | 1.10.10.5.6.4 | Baseline Schedule Publication | milestone | 0d | 2026-09-30 A | 2026-09-30 A | 3326FS+5d | 100% |  | 2026-09-30 | 2026-09-30 | 0d |  |  |  | SI Migration | Migration |  | 6.18 | Warren Fulton | Complete | COMPLETE |
| 3328 | 1.10.10.5.6.5 | Migration Sprint 5 Schedule Baselined | milestone | 0d | 2026-09-30 A | 2026-09-30 A | 3327 | 100% |  | 2026-09-30 | 2026-09-30 | 0d |  |  |  | SI Migration | Migration |  | 6.18 | Warren Fulton | Complete | COMPLETE |
| 3329 | 1.10.10.5.6.6 | Sprint Execution Start | milestone | 0d | 2026-10-07 A | 2026-10-07 A | 3328FS+5d | 100% |  | 2026-10-07 | 2026-10-07 | 0d |  |  |  | SI Migration | Migration |  | 6.18 | Warren Fulton | Complete | COMPLETE |
| 3330 | 1.10.10.5.6.7 | Sprint Execution |  | 39d | 2026-10-08 A | 2026-12-01 | 3329 | 26% | 29d | 2026-10-08 | 2026-12-01 | 0d | 267d | 0d |  | SI Migration, PP | Migration |  | 6.18 | Warren Fulton | Green | GREEN |
| 3331 | 1.10.10.5.6.8 | Sprint Execution End | milestone | 0d | 2026-12-01 | 2026-12-01 | 3330 |  |  | 2026-12-01 | 2026-12-01 | 0d | 267d | 0d |  | SI Migration | Migration | 41.71 | 6.18 | Warren Fulton | Green | GREEN |
| 3332 | 1.10.10.5.6.9 | Sprint 5 Retro |  | 10d | 2026-12-02 | 2026-12-15 | 3331 |  |  | 2026-12-02 | 2026-12-15 | 0d | 267d |  |  |  |  | 42.33 | 6.43 |  | Green | GREEN |
| 3333 | 1.10.10.5.7 | **Migration Sprint 6** |  | 75d | 2026-11-04 | 2027-02-16 |  |  |  | 2026-11-04 | 2027-02-02 | 0d | 222d |  |  | SI Migration | Migration | -833.67 | 6.18 | Warren Fulton |  |  |
| 3334 | 1.10.10.5.7.1 | Sprint 6 Planning start date |  | 6d | 2026-11-04 | 2026-11-11 |  |  |  | 2026-11-04 | 2026-11-11 | 0d | 222d | 0d | start no earlier than 2026-11-04 | SI Migration | Migration | 14.33 | 6.18 | Warren Fulton | Green | GREEN |
| 3335 | 1.10.10.5.7.2 | Issue Envelope | milestone | 0d | 2026-11-11 | 2026-11-11 | 3334 |  |  | 2026-11-11 | 2026-11-11 | 0d | 222d | 0d |  | SI Migration, PP | Migration | 21.71 | 6.18 | Warren Fulton | Green | GREEN |
| 3336 | 1.10.10.5.7.3 | Supplier Submission Deadline | milestone | 0d | 2026-11-18 | 2026-11-18 | 3335FS+5d |  |  | 2026-11-18 | 2026-11-18 | 0d | 222d | 0d |  | SI Migration | Migration | 28.71 | 6.18 | Warren Fulton | Green | GREEN |
| 3337 | 1.10.10.5.7.4 | Baseline Schedule Publication | milestone | 0d | 2026-11-25 | 2026-11-25 | 3336FS+5d |  |  | 2026-11-25 | 2026-11-25 | 0d | 222d | 0d |  | SI Migration | Migration | 35.71 | 6.18 | Warren Fulton | Green | GREEN |
| 3338 | 1.10.10.5.7.5 | Migration Sprint 6 Schedule Baselined | milestone | 0d | 2026-11-25 | 2026-11-25 | 3337 |  |  | 2026-11-25 | 2026-11-25 | 0d | 222d | 0d |  | SI Migration | Migration | 35.71 | 6.18 | Warren Fulton | Green | GREEN |
| 3339 | 1.10.10.5.7.6 | Sprint Execution Start | milestone | 0d | 2026-12-02 | 2026-12-02 | 3338FS+5d |  |  | 2026-12-02 | 2026-12-02 | 0d | 222d | 0d |  | SI Migration | Migration | 42.71 | 6.18 | Warren Fulton | Green | GREEN |
| 3340 | 1.10.10.5.7.7 | Sprint Execution |  | 44d | 2026-12-03 | 2027-02-02 | 3339 |  |  | 2026-12-03 | 2027-02-02 | 0d | 222d | 0d |  | SI Migration, PP | Migration | 43.33 | 6.18 | Warren Fulton | Green | GREEN |
| 3341 | 1.10.10.5.7.8 | Sprint Execution End | milestone | 0d | 2027-02-02 | 2027-02-02 | 3340 |  |  | 2027-02-02 | 2027-02-02 | 0d | 222d | 0d |  | SI Migration | Migration | 104.71 | 6.18 | Warren Fulton | Green | GREEN |
| 3342 | 1.10.10.5.7.9 | Sprint 6 Retro |  | 10d | 2027-02-03 | 2027-02-16 | 3341 |  |  | 2027-02-03 | 2027-02-16 | 0d | 222d |  |  |  |  | 105.33 | 6.43 |  | Green | GREEN |
| 3343 | 1.10.10.5.8 | **Migration Sprint 7** |  | 75d | 2027-01-06 | 2027-04-20 |  |  |  | 2027-01-06 | 2027-04-06 | 0d | 177d |  |  | SI Migration | Migration | -833.67 | 6.18 | Warren Fulton |  |  |
| 3344 | 1.10.10.5.8.1 | Sprint 7 Planning start date |  | 6d | 2027-01-06 | 2027-01-13 |  |  |  | 2027-01-06 | 2027-01-13 | 0d | 177d | 0d | start no earlier than 2027-01-06 | SI Migration | Migration | 77.33 | 6.18 | Warren Fulton | Green | GREEN |
| 3345 | 1.10.10.5.8.2 | Issue Envelope | milestone | 0d | 2027-01-13 | 2027-01-13 | 3344 |  |  | 2027-01-13 | 2027-01-13 | 0d | 177d | 0d |  | SI Migration, PP | Migration | 84.71 | 6.18 | Warren Fulton | Green | GREEN |
| 3346 | 1.10.10.5.8.3 | Supplier Submission Deadline | milestone | 0d | 2027-01-20 | 2027-01-20 | 3345FS+5d |  |  | 2027-01-20 | 2027-01-20 | 0d | 177d | 0d |  | SI Migration | Migration | 91.71 | 6.18 | Warren Fulton | Green | GREEN |
| 3347 | 1.10.10.5.8.4 | Baseline Schedule Publication | milestone | 0d | 2027-01-27 | 2027-01-27 | 3346FS+5d |  |  | 2027-01-27 | 2027-01-27 | 0d | 177d | 0d |  | SI Migration | Migration | 98.71 | 6.18 | Warren Fulton | Green | GREEN |
| 3348 | 1.10.10.5.8.5 | Migration Sprint 7 Schedule Baselined | milestone | 0d | 2027-01-27 | 2027-01-27 | 3347 |  |  | 2027-01-27 | 2027-01-27 | 0d | 177d | 0d |  | SI Migration | Migration | 98.71 | 6.18 | Warren Fulton | Green | GREEN |
| 3349 | 1.10.10.5.8.6 | Sprint Execution Start | milestone | 0d | 2027-02-03 | 2027-02-03 | 3348FS+5d |  |  | 2027-02-03 | 2027-02-03 | 0d | 177d | 0d |  | SI Migration | Migration | 105.71 | 6.18 | Warren Fulton | Green | GREEN |
| 3350 | 1.10.10.5.8.7 | Sprint Execution |  | 44d | 2027-02-04 | 2027-04-06 | 3349 |  |  | 2027-02-04 | 2027-04-06 | 0d | 177d | 0d |  | SI Migration, PP | Migration | 106.33 | 6.18 | Warren Fulton | Green | GREEN |
| 3351 | 1.10.10.5.8.8 | Sprint Execution End | milestone | 0d | 2027-04-06 | 2027-04-06 | 3350 |  |  | 2027-04-06 | 2027-04-06 | 0d | 177d | 0d |  | SI Migration | Migration | 167.71 | 6.18 | Warren Fulton | Green | GREEN |
| 3352 | 1.10.10.5.8.9 | Sprint 7 Retro |  | 10d | 2027-04-07 | 2027-04-20 | 3351 |  |  | 2027-04-07 | 2027-04-20 | 0d | 177d |  |  |  |  | 168.33 | 6.43 |  | Green | GREEN |

| ID | WBS | Task | Type | Duration | Start | Finish | Predecessors | Complete | Remaining | Baseline start | Baseline finish | Baseline duration | Baseline 1 start | Baseline 1 finish | Total slack | Constraint | Baseline cost | Responsible | Text9 | Task Status | Update Version | MHHS Resource Name | Sched Status | RAG | Milestone ID | Text29 | Tier | Involved | MHHS Programme Phase |
| --- | --- | --- | --- | --- | --- | --- | --- | --- | --- | --- | --- | --- | --- | --- | --- | --- | --- | --- | --- | --- | --- | --- | --- | --- | --- | --- | --- | --- | --- |
| 3353 | 1.10.10.5.9 | **Migration Sprint 8** |  | 59d | 2027-03-01 | 2027-05-20 |  |  |  | 2027-03-01 | 2027-05-05 | 0d |  |  | 0d |  |  | SI Migration | Migration | -833.67 | 6.18 | Warren Fulton |  |  |  |  |  |  |  |
| 3354 | 1.10.10.5.9.1 | Sprint 8 Planning start date |  | 6d | 2027-03-01 | 2027-03-08 |  |  |  | 2027-03-01 | 2027-03-08 | 0d |  |  | 0d | start no earlier than 2027-03-01 |  | SI Migration | Migration | 131.33 | 6.18 | Warren Fulton | Green | GREEN |  |  |  |  |  |
| 3355 | 1.10.10.5.9.2 | Issue Envelope | milestone | 0d | 2027-03-08 | 2027-03-08 | 3354 |  |  | 2027-03-08 | 2027-03-08 | 0d |  |  | 0d |  |  | SI Migration, PP | Migration | 138.71 | 6.18 | Warren Fulton | Green | GREEN |  |  |  |  |  |
| 3356 | 1.10.10.5.9.3 | Supplier Submission Deadline | milestone | 0d | 2027-03-15 | 2027-03-15 | 3355FS+5d |  |  | 2027-03-15 | 2027-03-15 | 0d |  |  | 0d |  |  | SI Migration | Migration | 145.71 | 6.18 | Warren Fulton | Green | GREEN |  |  |  |  |  |
| 3357 | 1.10.10.5.9.4 | Baseline Schedule Publication | milestone | 0d | 2027-03-22 | 2027-03-22 | 3356FS+5d |  |  | 2027-03-22 | 2027-03-22 | 0d |  |  | 0d |  |  | SI Migration | Migration | 152.71 | 6.18 | Warren Fulton | Green | GREEN |  |  |  |  |  |
| 3358 | 1.10.10.5.9.5 | Migration Sprint 8 Schedule Baselined | milestone | 0d | 2027-03-22 | 2027-03-22 | 3357 |  |  | 2027-03-22 | 2027-03-22 | 0d |  |  | 0d |  |  | SI Migration | Migration | 152.71 | 6.18 | Warren Fulton | Green | GREEN |  |  |  |  |  |
| 3359 | 1.10.10.5.9.6 | Sprint Execution Start | milestone | 0d | 2027-03-29 | 2027-03-29 | 3358FS+5d |  |  | 2027-03-29 | 2027-03-29 | 0d |  |  | 0d | start no earlier than 2027-03-29 |  | SI Migration | Migration | 159.71 | 6.18 | Warren Fulton | Green | GREEN |  |  |  |  |  |
| 3360 | 1.10.10.5.9.7 | Sprint Execution |  | 27d | 2027-03-30 | 2027-05-05 | 3359 |  |  | 2027-03-30 | 2027-05-05 | 0d |  |  | 0d |  |  | SI Migration, PP | Migration | 160.33 | 6.18 | Warren Fulton | Green | GREEN |  |  |  |  |  |
| 3361 | 1.10.10.5.9.8 | Sprint Execution End | milestone | 0d | 2027-05-05 | 2027-05-05 | 3360 |  |  | 2027-05-05 | 2027-05-05 | 0d |  |  | 0d |  |  | SI Migration | Migration | 196.71 | 6.18 | Warren Fulton | Green | GREEN | T2-MI-9000 | MCAG (Migration) | T2 |  |  |
| 3362 | 1.10.10.5.9.9 | Sprint 8 Retro |  | 10d | 2027-05-07 | 2027-05-20 | 3361 |  |  | 2027-05-07 | 2027-05-20 | 0d |  |  | 155d | start no earlier than 2027-05-07 |  |  |  | 198.33 | 6.43 | Warren Fulton | Green | GREEN |  |  |  |  |  |
| 3363 | 1.10.10.5.10 | **Complex Sites Migration** |  | 67d | 2026-11-02 A | 2027-02-02 |  | 3% | 64.79d | 2026-11-02 | 2027-02-02 | 0d |  |  | 232d |  |  |  |  | -1436.67 | 6.60 |  | Overdue Start | GREEN |  |  |  |  |  |
| 3364 | 1.10.10.5.10.1 | Complex Sites - Phase 1 |  | 10d | 2026-11-02 A | 2026-11-13 |  | 7% | 9.33d | 2026-11-02 | 2026-11-13 | 0d |  |  | 289d |  |  | SI Migration |  |  | 6.60 | Warren Fulton | Green | GREEN |  |  |  |  |  |
| 3365 | 1.10.10.5.10.2 | Complex Sites - Phase 2 |  | 29d | 2026-11-16 A | 2026-12-24 |  | 2% | 28.33d | 2026-11-16 | 2026-12-24 | 0d |  |  | 260d | finish no earlier than 2026-12-24 |  | SI Migration |  |  | 6.60 | Warren Fulton | Green | GREEN |  |  |  |  |  |
| 3366 | 1.10.10.5.10.3 | Complex Sites - Phase 3 |  | 22d | 2027-01-04 A | 2027-02-02 |  | 3% | 21.33d | 2027-01-04 | 2027-02-02 | 0d |  |  | 232d | finish no earlier than 2027-02-02 |  | SI Migration |  |  | 6.60 | Warren Fulton | Green | GREEN |  |  |  |  |  |
| 3367 | 1.10.11 | **External Programme Dependency Management** |  | 740d | 2022-10-31 A | 2025-08-29 A |  | 100% |  | 2022-10-31 | 2025-08-29 | 827d | 2022-10-31 | 2025-07-01 |  |  | -0 | N/A | Transition |  | 5.0 | N/A |  |  |  |  |  | N/A | Migration |
| 3368 | 1.10.11.1 | **BSC Mod P432 & REC CP R0015** |  | 392d | 2022-10-31 A | 2024-04-30 A |  | 100% |  | 2022-10-31 | 2024-04-30 | 827d | 2022-10-31 | 2025-07-01 |  |  | -0 | N/A | Transition |  | 5.0 | N/A |  |  |  |  |  | N/A | Migration |
| 3369 | 1.10.11.1.1 | MHHSP engagement with BSCCo until Ofgem decision |  | 316d | 2022-10-31 A | 2024-01-15 A |  | 100% |  | 2022-10-31 | 2024-01-15 | 400d | 2022-10-31 | 2022-12-30 |  |  |  | CPT,SRO Function | Transition |  | 5.0 | MHHS Programme | Complete | COMPLETE |  |  |  | Code Bodies | Migration |
| 3370 | 1.10.11.1.2 | Monitor progress and await implementation date |  | 76d | 2024-01-16 A | 2024-04-30 A | 3369 | 100% |  | 2024-01-16 | 2024-04-30 | 652d | 2023-01-02 | 2025-07-01 |  |  |  | CPT,SRO Function | Transition |  | 5.0 | MHHS Programme | Complete | COMPLETE |  |  |  | Code Bodies | Migration |
| 3371 | 1.10.11.2 | **BSC Mod P434** |  | 713d | 2022-10-31 A | 2025-07-23 A |  | 100% |  | 2022-10-31 | 2025-07-23 | 713d | 2022-10-31 | 2025-07-01 |  |  |  | N/A | Transition |  | 5.0 | N/A |  |  |  |  |  | N/A | Migration |
| 3372 | 1.10.11.2.1 | MHHSP engagement with BSCCo until Ofgem decision |  | 61d | 2022-10-31 A | 2023-01-23 A |  | 100% |  | 2022-10-31 | 2023-01-23 | 61d | 2022-10-31 | 2022-12-30 |  |  |  | CPT,SRO Function | Transition |  | 5.0 | MHHS Programme | Complete | COMPLETE |  |  |  | Code Bodies | Migration |
| 3373 | 1.10.11.2.2 | Monitor progress and await implementation date |  | 652d | 2023-01-24 A | 2025-07-23 A | 3372 | 100% |  | 2023-01-24 | 2025-07-23 | 652d | 2023-01-02 | 2025-07-01 |  |  |  | CPT,SRO Function | Transition |  | 5.0 | MHHS Programme | Complete | COMPLETE |  |  |  | Code Bodies | Migration |
| 3374 | 1.10.11.3 | **Elexon System Capacity Upgrade** |  | 697d | 2022-10-31 A | 2025-07-01 A |  | 100% |  | 2022-10-31 | 2025-07-01 | 697d | 2022-10-31 | 2025-07-01 |  |  |  | N/A | Transition |  | 5.0 | N/A |  |  |  |  |  | N/A | Migration |
| 3375 | 1.10.11.3.1 | Monitor progress to implementation |  | 697d | 2022-10-31 A | 2025-07-01 A |  | 100% |  | 2022-10-31 | 2025-07-01 | 697d | 2022-10-31 | 2025-07-01 |  |  |  | SI Migration | Transition |  | 5.0 | MHHS Programme | Complete | COMPLETE |  |  |  | PP | Migration |
| 3376 | 1.10.11.3.2 | Implementation date | milestone | 0d | 2025-07-01 A | 2025-07-01 A | 3375 | 100% |  | 2025-07-01 | 2025-07-01 | 0d | 2025-07-01 | 2025-07-01 |  |  |  | PP | Transition |  | 5.0 | MHHS Programme | Complete | COMPLETE |  |  |  | SI Migration | Migration |

| ID | WBS | Task | Type | Duration | Start | Finish | Predecessors | Complete | Remaining | Baseline start | Baseline finish | Baseline duration | Baseline 1 start | Baseline 1 finish | Total slack | Constraint | Baseline cost | Responsible | Involved | Text9 | Update Version | MHHS Resource Name | MHHS Programme Phase | Sched Status | RAG | Milestone ID | Text29 | Tier | Future RAG | Task Status |
| --- | --- | --- | --- | --- | --- | --- | --- | --- | --- | --- | --- | --- | --- | --- | --- | --- | --- | --- | --- | --- | --- | --- | --- | --- | --- | --- | --- | --- | --- | --- |
| 3377 | 1.10.11.4 | **DCC System Capacity Upgrade** |  | 25d | 2025-07-28 A | 2025-08-29 A |  | 100% |  | 2025-07-28 | 2025-08-29 | 25d | 2025-01-13 | 2025-02-14 |  |  |  | N/A | N/A | Transition | 5.0 | N/A | Migration |  |  |  |  |  |  |  |
| 3378 | 1.10.11.4.1 | Assurance of DCC capacity upgrade to ensure suitability to support migration |  | 20d | 2025-07-28 A | 2025-08-22 A | 1802FF-21d | 100% |  | 2025-07-28 | 2025-08-22 | 20d | 2025-01-13 | 2025-02-07 |  |  |  | SI Migration | PP | Transition | 5.0 | MHHS Programme | Migration | Complete | COMPLETE |  |  |  |  |  |
| 3379 | 1.10.11.4.2 | DCC Capacity Upgrade Operational | milestone | 0d | 2025-08-29 A | 2025-08-29 A | 3378FS+5d | 100% |  | 2025-08-29 | 2025-08-29 | 0d | 2025-02-14 | 2025-02-14 |  |  |  | PP | SI Migration,IPA | Transition | 5.0 | MHHS Programme | Migration | Complete | COMPLETE | T2-MI-0350 | MCAG | T2 |  |  |
| 3380 | 1.10.12 | **Migration - Tier 1 Milestones** |  | 424d | 2025-09-22 A | 2027-05-07 |  |  | 424d | 2025-09-24 | 2027-08-09 | 477d | 2025-03-07 | 2027-01-05 | 0d |  |  | N/A | N/A | Transition | 5.0 | N/A | Migration |  |  |  |  |  |  |  |
| 3381 | 1.10.12.1 | Load Shaping Service switched on (M13) | milestone | 0d | 2025-09-22 A | 2025-09-22 A | 1802 | 100% |  | 2025-09-22 | 2025-09-22 | 0d | 2025-03-07 | 2025-03-07 |  |  |  | CPT | CPT | Transition | 6.26 | CPT | Migration | Complete | COMPLETE | T1-MI-2000 | PSG | T1 | Load Shaping Service switched on |  |
| 3382 | 1.10.12.2 | Load Shaping Service switched on (M13*) - Late Exit | milestone | 0d | 2025-12-24 A | 2025-12-24 A | 3381FS+67d | 100% |  | 2025-12-24 | 2025-12-24 | 0d | 2025-06-06 | 2025-06-06 |  |  |  | CPT | CPT | Transition | 6.1 | CPT | Migration | Complete | COMPLETE | T2-MI-2500 | PSG | T1 | Load Shaping Service switched on |  |
| 3383 | 1.10.12.3 | Start of 18-month migration for UMS / Advanced (M11) | milestone | 0d | 2025-10-22 A | 2025-10-22 A | 3381, 1802FS+22d, 3048 | 100% |  | 2025-10-22 | 2025-10-22 | 0d | 2025-04-04 | 2025-04-04 |  |  |  | CPT | CPT | Transition | 6.1 | CPT | Migration | Complete | COMPLETE | T1-MI-3000 | PSG | T1 | Start of 1 year migration for UMS / Advanced |  |
| 3384 | 1.10.12.4 | Start of 18-month migration for UMS / Advanced (M11*) - Late Exit | milestone | 0d | 2026-01-21 A | 2026-01-21 A | 3383FS+65d | 100% |  | 2026-01-21 | 2026-01-21 | 0d | 2025-07-04 | 2025-07-04 |  |  |  | CPT | CPT | Transition | 6.1 | CPT | Migration | Complete | COMPLETE | T2-MI-3500 | PSG | T1 | Start of 1 year migration for UMS / Advanced |  |
| 3385 | 1.10.12.5 | Start of 18-month migration for Smart / Non-smart (M12) | milestone | 0d | 2025-10-22 A | 2025-10-22 A | 3381, 1802FS+22d | 100% |  | 2025-10-22 | 2025-10-22 | 0d | 2025-04-04 | 2025-04-04 |  |  |  | CPT | CPT | Transition | 6.1 | CPT | Migration | Complete | COMPLETE | T1-MI-4000 | PSG | T1 | Start of 1 year migration for Smart / Non-smart |  |
| 3386 | 1.10.12.6 | Start of 18-month migration for Smart / Non-smart (M12*) - Late Exit | milestone | 0d | 2026-01-21 A | 2026-01-21 A | 3385FS+65d | 100% |  | 2026-01-21 | 2026-01-21 | 0d | 2025-07-04 | 2025-07-04 |  |  |  | CPT | CPT | Transition | 6.1 | CPT | Migration | Complete | COMPLETE | T2-MI-4500 | PSG | T1 | Start of 1 year migration for Smart / Non-smart |  |
| 3387 | 1.10.12.7 | Full transition complete (M15) | milestone | 0d | 2027-05-07 | 2027-05-07 | 3361FS+2d |  |  | 2027-05-07 | 2027-05-07 | 0d | 2026-10-05 | 2026-10-05 | 0d |  |  | CPT | CPT | Transition | 6.1 | CPT | Migration | Green | GREEN | T1-MI-6000 | PSG | T1 | Full transition complete | 198.71 |
| 3388 | 1.11 | **BUSINESS & OPERATIONAL READINESS** |  | 1344d? | 2022-10-31 A | 2027-12-23 |  | 90% | 132.29d? | 2022-10-31 | 2027-12-23 | 964d | 2023-03-01 | 2026-12-07 | 0d |  | -0 | N/A | N/A | Business & Operation Readiness |  | N/A | Business & Operational Readiness |  |  |  |  |  |  |  |
| 3389 | 1.11.1 | **Service Management** |  | 1041d | 2022-10-31 A | 2026-10-27 |  | 99% | 0d | 2023-09-19 | 2027-06-24 | 840d | 2023-03-01 | 2026-12-07 | 303d |  | -0 | N/A | N/A | Business & Operation Readiness | 5.0 | N/A | Business & Operational Readiness |  |  |  |  |  |  |  |
| 3390 | 1.11.1.1 | **Service Management Strategy** |  | 116d | 2023-09-19 A | 2024-02-27 A |  | 100% |  | 2023-09-19 | 2024-02-27 | 116d | 2023-03-01 | 2023-05-31 |  |  | -0 | N/A | N/A | Business & Operation Readiness | 5.0 | N/A | Business & Operational Readiness |  |  |  |  |  |  |  |
| 3391 | 1.11.1.1.1 | Develop document with relevant participants (incl. review of the design baseline to ensure service management arrangements are in place across the solution architecture) |  | 84d | 2023-09-19 A | 2024-01-12 A |  | 100% |  | 2023-09-19 | 2024-01-12 | 84d | 2023-03-01 | 2023-04-28 |  | start no earlier than 2023-09-19 |  | SI Design |  | Business & Operation Readiness | 5.0 | Matthew Breen | Business & Operational Readiness | Complete | COMPLETE |  |  |  |  |  |
| 3392 | 1.11.1.1.2 | Artefact review (via relevant Advisory Group) and updates |  | 31d | 2024-01-15 A | 2024-02-26 A | 3391 | 100% |  | 2024-01-15 | 2024-02-26 | 31d | 2023-05-01 | 2023-05-24 |  |  |  | PP | SI Design,IPA | Business & Operation Readiness | 5.0 | Matthew Breen | Business & Operational Readiness | Complete | COMPLETE |  |  |  |  |  |
| 3393 | 1.11.1.1.3 | Service Management Strategy approved | milestone | 0d | 2024-02-27 A | 2024-02-27 A | 3392FS+1d | 100% |  | 2024-02-27 | 2024-02-27 | 0d | 2023-05-31 | 2023-05-31 |  |  |  | SI Design | PP | Business & Operation Readiness | 5.16 | Matthew Breen | Business & Operational Readiness | Complete | COMPLETE | T3-BC-0010 | MCAG | T3 |  |  |
| 3394 | 1.11.1.2 | **Early Life Support Model** |  | 305d | 2024-02-28 A | 2025-04-29 A |  | 100% |  | 2024-02-28 | 2024-07-30 | 110d |  |  |  |  | -0 | N/A | N/A | Business & Operation Readiness | 5.16 | Matthew Breen | Business & Operational Readiness |  |  |  |  |  |  | -441.67 |
| 3395 | 1.11.1.2.1 | Draft Document |  | 252d | 2024-02-28 A | 2025-02-13 A | 3393 | 100% |  | 2024-02-28 | 2024-06-10 | 74d |  |  |  | finish no earlier than 2025-02-13 |  | SI Transition | SI Transition,PP,SRO | Business & Operation Readiness | 6.19 | Matthew Breen | Business & Operational Readiness | Complete | COMPLETE |  |  |  |  |  |
| 3396 | 1.11.1.2.2 | Share Document with SRO |  | 1d | 2025-02-14 A | 2025-02-14 A | 3395 | 100% |  | 2024-06-11 | 2024-06-11 | 1d |  |  |  |  |  | SI Transition | SI Transition,PP,SRO | Business & Operation Readiness | 6.19 | Matthew Breen | Business & Operational Readiness | Complete | COMPLETE |  |  |  |  |  |
| 3397 | 1.11.1.2.3 | Industry Consultation |  | 11d | 2025-02-21 A | 2025-03-07 A | 3396FS+4d | 100% |  | 2024-06-18 | 2024-07-02 | 11d |  |  |  |  |  | SI Transition | SI Transition,PP,SRO | Business & Operation Readiness | 6.19 | Matthew Breen | Business & Operational Readiness | Complete | COMPLETE |  |  |  |  |  |
| 3398 | 1.11.1.2.4 | Assurance Meeting |  | 1d | 2025-04-03 A | 2025-04-03 A | 3397FS+9d | 100% |  | 2025-04-03 | 2025-04-03 | 1d |  |  |  | finish no earlier than 2025-04-03 |  | SI Transition | SI Transition,PP,SRO | Business & Operation Readiness | 6.19 | Matthew Breen | Business & Operational Readiness | Complete | COMPLETE |  |  |  |  |  |
| 3399 | 1.11.1.2.5 | MCAG Approval of Early Life Support Model | milestone | 0d | 2025-04-29 A | 2025-04-29 A | 3398FS+10d | 100% |  | 2025-04-29 | 2025-04-29 | 0d |  |  |  | finish no earlier than 2025-04-29 |  | SI Transition | PP,SRO,SI Transition | Business & Operation Readiness | 6.22 | Matthew Breen | Business & Operational Readiness | Complete | COMPLETE | T3-MI-0033 | MCAG (Transition) | T3 |  |  |
| 3400 | 1.11.1.3 | **Service Management Arrangements Implementation** |  | 838d | 2022-10-31 A | 2026-01-14 A |  | 100% |  | 2025-09-25 | 2027-06-24 | 453d | 2025-03-10 | 2026-12-07 |  |  | -0 | N/A | N/A | Business & Operation Readiness | 5.0 | N/A | Business & Operational Readiness |  |  |  |  |  |  |  |
| 3401 | 1.11.1.3.1 | Hypercare post M10 |  | 82d | 2025-09-23 A | 2026-01-14 A | 1802 | 100% |  | 2025-09-25 | 2026-01-14 | 80d | 2025-03-10 | 2025-06-27 |  |  |  | SI Design | PP | Business & Operation Readiness | 6.26 | Claire Silk | Business & Operational Readiness | Complete | COMPLETE |  |  |  |  |  |
| 3402 | 1.11.1.3.2 | Monitor Elexon implementation of Service Management arrangements |  | 436d | 2022-10-31 A | 2024-07-01 A |  | 100% |  | 2025-10-23 | 2027-06-24 | 436d | 2025-04-07 | 2026-12-07 |  |  |  | PP | SI Design | Business & Operation Readiness | 5.0 | Claire Silk | Business & Operational Readiness | Complete | COMPLETE |  |  |  |  |  |

| ID | WBS | Task | Type | Duration | Start | Finish | Predecessors | Complete | Baseline start | Baseline finish | Baseline duration | Constraint | Responsible | Text9 | Task Status | Update Version | MHHS Resource Name | Sched Status | RAG |
| --- | --- | --- | --- | --- | --- | --- | --- | --- | --- | --- | --- | --- | --- | --- | --- | --- | --- | --- | --- |
| 3403 | 1.11.1.4 | **Migration Pathway (MP1) and Migration Pathway 2 (MP2)** |  | 33d | 2026-03-31 A | 2026-05-15 A |  | 100% | 2026-03-31 | 2026-05-22 | 0d |  | Helix | Business & Operation Readiness | -650.67 | 5.31 | Helix |  |  |
| 3404 | 1.11.1.4.1 | **MP1 and MP2 - Service Activation Preparation Tasks** |  | 9d | 2026-03-31 A | 2026-04-10 A |  | 100% | 2026-03-31 | 2026-04-10 | 0d |  | Helix |  | -1002.67 | 6.30 | Helix |  |  |
| 3405 | 1.11.1.4.1.1 | Review Entry/Exit Criteria & Lessons Learned | milestone | 0d | 2026-03-31 A | 2026-03-31 A |  | 100% | 2026-03-31 | 2026-03-31 | 0d | finish no earlier than 2026-03-31 | Helix |  |  | 6.30 | Helix | Complete | COMPLETE |
| 3406 | 1.11.1.4.1.2 | Identify Resources |  | 1d | 2026-03-31 A | 2026-03-31 A |  | 100% | 2026-03-31 | 2026-03-31 | 0d | start no earlier than 2026-03-31 | Helix |  |  | 6.30 | Helix | Complete | COMPLETE |
| 3407 | 1.11.1.4.1.3 | Confirmation from Qualification of Wave Participants Complete | milestone | 0d | 2026-03-31 A | 2026-03-31 A |  | 100% | 2026-03-31 | 2026-03-31 | 0d | finish no earlier than 2026-03-31 | Helix |  |  | 6.30 | Helix | Complete | COMPLETE |
| 3408 | 1.11.1.4.1.4 | Agree & Understand Support Model |  | 1d | 2026-04-01 A | 2026-04-01 A |  | 100% | 2026-04-01 | 2026-04-01 | 0d | start no earlier than 2026-04-01 | Helix |  |  | 6.30 | Helix | Complete | COMPLETE |
| 3409 | 1.11.1.4.1.5 | Training Confirmation |  | 1d | 2026-04-02 A | 2026-04-02 A |  | 100% | 2026-04-02 | 2026-04-02 | 0d | start no earlier than 2026-04-02 | Helix |  |  | 6.30 | Helix | Complete | COMPLETE |
| 3410 | 1.11.1.4.1.6 | Training Confirmation Completed | milestone | 0d | 2026-04-02 A | 2026-04-02 A |  | 100% | 2026-04-02 | 2026-04-02 | 0d | finish no earlier than 2026-04-02 | Helix |  |  | 6.30 | Helix | Complete | COMPLETE |
| 3411 | 1.11.1.4.1.7 | Engagement / Communications with Participants Completed | milestone | 0d | 2026-04-03 A | 2026-04-03 A |  | 100% | 2026-04-03 | 2026-04-03 | 0d | finish no earlier than 2026-04-03 | Helix |  |  | 6.30 | Helix | Complete | COMPLETE |
| 3412 | 1.11.1.4.1.8 | **Internal Communications** |  | 1d | 2026-04-06 A | 2026-04-06 A |  | 100% | 2026-04-06 | 2026-04-06 | 0d |  | Helix |  | -1002.67 | 6.30 | Helix |  |  |
| 3413 | 1.11.1.4.1.8.1 | Agree Content for Livewire |  | 1d | 2026-04-06 A | 2026-04-06 A |  | 100% | 2026-04-06 | 2026-04-06 | 0d | start no earlier than 2026-04-06 | Helix |  |  | 6.30 | Helix | Complete | COMPLETE |
| 3414 | 1.11.1.4.1.8.2 | Publish Content for Livewire | milestone | 0d | 2026-04-06 A | 2026-04-06 A |  | 100% | 2026-04-06 | 2026-04-06 | 0d | finish no earlier than 2026-04-06 | Helix |  |  | 6.30 | Helix | Complete | COMPLETE |
| 3415 | 1.11.1.4.1.9 | Validate User Access |  | 1d | 2026-04-07 A | 2026-04-07 A |  | 100% | 2026-04-07 | 2026-04-07 | 0d | start no earlier than 2026-04-07 | Helix |  |  | 6.30 | Helix | Complete | COMPLETE |
| 3416 | 1.11.1.4.1.10 | Target Systems and Environments Ready |  | 1d | 2026-04-08 A | 2026-04-08 A |  | 100% | 2026-04-08 | 2026-04-08 | 0d | start no earlier than 2026-04-08 | Helix |  |  | 6.30 | Helix | Complete | COMPLETE |
| 3417 | 1.11.1.4.1.11 | Provide LWIs |  | 1d | 2026-04-09 A | 2026-04-09 A |  | 100% | 2026-04-09 | 2026-04-09 | 0d | start no earlier than 2026-04-09 | Helix |  |  | 6.30 | Helix | Complete | COMPLETE |
| 3418 | 1.11.1.4.1.12 | Business Readiness Governance Approval |  | 1d | 2026-04-10 A | 2026-04-10 A |  | 100% | 2026-04-10 | 2026-04-10 | 0d | start no earlier than 2026-04-10 | Helix |  |  | 6.30 | Helix | Complete | COMPLETE |
| 3419 | 1.11.1.4.1.13 | MP1 and MP2 - Service Activation Preparation Tasks (M) | milestone | 0d | 2026-04-10 A | 2026-04-10 A |  | 100% | 2026-04-10 | 2026-04-10 | 0d | finish no earlier than 2026-04-10 | Helix |  |  | 6.30 | Helix | Complete | COMPLETE |
| 3420 | 1.11.1.4.2 | **MP1 and MP2 - Service Activation Implementation** |  | 31d | 2026-04-02 A | 2026-05-15 A |  | 100% | 2026-04-02 | 2026-05-15 | 0d |  | Helix | Business & Operation Readiness |  | 6.35 | Helix |  |  |
| 3421 | 1.11.1.4.2.1 | Market Entry to confirm PP's Effective from Date |  | 1d | 2026-04-02 A | 2026-04-02 A |  | 100% | 2026-04-02 | 2026-04-02 | 0d | start no earlier than 2026-04-02 | Helix |  |  | 6.35 | Helix | Complete | COMPLETE |
| 3422 | 1.11.1.4.2.2 | PP is Qualified by Code Bodies | milestone | 0d | 2026-04-15 A | 2026-04-15 A | 2646 | 100% | 2026-04-15 | 2026-04-15 | 0d | finish no earlier than 2026-04-14 | Helix | Business & Operation Readiness |  | 6.35 | Helix | Complete | COMPLETE |
| 3423 | 1.11.1.4.2.3 | DIP Promoted to Production |  | 5d | 2026-04-16 A | 2026-04-22 A | 3422 | 100% | 2026-04-20 | 2026-04-24 | 0d | start no earlier than 2026-04-16 | Helix | Business & Operation Readiness |  | 6.35 | Helix | Complete | COMPLETE |
| 3424 | 1.11.1.4.2.4 | Create M16 in Customer Solution |  | 1d | 2026-04-16 A | 2026-04-16 A |  | 100% | 2026-04-17 | 2026-04-17 | 0d | start no earlier than 2026-04-16 | Helix | Business & Operation Readiness |  | 6.35 | Helix | Complete | COMPLETE |
| 3425 | 1.11.1.4.2.5 | MDD & ISD Publish |  | 1d | 2026-05-07 A | 2026-05-07 A | 3422, 3430 | 100% | 2026-05-07 | 2026-05-07 | 0d | start no earlier than 2026-05-07 | Helix | Business & Operation Readiness |  | 6.35 | Helix | Complete | COMPLETE |
| 3426 | 1.11.1.4.2.6 | MDD & ISD Go-Live |  | 1d | 2026-05-14 A | 2026-05-14 A | 3425FS+5d | 100% | 2026-05-14 | 2026-05-14 | 0d | start no earlier than 2026-05-14 | Helix |  |  | 6.35 | Helix | Complete | COMPLETE |
| 3427 | 1.11.1.4.2.7 | MP1 and MP2 - Service Activation Implementation Complete (M) | milestone | 0d | 2026-05-15 A | 2026-05-15 A | 3426 | 100% | 2026-05-15 | 2026-05-15 | 0d | start no earlier than 2026-05-15 | Helix | Business & Operation Readiness |  | 6.35 | Helix | Complete | COMPLETE |

Notes:
- 3403: 15/05/26: Task renamed to align with Migration Pathways, replacing the previous Waves approach. Migration Pathways 1 and 2 have been combined as no participants are service activating in MP1.
- 3404: 25/02/26: Programme and Elexon are working to update the Service Activation plan for Non-SIT PPs to reflect the ISD / MDD Calendar.
- 3420: 25/02/26: Programme and Elexon are working to update the Service Activation plan for Non-SIT PPs to reflect the ISD / MDD Calendar.
- 3421: 15/05/26: Task name changed from Market Entry to obtain Effective from Date from PP to Market Entry to confirm PP's Effective from Date, aligning with workstream processes in which the Effective from Date is obtained 40WD before a PPs target PAB a
- 3425: 06/05/26: Task date updated from 17/04 to 07/05 to align with latest MDD & ISD Publication dates.
- 3426: 06/05/26: Task date updated from 24/04 to 14/05 to align with latest MDD & ISD Go-Live dates.

| ID | WBS | Task | Type | Duration | Start | Finish | Predecessors | Complete | Remaining | Actual start | Actual finish | Baseline start | Baseline finish | Baseline duration | Constraint | Responsible | Text9 | Update Version | MHHS Resource Name | Sched Status | RAG | Task Status |
| --- | --- | --- | --- | --- | --- | --- | --- | --- | --- | --- | --- | --- | --- | --- | --- | --- | --- | --- | --- | --- | --- | --- |
| 3428 | 1.11.1.4.3 | **MP1 and MP2 - Service Activation Implementation MDD** |  | 2d | 2026-05-06 | 2026-05-07 |  | 100% |  | 2026-05-05 | 2026-05-06 | 2026-05-06 | 2026-05-06 | 0d |  | Helix | Business & Operation Readiness | 6.35 | Helix |  |  |  |
| 3429 | 1.11.1.4.3.1 | MDD Final Circular Completed | milestone | 0d | 2026-05-06 A | 2026-05-06 A |  | 100% |  |  |  | 2026-05-06 | 2026-05-06 | 0d | start no earlier than 2026-04-15 | Helix |  | 6.35 | Helix | Complete | COMPLETE |  |
| 3430 | 1.11.1.4.3.2 | MDD Manual Update |  | 2d | 2026-05-05 A | 2026-05-06 A | 3429 | 100% |  |  |  | 2026-05-05 | 2026-05-06 | 0d |  | Helix |  | 6.35 | Helix | Complete | COMPLETE |  |
| 3431 | 1.11.1.5 | **Migration Pathway 3 (MP3) and Migration Pathway 4 (MP4)** |  | 52d | 2026-03-27 A | 2026-06-09 A |  | 100% |  |  |  | 2026-03-27 | 2026-06-19 | 0d |  | Helix | Business & Operation Readiness | 6.50 | Helix |  |  | -650.67 |
| 3432 | 1.11.1.5.1 | **MP3 and MP4 - Service Activation Implementation** |  | 52d | 2026-03-27 A | 2026-06-09 A |  | 100% |  |  |  | 2026-05-15 | 2026-06-08 | 0d |  | Helix | Business & Operation Readiness | 6.50 | Helix |  |  |  |
| 3433 | 1.11.1.5.1.1 | PP to agree Effective from Date 40WD ahead of target PAB |  | 1d | 2026-03-27 A | 2026-03-27 A |  | 100% |  |  |  | 2026-03-27 | 2026-04-02 | 0d | start no earlier than 2026-04-02 | Helix |  | 6.50 | Helix | Complete | COMPLETE |  |
| 3434 | 1.11.1.5.1.2 | Market Entry to confirm PP's Effective from Date |  | 1d | 2026-05-13 A | 2026-05-13 A |  | 100% |  |  |  | 2026-05-15 | 2026-05-15 | 0d |  | Helix |  | 6.50 | Helix | Complete | COMPLETE |  |
| 3435 | 1.11.1.5.1.3 | PP is Qualified by Code Bodies | milestone | 0d | 2026-05-28 A | 2026-05-28 A | 2684 | 100% |  |  |  | 2026-05-28 | 2026-05-28 | 0d |  | Helix | Business & Operation Readiness | 6.50 | Helix | Complete | COMPLETE |  |
| 3436 | 1.11.1.5.1.4 | DIP Promoted to Production |  | 5d | 2026-05-29 A | 2026-06-04 A | 3435 | 100% |  |  |  | 2026-05-29 | 2026-06-04 | 0d | finish no earlier than 2025-11-06 | Helix | Business & Operation Readiness | 6.50 | Helix | Complete | COMPLETE |  |
| 3437 | 1.11.1.5.1.5 | Create M16 in Customer Solution |  | 1d | 2026-05-29 A | 2026-05-29 A | 3435 | 100% |  |  |  | 2026-05-29 | 2026-05-29 | 0d | finish no earlier than 2025-11-07 | Helix | Business & Operation Readiness | 6.50 | Helix | Complete | COMPLETE |  |
| 3438 | 1.11.1.5.1.6 | ISD Publish |  | 1d | 2026-06-01 A | 2026-06-01 A | 3435 | 100% |  |  |  | 2026-06-01 | 2026-06-01 | 0d | start no earlier than 2026-06-01 | Helix | Business & Operation Readiness | 6.50 | Helix | Complete | COMPLETE |  |
| 3439 | 1.11.1.5.1.7 | ISD Go-Live | milestone | 0d | 2026-06-08 A | 2026-06-08 A | 3438FS+5d | 100% |  |  |  | 2026-06-08 | 2026-06-08 | 0d | start no earlier than 2026-06-05 | Helix |  | 6.50 | Helix | Complete | COMPLETE |  |
| 3440 | 1.11.1.5.1.8 | MP3 and MP4 - Service Activation Implementation Complete (M) | milestone | 0d | 2026-06-09 A | 2026-06-09 A |  | 100% |  |  |  | 2026-06-09 | 2026-06-09 | 0d | start no earlier than 2026-06-09 | Helix | Business & Operation Readiness | 6.50 | Helix | Complete | COMPLETE |  |
| 3441 | 1.11.1.6 | **Migration Pathway 6 (MP6)** |  | 53d | 2026-04-24 A | 2026-07-07 |  | 99% | 0d |  |  | 2026-04-24 | 2026-07-07 | 0d |  | Helix | Business & Operation Readiness | 6.50 | Helix |  |  | -650.67 |
| 3442 | 1.11.1.6.1 | **MP6 - Service Activation Implementation** |  | 53d | 2026-04-24 A | 2026-07-07 A |  | 100% |  |  |  | 2026-04-24 | 2026-07-07 | 0d |  | Helix | Business & Operation Readiness | 6.50 | Helix |  |  |  |
| 3443 | 1.11.1.6.1.1 | PP to agree Effective from Date 40WD ahead of target PAB |  | 1d | 2026-04-24 A | 2026-04-24 A |  | 100% |  |  |  | 2026-04-24 | 2026-04-24 | 0d | start no earlier than 2026-04-24 | Helix |  | 6.50 | Helix | Complete | COMPLETE |  |
| 3444 | 1.11.1.6.1.2 | Market Entry to obtain Effective from Date from PP |  | 1d | 2026-06-11 A | 2026-06-11 A |  | 100% |  |  |  | 2026-06-11 | 2026-06-11 | 0d | start no earlier than 2026-06-11 | Helix |  | 6.50 | Helix | Complete | COMPLETE |  |
| 3445 | 1.11.1.6.1.3 | PP Qualified by Code Bodies | manual | 1d | 2026-06-25 A | 2026-06-25 A |  | 100% |  |  |  | 2026-06-25 | 2026-06-25 | 0d | start no earlier than 2026-06-25 | Helix | Business & Operation Readiness | 6.50 | Helix | Complete | COMPLETE |  |
| 3446 | 1.11.1.6.1.4 | DIP Promoted to Production | manual | 5d | 2026-06-26 A | 2026-07-02 A | 3445 | 100% |  |  |  | 2026-06-26 | 2026-07-02 | 0d | start no earlier than 2026-06-26 | Helix | Business & Operation Readiness | 6.50 | Helix | Complete | COMPLETE |  |
| 3447 | 1.11.1.6.1.5 | Create M16 in Customer Solution | manual | 1d | 2026-06-26 A | 2026-06-26 A |  | 100% |  |  |  | 2026-06-26 | 2026-06-26 | 0d | start no earlier than 2026-06-26 | Helix | Business & Operation Readiness | 6.50 | Helix | Complete | COMPLETE |  |
| 3448 | 1.11.1.6.1.6 | ISD Publish | manual | 1d | 2026-06-29 A | 2026-06-29 A | 3447SS | 100% |  |  |  | 2026-06-29 | 2026-06-29 | 0d | start no earlier than 2026-06-29 | Helix | Business & Operation Readiness | 6.50 | Helix | Complete | COMPLETE |  |
| 3449 | 1.11.1.6.1.7 | ISD Go-Live | milestone, manual | 0d | 2026-07-06 A | 2026-07-06 A | 3448FS+5d | 100% |  |  |  | 2026-07-06 | 2026-07-06 | 0d | start no earlier than 2026-07-06 | Helix |  | 6.50 | Helix | Complete | COMPLETE |  |
| 3450 | 1.11.1.6.1.8 | MP6 - Service Activation Implementation Complete (M) | milestone, manual | 0d | 2026-07-07 A | 2026-07-07 A | 3448 | 100% |  |  |  | 2026-07-07 | 2026-07-07 | 0d | start no earlier than 2026-07-07 | Helix | Business & Operation Readiness | 6.50 | Helix | Complete | COMPLETE |  |
| 3451 | 1.11.1.6.2 | **Migration Pathway 7 (MP7)** |  | 48d | 2026-05-21 A | 2026-07-28 A |  | 100% |  |  |  | 2026-05-21 | 2026-07-28 | 0d |  | Helix | Business & Operation Readiness | 6.50 | Helix |  |  | -650.67 |
| 3452 | 1.11.1.6.2.1 | **MP7 - Service Activation Implementation** |  | 48d | 2026-05-21 A | 2026-07-28 A |  | 100% |  |  |  | 2026-05-21 | 2026-07-28 | 0d |  | Helix | Business & Operation Readiness | 6.50 | Helix |  |  |  |
| 3453 | 1.11.1.6.2.1.1 | PP to agree Effective from Date 40WD ahead of target PAB | manual | 1d | 2026-05-21 A | 2026-05-21 A |  | 100% |  |  |  | 2026-05-21 | 2026-05-21 | 0d | start no earlier than 2026-05-21 | Helix |  | 6.50 | Helix | Complete | COMPLETE |  |
| 3454 | 1.11.1.6.2.1.2 | PP to submit MDD Change Request | manual | 5d | 2026-05-21 A | 2026-05-27 A |  | 100% |  |  |  | 2026-05-21 | 2026-05-27 | 0d | start no earlier than 2026-05-21 | Helix |  | 6.50 | Helix | Complete | COMPLETE |  |
| 3455 | 1.11.1.6.2.1.3 | Market Entry to obtain Effective from Date from PP | manual | 1d | 2026-07-01 A | 2026-07-01 A |  | 100% |  |  |  | 2026-07-01 | 2026-07-01 | 0d | start no earlier than 2026-07-01 | Helix |  | 6.50 | Helix | Complete | COMPLETE |  |
| 3456 | 1.11.1.6.2.1.4 | PP Qualified by Code Bodies | milestone, manual | 0d | 2026-07-15 A | 2026-07-15 A |  | 100% |  |  |  | 2026-07-15 | 2026-07-15 | 0d | start no earlier than 2026-07-15 | Helix | Business & Operation Readiness | 6.50 | Helix | Complete | COMPLETE |  |
| 3457 | 1.11.1.6.2.1.5 | DIP Promoted to Production | manual | 5d | 2026-07-16 A | 2026-07-22 A |  | 100% |  |  |  | 2026-07-16 | 2026-07-22 | 0d | start no earlier than 2026-07-16 | Helix | Business & Operation Readiness | 6.50 | Helix | Complete | COMPLETE |  |
| 3458 | 1.11.1.6.2.1.6 | Create M16 in Customer Solution | manual | 1d | 2026-07-16 A | 2026-07-16 A | 3456 | 100% |  |  |  | 2026-07-16 | 2026-07-16 | 0d | start no earlier than 2026-07-16 | Helix | Business & Operation Readiness | 6.50 | Helix | Complete | COMPLETE |  |
| 3459 | 1.11.1.6.2.1.7 | MDD & ISD Publish | manual | 1d | 2026-07-20 A | 2026-07-20 A | 3458SS | 100% |  |  |  | 2026-07-20 | 2026-07-20 | 0d | start no earlier than 2026-07-20 | Helix | Business & Operation Readiness | 6.50 | Helix | Complete | COMPLETE |  |
| 3460 | 1.11.1.6.2.1.8 | MDD & ISD Go-Live | milestone, manual | 0d | 2026-07-27 A | 2026-07-27 A | 3459FS+5d | 100% |  |  |  | 2026-07-27 | 2026-07-27 | 0d |  | Helix |  | 6.50 | Helix | Complete | COMPLETE |  |
| 3461 | 1.11.1.6.2.1.9 | MP7 - Service Activation Implementation Complete (M) | milestone, manual | 0d | 2026-07-28 A | 2026-07-28 A | 3459 | 100% |  |  |  | 2026-07-28 | 2026-07-28 | 0d | start no earlier than 2026-07-28 | Helix | Business & Operation Readiness | 6.50 | Helix | Complete | COMPLETE |  |

Notes:
- 3428: 25/02/26: Programme and Elexon are working to update the Service Activation plan for Non-SIT PPs to reflect the ISD / MDD Calendar.
- 3431: 15/05/26: Task renamed to align with Migration Pathways, replacing the previous Waves approach. Migration Pathways 3 and 4 have been combined as no participants are service activating in MP3. / 25/02/26 - Programme and Elexon are working to update the Service Activation plan for Non-SIT PPs to reflect the ISD / MDD Calendar.
- 3432: 25/02/26: Programme and Elexon are working to update the Service Activation plan for Non-SIT PPs to reflect the ISD / MDD Calendar.
- 3434: 15/05/26: Task name changed from Market Entry to obtain Effective from Date from PP to Market Entry to confirm PP's Effective from Date, aligning with workstream processes in which the Effective from Date is obtained 40WD before a PPs target PAB a
- 3438: 19/05/26: Task date changed from 29/05 to 01/06 in line with the updated ISD/MDD calendar. Task name updated to from 'MDD & ISD Publish' to 'ISD Publish' to reflect the new calendar.
- 3439: 19/05/26: Task date changed from 05/06 to 08/06 in line with the updated ISD/MDD calendar. Task name updated to from 'MDD & ISD Go-Live' to 'ISD Go-Live' to reflect the new calendar.
- 3441: 15/05/26: Task renamed to align with Migration Pathways, replacing the previous Waves approach. / 25/02/26 - Programme and Elexon are working to update the Service Activation plan for Non-SIT PPs to reflect the ISD / MDD Calendar.
- 3442: 25/02/26: Programme and Elexon are working to update the Service Activation plan for Non-SIT PPs to reflect the ISD / MDD Calendar.
- 3445: 20/05/26: Line item changed from 'MHHSP Enabled Confirmation' to 'PP Qualified by Code Bodies'.
- 3451: 15/05/26: Task renamed to align with Migration Pathways, replacing the previous Waves approach. / 25/02/26 - Programme and Elexon are working to update the Service Activation plan for Non-SIT PPs to reflect the ISD / MDD Calendar.

| ID | WBS | Task | Type | Duration | Start | Finish | Predecessors | Complete | Baseline start | Baseline finish | Baseline duration | Constraint | Responsible | Text9 | Update Version | MHHS Resource Name | Sched Status | RAG | Task Status |
| --- | --- | --- | --- | --- | --- | --- | --- | --- | --- | --- | --- | --- | --- | --- | --- | --- | --- | --- | --- |
| 3462 | 1.11.1.6.2.2 | **MP7 - Service Activation Implementation MDD** |  | 2d | 2026-07-16 A | 2026-07-17 A |  | 100% | 2026-07-16 | 2026-07-17 | 0d |  | Helix | Business & Operation Readiness | 6.50 | Helix |  |  |  |
| 3463 | 1.11.1.6.2.2.1 | MDD Final Circular Completed | milestone | 0d | 2026-07-17 A | 2026-07-17 A |  | 100% | 2026-07-17 | 2026-07-17 | 0d | start no earlier than 2026-07-17 | Helix |  | 6.50 | Helix | Complete | COMPLETE |  |
| 3464 | 1.11.1.6.2.2.2 | MDD Manual Update |  | 2d | 2026-07-16 A | 2026-07-17 A |  | 100% | 2026-07-16 | 2026-07-17 | 0d | start no earlier than 2026-07-16 | Helix |  | 6.50 | Helix | Complete | COMPLETE |  |
| 3465 | 1.11.1.6.3 | **Migration Pathway 8 (MP8)** |  | 48d | 2026-06-04 A | 2026-08-11 A |  | 100% | 2026-06-04 | 2026-08-11 | 0d |  | Helix | Business & Operation Readiness | 6.50 | Helix |  |  | -650.67 |
| 3466 | 1.11.1.6.3.1 | **MP8 - Service Activation Implementation** |  | 48d | 2026-06-04 A | 2026-08-11 A |  | 100% | 2026-06-04 | 2026-08-11 | 0d |  | Helix | Business & Operation Readiness | 6.50 | Helix |  |  |  |
| 3467 | 1.11.1.6.3.1.1 | PP to agree Effective from Date 40WD ahead of target PAB |  | 1d | 2026-06-04 A | 2026-06-04 A |  | 100% | 2026-06-04 | 2026-06-04 | 0d | start no earlier than 2026-06-04 | Helix |  | 6.50 | Helix | Complete | COMPLETE |  |
| 3468 | 1.11.1.6.3.1.2 | Market Entry to obtain Effective from Date from PP |  | 1d | 2026-07-16 A | 2026-07-16 A |  | 100% | 2026-07-16 | 2026-07-16 | 0d | start no earlier than 2026-07-16 | Helix |  | 6.50 | Helix | Complete | COMPLETE |  |
| 3469 | 1.11.1.6.3.1.3 | PP Qualified by Code Bodies | milestone | 0d | 2026-07-30 A | 2026-07-30 A |  | 100% | 2026-09-24 | 2026-09-24 | 0d | start no earlier than 2026-07-30 | Helix | Business & Operation Readiness | 6.50 | Helix | Complete | COMPLETE |  |
| 3470 | 1.11.1.6.3.1.4 | DIP Promoted to Production |  | 5d | 2026-07-31 A | 2026-08-06 A | 3469 | 100% | 2026-07-31 | 2026-08-06 | 0d | start no earlier than 2026-07-31 | Helix | Business & Operation Readiness | 6.50 | Helix | Complete | COMPLETE |  |
| 3471 | 1.11.1.6.3.1.5 | Create M16 in Customer Solution |  | 1d | 2026-07-31 A | 2026-07-31 A | 3469 | 100% | 2026-09-25 | 2026-09-25 | 0d | start no earlier than 2026-07-31 | Helix | Business & Operation Readiness | 6.50 | Helix | Complete | COMPLETE |  |
| 3472 | 1.11.1.6.3.1.6 | ISD Publish |  | 1d | 2026-08-03 A | 2026-08-03 A | 3471SS | 100% | 2026-09-25 | 2026-09-25 | 0d | start no earlier than 2026-08-03 | Helix | Business & Operation Readiness | 6.50 | Helix | Complete | COMPLETE |  |
| 3473 | 1.11.1.6.3.1.7 | ISD Go-Live | milestone | 0d | 2026-08-10 A | 2026-08-10 A | 3472FS+5d | 100% | 2026-08-10 | 2026-08-10 | 0d |  | Helix |  | 6.50 | Helix | Complete | COMPLETE |  |
| 3474 | 1.11.1.6.3.1.8 | MP8 - Service Activation Implementation Complete (M) | milestone | 0d | 2026-08-11 A | 2026-08-11 A | 3472 | 100% | 2026-08-11 | 2026-08-11 | 0d | start no earlier than 2026-08-11 | Helix | Business & Operation Readiness | 6.50 | Helix | Complete | COMPLETE |  |
| 3475 | 1.11.1.6.4 | **Migration Pathway 9 (MP9)** |  | 48d | 2026-06-18 A | 2026-08-25 A |  | 100% | 2026-07-03 | 2026-09-09 | 0d |  | Helix | Business & Operation Readiness | 6.50 | Helix |  |  | -650.67 |
| 3476 | 1.11.1.6.4.1 | **MP9 - Service Activation Implementation** |  | 48d | 2026-06-18 A | 2026-08-25 A |  | 100% | 2026-06-18 | 2026-08-25 | 0d |  | Helix | Business & Operation Readiness | 6.50 | Helix |  |  |  |
| 3477 | 1.11.1.6.4.1.1 | PP to agree Effective from Date 40WD ahead of target PAB |  | 1d | 2026-06-18 A | 2026-06-18 A |  | 100% | 2026-06-18 | 2026-06-18 | 0d | start no earlier than 2026-06-18 | Helix |  | 6.50 | Helix | Complete | COMPLETE |  |
| 3478 | 1.11.1.6.4.1.2 | PP to submit MDD Change Request |  | 5d | 2026-06-18 A | 2026-06-24 A |  | 100% | 2026-06-18 | 2026-06-24 | 0d | start no earlier than 2026-06-18 | Helix |  | 6.50 | Helix | Complete | COMPLETE |  |
| 3479 | 1.11.1.6.4.1.3 | Market Entry to obtain Effective from Date from PP |  | 1d | 2026-07-29 A | 2026-07-29 A |  | 100% | 2026-09-11 | 2026-09-11 | 0d | start no earlier than 2026-07-29 | Helix |  | 6.50 | Helix | Complete | COMPLETE |  |
| 3480 | 1.11.1.6.4.1.4 | PP Qualified by Code Bodies | milestone | 0d | 2026-08-12 A | 2026-08-12 A |  | 100% | 2026-09-24 | 2026-09-24 | 0d | start no earlier than 2026-08-12 | Helix | Business & Operation Readiness | 6.50 | Helix | Complete | COMPLETE |  |
| 3481 | 1.11.1.6.4.1.5 | DIP Promoted to Production |  | 5d | 2026-08-13 A | 2026-08-19 A | 3480 | 100% | 2026-09-25 | 2026-10-01 | 0d | start no earlier than 2026-08-13 | Helix | Business & Operation Readiness | 6.50 | Helix | Complete | COMPLETE |  |
| 3482 | 1.11.1.6.4.1.6 | Create M16 in Customer Solution |  | 1d | 2026-08-13 A | 2026-08-13 A | 3480 | 100% | 2026-09-25 | 2026-09-25 | 0d | start no earlier than 2026-08-13 | Helix | Business & Operation Readiness | 6.50 | Helix | Complete | COMPLETE |  |
| 3483 | 1.11.1.6.4.1.7 | MDD & ISD Publish |  | 1d | 2026-08-17 A | 2026-08-17 A | 3482SS | 100% | 2026-09-25 | 2026-09-25 | 0d | start no earlier than 2026-08-17 | Helix | Business & Operation Readiness | 6.50 | Helix | Complete | COMPLETE |  |
| 3484 | 1.11.1.6.4.1.8 | MDD & ISD Go-Live | milestone | 0d | 2026-08-24 A | 2026-08-24 A | 3483FS+5d | 100% | 2026-10-02 | 2026-10-02 | 0d |  | Helix |  | 6.50 | Helix | Complete | COMPLETE |  |
| 3485 | 1.11.1.6.4.1.9 | MP9 - Service Activation Implementation Complete (M) | milestone | 0d | 2026-08-25 A | 2026-08-25 A | 3483 | 100% | 2026-10-05 | 2026-10-05 | 0d | start no earlier than 2026-08-25 | Helix | Business & Operation Readiness | 6.50 | Helix | Complete | COMPLETE |  |

Notes:
- 3465: 15/05/26: Task renamed to align with Migration Pathways, replacing the previous Waves approach. / 25/02/26 - Programme and Elexon are working to update the Service Activation plan for Non-SIT PPs to reflect the ISD / MDD Calendar.
- 3475: 15/05/26: Task renamed to align with Migration Pathways, replacing the previous Waves approach. / 25/02/26 - Programme and Elexon are working to update the Service Activation plan for Non-SIT PPs to reflect the ISD / MDD Calendar.

| ID | WBS | Task | Type | Duration | Start | Finish | Predecessors | Complete | Actual finish | Baseline start | Baseline finish | Baseline duration | Constraint | Responsible | Text9 | Update Version | MHHS Resource Name | Sched Status | RAG | Task Status |
| --- | --- | --- | --- | --- | --- | --- | --- | --- | --- | --- | --- | --- | --- | --- | --- | --- | --- | --- | --- | --- |
| 3486 | 1.11.1.6.4.2 | **MP9 - Service Activation Implementation MDD** |  | 2d | 2026-08-13 A | 2026-08-14 A |  | 100% |  | 2026-08-13 | 2026-08-14 | 0d |  | Helix | Business & Operation Readiness | 6.50 | Helix |  |  |  |
| 3487 | 1.11.1.6.4.2.1 | MDD Final Circular Completed | milestone | 0d | 2026-08-14 A | 2026-08-14 A |  | 100% |  | 2026-08-14 | 2026-08-14 | 0d | start no earlier than 2026-08-14 | Helix |  | 6.50 | Helix | Complete | COMPLETE |  |
| 3488 | 1.11.1.6.4.2.2 | MDD Manual Update |  | 2d | 2026-08-13 A | 2026-08-14 A |  | 100% |  | 2026-08-13 | 2026-08-14 | 0d | start no earlier than 2026-08-13 | Helix |  | 6.50 | Helix | Complete | COMPLETE |  |
| 3489 | 1.11.1.6.5 | **Migration Pathway 10 (MP10)** |  | 48d | 2026-07-03 A | 2026-09-08 |  | 100% | 2026-09-09 | 2026-07-03 | 2026-09-09 | 0d |  | Helix | Business & Operation Readiness | 6.50 | Helix |  |  | -650.67 |
| 3490 | 1.11.1.6.5.1 | **MP10 - Service Activation Implementation** |  | 48d | 2026-07-03 A | 2026-09-08 |  | 100% | 2026-09-09 | 2026-07-03 | 2026-09-09 | 0d |  | Helix | Business & Operation Readiness | 6.50 | Helix |  |  |  |
| 3491 | 1.11.1.6.5.1.1 | PP to agree Effective from Date 40WD ahead of target PAB |  | 1d | 2026-07-03 A | 2026-07-03 A |  | 100% |  | 2026-07-03 | 2026-07-03 | 0d | start no earlier than 2026-07-03 | Helix |  | 6.50 | Helix | Complete | COMPLETE |  |
| 3492 | 1.11.1.6.5.1.2 | Market Entry to obtain Effective from Date from PP |  | 1d | 2026-08-13 A | 2026-08-13 A |  | 100% |  | 2026-08-13 | 2026-08-13 | 0d | start no earlier than 2026-08-13 | Helix |  | 6.50 | Helix | Complete | COMPLETE |  |
| 3493 | 1.11.1.6.5.1.3 | PP Qualified by Code Bodies | milestone | 0d | 2026-08-27 A | 2026-08-27 A |  | 100% |  | 2026-08-27 | 2026-08-27 | 0d | start no earlier than 2026-08-27 | Helix | Business & Operation Readiness | 6.50 | Helix | Complete | COMPLETE |  |
| 3494 | 1.11.1.6.5.1.4 | DIP Promoted to Production |  | 5d | 2026-08-28 A | 2026-09-03 A | 3493 | 100% |  | 2026-08-28 | 2026-09-03 | 0d | start no earlier than 2026-08-28 | Helix | Business & Operation Readiness | 6.50 | Helix | Complete | COMPLETE |  |
| 3495 | 1.11.1.6.5.1.5 | Create M16 in Customer Solution |  | 1d | 2026-08-28 A | 2026-08-28 A | 3493 | 100% |  | 2026-08-28 | 2026-08-28 | 0d | start no earlier than 2026-08-28 | Helix | Business & Operation Readiness | 6.50 | Helix | Complete | COMPLETE |  |
| 3496 | 1.11.1.6.5.1.6 | ISD Publish |  | 1d | 2026-09-01 A | 2026-09-01 A | 3495SS | 100% |  | 2026-09-01 | 2026-09-01 | 0d | start no earlier than 2026-09-01 | Helix | Business & Operation Readiness | 6.50 | Helix | Complete | COMPLETE |  |
| 3497 | 1.11.1.6.5.1.7 | ISD Go-Live | milestone | 0d | 2026-09-08 A | 2026-09-08 A | 3496FS+5d | 100% |  | 2026-09-08 | 2026-09-08 | 0d | start no earlier than 2026-09-08 | Helix |  | 6.50 | Helix | Complete | COMPLETE |  |
| 3498 | 1.11.1.6.5.1.8 | MP10 - Service Activation Implementation Complete (M) | milestone | 0d | 2026-09-09 A | 2026-09-09 A | 3496 | 100% |  | 2026-09-09 | 2026-09-09 | 0d | start no earlier than 2026-09-09 | Helix | Business & Operation Readiness | 6.50 | Helix | Complete | COMPLETE |  |
| 3499 | 1.11.1.6.6 | **Migration Pathway 11 (MP11)** |  | 51d | 2026-07-13 A | 2026-09-22 A |  | 100% |  | 2026-07-13 | 2026-09-22 | 0d |  | Helix | Business & Operation Readiness | 6.50 | Helix |  |  | -650.67 |
| 3500 | 1.11.1.6.6.1 | **MP11 - Service Activation Implementation** |  | 51d | 2026-07-13 A | 2026-09-22 A |  | 100% |  | 2026-07-13 | 2026-09-22 | 0d |  | Helix | Business & Operation Readiness | 6.50 | Helix |  |  |  |
| 3501 | 1.11.1.6.6.1.1 | PP to agree Effective from Date 40WD ahead of target PAB |  | 1d | 2026-07-13 A | 2026-07-13 A |  | 100% |  | 2026-07-13 | 2026-07-13 | 0d | start no earlier than 2026-07-13 | Helix |  | 6.50 | Helix | Complete | COMPLETE |  |
| 3502 | 1.11.1.6.6.1.2 | PP to submit MDD Change Request |  | 5d | 2026-07-13 A | 2026-07-17 A |  | 100% |  | 2026-07-13 | 2026-07-17 | 0d | start no earlier than 2026-07-13 | Helix |  | 6.50 | Helix | Complete | COMPLETE |  |
| 3503 | 1.11.1.6.6.1.3 | Market Entry to obtain Effective from Date from PP |  | 1d | 2026-08-25 A | 2026-08-25 A |  | 100% |  | 2026-09-11 | 2026-09-11 | 0d | start no earlier than 2026-08-25 | Helix |  | 6.50 | Helix | Complete | COMPLETE |  |
| 3504 | 1.11.1.6.6.1.4 | PP Qualified by Code Bodies | milestone | 0d | 2026-09-09 A | 2026-09-09 A |  | 100% |  | 2026-09-24 | 2026-09-24 | 0d | start no earlier than 2026-09-09 | Helix | Business & Operation Readiness | 6.50 | Helix | Complete | COMPLETE |  |
| 3505 | 1.11.1.6.6.1.5 | DIP Promoted to Production |  | 5d | 2026-09-10 A | 2026-09-16 A | 3504 | 100% |  | 2026-09-25 | 2026-10-01 | 0d | start no earlier than 2026-09-10 | Helix | Business & Operation Readiness | 6.50 | Helix | Complete | COMPLETE |  |
| 3506 | 1.11.1.6.6.1.6 | Create M16 in Customer Solution |  | 1d | 2026-09-10 A | 2026-09-10 A | 3504 | 100% |  | 2026-09-25 | 2026-09-25 | 0d | start no earlier than 2026-09-10 | Helix | Business & Operation Readiness | 6.50 | Helix | Complete | COMPLETE |  |
| 3507 | 1.11.1.6.6.1.7 | MDD & ISD Publish |  | 1d | 2026-09-14 A | 2026-09-14 A | 3506SS | 100% |  | 2026-09-25 | 2026-09-25 | 0d | start no earlier than 2026-09-14 | Helix | Business & Operation Readiness | 6.50 | Helix | Complete | COMPLETE |  |
| 3508 | 1.11.1.6.6.1.8 | MDD & ISD Go-Live | milestone | 0d | 2026-09-21 A | 2026-09-21 A | 3507FS+5d | 100% |  | 2026-10-02 | 2026-10-02 | 0d | start no earlier than 2026-09-21 | Helix |  | 6.50 | Helix | Complete | COMPLETE |  |
| 3509 | 1.11.1.6.6.1.9 | MP11 - Service Activation Implementation Complete (M) | milestone | 0d | 2026-09-22 A | 2026-09-22 A | 3507 | 100% |  | 2026-10-05 | 2026-10-05 | 0d | start no earlier than 2026-09-22 | Helix | Business & Operation Readiness | 6.50 | Helix | Complete | COMPLETE |  |

Notes:
- 3489: 15/05/26: Task renamed to align with Migration Pathways, replacing the previous Waves approach. / 25/02/26 - Programme and Elexon are working to update the Service Activation plan for Non-SIT PPs to reflect the ISD / MDD Calendar.
- 3499: 15/05/26: Task renamed to align with Migration Pathways, replacing the previous Waves approach. / 25/02/26 - Programme and Elexon are working to update the Service Activation plan for Non-SIT PPs to reflect the ISD / MDD Calendar.

| ID | WBS | Task | Type | Duration | Start | Finish | Predecessors | Complete | Remaining | Actual finish | Baseline start | Baseline finish | Baseline duration | Total slack | Constraint | Responsible | Text9 | Update Version | MHHS Resource Name | Sched Status | RAG | Task Status |
| --- | --- | --- | --- | --- | --- | --- | --- | --- | --- | --- | --- | --- | --- | --- | --- | --- | --- | --- | --- | --- | --- | --- |
| 3510 | 1.11.1.6.6.2 | **MP11 - Service Activation Implementation MDD** |  | 2d | 2026-08-13 A | 2026-08-14 |  | 100% |  | 2026-09-11 | 2026-08-13 | 2026-08-14 | 0d |  |  | Helix | Business & Operation Readiness | 6.50 | Helix |  |  |  |
| 3511 | 1.11.1.6.6.2.1 | MDD Final Circular Completed | milestone | 0d | 2026-09-11 A | 2026-09-11 A |  | 100% |  |  | 2026-09-11 | 2026-09-11 | 0d |  | start no earlier than 2026-09-11 | Helix |  | 6.50 | Helix | Complete | COMPLETE |  |
| 3512 | 1.11.1.6.6.2.2 | MDD Manual Update |  | 2d | 2026-08-13 A | 2026-08-14 A |  | 100% |  |  | 2026-08-13 | 2026-08-14 | 0d |  | finish no earlier than 2026-08-14 | Helix |  | 6.50 | Helix | Complete | COMPLETE |  |
| 3513 | 1.11.1.6.7 | **Migration Pathway 12a (MP12a)** |  | 49d | 2026-07-29 A | 2026-10-06 A |  | 100% |  |  | 2026-07-29 | 2026-10-06 | 0d |  |  | Helix | Business & Operation Readiness | 6.50 | Helix |  |  | -650.67 |
| 3514 | 1.11.1.6.7.1 | **MP12a - Service Activation Implementation** |  | 49d | 2026-07-29 A | 2026-10-06 A |  | 100% |  |  | 2026-07-29 | 2026-10-06 | 0d |  |  | Helix | Business & Operation Readiness | 6.50 | Helix |  |  |  |
| 3515 | 1.11.1.6.7.1.1 | PP to agree Effective from Date 40WD ahead of target PAB |  | 1d | 2026-07-29 A | 2026-07-29 A |  | 100% |  |  | 2026-07-29 | 2026-07-29 | 0d |  | start no earlier than 2026-07-29 | Helix |  | 6.50 | Helix | Complete | COMPLETE |  |
| 3516 | 1.11.1.6.7.1.2 | Market Entry to obtain Effective from Date from PP |  | 1d | 2026-09-10 A | 2026-09-10 A |  | 100% |  |  | 2026-09-10 | 2026-09-10 | 0d |  | start no earlier than 2026-09-10 | Helix |  | 6.50 | Helix | Complete | COMPLETE |  |
| 3517 | 1.11.1.6.7.1.3 | PP Qualified by Code Bodies | milestone | 0d | 2026-09-24 A | 2026-09-24 A | 2753 | 100% |  |  | 2026-09-24 | 2026-09-24 | 0d |  | start no earlier than 2026-09-23 | Helix | Business & Operation Readiness | 6.50 | Helix | Complete | COMPLETE |  |
| 3518 | 1.11.1.6.7.1.4 | DIP Promoted to Production |  | 5d | 2026-09-25 A | 2026-10-01 A | 3517 | 100% |  |  | 2026-09-25 | 2026-10-01 | 0d |  | finish no earlier than 2026-03-05 | Helix | Business & Operation Readiness | 6.50 | Helix | Complete | COMPLETE |  |
| 3519 | 1.11.1.6.7.1.5 | Create M16 in Customer Solution |  | 1d | 2026-09-25 A | 2026-09-25 A | 3517 | 100% |  |  | 2026-09-25 | 2026-09-25 | 0d |  | start no earlier than 2026-09-25 | Helix | Business & Operation Readiness | 6.50 | Helix | Complete | COMPLETE |  |
| 3520 | 1.11.1.6.7.1.6 | ISD Publish |  | 1d | 2026-09-28 A | 2026-09-28 A | 3519SS | 100% |  |  | 2026-09-28 | 2026-09-28 | 0d |  | start no earlier than 2026-09-28 | Helix | Business & Operation Readiness | 6.50 | Helix | Complete | COMPLETE |  |
| 3521 | 1.11.1.6.7.1.7 | ISD Go-Live | milestone | 0d | 2026-10-05 A | 2026-10-05 A | 3520FS+5d | 100% |  |  | 2026-10-05 | 2026-10-05 | 0d |  |  | Helix |  | 6.50 | Helix | Complete | COMPLETE |  |
| 3522 | 1.11.1.6.7.1.8 | MP12a - Service Activation Implementation Complete (M) | milestone | 0d | 2026-10-06 A | 2026-10-06 A | 3520 | 100% |  |  | 2026-10-06 | 2026-10-06 | 0d |  | start no earlier than 2026-10-06 | Helix | Business & Operation Readiness | 6.50 | Helix | Complete | COMPLETE |  |
| 3523 | 1.11.1.6.8 | **Migration Pathway 12b (MP12b)** |  | 64d | 2026-07-29 A | 2026-10-27 |  | 99% | 0d |  | 2026-07-29 | 2026-10-27 | 0d | 303d |  | Helix | Business & Operation Readiness | 6.50 | Helix |  |  | -650.67 |
| 3524 | 1.11.1.6.8.1 | **MP12b - Service Activation Implementation** |  | 64d | 2026-07-29 A | 2026-10-27 |  | 99% | 0d |  | 2026-07-29 | 2026-10-27 | 0d | 303d |  | Helix | Business & Operation Readiness | 6.50 | Helix |  |  |  |
| 3525 | 1.11.1.6.8.1.1 | PP to agree Effective from Date 40WD ahead of target PAB |  | 1d | 2026-07-29 A | 2026-07-29 A |  | 100% |  |  | 2026-07-29 | 2026-07-29 | 0d |  | start no earlier than 2026-07-29 | Helix |  | 6.50 | Helix | Complete | COMPLETE |  |
| 3526 | 1.11.1.6.8.1.2 | PP to submit MDD Change Request |  | 5d | 2026-07-29 A | 2026-08-04 A |  | 100% |  |  | 2026-07-29 | 2026-08-04 | 0d |  | start no earlier than 2026-07-29 | Helix |  | 6.50 | Helix | Complete | COMPLETE |  |
| 3527 | 1.11.1.6.8.1.3 | Market Entry to obtain Effective from Date from PP |  | 1d | 2026-09-10 A | 2026-09-10 A |  | 100% |  |  | 2026-09-11 | 2026-09-11 | 0d |  | start no earlier than 2026-09-10 | Helix |  | 6.50 | Helix | Complete | COMPLETE |  |
| 3528 | 1.11.1.6.8.1.4 | PP Qualified by Code Bodies | milestone | 0d | 2026-09-24 A | 2026-09-24 A | 2753 | 100% |  |  | 2026-09-24 | 2026-09-24 | 0d |  | start no earlier than 2026-09-23 | Helix | Business & Operation Readiness | 6.50 | Helix | Complete | COMPLETE |  |
| 3529 | 1.11.1.6.8.1.5 | DIP Promoted to Production |  | 5d | 2026-09-25 A | 2026-10-01 A | 3528 | 100% |  |  | 2026-09-25 | 2026-10-01 | 0d |  | finish no earlier than 2026-03-05 | Helix | Business & Operation Readiness | 6.50 | Helix | Complete | COMPLETE |  |
| 3530 | 1.11.1.6.8.1.6 | Create M16 in Customer Solution |  | 1d | 2026-09-25 A | 2026-09-25 A | 3528 | 100% |  |  | 2026-09-25 | 2026-09-25 | 0d |  | start no earlier than 2026-09-25 | Helix | Business & Operation Readiness | 6.50 | Helix | Complete | COMPLETE |  |
| 3531 | 1.11.1.6.8.1.7 | MDD & ISD Publish |  | 1d | 2026-10-19 A | 2026-10-19 A | 3530SS | 100% |  |  | 2026-10-19 | 2026-10-19 | 0d |  | start no earlier than 2026-10-19 | Helix | Business & Operation Readiness | 6.50 | Helix | Complete | COMPLETE |  |
| 3532 | 1.11.1.6.8.1.8 | MDD & ISD Go-Live | milestone | 0d | 2026-10-26 | 2026-10-26 | 3531FS+5d |  |  |  | 2026-10-26 | 2026-10-26 | 0d | 303d | start no earlier than 2026-10-26 | Helix |  | 6.50 | Helix | Green | GREEN | 5.71 |
| 3533 | 1.11.1.6.8.1.9 | MP12a - Service Activation Implementation Complete (M) | milestone | 0d | 2026-10-27 | 2026-10-27 | 3531 |  |  |  | 2026-10-27 | 2026-10-27 | 0d | 303d | start no earlier than 2026-10-27 | Helix | Business & Operation Readiness | 6.50 | Helix | Green | GREEN | 6.33 |

Notes:
- 3513: 15/05/26: Task renamed to align with Migration Pathways, replacing the previous Waves approach. / 25/02/26 - Programme and Elexon are working to update the Service Activation plan for Non-SIT PPs to reflect the ISD / MDD Calendar.
- 3523: 15/05/26: Task renamed to align with Migration Pathways, replacing the previous Waves approach. / 25/02/26 - Programme and Elexon are working to update the Service Activation plan for Non-SIT PPs to reflect the ISD / MDD Calendar.

| ID | WBS | Task | Type | Duration | Start | Finish | Predecessors | Complete | Actual finish | Baseline start | Baseline finish | Baseline duration | Baseline 1 start | Baseline 1 finish | Constraint | Baseline cost | Responsible | Text9 | Update Version | MHHS Resource Name | Sched Status | RAG | Involved | MHHS Programme Phase | Artefact ID | Task Status | Action |
| --- | --- | --- | --- | --- | --- | --- | --- | --- | --- | --- | --- | --- | --- | --- | --- | --- | --- | --- | --- | --- | --- | --- | --- | --- | --- | --- | --- |
| 3534 | 1.11.1.6.8.2 | **MP12b - Service Activation Implementation MDD** |  | 2d | 2026-10-15 A | 2026-10-16 A |  | 100% |  | 2026-10-15 | 2026-10-16 | 0d |  |  |  |  | Helix | Business & Operation Readiness | 6.50 | Helix |  |  |  |  |  |  |  |
| 3535 | 1.11.1.6.8.2.1 | MDD Final Circular Completed | milestone | 0d | 2026-10-16 A | 2026-10-16 A |  | 100% |  | 2026-10-16 | 2026-10-16 | 0d |  |  | start no earlier than 2026-10-16 |  | Helix |  | 6.50 | Helix | Complete | COMPLETE |  |  |  |  |  |
| 3536 | 1.11.1.6.8.2.2 | MDD Manual Update |  | 2d | 2026-10-15 A | 2026-10-16 A |  | 100% |  | 2026-10-15 | 2026-10-16 | 0d |  |  | start no earlier than 2026-10-15 |  | Helix |  | 6.50 | Helix | Complete | COMPLETE |  |  |  |  |  |
| 3537 | 1.11.2 | **Implement Early Life Support Plan** |  | 55d | 2025-07-07 A | 2025-09-19 A |  | 100% |  | 2025-07-07 | 2025-09-19 | 45d | 2025-01-06 | 2025-02-28 |  | -0 | N/A | Business & Operation Readiness | 5.0 | N/A |  |  | N/A | Business & Operational Readiness |  |  |  |
| 3538 | 1.11.2.1 | Implement Early Life Support Plan |  | 55d | 2025-07-07 A | 2025-09-19 A |  | 100% |  | 2025-07-07 | 2025-09-19 | 45d | 2025-02-28 | 2025-02-28 | start no earlier than 2025-07-07 |  | SI Transition | Business & Operation Readiness | 5.23 | Matthew Breen | Complete | COMPLETE | SI Transition,CPT | Business & Operational Readiness | MHHS-ART095 |  |  |
| 3539 | 1.11.3 | **Early Life Support Phase** |  | 81d | 2025-10-23 A | 2026-02-12 A |  | 100% |  | 2025-10-23 | 2026-01-22 | 0d |  |  |  |  | SI Transition |  | 6.37 | Matthew Breen |  |  |  |  |  | -1098.67 |  |
| 3540 | 1.11.3.1 | Phase 1 End |  | 26d | 2025-10-23 A | 2025-11-27 A | 3383 | 100% |  | 2025-10-23 | 2025-11-20 | 0d |  |  |  |  | SI Transition |  | 6.38 | Matthew Breen | Complete | COMPLETE |  |  |  |  |  |
| 3541 | 1.11.3.2 | Phase 2 End |  | 20d | 2025-11-21 A | 2025-12-18 A | 3540SS | 100% |  | 2025-11-21 | 2025-12-18 | 0d |  |  | start no earlier than 2025-11-21 |  | SI Transition |  | 6.37 | Matthew Breen | Complete | COMPLETE |  |  |  |  |  |
| 3542 | 1.11.3.3 | Phase 3 End/Early Life Exit |  | 40d | 2025-12-19 A | 2026-02-12 A | 3541 | 100% |  | 2025-12-19 | 2026-02-12 | 0d |  |  | finish no earlier than 2026-02-12 |  | SI Transition |  | 6.39 | Matthew Breen | Complete | COMPLETE |  |  |  |  |  |
| 3543 | 1.11.4 | **Business Continuity and Disaster Recovery Plan** |  | 40d | 2025-07-31 A | 2025-09-24 A |  | 100% |  | 2025-07-31 | 2025-09-24 | 40d | 2025-01-13 | 2025-03-07 |  |  | N/A | Business & Operation Readiness | 5.0 | N/A |  |  | N/A | Business & Operational Readiness |  |  |  |
| 3544 | 1.11.4.1 | Central Parties BCDRs in Place |  | 20d | 2025-07-31 A | 2025-08-27 A | 2945FS-38d | 100% |  | 2025-07-31 | 2025-08-27 | 20d | 2025-01-13 | 2025-02-07 |  |  | SI Design | Business & Operation Readiness | 5.0 | MHHS Programme | Complete | COMPLETE |  | Business & Operational Readiness |  |  |  |
| 3545 | 1.11.4.2 | Risk Based Assurance of Cental Party BCDRs |  | 20d | 2025-08-28 A | 2025-09-24 A | 3544 | 100% |  | 2025-08-28 | 2025-09-24 | 20d | 2025-02-10 | 2025-03-07 |  |  | PP | Business & Operation Readiness | 5.0 | MHHS Programme | Complete | COMPLETE | SI Design | Business & Operational Readiness |  |  |  |
| 3546 | 1.11.5 | **PP Business Change** |  | 129d | 2025-02-03 A | 2025-07-31 A |  | 100% |  | 2025-02-03 | 2025-07-31 | 129d | 2025-02-03 | 2025-07-31 |  |  | N/A | Business & Operation Readiness | 5.0 | N/A |  |  | N/A | Business & Operational Readiness |  | M11 | 10/5: Review with PPC (LH) |
| 3547 | 1.11.5.1 | Plan stakeholder management |  | 129d | 2025-02-03 A | 2025-07-31 A |  | 100% |  | 2025-02-03 | 2025-07-31 | 129d | 2025-02-03 | 2025-07-31 | start no earlier than 2025-02-03 |  | PP | Business & Operation Readiness | 5.0 | PPC | Complete | COMPLETE | PPC | Business & Operational Readiness |  |  |  |
| 3548 | 1.11.5.2 | Manage stakeholders |  | 129d | 2025-02-03 A | 2025-07-31 A |  | 100% |  | 2025-02-03 | 2025-07-31 | 129d | 2025-02-03 | 2025-07-31 | start no earlier than 2025-02-03 |  | PP | Business & Operation Readiness | 5.0 | PPC | Complete | COMPLETE | PPC | Business & Operational Readiness |  |  |  |
| 3549 | 1.11.5.3 | Develop & implement changes to KPIs, organisation & people management |  | 129d | 2025-02-03 A | 2025-07-31 A |  | 100% |  | 2025-02-03 | 2025-07-31 | 129d | 2025-02-03 | 2025-07-31 | start no earlier than 2025-02-03 |  | PP | Business & Operation Readiness | 5.0 | PPC | Complete | COMPLETE | PPC | Business & Operational Readiness |  |  |  |
| 3550 | 1.11.5.4 | Develop & test changes to business processes |  | 129d | 2025-02-03 A | 2025-07-31 A |  | 100% |  | 2025-02-03 | 2025-07-31 | 129d | 2025-02-03 | 2025-07-31 | start no earlier than 2025-02-03 |  | PP | Business & Operation Readiness | 5.0 | PPC | Complete | COMPLETE | PPC | Business & Operational Readiness |  |  |  |
| 3551 | 1.11.5.5 | Develop and deliver training |  | 129d | 2025-02-03 A | 2025-07-31 A |  | 100% |  | 2025-02-03 | 2025-07-31 | 129d | 2025-02-03 | 2025-07-31 | start no earlier than 2025-02-03 |  | PP | Business & Operation Readiness | 5.0 | PPC | Complete | COMPLETE | PPC | Business & Operational Readiness |  |  |  |
| 3552 | 1.11.5.6 | Programme support for PP Business Change activities |  | 129d | 2025-02-03 A | 2025-07-31 A |  | 100% |  | 2025-02-03 | 2025-07-31 | 129d | 2025-02-03 | 2025-07-31 | start no earlier than 2025-02-03 |  | PPC | Business & Operation Readiness | 5.0 | PPC | Complete | COMPLETE | PP | Business & Operational Readiness |  |  |  |
| 3553 | 1.11.6 | **M16: Decision Approach** |  | 95d? | 2026-01-09 A | 2026-05-21 |  | 100% | 2026-07-07 | 2026-01-09 | 2026-05-21 | 0d |  |  |  |  | SRO |  | 6.45 | SRO |  |  |  |  |  | -1225.67 |  |
| 3554 | 1.11.6.1 | **Agree Approach M16 Decision Proposal** |  | 75d | 2026-01-09 A | 2026-04-23 A |  | 100% |  | 2026-01-09 | 2026-04-23 | 0d |  |  |  |  | SRO |  | 6.45 | SRO |  |  |  |  |  | -1225.67 |  |
| 3555 | 1.11.6.1.1 | M16 Decision Proposal Agreed | milestone | 0d | 2026-01-09 A | 2026-01-09 A |  | 100% |  | 2026-01-09 | 2026-01-09 | 0d |  |  | start no earlier than 2026-01-09 |  | SRO |  | 6.45 | SRO | Complete | COMPLETE |  |  |  |  |  |
| 3556 | 1.11.6.1.2 | M16 Decision Approach Approved | milestone | 0d | 2026-04-23 A | 2026-04-23 A |  | 100% |  | 2026-04-23 | 2026-04-23 | 0d |  |  | start no earlier than 2026-04-23 |  | SRO |  | 6.45 | SRO | Complete | COMPLETE |  |  |  |  |  |
| 3557 | 1.11.6.1.3 | 2026 Settlement Calendar Produced | milestone | 0d | 2026-04-01 A | 2026-04-01 A |  | 100% |  | 2026-04-01 | 2026-04-01 | 0d |  |  | start no earlier than 2026-04-01 |  | SRO |  | 6.45 | SRO | Complete | COMPLETE |  |  |  |  |  |

| ID | WBS | Task | Type | Duration | Start | Finish | Predecessors | Complete | Actual finish | Baseline start | Baseline finish | Baseline duration | Total slack | Constraint | Responsible | Task Status | Update Version | MHHS Resource Name | Sched Status | RAG | Milestone ID | Text29 |
| --- | --- | --- | --- | --- | --- | --- | --- | --- | --- | --- | --- | --- | --- | --- | --- | --- | --- | --- | --- | --- | --- | --- |
| 3558 | 1.11.6.2 | **Consult and Agree with Industry** |  | 94d? | 2026-01-12 A | 2026-05-21 |  | 100% | 2026-07-07 | 2026-01-12 | 2026-05-21 | 0d |  |  | SRO | -1225.67 | 6.45 | SRO |  |  |  |  |
| 3559 | 1.11.6.2.1 | **M16 Working Group 1** |  | 39d | 2026-01-12 A | 2026-03-05 A |  | 100% |  | 2026-01-12 | 2026-03-05 | 0d |  |  |  | -57.67 | 6.45 |  | Overdue Start |  |  |  |
| 3560 | 1.11.6.2.1.1 | Materials Prepared and Shared |  | 13d | 2026-01-12 A | 2026-01-28 A | 3555FS+1d | 100% |  | 2026-01-12 | 2026-01-28 | 0d |  | finish no earlier than 2026-01-28 | SRO |  | 6.45 | SRO | Complete | COMPLETE |  |  |
| 3561 | 1.11.6.2.1.2 | M16 Working Group 1 Completed | milestone | 0d | 2026-02-06 A | 2026-02-06 A |  | 100% |  | 2026-02-06 | 2026-02-06 | 0d |  | start no earlier than 2026-02-06 | SRO |  | 6.45 | SRO | Complete | COMPLETE |  |  |
| 3562 | 1.11.6.2.1.3 | Outline Work Packages and Activities for Tracking and Decision Choreography for Decision 1 |  | 20d | 2026-02-06 A | 2026-03-05 A | 3561 | 100% |  | 2026-02-06 | 2026-03-05 | 0d |  | finish no earlier than 2026-03-05 | SRO |  | 6.45 | SRO | Complete | COMPLETE |  |  |
| 3563 | 1.11.6.2.1.4 | Replanning Session Post M16 Workshop 1 | milestone | 0d | 2026-02-09 A | 2026-02-09 A | 3561FS+2d | 100% |  | 2026-02-09 | 2026-02-09 | 0d |  | finish no earlier than 2026-02-09 | SRO |  | 6.45 | SRO | Complete | COMPLETE |  |  |
| 3564 | 1.11.6.2.2 | **M16 Working Group 2** |  | 17d | 2026-02-06 A | 2026-03-02 A |  | 100% |  | 2026-02-06 | 2026-03-02 | 0d |  |  |  | -57.67 | 6.45 |  | Overdue Start |  |  |  |
| 3565 | 1.11.6.2.2.1 | 2 Materials Prepared and Shared |  | 15d | 2026-02-06 A | 2026-02-26 A | 3561 | 100% |  | 2026-02-06 | 2026-02-26 | 0d |  | finish no earlier than 2026-02-26 | SRO |  | 6.45 | SRO | Complete | COMPLETE |  |  |
| 3566 | 1.11.6.2.2.2 | M16 Working Group 2 Completed | milestone | 0d | 2026-02-26 A | 2026-02-26 A |  | 100% |  | 2026-02-26 | 2026-02-26 | 0d |  | finish no earlier than 2026-02-26 | SRO |  | 6.45 | SRO | Complete | COMPLETE |  |  |
| 3567 | 1.11.6.2.2.3 | Replanning Session Post M16 Workshop 2 | milestone | 0d | 2026-03-02 A | 2026-03-02 A | 3566FS+2d | 100% |  | 2026-03-02 | 2026-03-02 | 0d |  | finish no earlier than 2026-03-02 | SRO |  | 6.45 | SRO | Complete | COMPLETE |  |  |
| 3568 | 1.11.6.2.3 | **M16 Working Group 3** |  | 8d | 2026-03-03 A | 2026-03-12 A |  | 100% |  | 2026-03-03 | 2026-03-12 | 0d |  |  |  | -57.67 | 6.45 |  | Overdue Start |  |  |  |
| 3569 | 1.11.6.2.3.1 | Materials Prepared and Shared |  | 3d | 2026-03-03 A | 2026-03-05 A | 3567 | 100% |  | 2026-03-03 | 2026-03-05 | 0d |  | finish no earlier than 2026-03-05 | SRO |  | 6.45 | SRO | Complete | COMPLETE |  |  |
| 3570 | 1.11.6.2.3.2 | M16 Working Group 3 Completed | milestone | 0d | 2026-03-12 A | 2026-03-12 A |  | 100% |  | 2026-03-12 | 2026-03-12 | 0d |  | finish no earlier than 2026-03-12 | SRO |  | 6.45 | SRO | Complete | COMPLETE |  |  |
| 3571 | 1.11.6.2.4 | **M16 Working Group 4** |  | 10d | 2026-03-13 A | 2026-03-26 A |  | 100% |  | 2026-03-13 | 2026-03-26 | 0d |  |  |  | -57.67 | 6.45 |  | Overdue Start |  |  |  |
| 3572 | 1.11.6.2.4.1 | Materials Prepared and Shared |  | 5d | 2026-03-13 A | 2026-03-19 A | 3570 | 100% |  | 2026-03-13 | 2026-03-19 | 0d |  | finish no earlier than 2026-03-19 | SRO |  | 6.45 | SRO | Complete | COMPLETE |  |  |
| 3573 | 1.11.6.2.4.2 | M16 Working Group 4 Completed | milestone | 0d | 2026-03-26 A | 2026-03-26 A |  | 100% |  | 2026-03-26 | 2026-03-26 | 0d |  | finish no earlier than 2026-03-26 | SRO |  | 6.45 | SRO | Complete | COMPLETE |  |  |
| 3574 | 1.11.6.2.5 | **M16 Decision Making and Monitoring Criteria Consultation - Decisions 1 and 2** |  | 72d | 2026-03-27 A | 2026-07-07 A |  | 100% |  | 2026-03-27 | 2026-07-07 | 0d |  |  |  | -57.67 | 6.55 | SRO | Overdue Start |  |  |  |
| 3575 | 1.11.6.2.5.1 | Prepare Consultation material |  | 10d | 2026-03-27 A | 2026-04-09 A | 3573 | 100% |  | 2026-03-27 | 2026-04-09 | 0d |  | finish no earlier than 2026-04-09 | SRO |  | 6.47 | SRO | Complete | COMPLETE |  |  |
| 3576 | 1.11.6.2.5.2 | Issue Consultation | milestone | 0d | 2026-04-29 A | 2026-04-29 A | 3575FS+1d | 100% |  | 2026-04-10 | 2026-04-10 | 0d |  | start no earlier than 2026-04-29 | SRO |  | 6.48 | SRO | Complete | COMPLETE |  |  |
| 3577 | 1.11.6.2.5.3 | Consultation Period |  | 20d | 2026-04-29 A | 2026-05-26 A | 3576FS-1d | 100% |  | 2026-04-10 | 2026-05-07 | 0d |  | start no earlier than 2026-04-29 | SRO |  | 6.48 | SRO | Complete | COMPLETE |  |  |
| 3578 | 1.11.6.2.5.4 | Consultation Period Completed | milestone | 0d | 2026-05-26 A | 2026-05-26 A | 3577 | 100% |  | 2026-05-26 | 2026-05-26 | 0d |  | finish no earlier than 2026-05-07 | SRO |  | 6.48 | SRO | Complete | COMPLETE |  |  |
| 3579 | 1.11.6.2.5.5 | Materials Issued for Approval at eMCAG | milestone | 0d | 2026-06-30 A | 2026-06-30 A | 3578FS+5d | 100% |  | 2026-06-30 | 2026-06-30 | 0d |  | start no earlier than 2026-06-30 | SRO |  | 6.53 | SRO | Complete | COMPLETE |  |  |
| 3580 | 1.11.6.2.5.6 | Decision 1 (RF to 7 months) and Decision 2 (RF to 4 months) Criteria approved at eMCAG | milestone | 0d | 2026-07-07 A | 2026-07-07 A | 3579FS+5d | 100% |  | 2026-07-07 | 2026-07-07 | 0d |  | start no earlier than 2026-07-07 | SRO |  | 6.55 | SRO | Complete | COMPLETE | T3-MI-0500 | MCAG |
| 3581 | 1.11.7 | **M16: Monitoring Period** |  | 306d | 2026-04-15 | 2027-06-16 | 3580FS+1d |  |  | 2026-04-15 | 2027-06-16 | 0d |  |  | SRO | -1225.67 | 6.50 | SRO |  |  |  |  |
| 3582 | 1.11.7.1 | STEG May - M16 Checkpoint 2 | milestone | 0d | 2027-05-12 | 2027-05-12 |  |  |  | 2027-05-17 | 2027-05-17 | 0d | 162d | start no earlier than 2027-05-12 | SRO | 203.33 | 6.60 | SRO | Green | GREEN | T2-MR-0400 | MCAG |

Notes:
- 3574: 27/07/26: Task name updated from "M16 Decision Making and Monitoring Criteria Consultation" to "M16 Decision Making and Monitoring Criteria Consultation Decisions 1 and 2" to provide greater clarity and distinguish it from the separate Decision 3 activity.
- 3576: 15/04/26: Consultation to be issued 29/04. Materials to be included in MCAG paper day on 21/04. Decision made to use existing MCAG on the 23/06 for approval as opposed to eMCAG - task name updated to reflect this. Data has been shown to STEG who have flagged no concerns. Additional time beneficial to complete full review of comments post consultation closure.
- 3577: 15/04/26: Consultation to be issued 29/04, hence date for this activity has been pushed out due to date change for linked predecessor. Materials to be included in MCAG paper day on 21/04. Decision made to use existing MCAG on the 23/06 for approval as opposed to eMCAG - task name updated to reflect this. Data has been shown to STEG who have flagged no concerns. Additional time beneficial to complete full review of comments post consultation closure.
- 3578: 15/04/26: Consultation to be issued 29/04, hence date for this activity has been pushed out due to date change for linked predecessor. Materials to be included in MCAG paper day on 21/04. Decision made to use existing MCAG on the 23/06 for approval as opposed to eMCAG - task name updated to reflect this. Data has been shown to STEG who have flagged no concerns. Additional time beneficial to complete full review of comments post consultation closure.
- 3579: 25/06/26: Task name updated from 'Materials Issued for Approval at MCAG' to 'Materials Issued for Approval at eMCAG'. M16 Approach to now be brought to eMCAG for approval following analysis of initial Consultation responses. Task date updated and rebaselined from 16/06/26 to 30/06/26 to align with the diarised eMCAG. / 15/06/26: Task date is contingent on addressing the issues raised during the initial Consultation. An update will follow. The aim is to circulate an updated set of decision criteria alongside the Consultation responses on 24/06. eMCAG is likely to be convened in early July. / 01/06/26: Materials to now be issued as part of the MCAG papers based on analysis of Consultation responses and potential ad hoc discussion with STEG prior to MCAG papers. / 15/04/26: Consultation to be issued 29/04, hence date for this activity has been pushed out due to date change for linked predecessor. Materials to be included in MCAG paper day on 21/04. Decision made to use existing MCAG on the 23/06 for approval as opposed to eMCAG - task name updated to reflect this. Data has been shown to STEG who have flagged no concerns. Additional time beneficial to complete full review of comments post consultation closure.
- 3580: 27/07/26: Activity name updated from 'M16 Approach Approved at eMCAG' to 'Decision 1 (RF to 7 months) and Decision 2 (RF to 4 months) Criteria approved at eMCAG'. / 24/07/26: Activity complete / 25/06/26: Task name updated from 'M16 Approach Approved at MCAG' to 'M16 Approach Approved at eMCAG'. The M16 Approach will now be taken to eMCAG for approval following analysis of the initial consultation responses. Task date updated and rebaselined from 23/06/26 to 07/07/26 to align with the diarised eMCAG. / 15/06/26 - task date is contingent on addressing the issues raised during the initial Consultation. An update will follow. The aim is to circulate an updated set of decision criteria alongside the Consultation responses on 24/06. eMCAG is likely to be convened in early July. / 06/05/25: Milestone status changed from proposed to approved following approval at 28/04 MCAG. / 15/04/26: Consultation to be issued 29/04, hence date for this activity has been pushed out due to date change for linked predecessor. Materials to be included in MCAG paper day on 21/04. Decision made to use existing MCAG on the 23/06 for approval as opposed to eMCAG - task name updated to reflect this. Data has been shown to STEG who have flagged no concerns. Additional time beneficial to complete full review of comments post consultation closure. This milestone will be taken to the 28/04 MCAG for approval. / 20/03/26: Milestone T3-MI-0500 transferred to activity 3680 "M16 Approach Approved at MCAG" - as developed M16 plan has superseeded activity "M16 Methodology Approved" in M16 Methodology Section. Milestone to be updated in Milestone Register. Kept as proposed for now, not formally approved, to be discussed at MCAG.
- 3582: 07/10/26: Milestone date proposed to move from 17/05/27 to 12/05/27 to align with the revised 2027 STEG calendar. Baseline date retained pending formal approval at MCAG. / 22/05/26: Milestone date reverted to 17/05/27 to align with the agreement reached at MCAG. The milestone will remain scheduled for Monday 17/05/27 rather than Wednesday in the week commencing 17/05/27. / 06/05/26: Milestone status updated from Proposed to Approved following approval at the 28/04 MCAG. / 14/04/26: Activity title updated to M16 Checkpoint 2 to ensure consistency of terminology. Proposed milestone added for approval at the 28/04 MCAG.

| ID | WBS | Task | Type | Duration | Start | Finish | Predecessors | Complete | Remaining | Actual start | Baseline start | Baseline finish | Baseline duration | Total slack | Free slack | Constraint | Responsible | Task Status | Update Version | MHHS Resource Name | Sched Status | RAG | Milestone ID | Text29 |
| --- | --- | --- | --- | --- | --- | --- | --- | --- | --- | --- | --- | --- | --- | --- | --- | --- | --- | --- | --- | --- | --- | --- | --- | --- |
| 3583 | 1.11.8 | **M16: Decision Points** |  | 245d? | 2026-07-13 | 2027-06-18 |  | 50% | 122.5d? | 2026-08-14 | 2026-07-13 | 2027-06-18 | 0d |  |  |  | SRO | -1225.67 | 6.45 | SRO |  |  |  |  |
| 3584 | 1.11.8.1 | **STEG to Assess Monitoring Report and recommend interim position to MCAG on Decision 1** |  | 5d | 2026-08-19 A | 2026-08-25 A |  | 100% |  |  | 2026-08-19 | 2026-08-25 | 0d |  |  |  | SRO | -1225.67 | 6.45 | SRO |  |  |  |  |
| 3585 | 1.11.8.1.1 | STEG Issue position to MCAG notifying Decision Checkpoint 1 On-track | milestone | 0d | 2026-08-19 A | 2026-08-19 A |  | 100% |  |  | 2026-08-19 | 2026-08-19 | 0d |  |  | start no earlier than 2026-08-19 | SRO |  | 6.53 | SRO | Complete | COMPLETE |  |  |
| 3586 | 1.11.8.1.2 | MCAG endorses STEG Assessment that M16 likely to be met | milestone | 0d | 2026-08-25 A | 2026-08-25 A |  | 100% |  |  | 2026-08-25 | 2026-08-25 | 0d |  |  | start no earlier than 2026-08-25 | SRO |  | 6.53 | SRO | Complete | COMPLETE | T2-MR-0500 | MCAG |
| 3587 | 1.11.8.1.3 | M16 Checkpoint 1 | milestone | 0d | 2026-08-25 A | 2026-08-25 A | 3586 | 100% |  |  | 2026-08-25 | 2026-08-25 | 0d |  |  |  | SRO |  | 6.53 | SRO | Complete | COMPLETE |  |  |
| 3588 | 1.11.8.2 | **Decision 1 RF Change to 7 months from Settlement Day 01/10** |  | 23d | 2026-08-14 A | 2026-09-15 A |  | 100% |  |  | 2026-08-14 | 2026-09-15 | 0d |  |  |  | SRO | -1225.67 | 6.45 | SRO |  |  |  |  |
| 3589 | 1.11.8.2.1 | Update Monitoring Data to be provided from Performance Assurance and MCC |  | 1d | 2026-08-14 A | 2026-08-14 A |  | 100% |  |  | 2026-09-01 | 2026-09-01 | 0d |  |  | start no earlier than 2026-08-14 |  |  | 6.58 | SRO | Complete | COMPLETE |  |  |
| 3590 | 1.11.8.2.2 | STEG to compare Monitoring report against agreed Assessment Criteria | milestone | 0d | 2026-09-02 A | 2026-09-02 A | 3589 | 100% |  |  | 2026-09-02 | 2026-09-02 | 0d |  |  | start no earlier than 2026-09-02 | SRO |  | 6.58 | SRO | Complete | COMPLETE |  |  |
| 3591 | 1.11.8.2.3 | STEG Issue recommendation to eMCAG | milestone | 0d | 2026-09-08 A | 2026-09-08 A | 3590 | 100% |  |  | 2026-09-14 | 2026-09-14 | 0d |  |  | finish no earlier than 2026-09-08 | SRO |  | 6.45 | SRO | Complete | COMPLETE |  |  |
| 3592 | 1.11.8.2.4 | eMCAG Approve Recommendation to Change to RF 7 Months Calendar | milestone | 0d | 2026-09-15 A | 2026-09-15 A | 3590FS+5d | 100% |  |  | 2026-09-15 | 2026-09-15 | 0d |  |  | start no earlier than 2026-09-15 | SRO |  | 6.58 | SRO | Complete | COMPLETE | T2-EL-0200 | MCAG |
| 3593 | 1.11.8.2.5 | Decision 1 - RF 7 Months | milestone | 0d | 2026-09-15 A | 2026-09-15 A | 3592 | 100% |  |  | 2026-09-15 | 2026-09-15 | 0d |  |  | finish no earlier than 2026-09-15 | SRO |  | 6.45 | SRO | Complete | COMPLETE |  |  |
| 3594 | 1.11.8.2.6 | Communication issued to Industry notifying Parties RF will be 7 months |  | 1d | 2026-09-15 A | 2026-09-15 A |  | 100% |  |  | 2026-09-15 | 2026-09-15 | 0d |  |  | start no earlier than 2026-09-15 |  |  | 6.53 | SRO | Complete | COMPLETE |  |  |
| 3595 | 1.11.8.3 | **Decision 2 RF Change to 4 months from Settlement Date 01/04** |  | 10d? | 2027-03-10 | 2027-03-23 |  |  |  |  | 2027-03-10 | 2027-03-23 | 0d |  |  |  | SRO | -1225.67 | 6.45 | SRO |  |  |  |  |
| 3596 | 1.11.8.3.1 | Transition Design states that RF to 4 months to take effect from 1 April 2027 onwards |  | 1d? | 2027-04-01 | 2027-04-01 | 3599 |  |  |  | 2027-04-01 | 2027-04-01 | 0d | 190d |  | start no earlier than 2027-04-01 | SRO | 162.33 | 6.60 | SRO | Green | GREEN |  |  |
| 3597 | 1.11.8.3.2 | STEG to compare Monitoring report against agreed assessment criteria | milestone | 0d | 2027-03-10 | 2027-03-10 |  |  |  |  | 2027-03-10 | 2027-03-10 | 0d | 201d | 0d | start no earlier than 2027-03-10 | SRO | 140.33 | 6.58 | SRO | Green | GREEN |  |  |
| 3598 | 1.11.8.3.3 | STEG Issue recommendation to MCAG | milestone | 0d | 2027-03-16 | 2027-03-16 | 3597FS+5d |  |  |  | 2027-03-16 | 2027-03-16 | 0d | 201d | 4d | start no earlier than 2027-03-16 | SRO | 146.71 | 6.58 | SRO | Green | GREEN |  |  |
| 3599 | 1.11.8.3.4 | MCAG Approve Recommendation to Change to RF 4 Months Calendar | milestone | 0d | 2027-03-23 | 2027-03-23 | 3598 |  |  |  | 2027-03-23 | 2027-03-23 | 0d | 197d | 0d | start no earlier than 2027-03-23 | SRO | 153.33 | 6.59 | SRO | Green | GREEN | T2-EL-0300 |  |
| 3600 | 1.11.8.3.5 | Decision 2 - RF 4 Months | milestone | 0d | 2027-03-23 | 2027-03-23 | 3599 |  |  |  | 2027-03-23 | 2027-03-23 | 0d | 198d |  | finish no earlier than 2027-03-19 | SRO | 153.33 | 6.58 | SRO | Green | GREEN |  |  |
| 3601 | 1.11.8.4 | **Decision 3 SF Change from 15WD to 7WD from Settlement Date 02/07** |  | 10d? | 2027-06-02 | 2027-06-15 |  |  |  |  | 2027-06-02 | 2027-06-15 | 0d |  |  |  | SRO | -1225.67 | 6.45 | SRO |  |  |  |  |
| 3602 | 1.11.8.4.1 | Transition Design states that SF from 15WD to 7WD to take effect from 2 July 2027 onwards |  | 1d? | 2027-07-02 | 2027-07-02 | 3605 |  |  |  | 2027-07-02 | 2027-07-02 | 0d | 124d |  | start no earlier than 2027-07-02 | SRO | 254.33 | 6.60 | SRO | Green | GREEN |  |  |
| 3603 | 1.11.8.4.2 | STEG to compare Monitoring report against agreed assessment criteria | milestone | 0d | 2027-06-02 | 2027-06-02 |  |  |  |  | 2027-06-02 | 2027-06-02 | 0d | 13d | 0d | start no earlier than 2027-06-02 | SRO | 224.33 | 6.58 | SRO | Green | GREEN |  |  |
| 3604 | 1.11.8.4.3 | STEG Issue recommendation to eMCAG | milestone | 0d | 2027-06-09 | 2027-06-09 | 3603FS+5d |  |  |  | 2027-06-09 | 2027-06-09 | 0d | 13d | 4d | start no earlier than 2027-06-09 | SRO | 231.33 | 6.58 | SRO | Green | GREEN |  |  |
| 3605 | 1.11.8.4.4 | eMCAG Approve Recommendation - Confirm M16 Date | milestone | 0d | 2027-06-15 | 2027-06-15 | 3604 |  |  |  | 2027-06-15 | 2027-06-15 | 0d | 9d | 0d | start no earlier than 2027-06-15 | SRO | 237.33 | 6.59 | SRO | Green | GREEN | T2-EL-0100 | MCAG |
| 3606 | 1.11.8.4.5 | Decision 3 - SF 7WD | milestone | 0d | 2027-06-15 | 2027-06-15 | 3605 |  |  |  | 2027-06-15 | 2027-06-15 | 0d | 138d |  | start no earlier than 2027-06-15 | SRO | 237.33 | 6.58 | SRO | Green | GREEN |  |  |

Notes:
- 3585: 26/06/26: Task date changed to 19/08/26 to align with the STEG calendar.
- 3586: 26/06/26: Milestone date updated to 25/08/26 to align with the MCAG calendar following analysis of the initial consultation responses. The baseline date was originally set at M16 minus one year; however, a further eMCAG is no longer considered necessary. The milestone has therefore been aligned with the scheduled August MCAG following submission of participants' RA8 responses and to allow additional time for Monitoring Data. Task name updated from 'MCAG Endorses Assessment' to 'MCAG Endorses STEG Assessment that M16 is Likely to be Met'. / 06/05/25: Milestone status changed from proposed to approved following approval at 28/04 MCAG. / 16/04/26: Predecessor for 2738 changed from 5WD to 3WD. Agreed with the workstream lead that this is sufficient time between STEG and MCAG for required activities to take place. / 25/03/26: New line item added to plan in line with M16 Plan Development. Plan continuing to evolve as discussions take place. MCAG will be engaged to formally create this Milestone ID. Hence proposed.
- 3587: 26/06/26: Milestone date updated to 25/08/26 to align with the MCAG calendar following analysis of the initial consultation responses. The baseline date was set at M16 minus one year; however, a further eMCAG is no longer considered necessary, so the milestone has been aligned to the scheduled August MCAG following submission of participants' RA8 responses. / 16/04/26 : Task name changed from Confidence Assessment 1 to M16 Checkpoint 1 to align terminology across the plan and transition design documents.
- 3588: 29/09/26: Summary task dates updated from 01/09/2618/09/26 to 14/08/2615/09/26 to align with the actual Decision 1 monitoring and governance activities.
- 3589: 01/09/26: Task date updated and rebaselined from 08/09/26 to 14/08/26 to align with the new STEG calendar. Monitoring data was provided by Performance Assurance and MCC ahead of plan on 14/08/26.
- 3590: 01/09/26: Task date updated and rebaselined from 08/09/26 to 02/09/26 to align with new September 2026 STEG calendar.
- 3591: 01/09/26: Task name updated from 'STEG Issue recommendation to MCAG' to 'STEG Issue recommendation to eMCAG' to align with extraordinary meeting. / 26/06/26: Task date rebaselined to align with September STEG dates.
- 3592: 01/09/26: Task name updated from 'MCAG Approve Recommendation to change to RF 7 months calendar' to 'eMCAG Approve Recommendation to change to RF 7 months calendar'. Milestone date updated and rebaselined from 18/09/26 to 15/09/26 to align with planned eMCAG. / 06/05/26: Milestone status changed from proposed to approved following approval at 28/04 MCAG. / 25/03/26: New line item added to plan in line with M16 Plan Development. Plan continuing to evolve as discussions take place. MCAG will be engaged to formally create this Milestone ID. Hence proposed.
- 3593: 26/06/26: Task date updated and rebaselined from 18/09/26 to 15/09/26 to align with eMCAG.
- 3595: 29/09/26: Summary task dates updated from 15/03/2719/03/27 to 10/03/2723/03/27 to align with the revised Decision 2 governance activities.
- 3597: 01/09/26: Task date update and raselined from 15/03/27 to 10/03/27 to align with new STEG monthly cadence.
- 3598: 01/09/26: Task date updated and rebaselined from 19/03/27 to 16/03/27 to align with MCAG 2027 calendar.
- 3599: 23/09/26: New Tier 2 milestone T2-EL-0300 MCAG Approve Recommendation to Change to RF 4 Months Calendar created for 23/03/27 following MCAG approval on 22/09/26, ensuring a consistent milestone approach across Decisions 1, 2 and 3. / 01/09/26: Task date updated and rebaselined from 19/03/27 to 23/03/27 to align with MCAG 2027 calendar.
- 3600: 01/09/26: Task date updated and rebaselined from 19/03/27 to 23/03/27 to align with MCAG 2027 calendar.
- 3603: 01/09/26: Task date updated and rebaselined from 14/06/27 to 02/06/27 to allow additional time to address STEG comments prior to MCAG Decision 3 Recommendation.
- 3604: 01/09/26: Task name updated from STEG Issue recommendation to MCAG to STEG Issue recommendation to eMCAG. Task date updated and rebaselined from 18/06/27 to 15/06/27 to align with the proposed eMCAG date for approval of Decision 3. / 28/07/26: Task date rebaselined from 22/06/27 to 18/06/27 to align with agreed M16 Decision Choreography.
- 3605: 23/09/26: Milestone T2-EL-0100 renamed from MCAG Approve Recommendation - Confirm M16 Date to eMCAG Approve Recommendation - Confirm M16 Date and rebaselined from 18/06/27 to 15/06/27 following MCAG approval on 22/09/26, aligning with the revised Decision 3 governance. / 01/09/26: Task date updated and rebaselined from 18/06/27 to 15/06/27 to align with the proposed eMCAG date for approval of Decision 3. Task name updated from 'MCAG Approve Recommendation - Confirm M16 Date' to 'eMCAG Approve Recommendation - Confirm M16 Date'. / 28/07/26: Task date rebaselined from 22/06/27 to 18/06/27 to align with agreed M16 Decision Choreography. / 06/05/25: Milestone status changed from proposed to approved following approval at 28/04 MCAG. / 18/03/26: Activity title updated to reflect latest M16 plan. Updated successor to now be dependent on "panel approval that M16 criteria met" as the activity this one superseeded is now removed from the plan. Milstone status changed to proposed as the date has changed since the original "Confirm M16 Date" activity and is yet to be approved at MCAG.
- 3606: 01/09/26: Task date updated and rebaselined from 18/06/27 to 15/06/27 to align with the proposed eMCAG date for approval of Decision 3. / 28/07/26: Task date rebaselined from 22/06/27 to 18/06/27 to align with agreed M16 Decision Choreography.

| ID | WBS | Task | Type | Duration | Start | Finish | Predecessors | Baseline start | Baseline finish | Baseline duration | Baseline 1 start | Baseline 1 finish | Total slack | Free slack | Constraint | Responsible | Task Status | Update Version | MHHS Resource Name | Sched Status | RAG | Involved | Text9 | MHHS Programme Phase | Milestone ID | Text29 | Tier | Future RAG | Artefact ID |
| --- | --- | --- | --- | --- | --- | --- | --- | --- | --- | --- | --- | --- | --- | --- | --- | --- | --- | --- | --- | --- | --- | --- | --- | --- | --- | --- | --- | --- | --- |
| 3607 | 1.11.9 | **M16: Creation & Implementation of Updated Settlement Calendars** |  | 130d | 2027-01-04 | 2027-07-02 |  | 2026-03-09 | 2027-06-17 | 0d |  |  | 0d |  |  | SRO | -1225.67 | 6.45 | SRO |  |  |  |  |  |  |  |  |  |  |
| 3608 | 1.11.9.1 | **Post Decision 1 & 2** |  | 55d | 2027-01-04 | 2027-03-19 |  | 2027-01-04 | 2027-03-19 | 0d |  |  |  |  |  | SRO | -1225.67 | 6.45 | SRO |  |  |  |  |  |  |  |  |  |  |
| 3609 | 1.11.9.1.1 | **Prepare Calendars** |  | 20d | 2027-01-04 | 2027-01-29 |  | 2027-01-04 | 2027-01-29 | 0d |  |  |  |  |  | SRO | -1225.67 | 6.45 | SRO |  |  |  |  |  |  |  |  |  |  |
| 3610 | 1.11.9.1.1.1 | Prepare Variant a) April-Jun 2027 Including change RF to 7& 4 Months |  | 20d | 2027-01-04 | 2027-01-29 |  | 2027-01-04 | 2027-01-29 | 0d |  |  | 234d |  | start no earlier than 2027-01-04 | SRO | 75.33 | 6.45 | SRO | Green | GREEN |  |  |  |  |  |  |  |  |
| 3611 | 1.11.9.1.1.2 | Prepare Variant b) April-Jun 2027 7 Month only where decision 2 Fails |  | 20d | 2027-01-04 | 2027-01-29 |  | 2027-01-04 | 2027-01-29 | 0d |  |  | 234d |  | start no earlier than 2027-01-04 | SRO | 75.33 | 6.45 | SRO | Green | GREEN |  |  |  |  |  |  |  |  |
| 3612 | 1.11.9.1.1.3 | Prepare Variant c) April-Jun 2027"No Change" Where both decisions fail |  | 20d | 2027-01-04 | 2027-01-29 |  | 2027-01-04 | 2027-01-29 | 0d |  |  | 234d |  | start no earlier than 2027-01-04 | SRO | 75.33 | 6.45 | SRO | Green | GREEN |  |  |  |  |  |  |  |  |
| 3613 | 1.11.9.1.2 | SVG Approval of Appropriate Calendar | milestone | 0d | 2027-02-26 | 2027-02-26 | 3609FS+20d | 2027-02-26 | 2027-02-26 | 0d |  |  | 204d | 6d | start no earlier than 2027-02-26 | SRO | 128.71 | 6.45 | SRO | Green | GREEN |  |  |  |  |  |  |  |  |
| 3614 | 1.11.9.1.3 | Implementation of April - Jun 2027 Calendar | milestone | 0d | 2027-03-23 | 2027-03-23 | 3592, 3599, 3613FS+10d | 2027-03-23 | 2027-03-23 | 0d |  |  | 198d |  | finish no earlier than 2027-03-19 | SRO | 153.33 | 6.45 | SRO | Green | GREEN |  |  |  |  |  |  |  |  |
| 3615 | 1.11.9.2 | **Post Decision 3** |  | 74d | 2027-03-08 | 2027-06-17 |  | 2027-03-08 | 2027-06-17 | 0d |  |  |  |  |  | SRO | -1225.67 | 6.55 | SRO |  |  |  |  |  |  |  |  |  |  |
| 3616 | 1.11.9.2.1 | Prepare Variant Jul-27 - Mar-28 Including 4/7 Month and 7 Day SF |  | 20d | 2027-03-08 | 2027-04-02 |  | 2027-03-08 | 2027-04-02 | 0d |  |  | 189d |  | start no earlier than 2027-03-08 | SRO | 138.33 | 6.47 | SRO | Green | GREEN |  |  |  |  |  |  |  |  |
| 3617 | 1.11.9.2.2 | Prepare Variant Jul-27 - Sep-28 Excluding SF Change Contingency |  | 20d | 2027-03-08 | 2027-04-02 |  | 2027-03-08 | 2027-04-02 | 0d |  |  | 189d |  | start no earlier than 2027-03-08 | SRO | 138.33 | 6.47 | SRO | Green | GREEN |  |  |  |  |  |  |  |  |
| 3618 | 1.11.9.2.3 | SVG Approval of Appropriate Calendar | milestone | 0d | 2027-06-03 | 2027-06-03 | 3387FS+19d | 2027-06-03 | 2027-06-03 | 0d |  |  | 0d |  | finish no earlier than 2027-06-03 | SRO | 225.71 | 6.45 | SRO | Green | GREEN |  |  |  |  |  |  |  |  |
| 3619 | 1.11.9.2.4 | Implementation of July 2027 Calendar | milestone | 0d | 2027-07-02 | 2027-07-02 | 3618FS+21d | 2027-07-02 | 2027-07-02 | 0d |  |  | 0d |  | finish no earlier than 2027-06-17 | SRO | 254.71 | 6.58 | SRO | Green | GREEN |  |  |  |  |  |  |  |  |
| 3620 | 1.11.10 | **M16 Approval Window** |  | 133d | 2027-06-21 | 2027-12-23 |  | 2027-06-29 | 2027-12-23 | 124d | 2026-12-07 | 2027-05-24 | 0d |  |  | SRO | 966.71 | 6.34 | Justin Andrews | Green | GREEN | N/A | Business & Operation Readiness | Business & Operational Readiness |  |  |  |  |  |
| 3621 | 1.11.10.1 | Panel approval that M16 criteria met | milestone | 0d | 2027-06-21 | 2027-06-21 | 3605FS+5d | 2027-06-29 | 2027-06-29 | 0d | 2026-12-07 | 2026-12-07 | 9d |  |  | SRO | 243.71 | 6.34 | Justin Andrews | Green | GREEN | Code Bodies,CPT,PP,SRO | Business & Operation Readiness | Business & Operational Readiness |  |  |  |  |  |
| 3622 | 1.11.10.2 | Cut over to new settlement timetable (M16) | milestone | 0d | 2027-07-02 | 2027-07-02 | 3621, 3387FS+40d, 3619 | 2027-07-02 | 2027-07-02 | 0d | 2026-12-07 | 2026-12-07 | 0d |  |  | SRO | 254.71 | 6.34 | CPT | Green | GREEN | PP | Business & Operation Readiness | Business & Operational Readiness | T1-EL-1000 | PSG | T1 |  |  |
| 3623 | 1.11.10.3 | Maximum 6-month window for approval of M16 |  | 124d | 2027-07-05 | 2027-12-23 | 3622 | 2027-07-05 | 2027-12-23 | 124d | 2026-12-08 | 2027-05-24 | 0d |  |  | SRO | 257.33 | 6.34 | CPT | Green | GREEN |  | Business & Operation Readiness | Business & Operational Readiness |  |  |  |  |  |
| 3624 | 1.12 | **EARLY LIVE RUNNING** |  | 45d | 2027-05-10 | 2027-07-09 |  | 2027-05-10 | 2027-07-09 | 889d | 2024-01-02 | 2027-05-28 | 119d |  |  | N/A |  |  | N/A |  |  | N/A | Business & Operation Readiness | Early Live Running |  |  |  | 1 Nov 2025 - 30 Apr 2026 |  |
| 3625 | 1.12.1 | **Early Live Running Stabilisation Period** |  | 45d | 2027-05-10 | 2027-07-09 |  | 2027-05-10 | 2027-07-09 | 45d | 2026-10-06 | 2026-12-07 | 119d |  |  | N/A |  | 5.0 | N/A |  |  | N/A | Business & Operation Readiness | Early Live Running |  |  |  |  |  |
| 3626 | 1.12.1.1 | Manage Early Live Running stabilisation period |  | 45d | 2027-05-10 | 2027-07-09 | 3387 | 2027-05-10 | 2027-07-09 | 45d | 2026-10-06 | 2026-12-07 | 119d | 0d |  | Code Bodies | 201.33 | 5.0 | Justin Andrews | Green | GREEN | PP | Business & Operation Readiness | Early Live Running |  |  |  |  |  |
| 3627 | 1.12.1.2 | Monitor Early Live Running stabilisation period |  | 45d | 2027-05-10 | 2027-07-09 | 3626SS | 2027-05-10 | 2027-07-09 | 45d | 2026-10-06 | 2026-12-07 | 119d |  |  | Migration | 201.33 | 5.0 | Justin Andrews | Green | GREEN | Code Bodies,PP | Business & Operation Readiness | Early Live Running |  |  |  |  |  |
| 3628 | 1.13 | **PROGRAMME CLOSURE** |  | 80d | 2027-03-08 | 2027-06-25 |  | 2027-03-08 | 2027-06-25 | 85d | 2026-08-04 | 2026-11-30 | 129d |  |  | N/A |  |  | N/A |  |  | N/A | Programme Closure | Programme Closure |  |  |  |  |  |
| 3629 | 1.13.1 | **Handover Pack** |  | 80d | 2027-03-08 | 2027-06-25 |  | 2027-03-08 | 2027-06-25 | 85d | 2026-08-04 | 2026-11-30 | 129d |  |  | N/A |  | 5.0 | N/A |  |  | N/A | Programme Closure | Programme Closure |  |  |  |  |  |
| 3630 | 1.13.1.1 | **Draft Handover Pack (for M15)** |  | 40d | 2027-03-08 | 2027-04-30 |  | 2027-03-08 | 2027-04-30 | 40d | 2026-08-04 | 2026-09-28 | 169d |  |  | N/A |  | 5.0 | N/A |  |  | N/A | Programme Closure | Programme Closure |  |  |  |  |  |
| 3631 | 1.13.1.1.1 | Develop document |  | 20d | 2027-03-08 | 2027-04-02 | 3387FS-45d | 2027-03-08 | 2027-04-02 | 20d | 2026-08-04 | 2026-08-31 | 169d | 0d |  | PMO | 138.33 | 5.0 |  | Green | GREEN | CPT | Programme Closure | Programme Closure |  |  |  |  |  |
| 3632 | 1.13.1.1.2 | Document review and update |  | 20d | 2027-04-05 | 2027-04-30 | 3631 | 2027-04-05 | 2027-04-30 | 20d | 2026-09-01 | 2026-09-28 | 169d | 0d |  | SRO | 166.33 | 5.0 |  | Green | GREEN | PMO,CPT,IPA,PP | Programme Closure | Programme Closure |  |  |  |  |  |
| 3633 | 1.13.1.1.3 | Draft Handover Pack approved | milestone | 0d | 2027-04-30 | 2027-04-30 | 3632 | 2027-04-30 | 2027-04-30 | 0d | 2026-09-28 | 2026-09-28 | 169d |  |  | SRO | 191.71 | 5.0 |  | Green | GREEN | PMO,CPT | Programme Closure | Programme Closure |  |  |  |  | MHHS-ART126 |

Notes:
- 3614: 01/09/26: Task date updated and rebaselined from 19/03/27 to 23/03/27 to align with the 2027 MCAG calendar and the scheduled MCAG approval of Decision 2 on 23/03/27.
- 3615: 28/07/26: Task dates rebaselined to align with agreed M16 choreography.
- 3616: 08/04/26: Error in original M16 planned dates. This has been identified and corrected to 2027.
- 3617: 08/04/26: Error in original M16 planned dates. This has been identified and corrected to 2027.
- 3619: 01/09/26: Task name updated from 'Implementation of Jul - Mar 2027 Calendar' to 'Implementation of July 2027 Calendar'. Predescessor updated from '3608FS+10d' to '3608FS+21d' to align with M16.

| ID | WBS | Task | Type | Duration | Start | Finish | Predecessors | Baseline start | Baseline finish | Baseline duration | Baseline 1 start | Baseline 1 finish | Total slack | Free slack | Responsible | Involved | Text9 | Update Version | MHHS Resource Name | MHHS Programme Phase | Task Status | Sched Status | RAG | Artefact ID | Milestone ID | Text29 | Tier |
| --- | --- | --- | --- | --- | --- | --- | --- | --- | --- | --- | --- | --- | --- | --- | --- | --- | --- | --- | --- | --- | --- | --- | --- | --- | --- | --- | --- |
| 3634 | 1.13.1.2 | **Master Handover Pack (for M16)** |  | 40d | 2027-05-03 | 2027-06-25 |  | 2027-05-03 | 2027-06-25 | 40d | 2026-10-06 | 2026-11-30 | 129d |  | N/A | N/A | Programme Closure | 5.0 | N/A | Programme Closure |  |  |  |  |  |  |  |
| 3635 | 1.13.1.2.1 | Update document |  | 20d | 2027-05-03 | 2027-05-28 | 3622FS-45d | 2027-05-03 | 2027-05-28 | 20d | 2026-10-06 | 2026-11-02 | 129d | 0d | PMO | CPT | Programme Closure | 5.0 |  | Programme Closure | 194.33 | Green | GREEN |  |  |  |  |
| 3636 | 1.13.1.2.2 | Document review and update |  | 20d | 2027-05-31 | 2027-06-25 | 3635 | 2027-05-31 | 2027-06-25 | 20d | 2026-11-03 | 2026-11-30 | 129d | 0d | SRO | PMO,CPT,IPA,PP | Programme Closure | 5.0 |  | Programme Closure | 222.33 | Green | GREEN |  |  |  |  |
| 3637 | 1.13.1.2.3 | Master Handover Pack approved | milestone | 0d | 2027-06-25 | 2027-06-25 | 3636 | 2027-06-25 | 2027-06-25 | 0d | 2026-11-30 | 2026-11-30 | 129d |  | SRO | PMO,CPT | Programme Closure | 5.0 |  | Programme Closure | 247.71 | Green | GREEN | MHHS-ART126 |  |  |  |
| 3638 | 1.13.2 | **Programme Lessons Learned** |  | 40d | 2027-03-08 | 2027-04-30 |  | 2027-03-08 | 2027-04-30 | 40d | 2026-08-04 | 2026-09-28 | 169d |  | N/A | N/A | Programme Closure | 5.0 | N/A | Programme Closure |  |  |  |  |  |  |  |
| 3639 | 1.13.2.1 | Develop document |  | 20d | 2027-03-08 | 2027-04-02 | 3387FS-45d | 2027-03-08 | 2027-04-02 | 20d | 2026-08-04 | 2026-08-31 | 169d | 0d | PMO | CPT | Programme Closure | 5.0 |  | Programme Closure | 138.33 | Green | GREEN |  |  |  |  |
| 3640 | 1.13.2.2 | Document review and update |  | 20d | 2027-04-05 | 2027-04-30 | 3639 | 2027-04-05 | 2027-04-30 | 20d | 2026-09-01 | 2026-09-28 | 169d | 0d | SRO | PMO,CPT,IPA | Programme Closure | 5.0 |  | Programme Closure | 166.33 | Green | GREEN |  |  |  |  |
| 3641 | 1.13.2.3 | Programme Lessons Learned document approved | milestone | 0d | 2027-04-30 | 2027-04-30 | 3640 | 2027-04-30 | 2027-04-30 | 0d | 2026-09-28 | 2026-09-28 | 169d |  | SRO | PMO,CPT | Programme Closure | 5.0 |  | Programme Closure | 191.71 | Green | GREEN | MHHS-ART131 |  |  |  |
| 3642 | 1.13.3 | **Programme Closure Report** |  | 40d | 2027-03-08 | 2027-04-30 |  | 2027-03-08 | 2027-04-30 | 40d | 2026-08-04 | 2026-09-28 | 169d |  | N/A | N/A | Programme Closure | 5.0 | N/A | Programme Closure |  |  |  |  |  |  |  |
| 3643 | 1.13.3.1 | Develop document |  | 20d | 2027-03-08 | 2027-04-02 | 3387FS-45d | 2027-03-08 | 2027-04-02 | 20d | 2026-08-04 | 2026-08-31 | 169d | 0d | PMO | CPT | Programme Closure | 5.0 |  | Programme Closure | 138.33 | Green | GREEN |  |  |  |  |
| 3644 | 1.13.3.2 | Document review and update |  | 20d | 2027-04-05 | 2027-04-30 | 3643 | 2027-04-05 | 2027-04-30 | 20d | 2026-09-01 | 2026-09-28 | 169d | 0d | Ofgem | PMO,CPT,IPA,SRO | Programme Closure | 5.0 |  | Programme Closure | 166.33 | Green | GREEN |  |  |  |  |
| 3645 | 1.13.3.3 | Programme Closure Report approved | milestone | 0d | 2027-04-30 | 2027-04-30 | 3644 | 2027-04-30 | 2027-04-30 | 0d | 2026-09-28 | 2026-09-28 | 169d |  | Ofgem | PMO,CPT,IPA,SRO | Programme Closure | 5.0 |  | Programme Closure | 191.71 | Green | GREEN | MHHS-ART130 |  |  |  |
| 3646 | 1.13.4 | **Benefit Realisation Report** |  | 45d | 2027-03-08 | 2027-05-07 |  | 2027-03-08 | 2027-05-07 | 45d | 2026-08-04 | 2026-10-05 | 164d |  | N/A | N/A | Programme Closure | 5.0 | N/A | Programme Closure |  |  |  |  |  |  |  |
| 3647 | 1.13.4.1 | Develop document |  | 20d | 2027-03-08 | 2027-04-02 | 3387FS-45d | 2027-03-08 | 2027-04-02 | 20d | 2026-08-04 | 2026-08-31 | 164d | 0d | PMO | CPT | Programme Closure | 5.0 |  | Programme Closure | 138.33 | Green | GREEN |  |  |  |  |
| 3648 | 1.13.4.2 | Document review and update |  | 20d | 2027-04-05 | 2027-04-30 | 3647 | 2027-04-05 | 2027-04-30 | 20d | 2026-09-01 | 2026-09-28 | 164d | 0d | PP | PMO,CPT,IPA,SRO | Programme Closure | 5.0 |  | Programme Closure | 166.33 | Green | GREEN |  |  |  |  |
| 3649 | 1.13.4.3 | Benefit Realisation Report approved | milestone | 0d | 2027-05-07 | 2027-05-07 | 3648FS+5d | 2027-05-07 | 2027-05-07 | 0d | 2026-10-05 | 2026-10-05 | 164d |  | PMO | CPT,PP,IPA,SRO | Programme Closure | 5.0 |  | Programme Closure | 198.71 | Green | GREEN | MHHS-ART124 | T3-PC-0010 | PSG | T3 |
| 3650 | 1.13.5 | **Operating Model Gap Review with recommendations** |  | 45d | 2027-03-08 | 2027-05-07 |  | 2027-03-08 | 2027-05-07 | 45d | 2026-08-04 | 2026-10-05 | 164d |  | N/A | N/A | Programme Closure | 5.0 | N/A | Programme Closure |  |  |  |  |  |  |  |
| 3651 | 1.13.5.1 | Develop document |  | 20d | 2027-03-08 | 2027-04-02 | 3387FS-45d | 2027-03-08 | 2027-04-02 | 20d | 2026-08-04 | 2026-08-31 | 164d | 0d | PMO | CPT | Programme Closure | 5.0 |  | Programme Closure | 138.33 | Green | GREEN |  |  |  |  |
| 3652 | 1.13.5.2 | Document review and update |  | 20d | 2027-04-05 | 2027-04-30 | 3651 | 2027-04-05 | 2027-04-30 | 20d | 2026-09-01 | 2026-09-28 | 164d | 0d | PP | PMO,CPT,IPA,SRO | Programme Closure | 5.0 |  | Programme Closure | 166.33 | Green | GREEN |  |  |  |  |
| 3653 | 1.13.5.3 | Operating Model Gap Review with recommendations approved | milestone | 0d | 2027-05-07 | 2027-05-07 | 3652FS+5d | 2027-05-07 | 2027-05-07 | 0d | 2026-10-05 | 2026-10-05 | 164d |  | Paul Pettitt | CPT,PP,IPA,SRO | Programme Closure | 5.0 | Paul Pettitt | Programme Closure | 198.71 | Green | GREEN | MHHS-ART128 | T3-PC-0020 | DAG | T3 |
| 3654 | 1.13.6 | **Post-Implementation Review** |  | 45d | 2027-03-08 | 2027-05-07 |  | 2027-03-08 | 2027-05-07 | 45d | 2026-08-04 | 2026-10-05 | 164d |  | N/A | N/A | Programme Closure | 5.0 | N/A | Programme Closure |  |  |  |  |  |  |  |
| 3655 | 1.13.6.1 | Develop document |  | 20d | 2027-03-08 | 2027-04-02 | 3387FS-45d | 2027-03-08 | 2027-04-02 | 20d | 2026-08-04 | 2026-08-31 | 164d | 0d | PMO | CPT | Programme Closure | 5.0 |  | Programme Closure | 138.33 | Green | GREEN |  |  |  |  |
| 3656 | 1.13.6.2 | Document review and update |  | 20d | 2027-04-05 | 2027-04-30 | 3655 | 2027-04-05 | 2027-04-30 | 20d | 2026-09-01 | 2026-09-28 | 164d | 0d | PP | PMO,CPT,IPA,SRO | Programme Closure | 5.0 |  | Programme Closure | 166.33 | Green | GREEN |  |  |  |  |
| 3657 | 1.13.6.3 | Post-Implementation Review approved | milestone | 0d | 2027-05-07 | 2027-05-07 | 3656FS+5d | 2027-05-07 | 2027-05-07 | 0d | 2026-10-05 | 2026-10-05 | 164d |  | PMO | CPT,PP,IPA,SRO | Programme Closure | 5.0 |  | Programme Closure | 198.71 | Green | GREEN | MHHS-ART129 | T3-PC-0030 | PSG | T3 |

Notes:
- 3653: Action: 5/2 - PP said ask MB if belonged to him. MB says doesn't sit with him

| ID | WBS | Task | Type | Duration | Start | Finish | Predecessors | Complete | Baseline start | Baseline finish | Baseline duration | Baseline 1 start | Baseline 1 finish | Total slack | Free slack | Constraint | Responsible | Involved | Text9 | Update Version | MHHS Resource Name | MHHS Programme Phase | Task Status | Sched Status | RAG | Artefact ID | Milestone ID | Text29 | Tier | Future RAG |
| --- | --- | --- | --- | --- | --- | --- | --- | --- | --- | --- | --- | --- | --- | --- | --- | --- | --- | --- | --- | --- | --- | --- | --- | --- | --- | --- | --- | --- | --- | --- |
| 3658 | 1.13.7 | **Reinforcement Guide** |  | 45d | 2027-03-08 | 2027-05-07 |  |  | 2027-03-08 | 2027-05-07 | 45d | 2026-08-04 | 2026-10-05 | 164d |  |  | N/A | N/A | Programme Closure | 5.0 | N/A | Programme Closure |  |  |  |  |  |  |  |  |
| 3659 | 1.13.7.1 | Develop document |  | 20d | 2027-03-08 | 2027-04-02 | 3387FS-45d |  | 2027-03-08 | 2027-04-02 | 20d | 2026-08-04 | 2026-08-31 | 164d | 0d |  | PMO | CPT | Programme Closure | 5.0 |  | Programme Closure | 138.33 | Green | GREEN |  |  |  |  |  |
| 3660 | 1.13.7.2 | Document review and update |  | 20d | 2027-04-05 | 2027-04-30 | 3659 |  | 2027-04-05 | 2027-04-30 | 20d | 2026-09-01 | 2026-09-28 | 164d | 0d |  | PP | PMO,CPT,IPA,SRO | Programme Closure | 5.0 |  | Programme Closure | 166.33 | Green | GREEN |  |  |  |  |  |
| 3661 | 1.13.7.3 | Reinforcement Guide approved | milestone | 0d | 2027-05-07 | 2027-05-07 | 3660FS+5d |  | 2027-05-07 | 2027-05-07 | 0d | 2026-10-05 | 2026-10-05 | 164d |  |  | PMO | CPT,PP,IPA,SRO | Programme Closure | 5.0 |  | Programme Closure | 198.71 | Green | GREEN | MHHS-ART133 | T3-PC-0040 | PSG | T3 |  |
| 3662 | 1.13.8 | **Material and Licenses Transfer** |  | 60d | 2027-04-05 | 2027-06-25 |  |  | 2027-04-05 | 2027-06-25 | 60d | 2026-09-08 | 2026-11-30 | 129d |  |  | N/A | N/A | Programme Closure | 5.0 | N/A | Programme Closure |  |  |  |  |  |  |  |  |
| 3663 | 1.13.8.1 | Transfer of Programme material to Elexon and perpetual licenses as appropriate |  | 60d | 2027-04-05 | 2027-06-25 | 3622FF-5d |  | 2027-04-05 | 2027-06-25 | 60d | 2026-09-08 | 2026-11-30 | 129d |  |  | PMO | CPT,PP | Programme Closure | 5.0 |  | Programme Closure | 166.33 | Green | GREEN | MHHS-ART139 |  |  |  |  |
| 3664 | 1.14 | **READINESS ASSESSMENTS** |  | 782d | 2023-09-05 A | 2026-09-02 A |  | 100% | 2023-09-05 | 2027-06-17 | 849d | 2023-09-11 | 2026-12-04 |  |  |  | N/A | N/A | Readiness Assessment |  | N/A | Readiness Assessments |  |  |  |  |  |  |  |  |
| 3665 | 1.14.1 | **Readiness Assessment 3 - Design and Build Progress Check and CP2 Check** |  | 60d | 2023-09-05 A | 2023-11-27 A |  | 100% | 2023-09-05 | 2023-11-27 | 50d | 2023-09-11 | 2023-11-17 |  |  |  | N/A | N/A | Readiness Assessment | 5.5 | N/A | Readiness Assessments | M5,M6 |  |  |  |  |  |  |  |
| 3666 | 1.14.1.1 | Launch Readiness Assessment survey | milestone | 0d | 2023-09-05 A | 2023-09-05 A | 1483FS-40d | 100% | 2023-09-05 | 2023-09-05 | 0d | 2023-09-11 | 2023-09-11 |  |  |  | PPC |  | Readiness Assessment | 5.5 | PPC | Readiness Assessments |  | Complete | COMPLETE |  |  |  |  |  |
| 3667 | 1.14.1.2 | PPs submit survey responses |  | 15d | 2023-09-05 A | 2023-09-25 A | 3666 | 100% | 2023-09-05 | 2023-09-25 | 15d | 2023-09-11 | 2023-09-29 |  |  |  | PP | PPC | Readiness Assessment | 5.5 | PPC | Readiness Assessments |  | Complete | COMPLETE |  |  |  |  |  |
| 3668 | 1.14.1.3 | Analyse survey responses |  | 15d | 2023-09-26 A | 2023-10-16 A | 3667 | 100% | 2023-09-26 | 2023-10-16 | 15d | 2023-10-02 | 2023-10-20 |  |  |  | PPC | CPT | Readiness Assessment | 5.5 | PPC | Readiness Assessments |  | Complete | COMPLETE |  |  |  |  |  |
| 3669 | 1.14.1.4 | Conduct deep-dive interviews (sample of PPs) |  | 15d | 2023-09-26 A | 2023-10-16 A | 3667 | 100% | 2023-09-26 | 2023-10-16 | 15d | 2023-10-02 | 2023-10-20 |  |  |  | PPC | CPT | Readiness Assessment | 5.5 | PPC | Readiness Assessments |  | Complete | COMPLETE |  |  |  |  |  |
| 3670 | 1.14.1.5 | Produce Readiness Assessment Reports (Overall Report & Individual Participant Reports) |  | 25d | 2023-10-17 A | 2023-11-20 A | 3668, 3669 | 100% | 2023-10-17 | 2023-11-20 | 15d | 2023-10-23 | 2023-11-10 |  |  |  | PPC |  | Readiness Assessment | 5.5 | PPC | Readiness Assessments |  | Complete | COMPLETE |  |  |  |  |  |
| 3671 | 1.14.1.6 | Readiness Assessment 3 - Design & Build Checkpoint 1 - Completed (incl. Readiness Assessment Report approval) | milestone | 0d | 2023-11-27 A | 2023-11-27 A | 3670FS+5d | 100% | 2023-11-27 | 2023-11-27 | 0d | 2023-11-17 | 2023-11-17 |  |  |  | CPT | PPC | Readiness Assessment | 5.13 | PPC | Readiness Assessments |  | Complete | COMPLETE |  | T2-RA-0200 | PSG | T2 |  |
| 3672 | 1.14.2 | **Readiness Assessment 5 / 6 - Start of Qualification and Participant Readiness for M10 and M11 and CP3/CP4 check** |  | 47d | 2025-04-28 A | 2025-07-01 A |  | 100% | 2025-04-21 | 2025-06-24 | 49d | 2024-11-12 | 2025-01-17 |  |  |  | N/A | N/A | Readiness Assessment | 6.18 | N/A | Readiness Assessments | M11 |  |  |  |  |  |  | D25 - RA6 Readiness Report |
| 3673 | 1.14.2.1 | Launch Readiness Assessment survey | milestone | 0d | 2025-04-28 A | 2025-04-28 A |  | 100% | 2025-04-28 | 2025-04-28 | 0d | 2024-11-12 | 2024-11-12 |  |  | start no earlier than 2025-04-28 | PPC |  | Readiness Assessment | 6.18 | PPC | Readiness Assessments |  | Complete | COMPLETE |  |  |  |  |  |
| 3674 | 1.14.2.2 | PPs submit survey responses |  | 15d | 2025-04-28 A | 2025-05-16 A | 3673 | 100% | 2025-04-28 | 2025-05-16 | 15d | 2024-11-12 | 2024-12-02 |  |  |  | PP | PPC | Readiness Assessment | 6.18 | PPC | Readiness Assessments |  | Complete | COMPLETE |  |  |  |  |  |
| 3675 | 1.14.2.3 | Analyse survey responses |  | 30d | 2025-05-19 A | 2025-06-27 A | 3674 | 100% | 2025-05-19 | 2025-06-27 | 15d | 2024-12-03 | 2024-12-23 |  |  |  | PPC | CPT | Readiness Assessment | 6.18 | PPC | Readiness Assessments |  | Complete | COMPLETE |  |  |  |  |  |
| 3676 | 1.14.2.4 | Conduct deep-dive interviews (sample of PPs) |  | 30d | 2025-05-19 A | 2025-06-27 A |  | 100% | 2025-05-19 | 2025-06-27 | 15d | 2024-12-03 | 2024-12-23 |  |  | start no earlier than 2025-05-19 | PPC | CPT | Readiness Assessment | 6.18 | PPC | Readiness Assessments |  | Complete | COMPLETE |  |  |  |  |  |
| 3677 | 1.14.2.5 | Produce Readiness Assessment Reports (Overall Report & Individual Participant Reports) |  | 15d | 2025-06-09 A | 2025-06-27 A |  | 100% | 2025-06-09 | 2025-06-27 | 15d | 2024-12-24 | 2025-01-13 |  |  | start no earlier than 2025-06-09 | PPC |  | Readiness Assessment | 6.18 | PPC | Readiness Assessments |  | Complete | COMPLETE |  |  |  |  |  |
| 3678 | 1.14.2.6 | Readiness Assessment 5 / 6 - Start of Qualification and Participant Readiness for M10 and M11 and CP3/CP4 check (incl. Readiness Assessment Report approval) Completed | milestone | 0d | 2025-07-01 A | 2025-07-01 A | 3677FS+2d | 100% | 2025-07-01 | 2025-07-01 | 0d | 2025-01-17 | 2025-01-17 |  |  | finish no earlier than 2025-07-01 | CPT | PPC | Readiness Assessment | 6.18 | PPC | Readiness Assessments |  | Complete | COMPLETE |  | T2-RA-0400 | PSG | T2 |  |
| 3679 | 1.14.3 | **Readiness Assessment 7 - Migration Checkpoint** |  | 23d | 2026-03-02 A | 2026-04-01 A |  | 100% | 2026-03-02 | 2026-04-01 | 0d |  |  |  |  |  |  |  |  | 6.43 |  |  | -1198.67 | Green |  |  |  |  |  |  |
| 3680 | 1.14.3.1 | Readiness Assessment 7 survey issued | milestone | 0d | 2026-03-02 A | 2026-03-02 A |  | 100% | 2026-03-02 | 2026-03-02 | 0d |  |  |  |  | start no earlier than 2026-03-02 | PPC |  |  | 6.43 | PPC |  |  | Complete | COMPLETE |  |  |  |  |  |
| 3681 | 1.14.3.2 | Draft response review point |  | 3d | 2026-03-06 A | 2026-03-10 A | 3680FS+4d | 100% | 2026-03-06 | 2026-03-10 | 0d |  |  |  |  |  | PPC |  |  | 6.43 | PPC |  |  | Complete | COMPLETE |  |  |  |  |  |
| 3682 | 1.14.3.3 | Evidence asessment |  | 19d | 2026-03-06 A | 2026-04-01 A |  | 100% | 2026-03-06 | 2026-04-01 | 0d |  |  |  |  | start no earlier than 2026-03-06 | PPC |  |  | 6.43 | PPC |  |  | Complete | COMPLETE |  |  |  |  |  |
| 3683 | 1.14.3.4 | Readiness Assessment 7 survey closes | milestone | 0d | 2026-03-16 A | 2026-03-16 A | 3680FS+11d | 100% | 2026-03-16 | 2026-03-16 | 0d |  |  |  |  | start no earlier than 2026-03-11 | PPC |  |  | 6.43 | PPC |  |  | Complete | COMPLETE |  |  |  |  |  |
| 3684 | 1.14.3.5 | Report on Readiness Assessment 7 findings at PSG | milestone | 0d | 2026-04-01 A | 2026-04-01 A | 3683FS+12d | 100% | 2026-04-01 | 2026-04-01 | 0d |  |  |  |  |  | PPC |  |  | 6.43 | PPC |  |  | Complete | COMPLETE |  |  |  |  |  |
| 3685 | 1.14.3.6 | Readiness Assessment 7 - Migration Checkpoint - Completed (incl. Readiness Assessment Report approval) | milestone | 0d | 2026-04-01 A | 2026-04-01 A | 3684 | 100% | 2026-04-01 | 2026-04-01 | 0d | 2025-10-09 | 2025-10-09 |  |  |  | CPT | PPC | Readiness Assessment | 6.43 | PPC | Readiness Assessments |  | Complete | COMPLETE |  | T2-RA-0600 | PSG | T2 |  |

| ID | WBS | Task | Type | Duration | Start | Finish | Predecessors | Complete | Remaining | Baseline start | Baseline finish | Baseline duration | Baseline 1 start | Baseline 1 finish | Total slack | Free slack | Constraint | Responsible | Involved | Future RAG | Text9 | Task Status | Update Version | MHHS Resource Name | MHHS Programme Phase | Sched Status | RAG | Milestone ID | Text29 | Tier |
| --- | --- | --- | --- | --- | --- | --- | --- | --- | --- | --- | --- | --- | --- | --- | --- | --- | --- | --- | --- | --- | --- | --- | --- | --- | --- | --- | --- | --- | --- | --- |
| 3686 | 1.14.4 | **Readiness Assessment 8 - Ready for New Settlement Timetable** |  | 46d | 2026-07-01 A | 2026-09-02 A |  | 100% |  | 2026-07-01 | 2026-09-02 | 49d | 2026-01-06 | 2026-03-13 |  |  |  | N/A | N/A | D29 - RA8 Readiness Report | Readiness Assessment | M14 | 6.53 | N/A | Readiness Assessments |  |  |  |  |  |
| 3687 | 1.14.4.1 | Launch Readiness Assessment survey | milestone | 0d | 2026-07-01 A | 2026-07-01 A |  | 100% |  | 2026-07-01 | 2026-07-01 | 0d | 2026-01-06 | 2026-01-06 |  |  | start no earlier than 2026-07-01 | PPC |  |  | Readiness Assessment |  | 6.53 | PPC | Readiness Assessments | Complete | COMPLETE |  |  |  |
| 3688 | 1.14.4.2 | PPs submit survey responses |  | 21d | 2026-07-01 A | 2026-07-29 A | 3687 | 100% |  | 2026-07-01 | 2026-07-29 | 15d | 2026-01-06 | 2026-01-26 |  |  |  | PPC | PPC |  | Readiness Assessment |  | 6.53 | PPC | Readiness Assessments | Complete | COMPLETE |  |  |  |
| 3689 | 1.14.4.3 | Analyse survey responses |  | 25d | 2026-07-30 A | 2026-09-02 A | 3688 | 100% |  | 2026-07-30 | 2026-09-02 | 15d | 2026-01-27 | 2026-02-16 |  |  |  | PPC | CPT |  | Readiness Assessment |  | 6.53 | PPC | Readiness Assessments | Complete | COMPLETE |  |  |  |
| 3690 | 1.14.4.4 | Conduct deep-dive interviews (sample of PPs) |  | 25d | 2026-07-30 A | 2026-09-02 A |  | 100% |  | 2026-07-30 | 2026-09-02 | 15d | 2026-01-27 | 2026-02-16 |  |  | start no earlier than 2026-07-30 | PPC | CPT |  | Readiness Assessment |  | 6.53 | PPC | Readiness Assessments | Complete | COMPLETE |  |  |  |
| 3691 | 1.14.4.5 | Produce Readiness Assessment Reports (Overall Report & Individual Participant Reports) |  | 25d | 2026-07-30 A | 2026-09-02 A |  | 100% |  | 2026-07-30 | 2026-09-02 | 15d | 2026-02-17 | 2026-03-09 |  |  | start no earlier than 2026-07-30 | PPC |  |  | Readiness Assessment |  | 6.53 | PPC | Readiness Assessments | Complete | COMPLETE |  |  |  |
| 3692 | 1.14.4.6 | Readiness Assessment 8 - Ready for New Settlement Timetable - Completed (incl. Readiness Assessment Report approval) | milestone | 0d | 2026-09-02 A | 2026-09-02 A |  | 100% |  | 2026-09-02 | 2026-09-02 | 0d | 2026-03-13 | 2026-03-13 |  |  | start no earlier than 2026-09-02 | CPT | PPC |  | Readiness Assessment |  | 6.53 | PPC | Readiness Assessments | Complete | COMPLETE | T2-RA-0700 | PSG | T2 |
| 3693 | 1.14.5 | **Readiness Assessments - Tier 1 Milestones** |  | 305d | 2025-07-01 A | 2026-09-02 A |  | 100% |  | 2025-06-24 | 2027-06-17 | 799d | 2023-11-17 | 2026-12-04 |  |  |  | N/A | N/A |  | Readiness Assessment |  | 5.0 | N/A | Readiness Assessments |  |  |  |  |  |
| 3694 | 1.14.5.1 | Readiness Assessment 6 - Start of Migration - Completed (incl. Readiness Assessment Report approval) | milestone | 0d | 2025-07-01 A | 2025-07-01 A | 3678 | 100% |  | 2025-07-01 | 2025-07-01 | 0d | 2025-04-04 | 2025-04-04 |  |  | finish no earlier than 2025-04-04 | CPT | PPC |  | Readiness Assessment |  | 6.18 | PPC | Readiness Assessments | Complete | COMPLETE | T2-RA-0500 | PSG | T2 |
| 3695 | 1.14.5.2 | Readiness Assessment 7 - Migration Checkpoint - Completed (incl. Readiness Assessment Report approval) | milestone | 0d | 2026-04-01 A | 2026-04-01 A |  | 100% |  | 2026-04-01 | 2026-04-01 | 0d | 2025-10-09 | 2025-10-09 |  |  | finish no earlier than 2026-04-01 | CPT | PPC |  | Readiness Assessment |  | 6.46 | PPC | Readiness Assessments | Complete | COMPLETE | T2-RA-0600 | PSG | T2 |
| 3696 | 1.14.5.3 | Readiness Assessment 8 - Ready for New Settlement Timetable - Completed (incl. Readiness Assessment Report approval) | milestone | 0d | 2026-09-02 A | 2026-09-02 A |  | 100% |  | 2026-09-02 | 2026-09-02 | 0d | 2026-03-13 | 2026-03-13 |  |  | start no earlier than 2026-09-02 | CPT | PPC |  | Readiness Assessment |  | 5.0 | PPC | Readiness Assessments | Complete | COMPLETE | T2-RA-0700 | PSG | T2 |
| 3697 | 1.15 | **CONTROL POINTS** |  | 1204d | 2022-11-10 A | 2027-06-23 |  | 79% | 258d | 2022-11-10 | 2027-06-23 | 1063d | 2022-11-10 | 2026-12-07 | 132d |  |  | N/A | N/A |  | Control Points |  |  | N/A | Control Points |  |  |  |  |  |
| 3698 | 1.15.1 | **Control Point 1 - Start of System Design, Build & Test** |  | 20d | 2022-11-10 A | 2022-12-07 A |  | 100% |  | 2022-11-10 | 2022-12-07 | 20d | 2022-11-10 | 2022-12-07 |  |  |  | N/A | N/A |  | Control Points |  | 5.0 | N/A | Control Points |  |  |  |  |  |
| 3699 | 1.15.1.1 | Control Point 1 Preparation (incl. Control Point Report development and review) |  | 15d | 2022-11-10 A | 2022-11-30 A | 3700SS-20d | 100% |  | 2022-11-10 | 2022-11-30 | 15d | 2022-11-10 | 2022-11-30 |  |  |  | CPT | PMO |  | Control Points |  | 5.0 | PMO | Control Points | Complete | COMPLETE |  |  |  |
| 3700 | 1.15.1.2 | Control Point 1 - Start of System Design, Build & Test (incl. Control Point Report approval) | milestone | 0d | 2022-12-07 A | 2022-12-07 A |  | 100% |  | 2022-12-07 | 2022-12-07 | 0d | 2022-12-07 | 2022-12-07 |  |  | must finish on 2022-12-07 | CPT | PMO | D24 - CP2 Approval | Control Points |  | 5.0 | PMO | Control Points | Complete | COMPLETE | T1-CP-1000 | PSG | T1 |
| 3701 | 1.15.2 | **Control Point 2 - Start of Integration & Test** |  | 20d | 2023-10-02 A | 2023-10-30 A |  | 100% |  | 2023-10-02 | 2023-10-30 | 20d | 2023-10-02 | 2023-10-30 |  |  |  | N/A | N/A |  | Control Points |  | 5.0 | N/A | Control Points |  |  |  |  |  |
| 3702 | 1.15.2.1 | Control Point 2 Preparation (incl. Control Point Report development and review) |  | 15d | 2023-10-02 A | 2023-10-20 A | 3703SS-20d | 100% |  | 2023-10-02 | 2023-10-20 | 15d | 2023-10-02 | 2023-10-20 |  |  |  | CPT | PMO |  | Control Points |  | 5.0 | PMO | Control Points | Complete | COMPLETE |  |  |  |
| 3703 | 1.15.2.2 | Control Point 2 - Start of Integration & Test (incl. Control Point Report approval) | milestone | 0d | 2023-10-30 A | 2023-10-30 A | 1483 | 100% |  | 2023-10-30 | 2023-10-30 | 0d | 2023-10-30 | 2023-10-30 |  |  |  | CPT | PMO | D24 - CP2 Approval | Control Points |  | 5.11 | PMO | Control Points | Complete | COMPLETE | T1-CP-2000 | PSG | T1 |
| 3704 | 1.15.3 | **Control Point 3/4 - Readiness for Migration** |  | 25d | 2025-08-21 A | 2025-09-24 A |  | 100% |  | 2025-08-21 | 2025-09-18 | 20d | 2025-03-03 | 2025-03-28 |  |  |  | N/A | N/A | D26 - CP3 Approval | Control Points |  | 5.0 | N/A | Control Points |  |  |  |  |  |
| 3705 | 1.15.3.1 | Control Point 3/4 Preparation (incl. Control Point Report development and review) |  | 25d | 2025-08-21 A | 2025-09-24 A | 3706SS-20d | 100% |  | 2025-08-21 | 2025-09-09 | 14d | 2025-03-03 | 2025-03-21 |  |  |  | CPT | PMO |  | Control Points |  | 5.0 | PMO | Control Points | Complete | COMPLETE |  |  |  |
| 3706 | 1.15.3.2 | Control Point 3/4 - Readiness for Migration (incl. Control Point Report approval) | milestone | 0d | 2025-09-24 A | 2025-09-24 A | 1802FS-3d | 100% |  | 2025-09-18 | 2025-09-18 | 0d | 2025-03-28 | 2025-03-28 |  |  | finish no earlier than 2025-09-24 | CPT | PMO |  | Control Points |  | 5.0 | PMO | Control Points | Complete | COMPLETE | T1-CP-3000 | PSG | T1 |
| 3707 | 1.15.4 | **Control Point 5 - Cut Over to New Settlement Timetable** |  | 20d | 2027-05-26 | 2027-06-23 |  |  |  | 2027-05-26 | 2027-06-23 | 20d | 2026-11-10 | 2026-12-07 | 132d |  |  | N/A | N/A | D33 - Control Point 6 Approval | Control Points | M16 | 5.0 | N/A | Control Points |  |  |  |  |  |
| 3708 | 1.15.4.1 | Control Point 5 Preparation (incl. Control Point Report development and review) |  | 15d | 2027-05-26 | 2027-06-15 | 3709SS-20d |  |  | 2027-05-26 | 2027-06-15 | 15d | 2026-11-10 | 2026-11-30 | 137d |  |  | CPT | PP |  | Control Points | 217.33 | 5.0 | PMO | Control Points | Green | GREEN |  |  |  |
| 3709 | 1.15.4.2 | Control Point 5 - Cut Over to New Settlement Timetable (incl. Control Point Report approval) | milestone | 0d | 2027-06-23 | 2027-06-23 | 3622FS-8d |  |  | 2027-06-23 | 2027-06-23 | 0d | 2026-12-07 | 2026-12-07 | 132d | 0d |  | CPT | CPT | D33 - Control Point 6 Approval | Control Points | 245.33 | 5.0 | PMO | Control Points | Green | GREEN | T1-CP-4000 | PSG | T1 |

Notes:
- 3686: 30/06/26: Readiness Assessment 8 timelines and activities updated following the 25/06/26 STEG. Readiness Assessment 8 is now scheduled to complete on 02/09/26, providing additional time to accommodate school holidays and participant deep dives where required. / 16/06/26: Readiness Assessment 8 contingent on Consultation responses. An update will be included in the next Programme Plan publication on 01/07/26. / 22/05/26: Task name changed from 'Readiness Assessment 8 - Ready to Accept New MPANs' to 'Readiness Assessment 8 - Ready for New Settlement Timetable'. Currently aligning task to Consultation close date. Finalised dates will be published imminently with activity under way to consisder bringing forward Readiness Assessment 8 Consultation.
- 3687: 30/06/26: Readiness Assessment 8 timelines and activities updated following the 25/06/26 STEG. Readiness Assessment 8 is now scheduled to complete on 02/09/26, providing additional time to accommodate school holidays and participant deep dives where required. / 16/06/26: Readiness Assessment 8 contingent on Consultation responses. An update will be included in the next Programme Plan publication on 01/07/26. / 22/05/26: Readiness Assessment 8 activity embedded in M16 version of plan which aligns to a date of 14/08/26 for Readiness Assessment 8 completion. The plan structure will be re-aligned in the next re-issue.
- 3688: 30/06/26: Readiness Assessment 8 timelines and activities updated following the 25/06/26 STEG. Readiness Assessment 8 is now scheduled to complete on 02/09/26, providing additional time to accommodate school holidays and participant deep dives where required. / 16/06/26: Readiness Assessment 8 contingent on Consultation responses. An update will be included in the next Programme Plan publication on 01/07/26. / 22/05/26: Readiness Assessment 8 activity embedded in M16 version of plan. The plan structure will be re-aligned in the next re-issue.
- 3689: 30/06/26: Readiness Assessment 8 timelines and activities updated following the 25/06/26 STEG. Readiness Assessment 8 is now scheduled to complete on 02/09/26, providing additional time to accommodate school holidays and participant deep dives where required. / 16/06/26: Readiness Assessment 8 contingent on Consultation responses. An update will be included in the next Programme Plan publication on 01/07/26. / 22/05/26: Readiness Assessment activity embedded in M16 version of plan. The plan structure will be re-aligned in the next re-issue.
- 3690: 30/06/26: Readiness Assessment 8 timelines and activities updated following the 25/06/26 STEG. Readiness Assessment 8 is now scheduled to complete on 02/09/26, providing additional time to accommodate school holidays and participant deep dives where required. / 16/06/26: Readiness Assessment 8 contingent on Consultation responses. An update will be included in the next Programme Plan publication on 01/07/26. / 22/05/26: Readiness Assessment activity embedded in M16 version of plan. The plan structure will be re-aligned in the next re-issue.
- 3691: 30/06/26: Readiness Assessment 8 timelines and activities updated following the 25/06/26 STEG. Readiness Assessment 8 is now scheduled to complete on 02/09/26, providing additional time to accommodate school holidays and participant deep dives where required. / 16/06/26: Readiness Assessment 8 contingent on Consultation responses. An update will be included in the next Programme Plan publication on 01/07/26. / 22/05/26: Readiness Assessment activity embedded in M16 version of plan. The plan structure will be re-aligned in the next re-issue.
- 3692: 30/06/26: Readiness Assessment 8 timelines and activities updated following the 25/06/26 STEG. Readiness Assessment 8 is now scheduled to complete on 02/09/26, providing additional time to accommodate school holidays and participant deep dives where required. Task name updated from 'Readiness Assessment 8 - Ready to Accept New MPANs - Completed (incl. Readiness Assessment Report approval)' to 'Readiness Assessment 8 - Ready for New Settlement Timetable - Completed (incl. Readiness Assessment Report approval)' to align with revised purpose of assessment. / 16/06/26: Readiness Assessment 8 contingent on Consultation responses. An update will be included in the next Programme Plan publication on 01/07/26. / 22/05/26: Readiness Assessment activity embedded in M16 version of plan. The plan structure will be re-aligned in the next re-issue.
- 3696: 24/07/26: Activity on track / 30/06/26: Readiness Assessment 8 timelines and activities updated following the 25/06/26 STEG. Readiness Assessment 8 is now scheduled to complete on 02/09/26, providing additional time to accommodate school holidays and participant deep dives where required. Task name updated from 'Readiness Assessment 8 - Ready to Accept New MPANs - Completed (incl. Readiness Assessment Report approval)' to 'Readiness Assessment 8 - Ready for New Settlement Timetable - Completed (incl. Readiness Assessment Report approval)' to align with revised purpose of assessment. / 08/06/26: Task name changed from 'Readiness Assessment 8 - Ready to Accept New MPANs' to 'Readiness Assessment 8 - Ready for New Settlement Timetable'. Task date changed from 13/10/26 to 14/08/26 to align with new planned sequence of events.

| ID | WBS | Task | Type | Duration | Start | Finish | Predecessors | Complete | Remaining | Baseline start | Baseline finish | Baseline duration | Baseline 1 start | Baseline 1 finish | Total slack | Free slack | Constraint | Responsible | Involved | Text9 | Update Version | MHHS Resource Name | MHHS Programme Phase | Sched Status | RAG | Milestone ID | Text29 | Tier | Future RAG | Task Status |
| --- | --- | --- | --- | --- | --- | --- | --- | --- | --- | --- | --- | --- | --- | --- | --- | --- | --- | --- | --- | --- | --- | --- | --- | --- | --- | --- | --- | --- | --- | --- |
| 3710 | 1.15.5 | **Control Points - Tier 1 Milestones** |  | 1184d | 2022-12-07 A | 2027-06-23 |  |  | 1184d | 2022-12-07 | 2027-06-23 | 1043d | 2022-12-07 | 2026-12-07 | 132d |  |  | N/A | N/A | Control Points | 5.0 | N/A | Control Points |  |  |  |  |  |  |  |
| 3711 | 1.15.5.1 | Control Point 1 - Start of System Design, Build & Test (incl. Control Point Report approval) | milestone | 0d | 2022-12-07 A | 2022-12-07 A | 3700SS | 100% |  | 2022-12-07 | 2022-12-07 | 0d | 2022-12-07 | 2022-12-07 |  |  |  | CPT | PMO | Control Points | 5.0 | PMO | Control Points | Complete | COMPLETE | T1-CP-1000 | PSG | T1 |  |  |
| 3712 | 1.15.5.2 | Control Point 2 - Start of Integration & Test (incl. Control Point Report approval) | milestone | 0d | 2023-10-30 A | 2023-10-30 A | 3703SS | 100% |  | 2023-10-30 | 2023-10-30 | 0d | 2023-10-30 | 2023-10-30 |  |  |  | CPT | PMO | Control Points | 5.11 | PMO | Control Points | Complete | COMPLETE | T1-CP-2000 | PSG | T1 | D24 - CP2 Approval |  |
| 3713 | 1.15.5.3 | Control Point 3/4 - Readiness for Migration (incl. Control Point Report approval) | milestone | 0d | 2025-09-24 A | 2025-09-24 A | 3706SS | 100% |  | 2025-09-18 | 2025-09-18 | 0d | 2025-03-28 | 2025-03-28 |  |  |  | CPT | PMO | Control Points | 5.0 | PMO | Control Points | Complete | COMPLETE | T1-CP-3000 | PSG | T1 |  |  |
| 3714 | 1.15.5.4 | Control Point 5 - Cut Over to New Settlement Timetable (incl. Control Point Report approval) | milestone | 0d | 2027-06-23 | 2027-06-23 | 3709SS |  |  | 2027-06-23 | 2027-06-23 | 0d | 2026-12-07 | 2026-12-07 | 132d |  |  | CPT | CPT | Control Points | 5.0 | PMO | Control Points | Green | GREEN | T1-CP-4000 | PSG | T1 | D33 - Control Point 6 Approval | 245.33 |
| 3715 | 1.16 | **MILESTONE RANGE CHECKPOINTS** |  | 402d? | 2025-07-31 A | 2027-02-15 |  |  | 402d? | 2022-10-31 | 2027-04-12 | 436d | 2025-01-13 | 2026-09-15 | 224d |  |  | N/A | N/A | Milestone Range Checkpoints |  | N/A | Milestone Range Checkpoints |  |  |  |  |  |  |  |
| 3716 | 1.16.1 | **M10, M11, M12 and M13 milestone checkpoint** |  | 0d | 2025-07-31 A | 2025-07-31 A |  | 100% |  | 2025-07-31 | 2025-07-31 | 0d | 2025-01-13 | 2025-01-13 |  |  |  | N/A | N/A | Milestone Range Checkpoints | 5.0 | N/A | Milestone Range Checkpoints |  |  |  |  |  |  |  |
| 3717 | 1.16.1.1 | M10, M11, M12, and M13 milestone checkpoint - date approval | milestone | 0d | 2025-07-31 A | 2025-07-31 A | 3383FS-3mo, 3385FS-3mo, 3381FS-3mo, 1802FS-3mo | 100% |  | 2025-07-31 | 2025-07-31 | 0d | 2025-01-13 | 2025-01-13 |  |  |  | CPT | CPT | Milestone Range Checkpoints | 5.0 | PMO | Milestone Range Checkpoints | Complete | COMPLETE | T2-MR-0100 | PSG | T2 |  |  |
| 3718 | 1.16.2 | **M14 milestone checkpoint** |  | 56d? | 2026-08-11 A | 2026-10-27 |  |  | 56d? | 2026-08-11 | 2026-10-27 | 0d | 2025-12-23 | 2025-12-23 |  |  |  | N/A | N/A | Milestone Range Checkpoints | 5.0 | N/A | Milestone Range Checkpoints |  |  |  |  |  |  |  |
| 3719 | 1.16.2.1 | M14 Checkpoint: QWG to assess M14 delivery confidence against the Acceptance Criteria | milestone | 0d | 2026-08-11 A | 2026-08-11 A |  | 100% |  | 2026-08-11 | 2026-08-11 | 0d | 2025-12-23 | 2025-12-23 |  |  | start no earlier than 2026-08-11 | CPT | CPT | Milestone Range Checkpoints | 6.54 | PMO | Milestone Range Checkpoints | Complete | COMPLETE |  | QWG |  |  |  |
| 3720 | 1.16.2.2 | M14 checkpoint: QAG to assess M14 delivery confidence against the Acceptance Criteria | milestone | 0d | 2026-08-18 A | 2026-08-18 A | 3719 | 100% |  | 2026-08-18 | 2026-08-18 | 0d |  |  |  |  | start no earlier than 2026-08-18 | CPT |  |  | 6.54 | PMO |  | Complete | COMPLETE |  | QAG |  |  |  |
| 3721 | 1.16.2.3 | M14 Checkpoint: PSG assesses M14 delivery confidence | milestone | 0d | 2026-09-02 A | 2026-09-02 A | 2720 | 100% |  | 2026-09-02 | 2026-09-02 | 0d |  |  |  |  | start no earlier than 2026-09-02 | CPT |  |  | 6.54 | PMO |  | Complete | COMPLETE | T2-MR-0200 | PSG | T2 |  |  |
| 3722 | 1.16.2.4 | Notification to Ofgem of no central issues as of QA+P Annex 4 | milestone | 0d | 2026-09-03 A | 2026-09-03 A | 3721 | 100% |  | 2026-09-03 | 2026-09-03 | 0d |  |  |  |  | start no earlier than 2026-09-03 | CPT |  |  |  | PMO |  | Complete | COMPLETE |  |  |  |  |  |
| 3723 | 1.16.2.5 | M14 Recommendation: eQWG to confirm Qualified participants for start of Migration | milestone | 0d | 2026-10-23 | 2026-10-23 |  |  |  | 2026-10-23 | 2026-10-23 | 0d |  |  | 305d | 1d | start no earlier than 2026-10-23 | CPT |  |  | 6.54 | PMO |  | Green | GREEN |  | QWG |  |  | 2.33 |
| 3724 | 1.16.2.6 | M14 Recommendation: eQAG to recommend M14 | milestone | 0d | 2026-10-26 | 2026-10-26 | 3723 |  |  | 2026-10-26 | 2026-10-26 | 0d |  |  | 304d | 1d | start no earlier than 2026-10-26 | CPT |  |  | 6.54 | PMO |  | Green | GREEN |  | QAG |  |  | 5.33 |
| 3725 | 1.16.2.7 | M14 Decision: ePSG to confirm M14 | milestone | 0d | 2026-10-27 | 2026-10-27 | 3724 |  |  | 2026-10-27 | 2026-10-27 | 0d |  |  | 303d | 2d | start no earlier than 2026-10-27 | CPT |  |  | 6.54 | PMO |  | Green | GREEN |  | PSG |  |  | 6.33 |
| 3726 | 1.16.3 | **M15 milestone checkpoint** |  | 0d | 2027-02-15 | 2027-02-15 |  |  |  | 2027-02-15 | 2027-02-15 | 0d | 2026-07-14 | 2026-07-14 | 224d |  |  | N/A | N/A | Milestone Range Checkpoints | 5.0 | N/A | Milestone Range Checkpoints |  |  |  |  |  |  |  |
| 3727 | 1.16.3.1 | M15 milestone checkpoint - date approval | milestone | 0d | 2027-02-15 | 2027-02-15 | 3387FS-3mo |  |  | 2027-02-15 | 2027-02-15 | 0d | 2026-07-14 | 2026-07-14 | 224d |  |  | CPT | CPT | Milestone Range Checkpoints | 5.0 | PMO | Milestone Range Checkpoints | Green | GREEN | T2-MR-0300 | PSG | T2 |  | 117.33 |

Notes:
- 3721: 10/07/26: Task date and name updated to reflect the M14 Decision Choreography agreed at QAG on 22/04/26.
